# PG032 - Melhoria dos Sistemas de Abastecimento de Água

Schedule from MS Project, 2015-11-09 to 2023-11-22, status date 2019-12-31, A marks actual dates.
03/05/19: Linha de Base salva com referência ao cronograma do Relatório ii de Fevereiro/19 / Linha de base após o replanejamento (não validada) salva como "Linha de Base2" / Linha de Base: Linha de base após o replanejamento (Salva em: 06/06) / Linha de Base 1: Linha de Base conforme o planejado pelo programa (Fonte: Relatório ii - Salva em 10/05) / Linha de Base 2: Linha de base após o replanejamento (Salva em: 30/04) / Linha de Base 4: Linha de Base Salva em 27/11, conforme datas enviadas à CT-SHQA para repcatuação do prazo do TTAC para Fev/23

## Calendars

- Calendário APRO: Mon-Fri 09:00-12:00, 13:00-18:00; Sat-Sun off. Exceptions (off unless hours are given): 2019-01-01 to 2019-01-23 (Período Não útil 1), 2019-01-25 to 2019-02-20 (Período Não útil 2), 2019-02-22 to 2019-04-03 (Período Não útil 3), 2019-04-05 to 2019-04-16 (Período Não útil 4), 2019-04-18 to 2019-05-22 (Período Não útil 5), 2019-05-24 to 2019-06-17 (Período Não útil 6), 2019-06-19 to 2019-07-24 (Período Não útil 7), 2019-07-26 to 2019-08-21 (Período Não útil 8), 2019-08-23 to 2019-09-17 (Período Não útil 9), 2019-09-19 to 2019-10-15 (Período Não útil 10), 2019-10-17 to 2019-11-12 (Período Não útil 11), 2019-11-14 to 2019-12-11 (Período Não útil 12), 2019-12-13 to 2019-12-31 (Período Não útil 13).
- Padrão_FR: Mon-Fri 09:00-12:00, 13:00-18:00; Sat-Sun off. Exceptions (off unless hours are given): 2019-01-01 (Ano-novo), 2019-03-04 to 2019-03-06 (Carnaval), 2019-04-18 (Quinta-feira santa (recesso)), 2019-04-19 (Sexta-feira Santa), 2019-04-21 (Tiradentes), 2019-05-01 (Trabalho), 2019-06-20 (Corpus Christi), 2019-08-15 (Assunção de Nossa Senhora), 2019-09-07 (Independência), 2019-10-12 (Nossa Senhora Aparecida), 2019-11-02 (Finados), 2019-11-15 (Proclamação da República), 2019-12-12 (Aniversário BH), 2019-12-24 (Véspera de Natal), 2019-12-25 (Natal), 2020-01-01 (Ano-novo), 2020-02-24 to 2020-02-26 (Carnaval), 2020-04-10 (Sexta-feira Santa), 2020-04-21 (Tiradentes), 2020-05-01 (Trabalho), 2020-06-11 (Corpus Christi), 2020-08-15 (Assunção de Nossa Senhora), 2020-09-07 (Independência), 2020-10-12 (Nossa Senhora Aparecida), 2020-11-02 (Finados), 2020-11-15 (Proclamação da República), 2020-12-12 (Aniversário BH), 2020-12-24 (Véspera de Natal), 2020-12-25 (Natal), 2021-01-01 (Ano-novo), 2021-02-15 to 2021-02-17 (Carnaval), 2021-04-02 (Sexta-feira Santa), 2021-04-21 (Tiradentes), 2021-05-01 (Trabalho), 2021-06-03 (Corpus Christi), 2021-08-15 (Assunção de Nossa Senhora), 2021-09-07 (Independência), 2021-10-12 (Nossa Senhora Aparecida), 2021-11-02 (Finados), 2021-11-15 (Programação da República), 2021-12-12 (Aniversário BH), 2021-12-24 (Véspera de Natal), 2021-12-25 (Natal), 2022-01-01 (Ano-novo), 2022-02-28 to 2022-03-02 (Carnaval), 2022-04-15 (Sexta-feira Santa), 2022-04-21 (Tiradentes), 2022-05-01 (Trabalho), 2022-06-16 (Corpus Christi), 2022-08-15 (Assunção de Nossa Senhora), 2022-09-07 (Independência), 2022-10-12 (Nossa Senhora Aparecida), 2022-11-02 (Finados), 2022-11-15 (Proclamação da República), 2022-12-12 (Aniversário BH), 2022-12-24 (Véspera de Natal), 2022-12-25 (Natal), 2023-01-01 (Ano-novo), 2023-02-20 to 2023-02-22 (Carnaval), 2023-04-07 (Sexta-feira Santa), 2023-04-21 (Tiradentes), 2023-05-01 (Trabalho), 2023-06-08 (Corpus Christ), 2023-08-15 (Assunção de Nossa Senhora), 2023-09-07 (Independência), 2023-10-12 (Nossa Senhora Aparecida), 2023-11-02 (Finados), 2023-11-15 (Proclamação da República).

## Schedule

| ID | WBS | Task | Type | Duration | Start | Finish | Predecessors | Complete | Remaining | Baseline start | Baseline finish | Baseline duration | Baseline 1 start | Baseline 1 finish | Total slack | Text3 | Text5 | Text26 | Text25 | Text27 | Text15 | Text4 | Text7 | Text23 | Text24 |
| --- | --- | --- | --- | --- | --- | --- | --- | --- | --- | --- | --- | --- | --- | --- | --- | --- | --- | --- | --- | --- | --- | --- | --- | --- | --- |
| 1 | 1 | **Marcos** |  | 1876d | 2016-06-17 A | 2023-11-22 |  |  | 1876d | 2016-03-02 | 2022-03-02 | 1525d |  |  | 0d | 0% |  |  |  |  |  |  |  |  |  |
| 2 | 1.1 | **Cláusula do TTAC** |  | 509d | 2020-11-04 | 2022-11-22 |  |  |  | 2018-03-02 | 2021-03-02 | 753d | 2018-03-23 | 2021-03-23 | 248d | 42% | 42 | ok |  |  |  |  |  |  |  |
| 3 | 1.1.1 | Cláusula 171 - Conclusão das obras de sistemas alternativos de captação e adução e melhoria das estações de tratamento de água para todas localidades. | milestone | 0d | 2022-11-22 | 2022-11-22 | 133, 267, 314, 410, 461, 703, 796, 840, 1210, 1281, 1380, 1460, 1564, 1620, 1672, 1777, 1826, 1912, 1996, 2113, 2221, 96, 203, 307, 664, 764, 924, 971, 1028, 1082, 1176, 1313, 1358, 1498, 1529, 1718, 1744, 1855, 1884, 2039, 2078, 2143, 2172 |  |  | 2021-03-02 | 2021-03-02 | 0d | 2021-03-23 | 2021-03-23 | 248d | 0% |  | ok | 0% | 0% |  |  |  |  |  |
| 4 | 1.1.2 | Cláusula 171, Parágrafo 1º - Conclusão dos Levantamentos de Campo, Projetos Conceituais e Básicos em todas localidades. | milestone | 0d | 2020-11-04 | 2020-11-04 | 354, 583, 684, 782, 1369, 1636, 1647, 1763, 2097, 119, 224, 231, 66, 176, 482, 548, 888, 904, 1005, 1056, 1339, 1399 |  |  | 2018-03-02 | 2018-03-02 | 0d | 2018-03-23 | 2018-03-23 | 757d | 100% | 100 | ok | 0% | 0% | 100 |  |  |  |  |
| 5 | 1.2 | **Deliberações** |  | 1876d | 2016-06-17 A | 2023-11-22 |  |  | 1876d | 2022-03-21 | 2022-03-21 | 1d | 2022-03-21 | 2022-03-21 | 0d | 0% |  | ok |  |  |  |  |  |  |  |
| 6 | 1.2.1 | Deliberação 4, Item 1 - Construção de sistemas alternativos de captação e adução e melhoria das estações de tratamento de água: 1.2) Apresentação de documentos que formalizem a concordância dos prestadores de serviço. | milestone | 0d | 2016-06-17 A | 2016-06-17 A | 24FS+78d | 100% |  | 2016-06-17 | 2016-06-17 | 0d |  |  |  |  |  |  |  |  |  |  |  |  |  |
| 7 | 1.2.2 | Deliberação 10 - Aprova parcialmente o cronograma de início da operação assistida de parte dos sistemas alternativos de abastecimento e determina solução específica para o abastecimento de Resplendor. | milestone | 0d | 2016-09-12 A | 2016-09-12 A | 24FS+139d | 100% |  | 2016-09-12 | 2016-09-12 | 0d |  |  |  |  |  |  |  |  |  |  |  |  |  |
| 8 | 1.2.3 | Deliberação 16 - Definições e recomendações complementares sobre o Programa de Melhoria dos Sistemas de Abastecimento de Água. | milestone | 0d | 2016-09-19 A | 2016-09-19 A | 24FS+144d | 100% |  | 2016-09-17 | 2016-09-17 | 0d |  |  |  |  |  |  |  |  |  |  |  |  |  |
| 9 | 1.2.4 | Deliberação 33, Item 1 - Promover a caracterização da composição da fração coloide e do sobrenadante observado nas águas da bacia do rio Doce após o evento. | milestone | 0d | 2017-06-29 A | 2017-06-29 A | 25FS-44d | 100% |  | 2017-01-30 | 2017-01-30 | 0d |  |  |  |  |  |  |  |  |  |  |  |  |  |
| 10 | 1.2.5 | Deliberação 33, Itens i e ii - Relatórios mensais ações de implementação de captações e de melhorias dos sistemas de abastecimento ("relatórios i e ii"). | milestone | 0d | 2023-11-22 | 2023-11-22 | 2236 |  |  | 2022-03-02 | 2022-03-02 | 0d |  |  | 0d |  |  |  |  |  |  |  |  |  |  |
| 11 | 1.2.6 | Deliberação 98 - Atualização e ajustes ao Plano de Ações para o Período Chuvoso nos temas relativos ao abastecimento de água para consumo humano. A Fundação deverá providenciar e apresentar em 30 dias a atualização do plano. | milestone | 0d | 2017-09-22 A | 2017-09-22 A | 25FS+18d | 100% |  | 2017-09-22 | 2017-09-22 | 0d |  |  |  |  |  |  |  |  |  |  |  |  |  |
| 12 | 1.2.7 | Deliberação 123 - Aprovação e recomendações complementares apontadas na Nota Técnica nº 16 do CT-SHQA sobre documento "Estudos de capacidade de mananciais superficiais e subterrâneos, visando a construção de sistemas alternativos de abastecimento de água' | milestone | 0d | 2018-02-05 A | 2018-02-05 A | 25FS+114d | 100% |  | 2018-02-05 | 2018-02-05 | 0d |  |  |  |  |  |  |  |  |  |  |  |  |  |
| 13 | 1.2.8 | Deliberação 124 - Aprovação e recomendações complementares sobre o Plano de Ações para o Período Chuvoso - setembro de 2017, com base na Nota Técnica nº 15 da CT - SHQA. Item 2: Estabelece-se o prazo de 20 dias para reapresentação do plano de ações para o | milestone | 0d | 2017-12-08 A | 2017-12-08 A | 25FS+73d | 100% |  | 2017-12-10 | 2017-12-10 | 0d |  |  |  |  |  |  |  |  |  |  |  |  |  |
| 14 | 1.2.9 | Deliberação 124 - O plano de ações para períodos chuvosos deverá ser apresentado pela Fundação Renova às Câmaras Técnicas de Gestão de Rejeitos, CT-FLOR, CT-BIO, CT-Comunicação, CT-Saúde. | milestone | 0d | 2018-02-23 A | 2018-02-23 A | 25FS+128d | 100% |  | 2018-02-23 | 2018-02-23 | 0d |  |  |  |  |  |  |  |  |  |  |  |  |  |
| 15 | 1.2.10 | Deliberação 185, Item 2 - A Fundação Renova deverá apresentar, em10 (dez) dias, um cronogramadetalhado preliminar contemplando os estudos de concepção, projetos básicos,projetos detalhados, obras e demais ações, além da distinção das ações que foremrelati | milestone | 0d | 2018-08-10 A | 2018-08-10 A | 106, 325, 422, 673, 805, 1221, 1426, 1538, 1574, 1630, 1787, 1922, 2087, 2181FS+101d, 37, 145, 473, 521, 604, 713, 850, 880, 935, 983, 1040, 1094, 1147, 1291, 1322, 1390, 1465, 1508, 1682, 1727, 2007, 2048, 2123FS+101d | 100% |  | 2018-08-12 | 2018-08-12 | 0d |  |  |  |  |  |  |  |  |  |  |  |  |  |
| 16 | 1.2.11 | Deliberação 185, Item 3 - A Fundação Renova deverá apresentar, até o dia 18 de setembro, na reunião da CT-SHQA, um Plano de Aceleração do Programa de Melhoria dos Sistemas de Abastecimento de Água, observando as considerações exaradas na Nota Técnica 22 d | milestone | 0d | 2018-09-28 A | 2018-09-28 A | 106, 325, 422, 673, 805, 1221, 1426, 1538, 1574, 1630, 1787, 1922, 2087, 2181FS+136d, 37, 145, 473, 521, 604, 713, 850, 880, 935, 983, 1040, 1094, 1147, 1291, 1322, 1390, 1465, 1508, 1682, 1727, 2007, 2048, 2123FS+136d | 100% |  | 2018-09-18 | 2018-09-18 | 0d |  |  |  |  |  |  |  |  |  |  |  |  |  |
| 17 | 1.2.12 | Deliberação 185, Item 4 - A Fundação Renova deverá apresentar os Termos de entrega e recebimentoassinado pelos prestadores de serviço e pelos Municípios, após a conclusão dasobras de captações alternativas adução e melhorias nos sistemas deabastecimento d | milestone | 0d | 2022-11-22 | 2022-11-22 | 133, 267, 314, 410, 461, 594, 703, 796, 840, 1210, 1281, 1380, 1460, 1564, 1620, 1672, 1777, 1826, 1912, 1996, 2113, 2221, 96, 203, 307, 512, 570, 664, 764, 871, 924, 971, 972, 1028, 1029, 1082, 1083, 1176, 1313, 1358, 1498, 1529, 1718, 1744, 1855, 1884, 2039, 2078, 2143, 2172 |  |  | 2021-03-02 | 2021-03-02 | 0d |  |  | 248d |  |  |  |  |  |  |  |  |  |  |
| 18 | 1.2.13 | Deliberação 258, Item 2 - A Fundação Renova deverá apresentar a anuência da Prefeitura e do prestador de servico de abastecimento de água para cada localidade, referentes à clausula 171, em 60 dias. | milestone | 0d | 2020-12-31 | 2020-12-31 | 362, 1254, 1594, 1653, 1804 |  |  | 2019-02-18 | 2019-02-18 | 0d |  |  | 718d |  |  |  |  |  |  |  |  |  |  |
| 19 | 1.2.14 | Deliberação 258, Item 4 - A Fundação Renova deveatualizar e revisar, em ate 10 (dez) dias, o cronograma detalhado das ações do Programa | milestone | 0d | 2019-01-04 A | 2019-01-04 A | 107FS+216d, 38FS+216d | 100% |  | 2019-01-02 | 2019-01-02 | 0d |  |  |  |  |  |  |  |  |  |  |  |  |  |
| 20 | 1.2.15 | Deliberação 258, Item 5 - A Fundação Renova deve atualizar e revisar, em até 10 (dez) dias, o Plano de Aceleração do Programa | milestone | 0d | 2019-01-11 A | 2019-01-11 A | 107FS+221d, 38FS+221d | 100% |  | 2019-01-02 | 2019-01-02 | 0d |  |  |  |  |  |  |  |  |  |  |  |  |  |
| 21 | 1.2.16 | Deliberação 308, Item 2: Determinar à Fundação Renova o atendimento imediato às diretrizes para elaboração de projetos básicos e do fluxograma de procedimento, previstos na Nota Técnica nº 45 da CT-SHQA. | milestone | 0d | 2020-11-04 | 2020-11-04 | 354, 583, 684, 782, 1369, 1636, 1647, 1763, 2097, 119, 224, 231, 66, 176, 482, 548, 888, 904, 1005, 1056, 1339, 1399 |  |  | 2019-07-31 | 2019-07-31 | 0d |  |  | 757d |  |  |  |  |  |  |  |  |  |  |
| 22 | 1.2.17 | Deliberação 315, Item 1: Determinar à Renova que revise e apresente o documento “Definição do Programa - Etapa 3”, no prazo de 30 dias, contemplando as propostas e considerações apresentadas na Nota Técnica nº 48 da CT-SHQA. | milestone | 0d | 2019-09-27 A | 2019-09-27 A | 30 | 100% |  | 2019-09-27 | 2019-09-27 | 0d |  |  |  |  |  |  |  |  |  |  |  |  |  |
| 23 | 2 | **Definição** |  | 1047d | 2016-03-02 A | 2020-03-30 |  | 99% | 0d | 2016-03-02 | 2019-12-26 | 984d | 2016-03-23 | 2022-03-21 | 907d | 99% | 99 | ok | 0% | 0% | 100 | 99 | 99 | Socioambiental |  |
| 24 | 2.1 | Assinatura do TTAC | milestone | 0d | 2016-03-02 A | 2016-03-02 A |  | 100% |  | 2016-03-02 | 2016-03-02 | 0d | 2016-03-23 | 2016-03-23 |  | 100% | 100 | ok | 0% | 0% | 100 | 100 | 100 | Programa | Programa |
| 25 | 2.2 | Realizar Estudo de Segurança Hídrica |  | 300ed | 2016-11-03 A | 2017-08-30 A | 24 | 100% |  | 2016-11-03 | 2017-08-30 | 300ed | 2016-11-03 | 2017-08-30 |  | 100% | 100 | ok | 0% | 0% | 100 | 100 | 100 | Programa | Programa |
| 26 | 2.3 | Realizar Levantamento de Campo e Diagnósticos |  | 320ed | 2017-01-02 A | 2017-11-18 A | 25SS+60ed | 100% |  | 2017-01-02 | 2017-11-18 | 320ed | 2017-01-02 | 2017-11-18 |  | 100% | 100 | ok | 0% | 0% | 100 | 100 | 100 | Programa | Programa |
| 27 | 2.4 | Obter Apoio Técnico |  | 100d | 2016-03-23 A | 2016-08-09 A | 24FS+15d | 100% |  | 2016-03-23 | 2016-08-09 | 100d | 2016-03-23 | 2016-08-09 |  | 100% | 100 | ok | 0% | 0% | 100 | 100 | 100 |  |  |
| 28 | 2.5 | Elaborar Definição do Programa e Protocolar no CIF |  | 196d | 2017-03-01 A | 2017-11-29 A | 24FS+245d | 100% |  | 2017-03-01 | 2017-11-29 | 196d | 2017-03-01 | 2017-11-29 |  | 100% | 100 | ok | 0% | 0% | 100 | 100 | 100 |  |  |
| 29 | 2.6 | Revisão e Aprovação da Definição do Programa pela Fundação Renova | milestone | 0d | 2017-11-29 A | 2017-11-29 A | 28 | 100% |  | 2017-11-29 | 2017-11-29 | 0d | 2017-11-29 | 2017-11-29 |  | 100% | 100 | Não OK | 0% | 0% | 100 | 100 | 100 | Socioambiental |  |
| 30 | 2.7 | Revisar a Definição do Programa conforme a NT 48/2019 da CT-SHQA e protocolar no CIF |  | 468d | 2017-11-30 A | 2019-09-27 A | 29 | 100% |  | 2017-11-30 | 2019-09-27 | 468d |  |  |  | 99% | 99 |  |  |  | 99 | 95 | 96 |  |  |
| 31 | 2.8 | Aprovação da Definição do programa pelo CIF | milestone | 0d | 2020-03-30 | 2020-03-30 | 30FS+123d |  |  | 2019-12-26 | 2019-12-26 | 0d |  |  | 907d | 0% |  |  |  |  |  |  |  |  |  |
| 32 | 2.9 | Conclusão das obras do período emergencial | milestone | 0d | 2017-12-28 A | 2017-12-28 A | 304, 2229, 2230, 2231, 2232, 2235, 2234, 2233 | 100% |  | 2017-12-28 | 2017-12-28 | 0d | 2017-12-28 | 2017-12-28 |  | 100% | 100 | ok | 0% | 0% | 100 | 100 | 100 |  |  |

Notes:
- 3: Cláusula 171 - Nos Municípios que tiveram localidades cuja operação do sistema de abastecimento público ficou inviabilizada temporariamente como decorrência do EVENTO, a FUNDAÇÃO deverá construir sistemas alternativos de captação e adução e melhoria das estações de tratamento de água para todas para as referidas localidades desses municípios que captam diretamente da calha do Rio Doce, utilizando a tecnologia apropriada, visando reduzir em 30% (trinta por cento) a dependência de abastecimento direto naquele rio, em relação aos níveis anteriores ao EVENTO, como medida reparatória.
- 4: Cláusula 171, Parágrafo 1º - Este programa incluirá os levantamentos de campo, estudos de concepção e projetos básicos, que deverão ser desenvolvidos em 2 (dois) anos, a contar da data da assinatura deste Acordo. A partir destas atividades, as obras necessárias deverão ser concluídas num prazo de 3 (três) anos / 2/Jan / - Refere-se à conclusão dos Levantamentos de Campo, Estudos de Concepção, Projetos Básicos
- 29: 20/03/19 - Dependendo do retorno do CIF

| ID | WBS | Task | Type | Duration | Start | Finish | Predecessors | Complete | Remaining | Baseline start | Baseline finish | Baseline duration | Baseline 1 start | Baseline 1 finish | Total slack | Free slack | Text3 | Text4 | Text5 | Text7 | Text15 | Text23 | Text25 | Text26 | Text27 | Text29 | Text28 |
| --- | --- | --- | --- | --- | --- | --- | --- | --- | --- | --- | --- | --- | --- | --- | --- | --- | --- | --- | --- | --- | --- | --- | --- | --- | --- | --- | --- |
| 33 | 3 | **Território Mariana** |  | 1239d | 2018-02-20 A | 2023-01-28 |  | 10% | 1115.18d | 2016-03-23 | 2021-12-28 | 1467d | 2016-03-23 | 2021-12-28 | 201d |  | 57% | 20 | 57 | 67 | 30 | Socioambiental | 0% | ok | 0% |  |  |
| 34 | 3.1 | **Camargos (distrito Mariana/MG)** |  | 1115d | 2018-03-08 A | 2022-08-18 |  | 8% | 1024.35d | 2018-03-08 | 2021-05-13 | 799d | 2018-03-08 | 2021-05-13 | 313d |  | 41% | 17 | 41 | 57 | 30 | Socioambiental | 0% | ok | 0% | Camargos (distrito Mariana/MG) |  |
| 35 | 3.1.1 | **Captação Alternativa (Poço Tubular)** |  | 1115d | 2018-03-08 A | 2022-08-18 |  | 10% | 1005.34d | 2018-03-08 | 2021-05-13 | 799d |  |  | 313d |  |  |  |  |  |  |  |  |  |  |  |  |
| 36 | 3.1.1.1 | **Estudos de Concepção do Sistema - Etapa 1** |  | 185d | 2018-03-08 A | 2018-11-21 A |  | 100% |  | 2018-03-08 | 2019-06-04 | 317d | 2018-03-08 | 2019-06-04 |  |  | 100% | 47 | 100 | 47 | 100 |  |  |  |  |  |  |
| 37 | 3.1.1.1.1 | Declaração de Escopo e Premissas de Projeto (DEPP) concluída - Camargos/MG | milestone | 0d | 2018-03-23 A | 2018-03-23 A | 25, 26 | 100% |  | 2018-03-23 | 2018-03-23 | 0d | 2018-03-23 | 2018-03-23 |  |  | 100% | 100 | 100 | 100 | 100 |  | 0% | ok | 0% | Camargos (distrito Mariana/MG) |  |
| 38 | 3.1.1.1.2 | Aprovação das DEPPs pela Operadora e Prefeitura - Camargos/MG | milestone | 0d | 2018-03-08 A | 2018-03-08 A | 25, 26 | 100% |  | 2018-03-08 | 2018-03-08 | 0d | 2018-03-08 | 2018-03-08 |  |  | 100% | 100 | 100 | 100 | 100 |  | 0% | ok | 0% | Camargos (distrito Mariana/MG) |  |
| 39 | 3.1.1.1.3 | **Estudos de Geofísica para Poço Tubular** |  | 174d | 2018-03-23 A | 2018-11-21 A |  | 100% |  | 2018-03-23 | 2018-11-21 | 174d | 2018-03-23 | 2018-11-21 |  |  | 100% | 100 | 100 | 100 | 100 |  | 0% | ok | 0% | Camargos (distrito Mariana/MG) |  |
| 40 | 3.1.1.1.3.1 | Executar Levantamento de Campo - Poço 1 - Camargos/MG |  | 24d | 2018-03-23 A | 2018-04-25 A | 37 | 100% |  | 2018-03-23 | 2018-04-25 | 24d | 2018-03-23 | 2018-04-25 |  |  | 100% | 100 | 100 | 100 | 100 |  | 0% | ok | 0% | Camargos (distrito Mariana/MG) |  |
| 41 | 3.1.1.1.3.2 | Emitir Relatório - Poço 1 - Camargos/MG |  | 22d | 2018-03-27 A | 2018-04-25 A | 40FF | 100% |  | 2018-03-27 | 2018-04-25 | 22d | 2018-03-27 | 2018-04-25 |  |  | 100% | 100 | 100 | 100 | 100 |  | 0% | ok | 0% | Camargos (distrito Mariana/MG) |  |
| 42 | 3.1.1.1.3.3 | Executar Levantamento de Campo - Poço 2 - Camargos/MG |  | 24d | 2018-10-19 A | 2018-11-21 A | 37 | 100% |  | 2018-10-19 | 2018-11-21 | 24d | 2018-10-19 | 2018-11-21 |  |  | 100% | 100 | 100 | 100 | 100 |  | 0% | ok | 0% | Camargos (distrito Mariana/MG) |  |
| 43 | 3.1.1.1.3.4 | Emitir Relatório - Poço 2 - Camargos/MG |  | 23d | 2018-10-22 A | 2018-11-21 A | 42FF | 100% |  | 2018-10-22 | 2018-11-21 | 23d | 2018-10-22 | 2018-11-21 |  |  | 100% | 100 | 100 | 100 | 100 |  | 0% | ok | 0% | Camargos (distrito Mariana/MG) |  |
| 44 | 3.1.1.1.3.5 | Conclusão dos Estudos de Geofísica - Camargos/MG | milestone | 0d | 2018-11-21 A | 2018-11-21 A | 41, 43 | 100% |  | 2018-11-21 | 2018-11-21 | 0d | 2018-11-21 | 2018-11-21 |  |  | 100% | 100 | 100 | 100 | 100 |  |  |  |  |  |  |
| 45 | 3.1.1.1.4 | **Serviços em Poços Tubulares - Poço SAAE Existente - Poço Tamponado** |  | 6d | 2018-06-27 A | 2018-07-04 A |  | 100% |  | 2018-06-27 | 2018-07-04 | 6d | 2018-06-27 | 2018-07-04 |  |  | 100% | 100 | 100 | 100 | 100 |  | 0% | ok | 0% | Camargos (distrito Mariana/MG) |  |
| 46 | 3.1.1.1.4.1 | Realizar Perfilagem (poço existente) - Camargos/MG |  | 5d | 2018-06-27 A | 2018-07-03 A | 37 | 100% |  | 2018-06-27 | 2018-07-04 | 6d | 2018-06-27 | 2018-07-04 |  |  | 100% | 100 | 100 | 100 | 100 |  | 0% | ok | 0% | Camargos (distrito Mariana/MG) |  |
| 47 | 3.1.1.1.4.2 | Realizar tamponamento - Poço SAAE Existente - Camargos/MG |  | 1d | 2018-07-04 A | 2018-07-04 A | 46 | 100% |  | 2018-07-04 | 2018-07-04 | 1d |  |  |  |  |  |  |  |  |  |  |  |  |  |  |  |
| 48 | 3.1.1.1.4.3 | Conclusão dos Serviços em poço tubular - Camargos/MG | milestone | 0d | 2018-07-04 A | 2018-07-04 A | 47 | 100% |  | 2018-07-04 | 2018-07-04 | 0d | 2018-07-04 | 2018-07-04 |  |  | 100% | 100 | 100 | 100 | 100 |  |  |  |  |  |  |
| 49 | 3.1.1.2 | **Estudos de Concepção do Sistema - Etapa 2** |  | 222d | 2019-06-28 A | 2020-05-21 |  |  | 222d | 2019-06-28 | 2020-04-02 | 191d |  |  | 396d |  |  |  |  |  |  |  |  |  |  |  |  |
| 50 | 3.1.1.2.1 | Definição do escopo para Camargos - Poço 2 e Nascente | milestone | 0d | 2019-06-28 A | 2019-06-28 A | 48FS+250d | 100% |  | 2019-06-28 | 2019-06-28 | 0d |  |  |  |  |  |  |  |  |  |  |  |  |  |  |  |
| 51 | 3.1.1.2.2 | **Serviços em Poços Tubulares - Poço 2 - Captação Alternativa** |  | 26d | 2020-04-14 | 2020-05-21 |  |  |  | 2019-04-15 | 2019-06-04 | 34d | 2019-04-15 | 2019-06-04 | 372d |  | 100% |  | 100 |  | 100 |  | 0% | ok | 0% | Camargos (distrito Mariana/MG) |  |
| 52 | 3.1.1.2.2.1 | Realizar Perfuração - Poço 2 - Captação Alternativa - Camargos/MG |  | 2d | 2020-04-14 | 2020-04-15 | 50, 84 |  |  | 2019-04-15 | 2019-04-23 | 5d | 2019-04-15 | 2019-04-23 | 372d | 0d | 100% |  | 100 |  | 100 |  | 0% | ok | 0% | Camargos (distrito Mariana/MG) |  |
| 53 | 3.1.1.2.2.2 | Realizar Teste de bombeamento - Poço 2 - Captação Alternativa - Camargos/MG |  | 1d | 2020-04-16 | 2020-04-16 | 52 |  |  | 2019-04-23 | 2019-04-25 | 3d | 2019-04-23 | 2019-04-25 | 372d | 0d | 100% |  | 100 |  | 100 |  | 0% | ok | 0% | Camargos (distrito Mariana/MG) |  |
| 54 | 3.1.1.2.2.3 | Realizar Laudo de Serviços de Coleta e Análise de Água - Poço 2 - Captação Alternativa - Camargos/MG |  | 20d | 2020-04-17 | 2020-05-18 | 53 |  |  | 2019-04-25 | 2019-05-23 | 20d | 2019-04-25 | 2019-05-23 | 399d | 3d | 100% |  | 100 |  | 100 |  | 0% | ok | 0% | Camargos (distrito Mariana/MG) | Não OK |
| 55 | 3.1.1.2.2.4 | Elaborar Relatório Técnico - Poço 2 - Captação Alternativa - Camargos/MG |  | 20d | 2020-04-17 | 2020-05-18 | 52, 53 |  |  | 2019-04-26 | 2019-05-30 | 24d | 2019-04-26 | 2019-05-30 | 372d | 0d | 100% |  | 100 |  | 100 |  | 0% | ok | 0% | Camargos (distrito Mariana/MG) |  |
| 56 | 3.1.1.2.2.5 | Realizar Instrumentação - Poço 2 - Captação Alternativa - Camargos/MG |  | 3d | 2020-05-19 | 2020-05-21 | 55 |  |  | 2019-05-31 | 2019-06-04 | 3d | 2019-05-31 | 2019-06-04 | 396d | 0d | 100% |  | 100 |  | 100 |  | 0% | ok | 0% | Camargos (distrito Mariana/MG) |  |
| 57 | 3.1.1.2.2.6 | Conclusão dos Serviços em poço tubular - Poço 2 - Captação Alternativa - Camargos/MG | milestone | 0d | 2020-05-21 | 2020-05-21 | 52, 53, 54, 55, 56 |  |  | 2019-06-04 | 2019-06-04 | 0d | 2019-06-04 | 2019-06-04 | 396d | 0d | 100% |  | 100 |  | 100 |  |  |  |  |  |  |
| 58 | 3.1.1.2.3 | Conclusão dos Estudos de Concepção das Melhorias do Sistema de Abastecimento de Água - Camargos/MG | milestone | 0d | 2020-05-21 | 2020-05-21 | 37, 38, 44, 48, 57 |  |  | 2019-06-04 | 2019-06-04 | 0d | 2019-06-04 | 2019-06-04 | 396d | 82d | 100% |  | 100 |  | 100 |  |  |  |  |  |  |

Notes:
- 37: 15/Dez / - A solução prevista para o SAA de Camargos não é a que está sendo colocada em prática hoje. A proposição era de que a Captação Principal fosse realizada em nascente e a Alternativa num poço tubular existente. / - O que está sendo posto em prática é a Captação Principal e Alternativa em poços tubulares (novos). / - A atividade de "Revisão de Definições" refere-se a um estudo que está sendo realizado pela equipe técnica do PG como medida adicional, caso os poços tubulares, depois de perfurados, não deem resultados satisfatórios.
- 38: 25/Nov: / - Anuência dada pelo SAAE de Mariana, por meio de Parecer Técnico, desde que a FR atenda as alterações, observações e acréscimos constantes no ofício 45/2018.
- 40: 14/Dez / - A necessidade dessa atividade não veio do Estudo de Concepção, apesar de estar sendo utilizado esse link.
- 46: 14/Dez / - Poço não será utilizado em função da qualidade da água, da baixa vazão e da estrutura do poço ser ruim. Previsto tamponamento assim que liberado pelo Fundiário os outros postos para serviços.
- 48: 22/04/19: O poço não foi perfurado pela FR e o tamponamento será realizado pelo SAAE
- 52: 14/Dez / - Aguardando anuência do Fundiário.
- 54: 15/Fev19: / - Essa atividade está sem Sucessora (deveria ser o Projeto Executivo da ETA), em função da Engenharia não ter respeitado o sequenciamento de atividades definido. (Ver e-mail enviado em 03/02/19 "Considerações Relevantes: Cronograma Engenharia X Cronograma Master PG 32" e "Relato Gerências").

| ID | WBS | Task | Type | Duration | Start | Finish | Predecessors | Complete | Remaining | Baseline start | Baseline finish | Baseline duration | Baseline 1 start | Baseline 1 finish | Total slack | Free slack | Calendar | Text3 | Text4 | Text5 | Text7 | Text15 | Text23 | Text25 | Text26 | Text27 | Text29 | Text9 |
| --- | --- | --- | --- | --- | --- | --- | --- | --- | --- | --- | --- | --- | --- | --- | --- | --- | --- | --- | --- | --- | --- | --- | --- | --- | --- | --- | --- | --- |
| 59 | 3.1.1.3 | **Engenharia Básica e Detalhada** |  | 500d | 2018-11-30 A | 2020-12-02 |  | 41% | 294.68d | 2018-09-20 | 2019-10-25 | 278d | 2018-09-20 | 2019-10-25 | 408d |  |  | 69% | 47 | 69 | 70 | 67 |  |  |  |  |  |  |
| 60 | 3.1.1.3.1 | **Engenharia Captação Alternativa (Poço 2)** |  | 500d | 2018-11-30 A | 2020-12-02 |  | 41% | 294.68d | 2018-11-30 | 2019-09-27 | 207d | 2018-11-30 | 2019-09-27 | 408d |  |  | 69% | 46 | 69 | 81 | 57 | Socioambiental | 0% | ok | 0% | Camargos (distrito Mariana/MG) |  |
| 61 | 3.1.1.3.1.1 | Aprovar Plano de Trabalho e abrir OSE - Captação Alternativa - Poço 2 - Camargos/MG |  | 11d | 2018-11-30 A | 2018-12-14 A | 37 | 100% |  | 2018-11-30 | 2018-12-14 | 11d | 2018-11-30 | 2018-12-14 |  |  |  | 100% | 100 | 100 | 100 | 100 |  | 0% | ok | 0% | Camargos (distrito Mariana/MG) |  |
| 62 | 3.1.1.3.1.2 | Realizar Levantamento de Campo - Captação Alternativa - Poço 2 - Camargos/MG |  | 6d | 2018-11-30 A | 2018-12-07 A | 61SS | 100% |  | 2018-11-30 | 2018-12-07 | 6d | 2018-11-30 | 2018-12-07 |  |  |  | 100% | 100 | 100 | 100 | 100 | Socioambiental |  | Não OK |  |  |  |
| 63 | 3.1.1.3.1.3 | Executar Topografia - Captação Alternativa - Poço 2 - Camargos/MG |  | 31d | 2018-11-30 A | 2019-01-14 A | 61SS | 100% |  | 2018-11-30 | 2019-01-14 | 31d | 2018-11-30 | 2019-01-14 |  |  |  | 100% | 100 | 100 | 100 | 100 | Socioambiental |  | Não OK |  |  |  |
| 64 | 3.1.1.3.1.4 | Elaborar Projeto Conceitual - Captação Alternativa - Poço 2 - Camargos/MG |  | 60d | 2018-12-18 A | 2019-03-15 A | 61SS, 62SS, 63FS-45d | 100% |  | 2018-12-18 | 2019-03-15 | 60d | 2018-12-18 | 2019-03-15 |  |  |  | 100% | 100 | 100 | 100 | 100 | Socioambiental | 0% | Não OK | 0% | Camargos (distrito Mariana/MG) | Não OK |
| 65 | 3.1.1.3.1.5 | Elaborar Projeto Básico - Captação Alternativa - Poço 2 - Camargos/MG |  | 70d | 2020-05-08 | 2020-08-14 | 64FS+283d |  |  | 2018-02-08 | 2018-03-21 | 30d | 2018-02-08 | 2018-03-21 | 314d | 0d |  | 100% |  | 100 |  | 100 |  |  |  |  |  |  |
| 66 | 3.1.1.3.1.6 | Aprovar projeto Básico com Prefeitura/Operadora - Poço 2 - Camargos/MG |  | 22d | 2020-08-17 | 2020-09-16 | 65 |  |  | 2018-03-01 | 2018-03-30 | 22d |  |  | 314d | 0d |  |  |  |  |  |  |  |  |  |  |  |  |
| 67 | 3.1.1.3.1.7 | Emitir RT/PQ para Suprimentos - Captação Alternativa - Poço 2 - Camargos/MG |  | 10d | 2020-11-19 | 2020-12-02 | 68FF |  |  | 2019-09-16 | 2019-09-27 | 10d | 2019-09-16 | 2019-09-27 | 314d | 0d |  | 0% |  |  |  |  |  | 0% | ok | 0% | Camargos (distrito Mariana/MG) |  |
| 68 | 3.1.1.3.1.8 | Elaborar Projeto Executivo - Captação Alternativa - Poço 2 - Camargos/MG |  | 53d | 2020-09-17 | 2020-12-02 | 55, 56, 57, 66, 58 |  |  | 2019-06-28 | 2019-09-27 | 65d | 2019-06-28 | 2019-09-27 | 314d | 0d |  | 1% |  |  |  |  |  | 0% | ok | 0% | Camargos (distrito Mariana/MG) |  |
| 69 | 3.1.1.3.1.9 | Elaboração do Projeto Executivo - Captação Alternativa - Poço 2 - Camargos/MG | milestone | 0d | 2020-12-02 | 2020-12-02 | 66, 68 |  |  | 2019-09-27 | 2019-09-27 | 0d | 2019-09-27 | 2019-09-27 | 408d | 94d |  | 0% |  |  |  |  |  |  |  |  |  |  |
| 70 | 3.1.1.4 | **Fundiária** |  | 340d | 2019-05-02 A | 2020-09-09 |  | 20% | 272d | 2018-03-23 | 2019-09-04 | 370d | 2018-03-23 | 2019-09-04 | 466d |  |  | 87% |  | 87 | 18 | 51 | Socioambiental | 0% | ok | 0% | Camargos (distrito Mariana/MG) |  |
| 71 | 3.1.1.4.1 | Obter Termos de Autorização de Superficiário - Captação Alternativa - Poço 2 - Camargos/MG |  | 20d | 2019-05-02 A | 2019-05-29 A | 43FS+108d | 100% |  | 2019-04-24 | 2019-04-30 | 5d | 2019-04-24 | 2019-04-30 |  |  |  | 100% |  | 100 |  | 100 |  |  |  |  |  |  |
| 72 | 3.1.1.4.2 | **Captação Alternativa - Poço 2 - Desimpedimento da Área e Negociação de Servidão** |  | 80d | 2020-05-19 | 2020-09-09 |  |  |  | 2019-05-02 | 2019-08-23 | 80d | 2019-05-02 | 2019-08-23 | 466d |  |  | 51% |  | 51 |  | 51 |  | 0% | ok | 0% | Camargos (distrito Mariana/MG) |  |
| 73 | 3.1.1.4.2.1 | Realizar Levantamento da documentação da propriedade - Camargos/MG |  | 10d | 2020-05-19 | 2020-06-01 | 55, 64 |  |  | 2019-05-02 | 2019-05-15 | 10d | 2019-05-02 | 2019-05-15 | 466d | 0d |  | 100% |  | 100 |  | 100 |  |  |  |  |  |  |
| 74 | 3.1.1.4.2.2 | Obter assinatura do Contrato de servidão pelo proprietário - Camargos/MG |  | 20d | 2020-06-02 | 2020-06-30 | 73 |  |  | 2019-05-16 | 2019-06-12 | 20d | 2019-05-16 | 2019-06-12 | 466d | 0d |  | 100% |  | 100 |  | 100 |  |  |  |  |  |  |
| 75 | 3.1.1.4.2.3 | Lavrar Escritura Pública de Servidão no cartório de notas - Camargos/MG |  | 30d | 2020-07-01 | 2020-08-11 | 74 |  |  | 2019-06-13 | 2019-07-25 | 30d | 2019-06-13 | 2019-07-25 | 466d | 0d |  | 36% |  | 36 |  | 36 |  |  |  |  |  |  |
| 76 | 3.1.1.4.2.4 | Averbar a escritura pública na matrícula do imóvel - Camargos/MG |  | 20d | 2020-08-12 | 2020-09-09 | 75 |  |  | 2019-07-26 | 2019-08-23 | 20d | 2019-07-26 | 2019-08-23 | 466d | 0d |  | 0% |  |  |  |  |  |  |  |  |  |  |
| 77 | 3.1.1.4.2.5 | Regularização da Servidão do Imóvel - Poço 2 - Camargos/MG | milestone | 0d | 2020-09-09 | 2020-09-09 | 76 |  |  | 2019-08-23 | 2019-08-23 | 0d | 2019-08-23 | 2019-08-23 | 488d | 0d | Calendário APRO | 0% |  |  |  |  |  |  |  |  |  |  |
| 78 | 3.1.1.4.3 | Conclusão da Regularização Fundiária para as obras de Melhoria do Sistema de Abastecimento da Localidade - Camargos/MG | milestone | 0d | 2020-09-09 | 2020-09-09 | 77 |  |  | 2019-09-04 | 2019-09-04 | 0d | 2019-09-04 | 2019-09-04 | 466d | 152d |  | 0% |  |  |  |  |  |  |  |  |  |  |
| 79 | 3.1.1.5 | **Licenciamento** |  | 264d | 2020-01-06 | 2021-01-26 |  |  |  | 2019-05-02 | 2019-09-17 | 97d | 2019-05-02 | 2019-09-17 | 372d |  |  | 42% |  | 42 |  | 47 | Socioambiental | 0% | ok | 0% | Camargos (distrito Mariana/MG) |  |
| 80 | 3.1.1.5.1 | **Captação Alternativa - Autorização de Perfuração Poço 2 (AM) - Captação Principal** |  | 67d | 2020-01-06 | 2020-04-13 |  |  |  | 2019-05-02 | 2019-08-07 | 69d | 2019-05-02 | 2019-08-07 | 372d |  |  | 59% |  | 59 |  | 59 |  | 0% | ok | 0% | Camargos (distrito Mariana/MG) |  |
| 81 | 3.1.1.5.1.1 | Realizar Análise Inicial da Demanda - Camargos/MG |  | 8d | 2020-01-06 | 2020-01-15 | 43, 71FS+150d |  |  | 2019-05-02 | 2019-05-15 | 10d | 2019-05-02 | 2019-05-15 | 372d | 0d |  | 100% |  | 100 |  | 100 |  |  |  |  |  |  |
| 82 | 3.1.1.5.1.2 | Protocolar FCE e documentos do FOB - Camargos/MG |  | 15d | 2020-01-16 | 2020-02-05 | 81 |  |  | 2019-05-16 | 2019-06-05 | 15d | 2019-05-16 | 2019-06-05 | 372d | 0d |  | 100% |  | 100 |  | 100 |  |  |  |  |  |  |
| 83 | 3.1.1.5.1.3 | Acompanhar Processo Junto ao Órgão - Camargos/MG |  | 44d | 2020-02-06 | 2020-04-13 | 82 |  |  | 2019-06-06 | 2019-08-07 | 44d | 2019-06-06 | 2019-08-07 | 372d | 0d |  | 36% |  | 36 |  | 36 |  |  |  |  |  |  |
| 84 | 3.1.1.5.1.4 | Obtenção de Autorização de Perfuração - Poço 2 - Camargos/MG | milestone | 0d | 2020-04-13 | 2020-04-13 | 83 |  |  | 2019-08-07 | 2019-08-07 | 0d | 2019-08-07 | 2019-08-07 | 372d | 0d |  | 0% |  |  |  |  |  |  |  |  |  |  |

Notes:
- 68: 25/Jan19: / - Projeto Executivo não considerando as datas corretas do Laudo de análise da água e o Relatório Técnico do Poço.
- 70: 14/Dez / - Único superficiário para a área dos dois poços. / - Definir o que será feito em relação ao Fundiário (sr. da moto - Álvaro Antônio), pois os serviços nos poços (captação principal e alternativa) não estão sendo executados em função da não liberação do mesmo para acesso a área. Verificar um "plano B".
- 79: 06/Fev19: / - Depois do caminhamento da adução (projeto conceitual), verificar se haverá necessidade de alguma autorização específica.
- 80: 26/Nov: / - Necessária autorização para perfuração (problema com fundiário: proprietário não autorizou perfuração no local definido). Verificar com PG se será em outro local e/ou se está sendo negociado com o proprietário. / 25/Nov: / - Processos constantes na planilha de Licenciamento todos cancelados.

| ID | WBS | Task | Type | Duration | Start | Finish | Predecessors | Complete | Remaining | Baseline start | Baseline finish | Baseline duration | Baseline 1 start | Baseline 1 finish | Total slack | Free slack | Text3 | Text5 | Text15 | Text25 | Text26 | Text27 | Text29 | Indicadores MIR | Text4 | Text7 |
| --- | --- | --- | --- | --- | --- | --- | --- | --- | --- | --- | --- | --- | --- | --- | --- | --- | --- | --- | --- | --- | --- | --- | --- | --- | --- | --- |
| 85 | 3.1.1.5.2 | **Outorga para Captação Alternativa (Poço 2)** |  | 174d | 2020-05-19 | 2021-01-26 |  |  |  | 2019-05-31 | 2019-09-17 | 76d | 2019-05-31 | 2019-09-17 | 372d |  | 26% | 26 | 26 | 0% | ok | 0% | Camargos (distrito Mariana/MG) |  |  |  |
| 86 | 3.1.1.5.2.1 | Protocolar FCE e documentos do FOB - Camargos/MG |  | 44d | 2020-05-19 | 2020-07-20 | 55, 64 |  |  | 2019-05-31 | 2019-06-13 | 10d | 2019-05-31 | 2019-06-13 | 372d | 0d | 100% | 100 | 100 |  |  |  |  |  |  |  |
| 87 | 3.1.1.5.2.2 | Acompanhar Processo Junto ao Órgão - Camargos/MG |  | 130d | 2020-07-21 | 2021-01-26 | 86 |  |  | 2019-06-14 | 2019-09-17 | 66d | 2019-06-14 | 2019-09-17 | 372d | 0d | 15% | 15 | 15 |  |  |  |  |  |  |  |
| 88 | 3.1.1.5.2.3 | Obtenção da Outorga para captação - Poço 2 - Camargos/MG | milestone | 0d | 2021-01-26 | 2021-01-26 | 87 |  |  | 2019-09-17 | 2019-09-17 | 0d | 2019-09-17 | 2019-09-17 | 372d | 0d | 0% |  |  |  |  |  |  |  |  |  |
| 89 | 3.1.1.5.3 | Conclusão do Licenciamento Ambiental da Localidade - Camargos/MG | milestone | 0d | 2021-01-26 | 2021-01-26 | 84, 88 |  |  | 2019-09-17 | 2019-09-17 | 0d | 2019-09-17 | 2019-09-17 | 372d | 58d | 0% |  |  |  |  |  |  |  |  |  |
| 90 | 3.1.1.6 | **Suprimentos** |  | 94d | 2020-12-03 | 2021-04-23 |  |  |  | 2019-09-27 | 2020-02-04 | 88d | 2019-09-27 | 2020-02-04 | 314d |  | 0% |  |  | 0% | ok | 0% | Camargos (distrito Mariana/MG) |  |  |  |
| 91 | 3.1.1.6.1 | Captações e ETA - Camargos/MG |  | 94d | 2020-12-03 | 2021-04-23 | 67 |  |  | 2019-09-27 | 2020-02-04 | 88d | 2019-09-27 | 2020-02-04 | 314d | 0d | 0% |  |  | 0% | ok | 0% | Camargos (distrito Mariana/MG) |  |  |  |
| 92 | 3.1.1.6.2 | Conclusão da Contratação de Suprimentos - Captações e ETA - Camargos/MG | milestone | 0d | 2021-04-23 | 2021-04-23 | 91 |  |  | 2020-02-04 | 2020-02-04 | 0d | 2020-02-04 | 2020-02-04 | 314d | 0d | 0% |  |  |  |  |  |  |  |  |  |
| 93 | 3.1.1.7 | **Infraestrutura** |  | 330d | 2021-04-26 | 2022-08-18 |  |  |  | 2020-02-04 | 2021-05-13 | 315d | 2020-02-04 | 2021-05-13 | 313d |  | 0% |  |  | 0% | ok | 0% | Camargos (distrito Mariana/MG) |  |  |  |
| 94 | 3.1.1.7.1 | **Obras** |  | 81d | 2021-04-26 | 2021-08-17 |  |  |  | 2020-02-04 | 2020-05-13 | 66d | 2020-02-04 | 2020-05-13 | 314d |  | 0% |  |  |  |  |  |  |  |  |  |
| 95 | 3.1.1.7.1.1 | Executar obras de Captação Alternativa (Poço 2) - Camargos/MG |  | 81d | 2021-04-26 | 2021-08-17 | 68, 69, 76, 77, 88, 92, 78, 89 |  |  | 2020-02-04 | 2020-05-13 | 66d | 2020-02-04 | 2020-05-13 | 314d | 0d | 0% |  |  | 0% | ok | 0% | Camargos (distrito Mariana/MG) | CA |  |  |
| 96 | 3.1.1.7.1.2 | Assinatura de Termo de Entrega das Obras de Melhoria do Sistema de Abastecimento de Água - Camargos/MG | milestone | 0d | 2021-08-17 | 2021-08-17 | 95 |  |  | 2020-05-13 | 2020-05-13 | 0d | 2020-05-13 | 2020-05-13 | 314d | 0d | 0% |  |  | 0% | ok | 0% | Camargos (distrito Mariana/MG) |  |  |  |
| 97 | 3.1.1.7.2 | **Operação** |  | 249d | 2021-08-18 | 2022-08-18 |  |  |  | 2020-05-13 | 2021-05-13 | 249d | 2020-05-13 | 2021-05-13 | 313d |  | 0% |  |  | 0% | ok | 0% | Camargos (distrito Mariana/MG) |  |  |  |
| 98 | 3.1.1.7.2.1 | Realizar Treinamento Operacional do Sistema - Camargos/MG |  | 5d | 2021-08-18 | 2021-08-24 | 95, 96 |  |  | 2020-05-14 | 2020-05-20 | 5d | 2020-05-14 | 2020-05-20 | 314d | 0d | 0% |  |  | 0% | ok | 0% | Camargos (distrito Mariana/MG) |  |  |  |
| 99 | 3.1.1.7.2.2 | Realizar Testes e Pré-operação - Camargos/MG |  | 14d | 2021-08-18 | 2021-09-06 | 98SS |  |  | 2020-05-21 | 2020-06-09 | 14d | 2020-05-21 | 2020-06-09 | 314d | 0d | 0% |  |  | 0% | ok | 0% | Camargos (distrito Mariana/MG) |  |  |  |
| 100 | 3.1.1.7.2.3 | Realizar Acompanhamento da Funcionalidade do Sistema - Captação Alternativa (Poço Tubular) - Camargos (distrito Mariana/MG) |  | 365ed | 2021-08-18 | 2022-08-18 | 102SS |  |  | 2020-05-13 | 2021-05-13 | 249d |  |  | 1384.12d | 0d |  |  |  |  |  |  |  |  |  |  |
| 101 | 3.1.1.7.2.4 | **Operação Assistida** |  | 60d | 2021-08-18 | 2021-11-16 |  |  |  | 2020-05-13 | 2020-08-11 | 63d | 2020-05-13 | 2020-08-11 | 314d |  | 0% |  |  | 0% | ok | 0% | Camargos (distrito Mariana/MG) |  |  |  |
| 102 | 3.1.1.7.2.4.1 | Realizar Operação Assistida - Camargos/MG |  | 90ed | 2021-08-18 | 2021-11-16 | 95, 99SS |  |  | 2020-05-13 | 2020-08-11 | 90ed | 2020-05-13 | 2020-08-11 | 1384.12d | 0d | 0% |  |  | 0% | ok | 0% | Camargos (distrito Mariana/MG) |  |  |  |
| 103 | 3.1.1.7.3 | Entrega das obras e conclusão do período de acompanhamento da operação - Camargos/MG | milestone | 0d | 2022-08-18 | 2022-08-18 | 96, 102, 100 |  |  | 2021-05-13 | 2021-05-13 | 0d | 2021-05-13 | 2021-05-13 | 313d |  | 0% |  |  |  |  |  |  |  |  |  |
| 104 | 3.1.2 | **ETA (Sistema de Tratamento Simplificado) e Captação Principal (Nascente)** |  | 1066d | 2018-03-08 A | 2022-06-08 |  | 6% | 1000.88d | 2018-03-08 | 2020-05-13 | 550d |  |  | 362d |  |  |  |  |  |  |  |  |  |  |  |
| 105 | 3.1.2.1 | **Estudos de Concepção do Sistema - Etapa 1** |  | 85d | 2018-03-08 A | 2018-07-04 A |  | 100% |  | 2018-03-08 | 2019-06-04 | 317d | 2018-03-08 | 2019-06-04 |  |  | 100% | 100 | 100 |  |  |  |  |  | 47 | 47 |
| 106 | 3.1.2.1.1 | Declaração de Escopo e Premissas de Projeto (DEPP) concluída - Camargos/MG | milestone | 0d | 2018-03-23 A | 2018-03-23 A | 25, 26 | 100% |  | 2018-03-23 | 2018-03-23 | 0d | 2018-03-23 | 2018-03-23 |  |  | 100% | 100 | 100 | 0% | ok | 0% | Camargos (distrito Mariana/MG) |  | 100 | 100 |
| 107 | 3.1.2.1.2 | Aprovação das DEPPs pela Operadora e Prefeitura - Camargos/MG | milestone | 0d | 2018-03-08 A | 2018-03-08 A | 25, 26 | 100% |  | 2018-03-08 | 2018-03-08 | 0d | 2018-03-08 | 2018-03-08 |  |  | 100% | 100 | 100 | 0% | ok | 0% | Camargos (distrito Mariana/MG) |  | 100 | 100 |
| 108 | 3.1.2.1.3 | **Serviços em Poços Tubulares - Poço SAAE Existente - Poço Tamponado** |  | 6d | 2018-06-27 A | 2018-07-04 A |  | 100% |  | 2018-06-27 | 2018-07-04 | 6d | 2018-06-27 | 2018-07-04 |  |  | 100% | 100 | 100 | 0% | ok | 0% | Camargos (distrito Mariana/MG) |  | 100 | 100 |
| 109 | 3.1.2.1.3.1 | Realizar Perfilagem (poço existente) - Camargos/MG |  | 5d | 2018-06-27 A | 2018-07-03 A | 106 | 100% |  | 2018-06-27 | 2018-07-04 | 6d | 2018-06-27 | 2018-07-04 |  |  | 100% | 100 | 100 | 0% | ok | 0% | Camargos (distrito Mariana/MG) |  | 100 | 100 |
| 110 | 3.1.2.1.3.2 | Realizar tamponamento - Poço SAAE Existente - Camargos/MG |  | 1d | 2018-07-04 A | 2018-07-04 A | 109 | 100% |  | 2018-07-04 | 2018-07-04 | 1d |  |  |  |  |  |  |  |  |  |  |  |  |  |  |
| 111 | 3.1.2.1.3.3 | Conclusão dos Serviços em poço tubular - Camargos/MG | milestone | 0d | 2018-07-04 A | 2018-07-04 A | 110 | 100% |  | 2018-07-04 | 2018-07-04 | 0d | 2018-07-04 | 2018-07-04 |  |  | 100% | 100 | 100 |  |  |  |  |  | 100 | 100 |

Notes:
- 85: 05/Fev19: / - Renata Vilela entende que o processo de outorga é de responsabilidade da Operadora/Concessionária. PG deverá alinhar entendimento correto com a área.
- 106: 15/Dez / - A solução prevista para o SAA de Camargos não é a que está sendo colocada em prática hoje. A proposição era de que a Captação Principal fosse realizada em nascente e a Alternativa num poço tubular existente. / - O que está sendo posto em prática é a Captação Principal e Alternativa em poços tubulares (novos). / - A atividade de "Revisão de Definições" refere-se a um estudo que está sendo realizado pela equipe técnica do PG como medida adicional, caso os poços tubulares, depois de perfurados, não deem resultados satisfatórios.
- 107: 25/Nov: / - Anuência dada pelo SAAE de Mariana, por meio de Parecer Técnico, desde que a FR atenda as alterações, observações e acréscimos constantes no ofício 45/2018.
- 109: 14/Dez / - Poço não será utilizado em função da qualidade da água, da baixa vazão e da estrutura do poço ser ruim. Previsto tamponamento assim que liberado pelo Fundiário os outros postos para serviços.
- 111: 22/04/19: O poço não foi perfurado pela FR e o tamponamento será realizado pelo SAAE

| ID | WBS | Task | Type | Duration | Start | Finish | Predecessors | Complete | Remaining | Baseline start | Baseline finish | Baseline duration | Baseline 1 start | Baseline 1 finish | Total slack | Free slack | Text3 | Text4 | Text5 | Text7 | Text15 | Text23 | Text25 | Text26 | Text27 | Text29 | Text9 | Indicadores MIR |
| --- | --- | --- | --- | --- | --- | --- | --- | --- | --- | --- | --- | --- | --- | --- | --- | --- | --- | --- | --- | --- | --- | --- | --- | --- | --- | --- | --- | --- |
| 112 | 3.1.2.2 | **Engenharia Básica e Detalhada** |  | 420d | 2018-11-30 A | 2020-08-07 |  | 40% | 250.75d | 2018-09-20 | 2019-10-25 | 278d | 2018-09-20 | 2019-10-25 | 488d |  | 69% | 47 | 69 | 70 | 67 |  |  |  |  |  |  |  |
| 113 | 3.1.2.2.1 | **Engenharia ETA (Sistema de Tratamento Simplificado) e Captação Principal (Nascente)** |  | 420d | 2018-11-30 A | 2020-08-07 |  | 40% | 250.75d | 2018-11-30 | 2019-09-27 | 207d | 2018-11-30 | 2019-09-27 | 488d |  | 69% | 46 | 69 | 67 | 69 | Socioambiental | 0% | ok | 0% | Camargos (distrito Mariana/MG) |  |  |
| 114 | 3.1.2.2.1.1 | Aprovar Plano de Trabalho e abrir OSE - ETA/Captação Principal - Camargos/MG |  | 11d | 2018-11-30 A | 2018-12-14 A | 106, 111 | 100% |  | 2018-11-30 | 2018-12-14 | 11d | 2018-11-30 | 2018-12-14 |  |  | 100% | 100 | 100 | 100 | 100 |  | 0% | ok | 0% | Camargos (distrito Mariana/MG) |  |  |
| 115 | 3.1.2.2.1.2 | Realizar Levantamento de Campo - ETA/Captação Principal - Camargos/MG |  | 6d | 2018-11-30 A | 2018-12-07 A | 114SS | 100% |  | 2018-11-30 | 2018-12-07 | 6d | 2018-11-30 | 2018-12-07 |  |  | 100% | 100 | 100 | 100 | 100 | Socioambiental | 0% | Não OK | 0% | Camargos (distrito Mariana/MG) | Não OK |  |
| 116 | 3.1.2.2.1.3 | Executar Topografia - ETA/Captação Principal - Camargos/MG |  | 31d | 2018-11-30 A | 2019-01-14 A | 114SS | 100% |  | 2018-11-30 | 2019-01-14 | 31d | 2018-11-30 | 2019-01-14 |  |  | 100% | 100 | 100 | 100 | 100 |  |  |  |  |  |  |  |
| 117 | 3.1.2.2.1.4 | Elaborar Projeto Conceitual - ETA/Captação Principal - Camargos/MG |  | 60d | 2018-12-18 A | 2019-03-15 A | 115, 116 | 100% |  | 2018-12-18 | 2019-03-15 | 60d | 2018-12-18 | 2019-03-15 |  |  | 100% | 100 | 100 | 100 | 100 | Socioambiental | 0% | Não OK | 0% | Camargos (distrito Mariana/MG) | Não OK |  |
| 118 | 3.1.2.2.1.5 | Elaborar Projeto Básico - ETA/Captação Principal - Camargos/MG |  | 60d | 2020-01-02 | 2020-03-30 | 117FS+198d |  |  | 2018-02-08 | 2018-03-21 | 30d | 2018-02-08 | 2018-03-21 | 365d | 0d | 100% |  | 100 |  | 100 |  |  |  |  |  |  |  |
| 119 | 3.1.2.2.1.6 | Aprovar projeto Básico com Prefeitura/Operadora - ETA/Captação Principal - Camargos/MG |  | 22d | 2020-03-31 | 2020-05-04 | 118 |  |  | 2018-03-01 | 2018-03-30 | 22d |  |  | 365d | 0d |  |  |  |  |  |  |  |  |  |  |  |  |
| 120 | 3.1.2.2.1.7 | Emitir RT/PQ para Suprimentos - ETA/Captação Principal - Camargos/MG |  | 10d | 2020-07-27 | 2020-08-07 | 121FF |  |  | 2019-09-16 | 2019-09-27 | 10d | 2019-09-16 | 2019-09-27 | 365d | 0d | 0% |  |  |  |  | Socioambiental | 0% | Não OK | 0% | Camargos (distrito Mariana/MG) |  |  |
| 121 | 3.1.2.2.1.8 | Elaborar Projeto Executivo - ETA/Captação Principal - Camargos/MG |  | 68d | 2020-05-05 | 2020-08-07 | 119 |  |  | 2019-06-28 | 2019-09-27 | 65d | 2019-06-28 | 2019-09-27 | 365d | 0d | 1% |  |  |  |  |  | 0% | ok | 0% | Camargos (distrito Mariana/MG) |  |  |
| 122 | 3.1.2.2.1.9 | Elaboração do Projeto Executivo - ETA/Captação Principal - Camargos/MG | milestone | 0d | 2020-08-07 | 2020-08-07 | 121, 119 |  |  | 2019-09-27 | 2019-09-27 | 0d | 2019-09-27 | 2019-09-27 | 488d | 94d | 0% |  |  |  |  |  |  |  |  |  |  |  |
| 123 | 3.1.2.3 | **Fundiária** |  | 5d | 2018-03-23 A | 2018-03-29 A |  | 100% |  | 2018-03-23 | 2019-09-04 | 370d | 2018-03-23 | 2019-09-04 |  |  | 87% |  | 87 | 18 | 51 | Socioambiental | 0% | ok | 0% | Camargos (distrito Mariana/MG) |  |  |
| 124 | 3.1.2.3.1 | Obter Termos de Autorização de Superficiário - ETA - Camargos/MG |  | 5d | 2018-03-23 A | 2018-03-29 A | 106 | 100% |  | 2018-03-23 | 2018-03-29 | 5d | 2018-03-23 | 2018-03-29 |  |  | 100% | 100 | 100 | 100 | 100 | Socioambiental | 0% | Não OK | 0% | Camargos (distrito Mariana/MG) |  |  |
| 125 | 3.1.2.3.2 | Conclusão da Regularização Fundiária para as obras de Melhoria do Sistema de Abastecimento da Localidade - Camargos/MG | milestone | 0d | 2018-03-29 A | 2018-03-29 A | 124 | 100% |  | 2019-09-04 | 2019-09-04 | 0d | 2019-09-04 | 2019-09-04 |  |  | 0% |  |  |  |  |  |  |  |  |  |  |  |
| 126 | 3.1.2.4 | **Suprimentos** |  | 94d | 2020-08-10 | 2020-12-22 |  |  |  | 2019-09-27 | 2020-02-04 | 88d | 2019-09-27 | 2020-02-04 | 365d |  | 0% |  |  |  |  |  | 0% | ok | 0% | Camargos (distrito Mariana/MG) |  |  |
| 127 | 3.1.2.4.1 | Captações e ETA - Camargos/MG |  | 94d | 2020-08-10 | 2020-12-22 | 120 |  |  | 2019-09-27 | 2020-02-04 | 88d | 2019-09-27 | 2020-02-04 | 365d | 0d | 0% |  |  |  |  |  | 0% | ok | 0% | Camargos (distrito Mariana/MG) |  |  |
| 128 | 3.1.2.4.2 | Conclusão da Contratação de Suprimentos - Captações e ETA - Camargos/MG | milestone | 0d | 2020-12-22 | 2020-12-22 | 127 |  |  | 2020-02-04 | 2020-02-04 | 0d | 2020-02-04 | 2020-02-04 | 394d | 0d | 0% |  |  |  |  |  |  |  |  |  |  |  |
| 129 | 3.1.2.5 | **Infraestrutura** |  | 361d | 2020-12-23 | 2022-06-08 |  |  |  | 2020-02-04 | 2021-05-13 | 315d | 2020-02-04 | 2021-05-13 | 362d |  | 0% |  |  |  |  |  | 0% | ok | 0% | Camargos (distrito Mariana/MG) |  |  |
| 130 | 3.1.2.5.1 | **Obras** |  | 110d | 2020-12-23 | 2021-06-07 |  |  |  | 2020-02-04 | 2020-05-13 | 66d | 2020-02-04 | 2020-05-13 | 365d |  | 0% |  |  |  |  |  |  |  |  |  |  |  |
| 131 | 3.1.2.5.1.1 | Executar Melhorias na Captação Superficial e Reservatório - Captação Principal - Camargos/MG |  | 110d | 2020-12-23 | 2021-06-07 | 127 |  |  | 2020-02-04 | 2020-05-13 | 66d |  |  | 365d | 0d |  |  |  |  |  |  |  |  |  |  |  |  |
| 132 | 3.1.2.5.1.2 | Executar obras da ETA 2L/s (Sistema de Tratamento Simplificado) - Camargos/MG |  | 81d | 2020-12-23 | 2021-04-26 | 121, 128, 122 |  |  | 2020-02-04 | 2020-05-13 | 66d | 2020-02-04 | 2020-05-13 | 394d | 29d | 0% |  |  |  |  |  | 0% | ok | 0% | Camargos (distrito Mariana/MG) |  | ETA |
| 133 | 3.1.2.5.1.3 | Assinatura de Termo de Entrega das Obras de Melhoria do Sistema de Abastecimento de Água - Camargos/MG | milestone | 0d | 2021-06-07 | 2021-06-07 | 132, 131 |  |  | 2020-05-13 | 2020-05-13 | 0d | 2020-05-13 | 2020-05-13 | 365d | 0d | 0% |  |  |  |  |  | 0% | ok | 0% | Camargos (distrito Mariana/MG) |  |  |
| 134 | 3.1.2.5.2 | **Operação** |  | 251d | 2021-06-08 | 2022-06-08 |  |  |  | 2020-05-13 | 2021-05-13 | 249d | 2020-05-13 | 2021-05-13 | 362d |  | 0% |  |  |  |  |  | 0% | ok | 0% | Camargos (distrito Mariana/MG) |  |  |
| 135 | 3.1.2.5.2.1 | Realizar Treinamento Operacional do Sistema - Camargos/MG |  | 5d | 2021-06-08 | 2021-06-14 | 132, 133 |  |  | 2020-05-14 | 2020-05-20 | 5d | 2020-05-14 | 2020-05-20 | 365d | 0d | 0% |  |  |  |  |  | 0% | ok | 0% | Camargos (distrito Mariana/MG) |  |  |
| 136 | 3.1.2.5.2.2 | Realizar Testes e Pré-operação - Camargos/MG |  | 14d | 2021-06-08 | 2021-06-25 | 135SS |  |  | 2020-05-21 | 2020-06-09 | 14d | 2020-05-21 | 2020-06-09 | 365d | 0d | 0% |  |  |  |  |  | 0% | ok | 0% | Camargos (distrito Mariana/MG) |  |  |
| 137 | 3.1.2.5.2.3 | Realizar Acompanhamento da Funcionalidade do Sistema - ETA (Sistema de Tratamento Simplificado) e Captação Principal (Nascente) - Camargos (distrito Mariana/MG) |  | 365ed | 2021-06-08 | 2022-06-08 | 139SS |  |  | 2020-05-13 | 2021-05-13 | 249d |  |  | 1597.12d | 0d |  |  |  |  |  |  |  |  |  |  |  |  |

Notes:
- 115: 25/Jan19: / - Levantamento de campo iniciado em 30/11 e finalizado em 07/12/18; Topografia iniciada em 20/09/18 e finalizada em 14/01/19; Resultado da vazão dos poços previsto para 15/02/19.
- 121: 25/Jan19: / - Projeto Executivo não considerando as datas corretas dos Laudos de análises da água.
- 123: 14/Dez / - Único superficiário para a área dos dois poços. / - Definir o que será feito em relação ao Fundiário (sr. da moto - Álvaro Antônio), pois os serviços nos poços (captação principal e alternativa) não estão sendo executados em função da não liberação do mesmo para acesso a área. Verificar um "plano B".
- 124: 14/Dez / - Verificar com a Gestão Fundiária como está o status de negociação com o superficiário onde será construída a ETA/UTR (área da antena - atrás da igreja).

| ID | WBS | Task | Type | Duration | Start | Finish | Predecessors | Complete | Remaining | Baseline start | Baseline finish | Baseline duration | Baseline 1 start | Baseline 1 finish | Total slack | Free slack | Text3 | Text25 | Text26 | Text27 | Text29 | Text4 | Text5 | Text7 | Text15 | Text23 | Text28 |
| --- | --- | --- | --- | --- | --- | --- | --- | --- | --- | --- | --- | --- | --- | --- | --- | --- | --- | --- | --- | --- | --- | --- | --- | --- | --- | --- | --- |
| 138 | 3.1.2.5.2.4 | **Operação Assistida** |  | 64d | 2021-06-08 | 2021-09-06 |  |  |  | 2020-05-13 | 2020-08-11 | 63d | 2020-05-13 | 2020-08-11 | 363d |  | 0% | 0% | ok | 0% | Camargos (distrito Mariana/MG) |  |  |  |  |  |  |
| 139 | 3.1.2.5.2.4.1 | Realizar Operação Assistida - Camargos/MG |  | 90ed | 2021-06-08 | 2021-09-06 | 132, 136SS |  |  | 2020-05-13 | 2020-08-11 | 90ed | 2020-05-13 | 2020-08-11 | 1597.12d | 0d | 0% | 0% | ok | 0% | Camargos (distrito Mariana/MG) |  |  |  |  |  |  |
| 140 | 3.1.2.5.3 | Entrega das obras e conclusão do período de acompanhamento da operação - Camargos/MG | milestone | 0d | 2022-06-08 | 2022-06-08 | 133, 139, 137 |  |  | 2021-05-13 | 2021-05-13 | 0d | 2021-05-13 | 2021-05-13 | 362d |  | 0% |  |  |  |  |  |  |  |  |  |  |
| 141 | 3.2 | **Pedras (distrito Mariana/MG)** |  | 1239d | 2018-02-20 A | 2023-01-28 |  | 12% | 1095.1d | 2018-02-20 | 2021-05-28 | 822d | 2018-02-20 | 2021-05-28 | 201d |  | 42% | 0% | ok | 0% | Pedras (distrito Mariana/MG) | 23 | 42 | 77 | 30 | Socioambiental |  |
| 142 | 3.2.1 | **Captação Alternativa (Poço Tubular)** |  | 1084d | 2018-02-20 A | 2022-06-17 |  | 21% | 852.48d | 2018-02-20 | 2021-05-28 | 822d |  |  | 356d |  |  |  |  |  |  |  |  |  |  |  |  |
| 143 | 3.2.1.1 | **Engenharia** |  | 599d | 2018-02-20 A | 2020-07-06 |  | 73% | 162.64d | 2018-02-20 | 2020-02-12 | 503d | 2018-02-20 | 2020-02-12 | 447d |  | 68% |  | ok |  |  | 54 | 68 | 77 | 70 | Socioambiental |  |
| 144 | 3.2.1.1.1 | **Estudos de Concepção do Sistema - Etapa 1** |  | 286d | 2018-02-20 A | 2019-04-01 A |  | 100% |  | 2018-02-20 | 2019-10-09 | 418d | 2018-02-20 | 2019-10-09 |  |  | 82% |  |  |  |  | 72 | 82 | 104 | 69 |  |  |
| 145 | 3.2.1.1.1.1 | Declaração de Escopo e Premissas de Projeto (DEPP) concluída - Pedras/MG | milestone | 0d | 2018-03-23 A | 2018-03-23 A | 25, 26FS+90d | 100% |  | 2018-03-23 | 2018-03-23 | 0d | 2018-03-23 | 2018-03-23 |  |  | 100% | 0% | ok | 0% | Pedras (distrito Mariana/MG) | 100 | 100 | 100 | 100 |  |  |
| 146 | 3.2.1.1.1.2 | Aprovação das DEPPs pela Operadora e Prefeitura - Pedras/MG | milestone | 0d | 2018-03-23 A | 2018-03-23 A | 145 | 100% |  | 2018-03-08 | 2018-03-08 | 0d | 2018-03-08 | 2018-03-08 |  |  | 100% | 0% | ok | 0% | Pedras (distrito Mariana/MG) | 100 | 100 | 100 | 100 |  |  |
| 147 | 3.2.1.1.1.3 | **Estudos de Geofísica para Poço Tubular** |  | 197d | 2018-02-20 A | 2018-11-21 A |  | 100% |  | 2018-02-20 | 2018-11-21 | 197d | 2018-02-20 | 2018-11-21 |  |  | 100% | 0% | ok | 0% | Pedras (distrito Mariana/MG) | 100 | 100 | 100 | 100 |  |  |
| 148 | 3.2.1.1.1.3.1 | Executar Levantamento de Campo - Poço 1 - Pedras/MG |  | 21d | 2018-02-20 A | 2018-03-20 A | 145FS-24d | 100% |  | 2018-02-20 | 2018-03-20 | 21d | 2018-02-20 | 2018-03-20 |  |  | 100% | 0% | ok | 0% | Pedras (distrito Mariana/MG) | 100 | 100 | 100 | 100 |  |  |
| 149 | 3.2.1.1.1.3.2 | Emitir Relatório - Poço 1 - Pedras/MG |  | 15d | 2018-02-28 A | 2018-03-20 A | 148FF | 100% |  | 2018-02-28 | 2018-03-20 | 15d | 2018-02-28 | 2018-03-20 |  |  | 100% | 0% | ok | 0% | Pedras (distrito Mariana/MG) | 100 | 100 | 100 | 100 |  |  |
| 150 | 3.2.1.1.1.3.3 | Executar Levantamento de Campo - Poço 2 - Pedras/MG |  | 23d | 2018-10-22 A | 2018-11-21 A | 145FS+154d | 100% |  | 2018-10-22 | 2018-11-21 | 23d | 2018-10-22 | 2018-11-21 |  |  | 100% | 0% | ok | 0% | Pedras (distrito Mariana/MG) | 100 | 100 | 100 | 100 |  |  |
| 151 | 3.2.1.1.1.3.4 | Emitir Relatório - Poço 2 - Pedras/MG |  | 15d | 2018-11-01 A | 2018-11-21 A | 150FF | 100% |  | 2018-11-01 | 2018-11-21 | 15d | 2018-11-01 | 2018-11-21 |  |  | 100% | 0% | ok | 0% | Pedras (distrito Mariana/MG) | 100 | 100 | 100 | 100 |  |  |
| 152 | 3.2.1.1.1.3.5 | Conclusão dos Estudos de Geofísica - Pedras/MG | milestone | 0d | 2018-11-21 A | 2018-11-21 A | 149, 151 | 100% |  | 2018-11-21 | 2018-11-21 | 0d | 2018-11-21 | 2018-11-21 |  |  | 100% |  |  |  |  | 100 | 100 | 100 | 100 |  |  |
| 153 | 3.2.1.1.1.4 | **Serviços em Poços Tubulares - Poço 1 - Poço seco, não será utilizado** |  | 53d | 2019-01-14 A | 2019-04-01 A |  | 100% |  | 2019-01-14 | 2019-04-01 | 53d | 2019-01-14 | 2019-04-01 |  |  | 100% | 0% | ok | 0% | Pedras (distrito Mariana/MG) | 100 | 100 | 100 | 100 |  |  |
| 154 | 3.2.1.1.1.4.1 | Realizar Perfuração - Poço 1 - Poço seco, não será utilizado - Pedras/MG |  | 5d | 2019-01-14 A | 2019-01-18 A | 149 | 100% |  | 2019-01-14 | 2019-01-18 | 5d | 2019-01-14 | 2019-01-18 |  |  | 100% | 0% | ok | 0% | Pedras (distrito Mariana/MG) | 100 | 100 | 100 | 100 |  |  |
| 155 | 3.2.1.1.1.4.2 | Realizar Tamponamento - Poço 1 - Poço seco, não será utilizado - Pedras/MG |  | 1d | 2019-01-18 A | 2019-01-18 A | 154FF | 100% |  | 2019-01-18 | 2019-01-18 | 1d | 2019-01-18 | 2019-01-18 |  |  | 100% | 0% | ok | 0% | Pedras (distrito Mariana/MG) | 100 | 100 | 100 | 100 |  |  |
| 156 | 3.2.1.1.1.4.3 | Elaborar Relatório Técnico - Poço 1 - Poço seco, não será utilizado - Pedras/MG |  | 48d | 2019-01-21 A | 2019-04-01 A | 154 | 100% |  | 2019-01-21 | 2019-04-01 | 48d | 2019-01-21 | 2019-04-01 |  |  | 100% | 0% | ok | 0% | Pedras (distrito Mariana/MG) | 100 | 100 | 100 | 100 |  |  |
| 157 | 3.2.1.1.1.4.4 | Conclusão dos Serviços em poço tubular - Poço 1 - Poço seco, não será utilizado - Pedras/MG | milestone | 0d | 2019-02-21 A | 2019-02-21 A | 156 | 100% |  | 2019-02-21 | 2019-02-21 | 0d | 2019-02-21 | 2019-02-21 |  |  | 100% |  |  |  |  | 100 | 100 | 100 | 100 |  |  |
| 158 | 3.2.1.1.2 | **Estudos de Concepção do Sistema - Etapa 2** |  | 244d | 2019-04-15 A | 2020-04-07 |  | 97% | 7.47d | 2019-04-15 | 2019-11-29 | 159d |  |  | 507d |  |  |  |  |  |  |  |  |  |  |  |  |
| 159 | 3.2.1.1.2.1 | **Serviços em Poços Tubulares - Poço 2 - Captação Alternativa** |  | 244d | 2019-04-15 A | 2020-04-07 |  | 97% | 7.47d | 2019-04-15 | 2019-05-30 | 31d | 2019-04-15 | 2019-05-30 | 507d |  | 100% | 0% | ok | 0% | Pedras (distrito Mariana/MG) | 97 | 100 | 97 | 100 |  |  |
| 160 | 3.2.1.1.2.1.1 | Realizar Perfuração - Poço 2 - Captação Alternativa - Pedras/MG |  | 3d | 2019-04-15 A | 2019-04-17 A | 191 | 100% |  | 2019-04-15 | 2019-04-17 | 3d | 2019-04-15 | 2019-04-17 |  |  | 100% | 0% | ok | 0% | Pedras (distrito Mariana/MG) | 100 | 100 | 100 | 100 |  |  |
| 161 | 3.2.1.1.2.1.2 | Realizar Teste de bombeamento - Poço 2 - Captação Alternativa - Pedras/MG |  | 4d | 2019-04-22 A | 2019-04-25 A | 160 | 100% |  | 2019-04-22 | 2019-04-24 | 3d | 2019-04-22 | 2019-04-24 |  |  | 100% | 0% | ok | 0% | Pedras (distrito Mariana/MG) | 100 | 100 | 100 | 100 |  |  |
| 162 | 3.2.1.1.2.1.3 | Realizar Laudo de Serviços de Coleta e Análise de Água - Poço 2 - Captação Alternativa - Pedras/MG |  | 44d | 2019-04-26 A | 2019-06-28 A | 161 | 100% |  | 2019-04-25 | 2019-05-27 | 22d | 2019-04-25 | 2019-05-27 |  |  | 100% | 0% | ok | 0% | Pedras (distrito Mariana/MG) | 100 | 100 | 100 | 100 |  | Não OK |
| 163 | 3.2.1.1.2.1.4 | Elaborar Relatório Técnico - Poço 2 - Captação Alternativa - Pedras/MG |  | 44d | 2019-04-26 A | 2019-06-28 A | 161 | 100% |  | 2019-04-25 | 2019-05-27 | 22d | 2019-04-25 | 2019-05-27 |  |  | 100% | 0% | ok | 0% | Pedras (distrito Mariana/MG) | 100 | 100 | 100 | 100 |  |  |
| 164 | 3.2.1.1.2.1.5 | Realizar Instrumentação - Poço 2 - Captação Alternativa - Pedras/MG |  | 3d | 2020-04-03 | 2020-04-07 | 163FS+190d |  |  | 2019-05-28 | 2019-05-30 | 3d | 2019-05-28 | 2019-05-30 | 507d | 0d | 100% | 0% | ok | 0% | Pedras (distrito Mariana/MG) |  | 100 |  | 100 |  |  |
| 165 | 3.2.1.1.2.1.6 | Conclusão dos Serviços em poço tubular - Poço 2 - Captação Alternativa - Pedras/MG | milestone | 0d | 2020-04-07 | 2020-04-07 | 162, 164 |  |  | 2019-05-30 | 2019-05-30 | 0d | 2019-05-30 | 2019-05-30 | 507d | 0d | 100% |  |  |  |  |  | 100 |  | 100 |  |  |
| 166 | 3.2.1.1.2.2 | Conclusão dos Estudos de Concepção das Melhorias do Sistema de Abastecimento de Água - Pedras/MG | milestone | 0d | 2020-04-07 | 2020-04-07 | 152, 157, 165 |  |  | 2019-10-09 | 2019-10-09 | 0d | 2019-10-09 | 2019-10-09 | 507d | 60d | 0% |  |  |  |  |  |  |  |  |  |  |

Notes:
- 146: 25/Nov: / - Anuência dada pelo SAAE de Mariana, por meio de Parecer Técnico, desde que a FR atenda as alterações, observações e acréscimos constantes no ofício 44/2018.
- 153: 29/Jan19: / - Poço seco, não será utilizado como Captação Principal.
- 154: 14/Dez / - Fundiário já concedeu a anuência. Licença de autorização para perfuração ok em 26/11.
- 160: 05/Fev19: / - Termo de Anuência Superficiário obtido nesta data. / 14/Dez / - Mesmo superficiário do Poço 1, porém não há anuência concedida ainda. Necessário iniciar a negociação com o fundiário. / - Para iniciar o serviço no Poço, terá que aguardar a Licença de Autorização de Perfuração sair.
- 162: 15/Fev19: / - Essa atividade está sem Sucessora (deveria ser o Projeto Executivo da ETA), em função da Engenharia não ter respeitado o sequenciamento de atividades definido. (Ver e-mail enviado em 03/02/19 "Considerações Relevantes: Cronograma Engenharia X Cronograma Master PG 32" e Relato Gerências").

| ID | WBS | Task | Type | Duration | Start | Finish | Predecessors | Complete | Remaining | Baseline start | Baseline finish | Baseline duration | Baseline 1 start | Baseline 1 finish | Total slack | Free slack | Text3 | Text4 | Text5 | Text7 | Text15 | Text23 | Text25 | Text26 | Text27 | Text29 | Text9 |
| --- | --- | --- | --- | --- | --- | --- | --- | --- | --- | --- | --- | --- | --- | --- | --- | --- | --- | --- | --- | --- | --- | --- | --- | --- | --- | --- | --- |
| 167 | 3.2.1.1.3 | **Engenharia Conceitual - Pedras** |  | 72d | 2018-11-30 A | 2019-03-15 A |  | 100% |  | 2018-11-30 | 2019-09-04 | 190d | 2018-11-30 | 2019-09-04 |  |  | 75% | 44 | 75 | 59 | 75 | Socioambiental | 0% | ok | 0% | Pedras (distrito Mariana/MG) |  |
| 168 | 3.2.1.1.3.1 | Aprovar Plano de Trabalho e abrir OSE - Pedras/MG |  | 11d | 2018-11-30 A | 2018-12-14 A | 145 | 100% |  | 2018-11-30 | 2018-12-14 | 11d | 2018-11-30 | 2018-12-14 |  |  | 100% | 100 | 100 | 100 | 100 |  | 0% | ok | 0% | Pedras (distrito Mariana/MG) |  |
| 169 | 3.2.1.1.3.2 | Realizar Levantamento de Campo - Pedras/MG |  | 6d | 2018-11-30 A | 2018-12-07 A | 168SS | 100% |  | 2018-11-30 | 2018-12-07 | 6d | 2018-11-30 | 2018-12-07 |  |  | 100% | 100 | 100 | 100 | 100 | Socioambiental | 0% | Não OK | 0% | Pedras (distrito Mariana/MG) | Não OK |
| 170 | 3.2.1.1.3.3 | Executar Topografia - Pedras/MG |  | 23d | 2018-11-30 A | 2019-01-02 A | 168SS | 100% |  | 2018-11-30 | 2019-01-02 | 23d | 2018-11-30 | 2019-01-02 |  |  | 100% | 100 | 100 | 100 | 100 |  |  |  |  |  |  |
| 171 | 3.2.1.1.3.4 | Elaborar Projeto Conceitual - Pedras/MG |  | 60d | 2018-12-18 A | 2019-03-15 A | 169, 170 | 100% |  | 2018-12-18 | 2019-03-15 | 60d | 2018-12-18 | 2019-03-15 |  |  | 100% | 100 | 100 | 100 | 100 | Socioambiental | 0% | Não OK | 0% | Pedras (distrito Mariana/MG) | Não OK |
| 172 | 3.2.1.1.4 | **Engenharia Básica e Detalhada** |  | 164d | 2019-11-04 A | 2020-07-06 |  | 22% | 127.51d | 2018-11-30 | 2020-02-12 | 300d | 2018-11-30 | 2020-02-12 | 447d |  | 47% | 46 | 47 | 66 | 70 |  |  |  |  |  |  |
| 173 | 3.2.1.1.4.1 | **Engenharia Captação Alternativa (Poço 2) - Etapa 2** |  | 164d | 2019-11-04 A | 2020-07-06 |  | 22% | 127.51d | 2019-11-04 | 2020-07-13 | 169d |  |  | 447d |  |  |  |  |  |  |  |  |  |  |  |  |
| 174 | 3.2.1.1.4.1.1 | Aprovar Plano de Trabalho e Abrir OSE - OeM - Captação Alternativa - Poço 2 - Pedras/MG |  | 10d | 2019-11-04 A | 2019-11-18 A | 171FS+160d | 100% |  | 2019-11-04 | 2019-11-18 | 10d |  |  |  |  |  |  |  |  |  |  |  |  |  |  |  |
| 175 | 3.2.1.1.4.1.2 | Elaborar Projeto Básico - Captação Alternativa - Poço 2 - Pedras/MG |  | 60d | 2019-11-26 A | 2020-02-21 | 174FS+5d | 46% | 32.4d | 2018-02-08 | 2018-03-21 | 30d | 2018-02-08 | 2018-03-21 | 359d | 0d | 100% |  | 100 |  | 100 |  |  |  |  |  |  |
| 176 | 3.2.1.1.4.1.3 | Aprovar Projeto Básico com Prefeitura e Operadora - Captação Alternativa - Poço 2 - Pedras/MG |  | 22d | 2020-02-27 | 2020-03-27 | 175 |  |  | 2018-03-01 | 2018-03-30 | 22d |  |  | 359d | 0d |  |  |  |  |  |  |  |  |  |  |  |
| 177 | 3.2.1.1.4.1.4 | Emitir RT/PQ para Suprimentos - Captação Alternativa - Poço 2 - Pedras/MG |  | 10d | 2020-06-23 | 2020-07-06 | 178FF |  |  | 2019-08-22 | 2019-09-04 | 10d | 2019-08-22 | 2019-09-04 | 359d | 0d | 0% |  |  |  |  |  | 0% | ok | 0% | Pedras (distrito Mariana/MG) |  |
| 178 | 3.2.1.1.4.1.5 | Elaborar Projeto Executivo - Captação Alternativa - Poço 2 - Pedras/MG |  | 67d | 2020-03-30 | 2020-07-06 | 176 |  |  | 2019-06-04 | 2019-09-04 | 65d | 2019-06-04 | 2019-09-04 | 359d | 0d | 27% |  | 27 |  | 27 |  | 0% | ok | 0% | Pedras (distrito Mariana/MG) |  |
| 179 | 3.2.1.1.4.1.6 | Elaboração do Projeto Executivo - Captação Alternativa - Poço 2 - Pedras/MG | milestone | 0d | 2020-07-06 | 2020-07-06 | 178 |  |  | 2019-09-04 | 2019-09-04 | 0d | 2019-09-04 | 2019-09-04 | 447d | 0d | 0% |  |  |  |  |  |  |  |  |  |  |
| 180 | 3.2.1.1.5 | Conclusão e Validação da Engenharia - Pedras/MG | milestone | 0d | 2020-07-06 | 2020-07-06 | 166, 179 |  |  | 2020-02-12 | 2020-02-12 | 0d | 2020-02-12 | 2020-02-12 | 447d | 88d | 0% |  |  |  |  |  |  |  |  |  |  |
| 181 | 3.2.1.2 | **Fundiária** |  | 415d | 2018-11-22 A | 2020-07-23 |  | 40% | 247.76d | 2018-03-21 | 2019-10-01 | 391d | 2018-03-21 | 2019-10-01 | 434d |  | 83% | 38 | 83 | 60 | 63 | Socioambiental | 0% | ok | 0% | Pedras (distrito Mariana/MG) |  |
| 182 | 3.2.1.2.1 | Obter Termo de Autorização de Superficiário - Captação Alternativa (Poço 2) - Pedras/MG |  | 54d | 2018-11-22 A | 2019-02-06 A | 151 | 100% |  | 2018-11-22 | 2019-02-06 | 54d | 2018-11-22 | 2019-02-06 |  |  | 100% | 100 | 100 | 100 | 100 |  | 0% | ok | 0% | Pedras (distrito Mariana/MG) |  |
| 183 | 3.2.1.2.2 | **Captação Alternativa (Poço 2) - Desimpedimento de Área e Negociação de Servidão** |  | 80d | 2020-03-30 | 2020-07-23 |  |  |  | 2019-05-09 | 2019-08-30 | 80d | 2019-05-09 | 2019-08-30 | 434d |  | 45% |  | 45 |  | 45 |  | 0% | ok | 0% | Pedras (distrito Mariana/MG) |  |
| 184 | 3.2.1.2.2.1 | Realizar Levantamento da documentação da propriedade - Pedras/MG |  | 10d | 2020-03-30 | 2020-04-13 | 163FS+70d, 171FS+35d, 176, 182FS+35d |  |  | 2019-05-09 | 2019-05-22 | 10d | 2019-05-09 | 2019-05-22 | 434d | 0d | 100% |  | 100 |  | 100 |  |  |  |  |  |  |
| 185 | 3.2.1.2.2.2 | Obter assinatura do Contrato de servidão pelo proprietário - Pedras/MG |  | 20d | 2020-04-14 | 2020-05-13 | 184 |  |  | 2019-05-23 | 2019-06-19 | 20d | 2019-05-23 | 2019-06-19 | 434d | 0d | 100% |  | 100 |  | 100 |  |  |  |  |  |  |
| 186 | 3.2.1.2.2.3 | Lavrar Escritura Pública de Servidão no cartório de notas - Pedras/MG |  | 30d | 2020-05-14 | 2020-06-25 | 185 |  |  | 2019-06-21 | 2019-08-01 | 30d | 2019-06-21 | 2019-08-01 | 434d | 0d | 20% |  | 20 |  | 20 |  |  |  |  |  |  |
| 187 | 3.2.1.2.2.4 | Averbar a escritura pública na matrícula do imóvel - Pedras/MG |  | 20d | 2020-06-26 | 2020-07-23 | 186 |  |  | 2019-08-02 | 2019-08-30 | 20d | 2019-08-02 | 2019-08-30 | 434d | 0d | 0% |  |  |  |  |  |  |  |  |  |  |
| 188 | 3.2.1.2.2.5 | Regularização da Servidão do Imóvel - Poço 2 - Pedras/MG | milestone | 0d | 2020-07-23 | 2020-07-23 | 187 |  |  | 2019-08-30 | 2019-08-30 | 0d | 2019-08-30 | 2019-08-30 | 434d | 0d | 0% |  |  |  |  |  |  |  |  |  |  |
| 189 | 3.2.1.2.3 | Conclusão da Regularização Fundiária para as obras de Melhoria do Sistema de Abastecimento da Localidade - Pedras/MG | milestone | 0d | 2020-07-23 | 2020-07-23 | 188 |  |  | 2019-10-01 | 2019-10-01 | 0d | 2019-10-01 | 2019-10-01 | 434d | 75d | 0% |  |  |  |  |  |  |  |  |  |  |
| 190 | 3.2.1.3 | **Licenciamento** |  | 256d | 2019-02-14 A | 2020-02-28 |  | 66% | 86.82d | 2018-08-29 | 2020-02-04 | 361d | 2018-08-29 | 2020-02-04 | 534d |  | 58% | 25 | 58 | 49 | 51 |  | 0% | ok | 0% | Pedras (distrito Mariana/MG) |  |
| 191 | 3.2.1.3.1 | Obter Autorização de Perfuração Captação Alternativa - Poço 2 - Pedras/MG |  | 39d | 2019-02-14 A | 2019-04-12 A | 151, 182FS+5d | 100% |  | 2019-02-14 | 2019-04-12 | 39d | 2019-02-14 | 2019-04-12 |  |  | 100% | 100 | 100 | 100 | 100 |  | 0% | ok | 0% | Pedras (distrito Mariana/MG) |  |

Notes:
- 169: 25/Jan19: / - Levantamento de campo iniciado em 30/11 e finalizado em 07/12/18; Topografia iniciada em 30/11/18 e concluída em 02/01/19; Resultado da vazão do poço previsto para 15/02/19. / - Engenharia não ciente que o resultado da análise do poço e o Relatório Técnico estão previstos para Jul/19 (no Cronograma, a Engenharia está prevendo que terá a informação da análise da água em 15/02/19).
- 178: 25/Jan19: / - Projeto Executivo não considerando as datas corretas do Laudo de análise da água e do Relatório Técnico do Poço.
- 182: 05/Fev19: / - Termo de Anuência Superficiário obtido nesta data. / 14/Dez / - Mesmo superficiário do Poço 1 (Captação Principal), porém o Fundiário não possui anuência para o Licenciamento dar entrada no processo de autorização de perfuração. Solicitar ao Fundiário agilidade nesse processo.
- 191: 05/Fev19: / - Termo de Anuência Superficiário obtido nesta data. / 15/Dez / - Licenciamento aguardando anuência do superficiário (Gestão Fundiária) para dar entrada no processo de autorização de perfuração. Verificar com a área.

| ID | WBS | Task | Type | Duration | Start | Finish | Predecessors | Complete | Remaining | Baseline start | Baseline finish | Baseline duration | Baseline 1 start | Baseline 1 finish | Total slack | Free slack | Text3 | Text5 | Text15 | Text25 | Text26 | Text27 | Text29 | Text13 | Text4 | Text7 | Text23 | Text28 |
| --- | --- | --- | --- | --- | --- | --- | --- | --- | --- | --- | --- | --- | --- | --- | --- | --- | --- | --- | --- | --- | --- | --- | --- | --- | --- | --- | --- | --- |
| 192 | 3.2.1.3.2 | **Outorga para Captação Alternativa - Poço 2** |  | 76d | 2019-11-05 A | 2020-02-28 |  | 49% | 39d | 2019-05-28 | 2019-09-12 | 76d | 2019-05-28 | 2019-09-12 | 534d |  | 30% | 30 | 30 | 0% | ok | 0% | Pedras (distrito Mariana/MG) |  |  |  |  |  |
| 193 | 3.2.1.3.2.1 | Protocolar FCE e documentos do FOB - Pedras/MG |  | 10d | 2019-11-05 A | 2019-11-19 A | 163FS+90d, 171 | 100% |  | 2019-05-28 | 2019-06-10 | 10d | 2019-05-28 | 2019-06-10 |  |  | 100% | 100 | 100 |  |  |  |  |  |  |  |  |  |
| 194 | 3.2.1.3.2.2 | Acompanhar Processo Junto ao Órgão - Pedras/MG |  | 66d | 2019-11-20 A | 2020-02-28 | 193 | 41% | 39d | 2019-06-11 | 2019-09-12 | 66d | 2019-06-11 | 2019-09-12 | 534d | 0d | 19% | 19 | 19 |  |  |  |  | 8888888 |  |  |  |  |
| 195 | 3.2.1.3.2.3 | Obtenção da Outorga para captação - Poço 2 - Pedras/MG | milestone | 0d | 2020-02-28 | 2020-02-28 | 194 |  |  | 2019-09-12 | 2019-09-12 | 0d | 2019-09-12 | 2019-09-12 | 534d | 0d | 0% |  |  |  |  |  |  |  |  |  |  |  |
| 196 | 3.2.1.3.3 | Conclusão do Licenciamento Ambiental da Localidade - Pedras/MG | milestone | 0d | 2020-02-28 | 2020-02-28 | 191, 195 |  |  | 2020-02-04 | 2020-02-04 | 0d | 2020-02-04 | 2020-02-04 | 534d | 175d | 0% |  |  |  |  |  |  |  |  |  |  |  |
| 197 | 3.2.1.4 | **Suprimentos** |  | 88d | 2020-07-07 | 2020-11-10 |  |  |  | 2019-09-27 | 2020-02-04 | 88d | 2019-09-27 | 2020-02-04 | 359d |  | 0% |  |  | 0% | ok | 0% | Pedras (distrito Mariana/MG) |  |  |  |  |  |
| 198 | 3.2.1.4.1 | Realizar contratação - Captações e ETA - Pedras/MG |  | 88d | 2020-07-07 | 2020-11-10 | 177 |  |  | 2019-09-27 | 2020-02-04 | 88d | 2019-09-27 | 2020-02-04 | 359d | 0d | 0% |  |  | 0% | ok | 0% | Pedras (distrito Mariana/MG) |  |  |  |  |  |
| 199 | 3.2.1.4.2 | Conclusão da Contratação de Suprimentos para as obras de Melhoria do Sistema de Abastecimento de Água- Pedras/MG | milestone | 0d | 2020-11-10 | 2020-11-10 | 198 |  |  | 2020-02-04 | 2020-02-04 | 0d | 2020-02-04 | 2020-02-04 | 359d | 0d | 0% |  |  |  |  |  |  |  |  |  |  |  |
| 200 | 3.2.1.5 | **Infraestrutura** |  | 397d | 2020-11-11 | 2022-06-17 |  |  |  | 2020-02-04 | 2021-05-28 | 326d | 2020-02-04 | 2021-05-28 | 356d |  | 0% |  |  | 0% | ok | 0% | Pedras (distrito Mariana/MG) |  |  |  |  |  |
| 201 | 3.2.1.5.1 | **Obras** |  | 81d | 2020-11-11 | 2021-03-11 |  |  |  | 2020-02-04 | 2020-05-13 | 66d | 2020-02-04 | 2020-05-13 | 359d |  | 0% |  |  |  |  |  |  |  |  |  |  |  |
| 202 | 3.2.1.5.1.1 | Executar obras de Captação Alternativa (Urbanização e Adução) - Poço 2 - Pedras/MG |  | 81d | 2020-11-11 | 2021-03-11 | 165, 179, 187, 188, 195, 198, 199, 180, 189, 196 |  |  | 2020-02-04 | 2020-05-13 | 66d | 2020-02-04 | 2020-05-13 | 359d | 0d | 0% |  |  | 0% | ok | 0% | Pedras (distrito Mariana/MG) |  |  |  |  |  |
| 203 | 3.2.1.5.1.2 | Assinatura de Termo de Entrega das Obras de Melhoria do Sistema de Abastecimento de Água - Pedras/MG | milestone | 0d | 2021-03-11 | 2021-03-11 | 202 |  |  | 2020-05-13 | 2020-05-13 | 0d | 2020-05-13 | 2020-05-13 | 672d | 316d | 0% |  |  | 0% | ok | 0% | Pedras (distrito Mariana/MG) |  |  |  |  |  |
| 204 | 3.2.1.5.2 | **Operação** |  | 316d | 2021-03-12 | 2022-06-17 |  |  |  | 2020-05-14 | 2021-05-28 | 260d | 2020-05-14 | 2021-05-28 | 356d |  | 0% |  |  | 0% | ok | 0% | Pedras (distrito Mariana/MG) |  |  |  |  |  |
| 205 | 3.2.1.5.2.1 | Realizar Treinamento Operacional do Sistema - Pedras/MG |  | 5d | 2021-03-12 | 2021-03-18 | 202 |  |  | 2020-05-14 | 2020-05-20 | 5d | 2020-05-14 | 2020-05-20 | 359d | 0d | 0% |  |  | 0% | ok | 0% | Pedras (distrito Mariana/MG) |  |  |  |  |  |
| 206 | 3.2.1.5.2.2 | Realizar Testes e Pré-operação - Pedras/MG |  | 14d | 2021-03-19 | 2021-04-08 | 205 |  |  | 2020-05-21 | 2020-06-09 | 14d | 2020-05-21 | 2020-06-09 | 359d | 0d | 0% |  |  | 0% | ok | 0% | Pedras (distrito Mariana/MG) |  |  |  |  |  |
| 207 | 3.2.1.5.2.3 | Realizar Acompanhamento da Funcionalidade do Sistema - Captação Alternativa (Poço Tubular) - Pedras (distrito Mariana/MG) |  | 365ed | 2021-06-17 | 2022-06-17 | 209 |  |  | 2020-05-14 | 2021-05-28 | 260d |  |  | 1570.12d | 0d |  |  |  |  |  |  |  |  |  |  |  |  |
| 208 | 3.2.1.5.2.4 | **Operação Assistida** |  | 61d | 2021-03-19 | 2021-06-17 |  |  |  | 2020-05-14 | 2020-08-12 | 64d | 2020-05-14 | 2020-08-12 | 358d |  | 0% |  |  | 0% | ok | 0% | Pedras (distrito Mariana/MG) |  |  |  |  |  |
| 209 | 3.2.1.5.2.4.1 | Realizar Operação Assistida - Pedras/MG |  | 90ed | 2021-03-19 | 2021-06-17 | 202, 206SS |  |  | 2020-05-14 | 2020-08-12 | 3.2mo | 2020-05-14 | 2020-08-12 | 1570.12d | 0d | 0% |  |  | 0% | ok | 0% | Pedras (distrito Mariana/MG) |  |  |  |  |  |
| 210 | 3.2.1.5.3 | Entrega das obras e conclusão do período de acompanhamento da operação - Pedras/MG | milestone | 0d | 2022-06-17 | 2022-06-17 | 203, 207 |  |  | 2021-05-28 | 2021-05-28 | 0d | 2021-05-28 | 2021-05-28 | 356d |  | 0% |  |  |  |  |  |  |  |  |  |  |  |
| 211 | 3.2.2 | **ETA (Sistema de Tratamento Simplificado) e Captação Principal (Nascente)** |  | 1216d | 2018-03-23 A | 2023-01-28 |  | 3% | 1179.54d | 2018-03-23 | 2021-05-28 | 799d |  |  | 201d |  |  |  |  |  |  |  |  |  |  |  |  |  |
| 212 | 3.2.2.1 | **Engenharia** |  | 252d | 2019-11-04 A | 2020-11-10 |  | 17% | 209.47d | 2018-02-20 | 2020-02-12 | 503d | 2018-02-20 | 2020-02-12 | 753d |  | 68% | 68 | 70 |  | ok |  |  |  | 54 | 77 | Socioambiental |  |
| 213 | 3.2.2.1.1 | **Estudos de Concepção do Sistema** |  | 62d | 2020-08-12 | 2020-11-10 |  |  |  | 2020-08-12 | 2020-11-10 | 62d |  |  | 202d |  |  |  |  |  |  |  |  |  |  |  |  |  |
| 214 | 3.2.2.1.1.1 | **Serviço em Nascente - Captação Principal** |  | 62d | 2020-08-12 | 2020-11-10 |  |  |  | 2019-07-15 | 2019-10-09 | 62d | 2019-07-15 | 2019-10-09 | 202d |  | 0% |  |  | 0% | ok | 0% | Pedras (distrito Mariana/MG) |  |  |  |  |  |
| 215 | 3.2.2.1.1.1.1 | Realizar Recuperação de Nascente - Captação Principal - Pedras/MG |  | 40d | 2020-08-12 | 2020-10-07 | 237FS+80d |  |  | 2019-07-15 | 2019-09-09 | 40d | 2019-07-15 | 2019-09-09 | 202d | 0d | 0% |  |  | 0% | ok | 0% | Pedras (distrito Mariana/MG) |  |  |  |  |  |
| 216 | 3.2.2.1.1.1.2 | Elaborar Relatório Técnico - Captação Principal - Pedras/MG |  | 22d | 2020-10-08 | 2020-11-10 | 215 |  |  | 2019-09-10 | 2019-10-09 | 22d | 2019-09-10 | 2019-10-09 | 202d | 0d | 0% |  |  | 0% | ok | 0% | Pedras (distrito Mariana/MG) |  |  |  |  |  |
| 217 | 3.2.2.1.1.1.3 | Realizar Laudo de Serviços de Coleta e Análise de Água - Captação Principal - Pedras/MG |  | 22d | 2020-10-08 | 2020-11-10 | 215 |  |  | 2019-09-10 | 2019-10-09 | 22d | 2019-09-10 | 2019-10-09 | 419d | 0d | 0% |  |  | 0% | ok | 0% | Pedras (distrito Mariana/MG) |  |  |  |  | Não OK |
| 218 | 3.2.2.1.1.1.4 | Conclusão dos Serviços em nascente - Captação Principal - Pedras/MG | milestone | 0d | 2020-11-10 | 2020-11-10 | 216, 217 |  |  | 2019-10-09 | 2019-10-09 | 0d | 2019-10-09 | 2019-10-09 | 419d | 0d | 0% |  |  |  |  |  |  |  |  |  |  |  |
| 219 | 3.2.2.1.1.2 | Conclusão dos Estudos de Concepção das Melhorias do Sistema de Abastecimento de Água - Pedras/MG | milestone | 0d | 2020-11-10 | 2020-11-10 | 218 |  |  | 2019-10-09 | 2019-10-09 | 0d | 2019-10-09 | 2019-10-09 | 753d | 0d | 0% |  |  |  |  |  |  |  |  |  |  |  |

Notes:
- 192: 05/Fev19: / - Renata Vilela entende que o processo de outorga é de responsabilidade da Operadora/Concessionária. PG deverá alinhar entendimento correto com a área. / 26/Nov: / - O Licenciamento FR acredita que o processo de outorga para captação será do SAAE Mariana, que necessita aprovar o projeto de adução (Engenharia).
- 217: 15/Fev19: / - Essa atividade está sem Sucessora (deveria ser o Projeto Executivo da ETA), em função da Engenharia não ter respeitado o sequenciamento de atividades definido. (Ver e-mail enviado em 03/02/19 "Considerações Relevantes: Cronograma Engenharia X Cronograma Master PG 32" e Relato Gerências").

| ID | WBS | Task | Type | Duration | Start | Finish | Predecessors | Complete | Remaining | Baseline start | Baseline finish | Baseline duration | Baseline 1 start | Baseline 1 finish | Total slack | Free slack | Text3 | Text4 | Text5 | Text7 | Text15 | Text23 | Text25 | Text26 | Text27 | Text29 | Text13 |
| --- | --- | --- | --- | --- | --- | --- | --- | --- | --- | --- | --- | --- | --- | --- | --- | --- | --- | --- | --- | --- | --- | --- | --- | --- | --- | --- | --- |
| 220 | 3.2.2.1.2 | **Engenharia Básica e Detalhada** |  | 169d | 2019-11-04 A | 2020-07-13 |  | 21% | 133.6d | 2018-11-30 | 2020-02-12 | 300d | 2018-11-30 | 2020-02-12 | 502d |  | 47% | 46 | 47 | 66 | 70 |  |  |  |  |  |  |
| 221 | 3.2.2.1.2.1 | **Engenharia Captação Principal (Nascente)** |  | 169d | 2019-11-04 A | 2020-07-13 |  | 23% | 130.25d | 2018-11-30 | 2019-09-04 | 190d | 2018-11-30 | 2019-09-04 | 502d |  | 75% | 44 | 75 | 59 | 75 | Socioambiental | 0% | ok | 0% | Pedras (distrito Mariana/MG) |  |
| 222 | 3.2.2.1.2.1.1 | Aprovar Plano de Trabalho e Abrir OSE - OeM - Captação Principal - Pedras/MG |  | 10d | 2019-11-04 A | 2019-11-18 A | 171FS+160d | 100% |  | 2019-11-04 | 2019-11-18 | 10d |  |  |  |  |  |  |  |  |  |  |  |  |  |  |  |
| 223 | 3.2.2.1.2.1.2 | Elaborar Projeto Básico - Captação Principal - Nascente - Pedras/MG |  | 65d | 2019-11-26 A | 2020-03-04 | 222FS+5d | 46% | 35.1d | 2018-02-08 | 2018-03-21 | 30d | 2018-02-08 | 2018-03-21 | 202d | 0d | 100% |  | 100 |  | 100 |  |  |  |  |  |  |
| 224 | 3.2.2.1.2.1.3 | Aprovar Projeto Básico com Prefeitura/Operadora - Captação Principal - Nascente - Pedras/MG |  | 22d | 2020-03-05 | 2020-04-03 | 223 |  |  | 2018-03-01 | 2018-03-30 | 22d |  |  | 414d | 0d |  |  |  |  |  |  |  |  |  |  |  |
| 225 | 3.2.2.1.2.1.4 | Emitir RT/PQ para Suprimentos - Captação Principal - Nascente - Pedras/MG |  | 10d | 2020-06-30 | 2020-07-13 | 226FF |  |  | 2019-08-22 | 2019-09-04 | 10d | 2019-08-22 | 2019-09-04 | 414d | 0d | 0% |  |  |  |  |  | 0% | ok | 0% | Pedras (distrito Mariana/MG) |  |
| 226 | 3.2.2.1.2.1.5 | Elaborar Projeto Executivo - Captação Principal - Nascente - Pedras/MG |  | 67d | 2020-04-06 | 2020-07-13 | 223, 224 |  |  | 2019-06-04 | 2019-09-04 | 65d | 2019-06-04 | 2019-09-04 | 414d | 0d | 27% |  | 27 |  | 27 |  | 0% | ok | 0% | Pedras (distrito Mariana/MG) |  |
| 227 | 3.2.2.1.2.1.6 | Elaboração do Projeto Executivo - Captação Principal - Nascente - Pedras/MG | milestone | 0d | 2020-07-13 | 2020-07-13 | 226 |  |  | 2019-09-04 | 2019-09-04 | 0d | 2019-09-04 | 2019-09-04 | 502d | 300d | 0% |  |  |  |  |  |  |  |  |  |  |
| 228 | 3.2.2.1.2.2 | **Engenharia ETA (Sistema de Tratamento Simplificado)** |  | 169d | 2019-11-04 A | 2020-07-13 |  | 19% | 136.95d | 2018-11-30 | 2020-01-15 | 280d | 2018-11-30 | 2020-01-15 | 502d |  | 51% | 54 | 51 | 81 | 67 | Socioambiental | 0% | ok | 0% | Pedras (distrito Mariana/MG) |  |
| 229 | 3.2.2.1.2.2.1 | Aprovar Plano de Trabalho e Abrir OSE - OeM - ETA - Pedras/MG |  | 10d | 2019-11-04 A | 2019-11-18 A | 171FS+160d | 100% |  | 2019-11-04 | 2019-11-18 | 10d |  |  |  |  |  |  |  |  |  |  |  |  |  |  |  |
| 230 | 3.2.2.1.2.2.2 | Elaborar Projeto Básico - ETA - Pedras/MG |  | 65d | 2019-11-26 A | 2020-03-04 | 229FS+5d | 35% | 42d | 2018-02-08 | 2018-03-21 | 30d | 2018-02-08 | 2018-03-21 | 414d | 0d | 100% |  | 100 |  | 100 |  |  |  |  |  | 8888888 |
| 231 | 3.2.2.1.2.2.3 | Aprovar Projeto Básico com Prefeitura/Operadora - ETA - Pedras/MG |  | 22d | 2020-03-05 | 2020-04-03 | 230 |  |  | 2018-03-01 | 2018-03-30 | 22d |  |  | 414d | 0d |  |  |  |  |  |  |  |  |  |  |  |
| 232 | 3.2.2.1.2.2.4 | Emitir RT/PQ para Suprimentos - ETA - Pedras/MG |  | 10d | 2020-06-30 | 2020-07-13 | 233FF |  |  | 2020-01-02 | 2020-01-15 | 10d | 2020-01-02 | 2020-01-15 | 414d | 0d | 0% |  |  |  |  |  | 0% | ok | 0% | Pedras (distrito Mariana/MG) |  |
| 233 | 3.2.2.1.2.2.5 | Elaborar Projeto Executivo - ETA - Pedras/MG |  | 67d | 2020-04-06 | 2020-07-13 | 231, 224 |  |  | 2019-10-10 | 2020-01-15 | 65d | 2019-10-10 | 2020-01-15 | 414d | 0d | 0% |  |  |  |  |  | 0% | ok | 0% | Pedras (distrito Mariana/MG) |  |
| 234 | 3.2.2.1.2.2.6 | Elaboração do Projeto Executivo - ETA - Pedras/MG | milestone | 0d | 2020-07-13 | 2020-07-13 | 233 |  |  | 2020-01-15 | 2020-01-15 | 0d | 2020-01-15 | 2020-01-15 | 502d | 88d | 0% |  |  |  |  |  |  |  |  |  |  |
| 235 | 3.2.2.1.3 | Conclusão e Validação da Engenharia - Pedras/MG | milestone | 0d | 2020-11-10 | 2020-11-10 | 219 |  |  | 2020-02-12 | 2020-02-12 | 0d | 2020-02-12 | 2020-02-12 | 753d |  | 0% |  |  |  |  |  |  |  |  |  |  |
| 236 | 3.2.2.2 | **Fundiária** |  | 602d | 2018-03-23 A | 2020-08-11 |  | 3% | 586.56d | 2018-03-21 | 2019-10-01 | 391d | 2018-03-21 | 2019-10-01 | 815d |  | 83% | 38 | 83 | 60 | 63 | Socioambiental | 0% | ok | 0% | Pedras (distrito Mariana/MG) |  |
| 237 | 3.2.2.2.1 | Obter Termo de Autorização de Superficiário - Captação Principal (Nascente) - Pedras/MG |  | 30d | 2020-03-05 | 2020-04-16 | 223 |  |  | 2019-05-09 | 2019-06-07 | 22d | 2019-05-09 | 2019-06-07 | 202d | 0d | 100% | 25 | 100 | 25 | 100 |  | 0% | ok | 0% | Pedras (distrito Mariana/MG) |  |
| 238 | 3.2.2.2.2 | Obter Termo de Autorização de Superficiário - ETA - Pedras/MG |  | 5d | 2018-03-23 A | 2018-03-29 A |  | 100% |  | 2018-03-23 | 2018-03-29 | 5d | 2018-03-23 | 2018-03-29 |  |  | 100% | 100 | 100 | 100 | 100 | Socioambiental | 0% | Não OK | 0% | Pedras (distrito Mariana/MG) |  |
| 239 | 3.2.2.2.3 | **Captação Principal (Nascente) - Desimpedimento de Área e Negociação de Servidão** |  | 80d | 2020-04-17 | 2020-08-11 |  |  |  | 2019-06-10 | 2019-10-01 | 80d | 2019-06-10 | 2019-10-01 | 481d |  | 17% |  | 17 |  | 18 |  | 0% | ok | 0% | Pedras (distrito Mariana/MG) |  |
| 240 | 3.2.2.2.3.1 | Realizar Levantamento da documentação da propriedade - Pedras/MG |  | 10d | 2020-04-17 | 2020-05-04 | 237, 224 |  |  | 2019-06-10 | 2019-06-24 | 10d | 2019-06-10 | 2019-06-24 | 481d | 0d | 100% |  | 100 |  | 100 |  |  |  |  |  |  |
| 241 | 3.2.2.2.3.2 | Obter assinatura do Contrato de servidão pelo proprietário - Pedras/MG |  | 20d | 2020-05-05 | 2020-06-01 | 240 |  |  | 2019-06-25 | 2019-07-22 | 20d | 2019-06-25 | 2019-07-22 | 481d | 0d | 20% |  | 20 |  | 20 |  |  |  |  |  |  |
| 242 | 3.2.2.2.3.3 | Lavrar Escritura Pública de Servidão no cartório de notas - Pedras/MG |  | 30d | 2020-06-02 | 2020-07-14 | 241 |  |  | 2019-07-23 | 2019-09-03 | 30d | 2019-07-23 | 2019-09-03 | 481d | 0d | 0% |  |  |  |  |  |  |  |  |  |  |
| 243 | 3.2.2.2.3.4 | Averbar a escritura pública na matrícula do imóvel - Pedras/MG |  | 20d | 2020-07-15 | 2020-08-11 | 242 |  |  | 2019-09-04 | 2019-10-01 | 20d | 2019-09-04 | 2019-10-01 | 481d | 0d | 0% |  |  |  |  |  |  |  |  |  |  |
| 244 | 3.2.2.2.3.5 | Regularização da Servidão - Nascente - Pedras/MG | milestone | 0d | 2020-08-11 | 2020-08-11 | 243 |  |  | 2019-10-01 | 2019-10-01 | 0d | 2019-10-01 | 2019-10-01 | 481d | 0d | 0% |  |  |  |  |  |  |  |  |  |  |

Notes:
- 226: 25/Jan19: / - Projeto Executivo não considerando as datas corretas do Laudo de análise da água e do Relatório Técnico da Nascente.
- 233: 25/Jan19: / - Projeto Executivo não considerando as datas corretas dos Laudos de análise da água do Poço e da Nascente.
- 238: 05/Fev19: / - Em paralelo, Fundiário irá apresentar data de aquisição do terreno (onde será construído o campo de futebol) para definição sobre o melhor local para construção da ETA/UTR. / 14/Dez / - A ETA está prevista para ser construída ao lado da Igreja. Fundiário tem que verificar as demandas para iniciar o processo de negociação.

| ID | WBS | Task | Type | Duration | Start | Finish | Predecessors | Baseline start | Baseline finish | Baseline duration | Baseline 1 start | Baseline 1 finish | Total slack | Free slack | Text3 | Text5 | Text15 | Text25 | Text26 | Text27 | Text29 | Text4 | Text7 | Indicadores MIR |
| --- | --- | --- | --- | --- | --- | --- | --- | --- | --- | --- | --- | --- | --- | --- | --- | --- | --- | --- | --- | --- | --- | --- | --- | --- |
| 245 | 3.2.2.2.4 | **ETA/Reservatório - Desimpedimento de Área e Negociação de Servidão** |  | 80d | 2020-03-05 | 2020-06-30 |  | 2019-05-09 | 2019-08-30 | 80d | 2019-05-09 | 2019-08-30 | 511d |  | 45% | 45 | 45 | 0% | ok | 0% | Pedras (distrito Mariana/MG) |  |  |  |
| 246 | 3.2.2.2.4.1 | Realizar Levantamento da documentação da propriedade - Pedras/MG |  | 10d | 2020-03-05 | 2020-03-18 | 238, 230 | 2019-05-09 | 2019-05-22 | 10d | 2019-05-09 | 2019-05-22 | 511d | 0d | 100% | 100 | 100 |  |  |  |  |  |  |  |
| 247 | 3.2.2.2.4.2 | Obter assinatura do Contrato de servidão pelo proprietário - Pedras/MG |  | 20d | 2020-03-19 | 2020-04-16 | 246 | 2019-05-23 | 2019-06-19 | 20d | 2019-05-23 | 2019-06-19 | 511d | 0d | 100% | 100 | 100 |  |  |  |  |  |  |  |
| 248 | 3.2.2.2.4.3 | Lavrar Escritura Pública de Servidão no cartório de notas - Pedras/MG |  | 30d | 2020-04-17 | 2020-06-01 | 247 | 2019-06-21 | 2019-08-01 | 30d | 2019-06-21 | 2019-08-01 | 511d | 0d | 20% | 20 | 20 |  |  |  |  |  |  |  |
| 249 | 3.2.2.2.4.4 | Averbar a escritura pública na matrícula do imóvel - Pedras/MG |  | 20d | 2020-06-02 | 2020-06-30 | 248 | 2019-08-02 | 2019-08-30 | 20d | 2019-08-02 | 2019-08-30 | 511d | 0d | 0% |  |  |  |  |  |  |  |  |  |
| 250 | 3.2.2.2.4.5 | Regularização da Servidão - ETA/Resrvatório - Pedras/MG | milestone | 0d | 2020-06-30 | 2020-06-30 | 249 | 2019-08-30 | 2019-08-30 | 0d | 2019-08-30 | 2019-08-30 | 511d | 30d | 0% |  |  |  |  |  |  |  |  |  |
| 251 | 3.2.2.2.5 | Conclusão da Regularização Fundiária para as obras de Melhoria do Sistema de Abastecimento da Localidade - Pedras/MG | milestone | 0d | 2020-08-11 | 2020-08-11 | 244, 249, 250 | 2019-10-01 | 2019-10-01 | 0d | 2019-10-01 | 2019-10-01 | 815d |  | 0% |  |  |  |  |  |  |  |  |  |
| 252 | 3.2.2.3 | **Licenciamento** |  | 367d | 2020-04-06 | 2021-09-23 |  | 2018-08-29 | 2020-02-04 | 361d | 2018-08-29 | 2020-02-04 | 352d |  | 58% | 58 | 51 | 0% | ok | 0% | Pedras (distrito Mariana/MG) | 25 | 49 |  |
| 253 | 3.2.2.3.1 | **Captação Alternativa (Nascente) - Certidão de Uso Insignificante e DAIA para acumulação de água** |  | 217d | 2020-11-11 | 2021-09-23 |  | 2019-03-28 | 2020-02-04 | 214d | 2019-03-28 | 2020-02-04 | 202d |  | 29% | 29 | 30 | 0% | ok | 0% | Pedras (distrito Mariana/MG) |  |  |  |
| 254 | 3.2.2.3.1.1 | Enviar a documentação ao SAAE para obter a certidão de uso insignificante - Pedras/MG |  | 1d | 2020-11-11 | 2020-11-11 | 216, 237 | 2019-03-28 | 2019-03-28 | 1d | 2019-03-28 | 2019-03-28 | 202d | 0d | 100% | 100 | 100 |  |  |  |  |  |  |  |
| 255 | 3.2.2.3.1.2 | Realizar Análise Inicial da Demanda para DAIA para acumulação de água - Pedras/MG |  | 10d | 2020-11-12 | 2020-11-25 | 216, 254 | 2019-03-28 | 2019-04-10 | 10d | 2019-03-28 | 2019-04-10 | 202d | 0d | 100% | 100 | 100 |  |  |  |  |  |  |  |
| 256 | 3.2.2.3.1.3 | Elaborar Estudos Ambientais para DAIA para acumulação de água - Pedras/MG |  | 30d | 2020-11-26 | 2021-01-11 | 255 | 2019-04-10 | 2019-05-24 | 30d | 2019-04-10 | 2019-05-24 | 202d | 0d | 100% | 100 | 100 |  |  |  |  |  |  |  |
| 257 | 3.2.2.3.1.4 | Acompanhar Processo Junto ao Órgão para DAIA para acumulação de água - Pedras/MG |  | 176d | 2021-01-12 | 2021-09-23 | 256 | 2019-05-24 | 2020-02-04 | 176d | 2019-05-24 | 2020-02-04 | 202d | 0d | 14% | 14 | 14 |  |  |  |  |  |  |  |
| 258 | 3.2.2.3.1.5 | Obtenção de DAIA para acumulação de água - Nascente - Pedras/MG | milestone | 0d | 2021-09-23 | 2021-09-23 | 257 | 2020-02-04 | 2020-02-04 | 0d | 2020-02-04 | 2020-02-04 | 202d | 0d | 0% |  |  |  |  |  |  |  |  |  |
| 259 | 3.2.2.3.2 | Realizar diagnóstico para verificar a necessidade de licença do SAA - Pedras/MG |  | 120d | 2020-04-06 | 2020-09-25 | 231 | 2019-05-02 | 2019-05-31 | 22d | 2019-05-02 | 2019-05-31 | 449d | 35d | 100% | 100 | 100 | 0% | ok | 0% | Pedras (distrito Mariana/MG) |  |  |  |
| 260 | 3.2.2.3.3 | Conclusão do Licenciamento Ambiental da Localidade - Pedras/MG | milestone | 0d | 2021-09-23 | 2021-09-23 | 258, 259 | 2020-02-04 | 2020-02-04 | 0d | 2020-02-04 | 2020-02-04 | 536d |  | 0% |  |  |  |  |  |  |  |  |  |
| 261 | 3.2.2.4 | **Suprimentos** |  | 88d | 2020-07-14 | 2020-11-17 |  | 2019-09-27 | 2020-02-04 | 88d | 2019-09-27 | 2020-02-04 | 414d |  | 0% |  |  | 0% | ok | 0% | Pedras (distrito Mariana/MG) |  |  |  |
| 262 | 3.2.2.4.1 | Realizar contratação - Captações e ETA - Pedras/MG |  | 88d | 2020-07-14 | 2020-11-17 | 225, 232 | 2019-09-27 | 2020-02-04 | 88d | 2019-09-27 | 2020-02-04 | 414d | 0d | 0% |  |  | 0% | ok | 0% | Pedras (distrito Mariana/MG) |  |  |  |
| 263 | 3.2.2.4.2 | Conclusão da Contratação de Suprimentos para as obras de Melhoria do Sistema de Abastecimento de Água- Pedras/MG | milestone | 0d | 2020-11-17 | 2020-11-17 | 262 | 2020-02-04 | 2020-02-04 | 0d | 2020-02-04 | 2020-02-04 | 414d | 0d | 0% |  |  |  |  |  |  |  |  |  |
| 264 | 3.2.2.5 | **Infraestrutura** |  | 547d | 2020-11-18 | 2023-01-28 |  | 2020-02-04 | 2021-05-28 | 326d | 2020-02-04 | 2021-05-28 | 201d |  | 0% |  |  | 0% | ok | 0% | Pedras (distrito Mariana/MG) |  |  |  |
| 265 | 3.2.2.5.1 | Executar obras na Captação Principal (Nascente) - Pedras/MG |  | 81d | 2021-09-24 | 2022-01-20 | 243, 244, 258, 262, 263, 218, 227 | 2020-02-04 | 2020-05-13 | 66d | 2020-02-04 | 2020-05-13 | 202d | 0d | 0% |  |  | 0% | ok | 0% | Pedras (distrito Mariana/MG) |  |  | CA |
| 266 | 3.2.2.5.2 | Executar obras da ETA (Sistema de Tratamento Simplificado/Melhorias no reservatório) - Pedras/MG |  | 81d | 2020-11-18 | 2021-03-18 | 249, 250, 259, 262, 263, 234 | 2020-02-04 | 2020-05-13 | 66d | 2020-02-04 | 2020-05-13 | 414d | 212d | 0% |  |  | 0% | ok | 0% | Pedras (distrito Mariana/MG) |  |  | ETA |
| 267 | 3.2.2.5.3 | Assinatura de Termo de Entrega das Obras de Melhoria do Sistema de Abastecimento de Água - Pedras/MG | milestone | 0d | 2022-01-20 | 2022-01-20 | 265, 266 | 2020-05-13 | 2020-05-13 | 0d | 2020-05-13 | 2020-05-13 | 455d | 207d | 0% |  |  | 0% | ok | 0% | Pedras (distrito Mariana/MG) |  |  |  |
| 268 | 3.2.2.5.4 | **Operação** |  | 254d | 2022-01-21 | 2023-01-28 |  | 2020-05-14 | 2021-05-28 | 260d | 2020-05-14 | 2021-05-28 | 201d |  | 0% |  |  | 0% | ok | 0% | Pedras (distrito Mariana/MG) |  |  |  |
| 269 | 3.2.2.5.4.1 | Realizar Treinamento Operacional do Sistema - Pedras/MG |  | 5d | 2022-01-21 | 2022-01-27 | 265, 266 | 2020-05-14 | 2020-05-20 | 5d | 2020-05-14 | 2020-05-20 | 202d | 0d | 0% |  |  | 0% | ok | 0% | Pedras (distrito Mariana/MG) |  |  |  |
| 270 | 3.2.2.5.4.2 | Realizar Testes e Pré-operação - Pedras/MG |  | 14d | 2022-01-28 | 2022-02-16 | 269 | 2020-05-21 | 2020-06-09 | 14d | 2020-05-21 | 2020-06-09 | 202d | 0d | 0% |  |  | 0% | ok | 0% | Pedras (distrito Mariana/MG) |  |  |  |
| 271 | 3.2.2.5.4.3 | Realizar Acompanhamento da Funcionalidade do Sistema - ETA (Sistema de Tratamento Simplificado) e Captação Principal (Nascente) - Pedras (distrito Mariana/MG) |  | 365ed | 2022-01-28 | 2023-01-28 | 273SS | 2020-05-14 | 2021-05-28 | 260d |  |  | 895.12d | 0d |  |  |  |  |  |  |  |  |  |  |

| ID | WBS | Task | Type | Duration | Start | Finish | Predecessors | Complete | Remaining | Baseline start | Baseline finish | Baseline duration | Baseline 1 start | Baseline 1 finish | Total slack | Free slack | Text3 | Text25 | Text26 | Text27 | Text29 | Text4 | Text5 | Text7 | Text15 | Text23 | Text9 |
| --- | --- | --- | --- | --- | --- | --- | --- | --- | --- | --- | --- | --- | --- | --- | --- | --- | --- | --- | --- | --- | --- | --- | --- | --- | --- | --- | --- |
| 272 | 3.2.2.5.4.4 | **Operação Assistida** |  | 59d | 2022-01-28 | 2022-04-28 |  |  |  | 2020-05-14 | 2020-08-12 | 64d | 2020-05-14 | 2020-08-12 | 202d |  | 0% | 0% | ok | 0% | Pedras (distrito Mariana/MG) |  |  |  |  |  |  |
| 273 | 3.2.2.5.4.4.1 | Realizar Operação Assistida - Pedras/MG |  | 90ed | 2022-01-28 | 2022-04-28 | 265, 266, 270SS |  |  | 2020-05-14 | 2020-08-12 | 3.2mo | 2020-05-14 | 2020-08-12 | 895.12d | 0d | 0% | 0% | ok | 0% | Pedras (distrito Mariana/MG) |  |  |  |  |  |  |
| 274 | 3.2.2.5.5 | Entrega das obras e conclusão do período de acompanhamento da operação - Pedras/MG | milestone | 0d | 2023-01-28 | 2023-01-28 | 267, 271 |  |  | 2021-05-28 | 2021-05-28 | 0d | 2021-05-28 | 2021-05-28 | 201d |  | 0% |  |  |  |  |  |  |  |  |  |  |
| 275 | 4 | **Território Alto Rio Doce** |  | 1365d | 2016-12-20 A | 2022-05-13 |  | 17% | 1134.04d | 2016-12-20 | 2021-05-28 | 1127d | 2016-12-20 | 2021-05-28 | 380d |  | 57% | 0% | ok | 0% | Paracatu de Baixo (distrito Mariana/MG) | 22 | 57 | 50 | 44 | Socioambiental |  |
| 276 | 4.1 | **Gesteira (distrito Barra Longa/MG)** |  | 1109d | 2016-12-20 A | 2021-05-05 |  | 29% | 782.59d | 2016-12-20 | 2021-02-05 | 1052d | 2016-12-20 | 2021-02-05 | 636d |  | 61% | 0% | ok | 0% | Gesteira (distrito Barra Longa/MG) | 28 | 61 | 50 | 56 | Socioambiental |  |
| 277 | 4.1.1 | **Captação Principal/Alternativa/ETA** |  | 651d | 2016-12-20 A | 2019-06-28 A |  | 100% |  | 2016-12-20 | 2019-06-28 | 651d |  |  |  |  |  |  |  |  |  |  |  |  |  |  |  |
| 278 | 4.1.1.1 | **Estudos de Concepção do Sistema** |  | 395d | 2016-12-20 A | 2018-06-25 A |  | 100% |  | 2016-12-20 | 2019-08-27 | 692d | 2016-12-20 | 2019-08-27 |  |  | 94% |  |  |  |  | 100 | 94 | 100 | 100 |  |  |
| 279 | 4.1.1.1.1 | Elaboração do Relatório Obra - Gesteira/MG | milestone | 0d | 2018-03-23 A | 2018-03-23 A | 26 | 100% |  | 2018-03-23 | 2018-03-23 | 0d | 2018-03-23 | 2018-03-23 |  |  | 100% | 0% | ok | 0% | Gesteira (distrito Barra Longa/MG) | 100 | 100 | 100 | 100 |  |  |
| 280 | 4.1.1.1.2 | **Serviços em Poços Tubulares - Captação Principal** |  | 395d | 2016-12-20 A | 2018-06-25 A |  | 100% |  | 2016-12-20 | 2018-06-25 | 395d | 2016-12-20 | 2018-06-25 |  |  | 100% | 0% | ok | 0% | Gesteira (distrito Barra Longa/MG) | 100 | 100 | 100 | 100 |  |  |
| 281 | 4.1.1.1.2.1 | Realizar Perfilagem (Poço Beira Rio) - Gesteira/MG |  | 1d | 2018-06-21 A | 2018-06-21 A | 279FS+65d | 100% |  | 2018-06-21 | 2018-06-21 | 1d | 2018-06-21 | 2018-06-21 |  |  | 100% | 0% | ok | 0% | Gesteira (distrito Barra Longa/MG) | 100 | 100 | 100 | 100 |  |  |
| 282 | 4.1.1.1.2.2 | Realizar Limpeza (Poço Beira Rio) - Gesteira/MG |  | 1d | 2018-06-22 A | 2018-06-22 A | 281 | 100% |  | 2018-06-22 | 2018-06-22 | 1d | 2018-06-22 | 2018-06-22 |  |  | 100% | 0% | ok | 0% | Gesteira (distrito Barra Longa/MG) | 100 | 100 | 100 | 100 |  |  |
| 283 | 4.1.1.1.2.3 | Elaborar Relatório Técnico (Poço Beira Rio) - Gesteira/MG |  | 26d | 2018-05-21 A | 2018-06-25 A | 281FF, 282FF | 100% |  | 2018-05-21 | 2018-06-25 | 26d | 2018-05-21 | 2018-06-25 |  |  | 100% | 0% | ok | 0% | Gesteira (distrito Barra Longa/MG) | 100 | 100 | 100 | 100 |  |  |
| 284 | 4.1.1.1.2.4 | Realizar Laudo Serviços de Coleta e Análise de Água (Poço Beira Rio) - Gesteira/MG |  | 26d | 2018-05-21 A | 2018-06-25 A | 283FF | 100% |  | 2018-05-21 | 2018-06-25 | 26d | 2018-05-21 | 2018-06-25 |  |  | 100% | 0% | ok | 0% | Gesteira (distrito Barra Longa/MG) | 100 | 100 | 100 | 100 |  |  |
| 285 | 4.1.1.1.2.5 | Realizar Perfuração/Instrumentação (Poço Posto de Saúde) - Gesteira/MG |  | 2d | 2016-12-20 A | 2016-12-21 A | 24 | 100% |  | 2016-12-20 | 2016-12-21 | 2d | 2016-12-20 | 2016-12-21 |  |  | 100% | 0% | ok | 0% | Gesteira (distrito Barra Longa/MG) | 100 | 100 | 100 | 100 |  |  |
| 286 | 4.1.1.1.2.6 | Elaborar Relatório Técnico (Poço Posto de Saúde) - Gesteira/MG |  | 19d | 2016-12-22 A | 2017-01-17 A | 285 | 100% |  | 2016-12-22 | 2017-01-17 | 19d | 2016-12-22 | 2017-01-17 |  |  | 100% | 0% | ok | 0% | Gesteira (distrito Barra Longa/MG) | 100 | 100 | 100 | 100 |  |  |
| 287 | 4.1.1.1.2.7 | Realizar Laudo Serviços de Coleta e Análise de Água (Poço Posto de Saúde) - Gesteira/MG |  | 9d | 2017-10-03 A | 2017-10-13 A | 285FS+203d | 100% |  | 2017-10-03 | 2017-10-13 | 9d | 2017-10-03 | 2017-10-13 |  |  | 100% | 0% | ok | 0% | Gesteira (distrito Barra Longa/MG) | 100 | 100 | 100 | 100 |  |  |
| 288 | 4.1.1.1.2.8 | Conclusão dos Serviços em poço tubular - Gesteira/MG | milestone | 0d | 2017-10-13 A | 2017-10-13 A | 287 | 100% |  | 2017-10-13 | 2017-10-13 | 0d | 2017-10-13 | 2017-10-13 |  |  | 100% |  |  |  |  | 100 | 100 | 100 | 100 |  |  |
| 289 | 4.1.1.1.3 | Conclusão dos Estudos de Concepção das Melhorias do Sistema de Abastecimento de Água - Gesteira/MG | milestone | 0d | 2018-06-25 A | 2018-06-25 A | 281, 282, 283, 284, 285, 286, 288 | 100% |  | 2018-06-25 | 2018-06-25 | 0d | 2018-06-25 | 2018-06-25 |  |  | 100% |  |  |  |  | 100 | 100 | 100 | 100 |  |  |
| 290 | 4.1.1.2 | **Engenharia Básica e Detalhada** |  | 433d | 2017-10-20 A | 2019-06-28 A |  | 100% |  | 2017-10-20 | 2019-06-12 | 422d | 2017-10-20 | 2019-06-12 |  |  | 100% |  |  |  |  | 85 | 100 | 85 | 100 |  |  |
| 291 | 4.1.1.2.1 | Elaborar projeto de Engenharia Captação Principal - Poço Beira Rio (existente) - Gesteira/MG |  | 60d | 2018-03-09 A | 2018-05-31 A | 26 | 100% |  | 2018-03-09 | 2018-05-31 | 60d | 2018-03-09 | 2018-05-31 |  |  | 100% | 0% | ok | 0% | Gesteira (distrito Barra Longa/MG) | 100 | 100 | 100 | 100 |  |  |
| 292 | 4.1.1.2.2 | **Engenharia** |  | 33d | 2017-10-20 A | 2017-12-05 A |  | 100% |  | 2017-10-20 | 2019-06-12 | 422d | 2017-10-20 | 2019-06-12 |  |  | 100% | 0% | ok | 0% | Gesteira (distrito Barra Longa/MG) | 87 | 100 | 87 | 100 | Socioambiental |  |
| 293 | 4.1.1.2.2.1 | Elaborar Projeto Executivo Melhorias de ETA - Melhorias na ETA - Gesteira/MG |  | 33d | 2017-10-20 A | 2017-12-05 A | 288, 26SS | 100% |  | 2017-10-20 | 2017-12-05 | 33d | 2017-10-20 | 2017-12-05 |  |  | 100% | 0% | ok | 0% | Gesteira (distrito Barra Longa/MG) | 100 | 100 | 100 | 100 |  |  |
| 294 | 4.1.1.2.3 | **Engenharia (Adutora Poço Beira-Rio e Reservatório)** |  | 245d | 2018-07-11 A | 2019-06-28 A |  | 100% |  | 2018-07-11 | 2019-06-28 | 245d |  |  |  |  |  |  |  |  |  |  |  |  |  |  |  |
| 295 | 4.1.1.2.3.1 | Aprovar Plano de Trabalho /abertura OSE + Levantamento de Campo (Projeto Reservatório + adutora) - Melhorias na ETA - Gesteira/MG |  | 81d | 2018-07-11 A | 2018-10-31 A | 293 | 100% |  | 2018-07-11 | 2018-10-31 | 81d | 2018-07-11 | 2018-10-31 |  |  | 100% | 0% | ok | 0% | Gesteira (distrito Barra Longa/MG) | 100 | 100 | 100 | 100 |  |  |
| 296 | 4.1.1.2.3.2 | Emitir RT/PQ para Suprimentos - Melhorias na ETA - Gesteira/MG |  | 11d | 2019-05-17 A | 2019-05-31 A | 297FF | 100% |  | 2019-04-29 | 2019-05-13 | 10d | 2019-04-29 | 2019-05-13 |  |  | 100% |  |  |  |  | 100 | 100 | 100 | 100 |  |  |
| 297 | 4.1.1.2.3.3 | Elaborar Projeto Executivo - Melhorias na ETA - Gesteira/MG |  | 174d | 2018-10-18 A | 2019-06-28 A | 295SS+71d | 100% |  | 2018-10-18 | 2019-05-13 | 141d | 2018-10-18 | 2019-05-13 |  |  | 100% | 0% | Não OK | 0% | Gesteira (distrito Barra Longa/MG) | 100 | 100 | 100 | 100 | Socioambiental | Não OK |
| 298 | 4.1.1.2.3.4 | Elaboração do Projeto Executivo - Melhorias na ETA - Gesteira/MG | milestone | 0d | 2019-06-28 A | 2019-06-28 A | 297, 289 | 100% |  | 2019-06-12 | 2019-06-12 | 0d | 2019-06-12 | 2019-06-12 |  |  | 100% |  |  |  |  |  | 100 |  | 100 |  |  |

Notes:
- 287: 21/Dez / - Laudo realizado pela Itapoços.
- 291: 12/Dez / - Entrega está condicionada a implantação da nova adutora entre o poço Beira Rio e o tratamento de água. / - Não precisa ser submetido à aprovação do CIF.
- 292: 12/Dez / - "Projeto" de construção e implantação da ETA realizado pela Rota Ambiental. E o projeto de substituição dos reservatórios desenvolvido pela ENG FR. / - UTR não se aplica a Gesteira por se tratar de água subterrânea.
- 293: 21/12 / - Realizado pela Rota Ambiental.
- 295: 29/Jan19: / - Projeto de reforma do reservatório sendo considerado junto com o de distribuição de água.

| ID | WBS | Task | Type | Duration | Start | Finish | Predecessors | Complete | Remaining | Baseline start | Baseline finish | Baseline duration | Baseline 1 start | Baseline 1 finish | Total slack | Free slack | Text3 | Text4 | Text5 | Text7 | Text15 | Text25 | Text26 | Text27 | Text29 | Indicadores MIR | Text23 |
| --- | --- | --- | --- | --- | --- | --- | --- | --- | --- | --- | --- | --- | --- | --- | --- | --- | --- | --- | --- | --- | --- | --- | --- | --- | --- | --- | --- |
| 299 | 4.1.1.3 | **Fundiária** |  | 95d | 2018-07-23 A | 2018-11-30 A |  | 100% |  | 2018-07-23 | 2019-09-19 | 295d | 2018-07-23 | 2019-09-19 |  |  | 80% | 54 | 80 | 81 | 67 | 0% | ok | 0% | Gesteira (distrito Barra Longa/MG) |  |  |
| 300 | 4.1.1.3.1 | Obter Autorização de Acesso e Documento do Superficiário - Gesteira/MG |  | 95d | 2018-07-23 A | 2018-11-30 A | 279 | 100% |  | 2018-07-23 | 2018-11-30 | 95d | 2018-07-23 | 2018-11-30 |  |  | 100% | 100 | 100 | 100 | 100 | 0% | ok | 0% | Gesteira (distrito Barra Longa/MG) |  |  |
| 301 | 4.1.1.3.2 | Conclusão da Regularização Fundiária para as obras de Melhoria do Sistema de Abastecimento da Localidade - Gesteira/MG | milestone | 0d | 2018-11-30 A | 2018-11-30 A | 300 | 100% |  | 2019-09-19 | 2019-09-19 | 0d | 2019-09-19 | 2019-09-19 |  |  | 0% |  |  |  |  |  |  |  |  |  |  |
| 302 | 4.1.1.4 | **Infraestrutura** |  | 174d | 2017-11-01 A | 2018-07-02 A |  | 100% |  | 2017-11-01 | 2021-02-05 | 826d | 2017-11-01 | 2021-02-05 |  |  | 51% |  | 51 | 18 | 38 | 0% | ok | 0% | Gesteira (distrito Barra Longa/MG) |  |  |
| 303 | 4.1.1.4.1 | **Obras - Etapa 1** |  | 174d | 2017-11-01 A | 2018-07-02 A |  | 100% |  | 2017-11-01 | 2020-02-20 | 588d | 2017-11-01 | 2020-02-20 |  |  | 72% | 45 | 72 | 118 | 38 |  |  |  |  |  |  |
| 304 | 4.1.1.4.1.1 | Executar Melhorias na ETA - Gesteira/MG |  | 2.1mo | 2017-11-01 A | 2017-12-28 A | 24, 296 | 100% |  | 2017-11-01 | 2017-12-28 | 2.1mo | 2017-11-01 | 2017-12-28 |  |  | 100% | 100 | 100 | 100 | 100 | 0% | ok | 0% |  | ETA |  |
| 305 | 4.1.1.4.1.2 | Executar Captação Principal - Poço Beira Rio - Gesteira/MG |  | 22d | 2018-06-01 A | 2018-07-02 A | 291 | 100% |  | 2019-06-01 | 2019-07-02 | 22d | 2018-06-01 | 2018-07-02 |  |  | 90% | 100 | 90 | 111 | 90 |  |  |  |  |  |  |
| 306 | 4.1.1.4.1.3 | Executar Captação Alternativa (Poço - área Posto de Saúde) - Gesteira/MG |  | 42d | 2017-11-01 A | 2017-12-28 A | 304SS | 100% |  | 2019-11-01 | 2019-12-28 | 42d | 2017-11-01 | 2017-12-28 |  |  | 0% | 100 |  |  |  | 0% | ok | 0% | Gesteira (distrito Barra Longa/MG) | CA |  |
| 307 | 4.1.1.4.1.4 | Assinatura de Termo de Entrega das Obras de Melhoria do Sistema de Abastecimento de Água - Gesteira/MG | milestone | 0d | 2018-07-02 A | 2018-07-02 A | 305, 306, 298 | 100% |  | 2020-02-20 | 2020-02-20 | 0d | 2020-02-20 | 2020-02-20 |  |  | 0% |  |  |  |  | 0% | ok | 0% | Gesteira (distrito Barra Longa/MG) |  |  |
| 308 | 4.1.2 | **Reforma do Reservatório + Adutora Poço Centro de Saúde + Melhorias no Acesso** |  | 394d | 2019-09-27 A | 2021-05-05 |  |  | 394d | 2016-12-20 | 2019-08-27 | 692d | 2016-12-20 | 2019-08-27 | 636d |  | 94% | 87 | 94 | 87 | 100 |  | ok |  |  |  | Socioambiental |
| 309 | 4.1.2.1 | **Infraestrutura** |  | 394d | 2019-09-27 A | 2021-05-05 |  |  | 394d | 2017-11-01 | 2021-02-05 | 826d | 2017-11-01 | 2021-02-05 | 636d |  | 51% |  | 51 | 18 | 38 | 0% | ok | 0% | Gesteira (distrito Barra Longa/MG) |  |  |
| 310 | 4.1.2.1.1 | **Obras - Etapa 2** |  | 145d | 2019-09-27 A | 2020-05-04 |  |  | 145d | 2019-09-27 | 2020-04-28 | 143d |  |  | 885d |  |  |  |  |  |  |  |  |  |  |  |  |
| 311 | 4.1.2.1.1.1 | Definição de novo escopo - Reforma do Reservatório + Adutora Poço Centro de Saúde + Melhorias no Acesso - Gesteira/MG | milestone | 0d | 2019-09-27 A | 2019-09-27 A | 307FS+315d | 100% |  | 2019-09-27 | 2019-09-27 | 0d |  |  |  |  |  |  |  |  |  |  |  |  |  |  |  |
| 312 | 4.1.2.1.1.2 | Executar Reforma Adutora Poço Beira Rio existente - Gesteira/MG |  | 80d | 2020-01-06 | 2020-05-04 | 311FS+65d |  |  | 2019-07-08 | 2019-10-08 | 66d | 2019-07-08 | 2019-10-08 | 637d | 0d | 0% |  |  |  |  | 0% | ok | 0% | Gesteira (distrito Barra Longa/MG) |  |  |
| 313 | 4.1.2.1.1.3 | Executar Melhoria em ETA - Ampliação do reservatório - Gesteira/MG |  | 80d | 2020-01-06 | 2020-05-04 | 311FS+65d |  |  | 2019-10-15 | 2020-01-21 | 66d | 2019-10-15 | 2020-01-21 | 637d | 0d | 0% |  |  |  |  | 0% | ok | 0% | Gesteira (distrito Barra Longa/MG) |  |  |
| 314 | 4.1.2.1.1.4 | Assinatura de Termo de Entrega das Obras de Melhoria do Sistema de Abastecimento de Água - Gesteira/MG | milestone | 0d | 2020-05-04 | 2020-05-04 | 312, 313 |  |  | 2020-02-20 | 2020-02-20 | 0d | 2020-02-20 | 2020-02-20 | 885d | 637d | 0% |  |  |  |  | 0% | ok | 0% | Gesteira (distrito Barra Longa/MG) |  |  |
| 315 | 4.1.2.1.2 | **Operação** |  | 249d | 2020-05-05 | 2021-05-05 |  |  |  | 2020-01-22 | 2021-02-05 | 260d | 2020-01-22 | 2021-02-05 | 636d |  | 0% |  |  |  |  | 0% | ok | 0% | Gesteira (distrito Barra Longa/MG) |  |  |
| 316 | 4.1.2.1.2.1 | Realizar Treinamento Operacional do Sistema - Gesteira/MG |  | 5d | 2020-05-05 | 2020-05-11 | 312, 313 |  |  | 2020-01-22 | 2020-01-28 | 5d | 2020-01-22 | 2020-01-28 | 637d | 0d | 0% |  |  |  |  | 0% | ok | 0% | Gesteira (distrito Barra Longa/MG) |  |  |
| 317 | 4.1.2.1.2.2 | Realizar Testes e Pré-operação - Gesteira/MG |  | 14d | 2020-05-05 | 2020-05-22 | 316SS |  |  | 2020-01-29 | 2020-02-17 | 14d | 2020-01-29 | 2020-02-17 | 637d | 0d | 0% |  |  |  |  | 0% | ok | 0% | Gesteira (distrito Barra Longa/MG) |  |  |
| 318 | 4.1.2.1.2.3 | Realizar Acompanhamento da Funcionalidade do Sistema - Reforma do Reservatório + Adutora Poço Centro de Saúde + Melhorias no Acesso - Gesteira (distrito Barra Longa/MG) |  | 365ed | 2020-05-05 | 2021-05-05 | 320SS |  |  | 2020-01-22 | 2021-02-05 | 260d |  |  | 2794.12d | 0d |  |  |  |  |  |  |  |  |  |  |  |
| 319 | 4.1.2.1.2.4 | **Operação Assistida** |  | 249d | 2020-05-05 | 2021-05-05 |  |  |  | 2020-01-22 | 2020-04-27 | 64d | 2020-01-22 | 2020-04-27 | 636d |  | 0% |  |  |  |  | 0% | ok | 0% | Gesteira (distrito Barra Longa/MG) |  |  |
| 320 | 4.1.2.1.2.4.1 | Realizar Operação Assistida - Gesteira/MG |  | 90ed | 2020-05-05 | 2020-08-03 | 312, 313, 317SS |  |  | 2020-01-22 | 2020-04-27 | 3.2mo | 2020-01-22 | 2020-04-27 | 2794.12d | 0d | 0% |  |  |  |  | 0% | ok | 0% | Gesteira (distrito Barra Longa/MG) |  |  |
| 321 | 4.1.2.1.2.4.2 | Entrega das obras e conclusão do período de acompanhamento da operação - Gesteira/MG | milestone | 0d | 2021-05-05 | 2021-05-05 | 318, 320 |  |  | 2020-04-27 | 2020-04-27 | 0d |  |  | 636d |  |  |  |  |  |  |  |  |  |  |  |  |
| 322 | 4.2 | **Barreto (distrito Barra Longa/MG)** |  | 1082d | 2018-01-19 A | 2022-05-13 |  | 7% | 1002.1d | 2018-01-19 | 2021-05-28 | 844d | 2018-01-19 | 2021-05-28 | 380d |  | 43% | 17 | 43 | 53 | 32 | 0% | ok | 0% | Barreto (distrito Barra Longa/MG) |  | Socioambiental |
| 323 | 4.2.1 | **Captação Principal/Alternativa/ETA/Adução** |  | 1082d | 2018-01-19 A | 2022-05-13 |  | 7% | 1002.1d | 2018-01-19 | 2021-05-28 | 844d |  |  | 380d |  |  |  |  |  |  |  |  |  |  |  |  |
| 324 | 4.2.1.1 | **Estudos de Concepção do Sistema - Etapa 1** |  | 350d | 2018-01-19 A | 2019-06-03 A |  | 100% |  | 2018-01-19 | 2019-07-23 | 385d | 2018-01-19 | 2019-07-23 |  |  | 95% | 62 | 95 | 77 | 81 |  |  |  |  |  |  |
| 325 | 4.2.1.1.1 | Declaração de Escopo e Premissas de Projeto (DEPP) concluída - Barreto/MG | milestone | 0d | 2018-03-23 A | 2018-03-23 A | 25, 26 | 100% |  | 2018-03-23 | 2018-03-23 | 0d | 2018-03-23 | 2018-03-23 |  |  | 100% | 100 | 100 | 100 | 100 | 0% | ok | 0% | Barreto (distrito Barra Longa/MG) |  |  |
| 326 | 4.2.1.1.2 | Revisão de Definições - Barreto/MG | milestone | 0d | 2018-03-23 A | 2018-03-23 A | 325 | 100% |  | 2018-03-23 | 2018-03-23 | 0d | 2018-03-23 | 2018-03-23 |  |  | 100% | 100 | 100 | 100 | 100 | 0% | Não OK | 0% | Barreto (distrito Barra Longa/MG) |  | Socioambiental |
| 327 | 4.2.1.1.3 | Aprovação das DEPPs pela Operadora e Prefeitura - Barreto/MG | milestone | 0d | 2018-04-16 A | 2018-04-16 A | 325, 326FS+17d | 100% |  | 2018-04-16 | 2018-04-16 | 0d | 2018-04-16 | 2018-04-16 |  |  | 100% | 100 | 100 | 100 | 100 | 0% | Não OK | 0% | Barreto (distrito Barra Longa/MG) |  | Socioambiental |

Notes:
- 306: 21/Dez / - O Poço foi perfurado e as obras foram realizadas pela Samarco em período emergencial. / - Linkar no emergencial.
- 312: 21/Dez / - O Poço Beiro Rio é anterior ao rompimento, foi impactado, foi recuperado pela Samarco e posteriormente pela FR. O que será executado é o projeto da adutora.
- 322: 29/Jan19: / - A Captação Principal será poço e a Alternativa nascente. / 14/Dez / - Em função da pendência na obtenção de anuência junto a Prefeitura de Barra Longa, as atividades desenvolvidas até o momento foram de Geofísica (locação do poço), com autorização para perfuração já obtida do poço.
- 327: 17/01/19: / Foram considerados 17 dias úteis para aprovação da "Revisão da Definição" pela Prefeitura. / 14/Dez / A Prefeitura não aprovou de forma oficial o Estudo de Concepção apresentado.

| ID | WBS | Task | Type | Duration | Start | Finish | Predecessors | Complete | Remaining | Baseline start | Baseline finish | Baseline duration | Baseline 1 start | Baseline 1 finish | Total slack | Free slack | Text3 | Text4 | Text5 | Text7 | Text15 | Text25 | Text26 | Text27 | Text29 | Text23 | Text13 | Text9 |
| --- | --- | --- | --- | --- | --- | --- | --- | --- | --- | --- | --- | --- | --- | --- | --- | --- | --- | --- | --- | --- | --- | --- | --- | --- | --- | --- | --- | --- |
| 328 | 4.2.1.1.4 | **Estudos de Geofísica para Poço Tubular** |  | 24d | 2018-01-19 A | 2018-02-21 A |  | 100% |  | 2018-01-19 | 2018-02-21 | 24d | 2018-01-19 | 2018-02-21 |  |  | 100% | 100 | 100 | 100 | 100 | 0% | ok | 0% | Barreto (distrito Barra Longa/MG) |  |  |  |
| 329 | 4.2.1.1.4.1 | Executar Levantamento de Campo - Barreto/MG |  | 24d | 2018-01-19 A | 2018-02-21 A | 26FS+44d | 100% |  | 2018-01-19 | 2018-02-21 | 24d | 2018-01-19 | 2018-02-21 |  |  | 100% | 100 | 100 | 100 | 100 | 0% | ok | 0% | Barreto (distrito Barra Longa/MG) |  |  |  |
| 330 | 4.2.1.1.4.2 | Emitir Relatório - Barreto/MG |  | 15d | 2018-02-01 A | 2018-02-21 A | 329FF | 100% |  | 2018-02-01 | 2018-02-21 | 15d | 2018-02-01 | 2018-02-21 |  |  | 100% | 100 | 100 | 100 | 100 | 0% | ok | 0% | Barreto (distrito Barra Longa/MG) |  |  |  |
| 331 | 4.2.1.1.4.3 | Conclusão dos Estudos de Geofísica para Poço Tubular - Barreto/MG | milestone | 0d | 2018-02-21 A | 2018-02-21 A | 330 | 100% |  | 2018-02-21 | 2018-02-21 | 0d | 2018-02-21 | 2018-02-21 |  |  | 100% | 100 | 100 | 100 | 100 |  |  |  |  |  |  |  |
| 332 | 4.2.1.1.5 | **Serviços em Poços Tubulares - Poço Seco** |  | 6d | 2019-04-08 A | 2019-04-15 A |  | 100% |  | 2019-04-08 | 2019-04-15 | 6d | 2019-04-08 | 2019-04-15 |  |  | 100% | 100 | 100 | 100 | 100 | 0% | ok | 0% | Barreto (distrito Barra Longa/MG) |  |  |  |
| 333 | 4.2.1.1.5.1 | Realizar Perfuração - Barreto/MG |  | 5d | 2019-04-08 A | 2019-04-12 A | 327 | 100% |  | 2019-04-08 | 2019-04-12 | 5d | 2019-04-08 | 2019-04-12 |  |  | 100% | 100 | 100 | 100 | 100 | 0% | ok | 0% | Barreto (distrito Barra Longa/MG) |  |  |  |
| 334 | 4.2.1.1.5.2 | Realizar Tamponamento - Barreto/MG |  | 1d | 2019-04-15 A | 2019-04-15 A | 333 | 100% |  | 2019-04-15 | 2019-04-15 | 1d | 2019-04-15 | 2019-04-15 |  |  | 100% | 100 | 100 | 100 | 100 |  |  |  |  |  |  |  |
| 335 | 4.2.1.1.5.3 | Conclusão dos Serviços em Poços Tubulares - Captação Principal concluído - Barreto/MG | milestone | 0d | 2019-04-15 A | 2019-04-15 A | 334 | 100% |  | 2019-04-15 | 2019-04-15 | 0d | 2019-04-15 | 2019-04-15 |  |  | 100% | 100 | 100 | 100 | 100 |  |  |  |  |  |  |  |
| 336 | 4.2.1.1.6 | **Captações Superficiais (Captação Alternativa) - Nascente 1 (Córrego Sem Nome)** |  | 104d | 2018-05-01 A | 2018-09-21 A |  | 100% |  | 2018-05-01 | 2018-09-21 | 104d | 2018-05-01 | 2018-09-21 |  |  | 100% | 100 | 100 | 100 | 100 | 0% | ok | 0% | Barreto (distrito Barra Longa/MG) | Socioambiental |  |  |
| 337 | 4.2.1.1.6.1 | Realizar Recuperação de Nascente - Nascente 1 (Córrego Sem Nome) - Captação Alternativa - Barreto/MG |  | 60d | 2018-05-01 A | 2018-07-23 A | 327, 365 | 100% |  | 2018-05-01 | 2018-07-23 | 60d | 2018-05-01 | 2018-07-23 |  |  | 100% | 100 | 100 | 100 | 100 | 0% | Não OK | 0% | Barreto (distrito Barra Longa/MG) | Socioambiental |  |  |
| 338 | 4.2.1.1.6.2 | Elaborar Relatório Técnico - Nascente 1 (Córrego Sem Nome) - Captação Alternativa - Barreto/MG |  | 22d | 2018-07-24 A | 2018-08-22 A | 337 | 100% |  | 2018-07-24 | 2018-08-22 | 22d | 2018-07-24 | 2018-08-22 |  |  | 100% | 100 | 100 | 100 | 100 | 0% | Não OK | 0% | Barreto (distrito Barra Longa/MG) | Socioambiental |  |  |
| 339 | 4.2.1.1.6.3 | Realizar Laudo de Serviços de Coleta e Análise de Água Preliminar - Nascente 1 (Córrego Sem Nome) - Captação Alternativa - Barreto/MG |  | 18d | 2018-08-29 A | 2018-09-21 A | 26 | 100% |  | 2018-08-29 | 2018-09-21 | 18d | 2018-08-29 | 2018-09-21 |  |  | 100% | 100 | 100 | 100 | 100 | 0% | ok | 0% | Barreto (distrito Barra Longa/MG) |  |  |  |
| 340 | 4.2.1.1.6.4 | Realizar Laudo de Serviços de Coleta e Análise de Água Final - Nascente 1 (Córrego Sem Nome) - Captação Alternativa - Barreto/MG |  | 22d | 2018-07-24 A | 2018-08-22 A | 337 | 100% |  | 2018-07-24 | 2018-08-22 | 22d | 2018-07-24 | 2018-08-22 |  |  | 100% | 100 | 100 | 100 | 100 | 0% | Não OK | 0% | Barreto (distrito Barra Longa/MG) | Socioambiental |  |  |
| 341 | 4.2.1.1.6.5 | Conclusão da Recuperação da Nascente 1 - Captação Alternativa- Barreto/MG | milestone | 0d | 2018-08-22 A | 2018-08-22 A | 338, 340 | 100% |  | 2018-08-22 | 2018-08-22 | 0d | 2018-08-22 | 2018-08-22 |  |  | 100% | 100 | 100 | 100 | 100 |  |  |  |  |  |  |  |
| 342 | 4.2.1.1.7 | Definição de Nacente para Captação - Nascente 2 (Córrego Barroso) - Captação Principal - Barreto/MG | milestone | 0d | 2019-06-03 A | 2019-06-03 A | 334FS+32d | 100% |  | 2019-04-25 | 2019-04-25 | 0d | 2019-04-25 | 2019-04-25 |  |  | 100% | 100 | 100 | 100 | 100 |  |  |  |  |  |  |  |
| 343 | 4.2.1.2 | **Estudos de Concepção do Sistema - Etapa 2** |  | 79d | 2020-06-05 | 2020-09-25 |  |  |  | 2020-04-23 | 2020-08-13 | 79d |  |  | 395d |  |  |  |  |  |  |  |  |  |  |  |  |  |
| 344 | 4.2.1.2.1 | **Captações Superficiais (Captação Principal) - Nascente 2 (Córrego Barreto)** |  | 79d | 2020-06-05 | 2020-09-25 |  |  |  | 2019-04-25 | 2019-07-23 | 62d | 2019-04-25 | 2019-07-23 | 395d |  | 72% |  | 72 |  | 50 |  |  |  |  |  |  |  |
| 345 | 4.2.1.2.1.1 | Realizar Recuperação de Nascente - Nascente 2 (Córrego Barreto) - Captação Principal - Barreto/MG |  | 57d | 2020-06-05 | 2020-08-25 | 342, 366FS+90d |  |  | 2019-04-29 | 2019-07-23 | 60d | 2019-04-29 | 2019-07-23 | 395d | 0d | 71% |  | 71 |  | 71 |  |  |  |  |  |  |  |
| 346 | 4.2.1.2.1.2 | Elaborar Relatório Técnico - Nascente 2 (Córrego Barreto) - Captação Principal - Barreto/MG |  | 22d | 2020-08-26 | 2020-09-25 | 345 |  |  | 2019-06-24 | 2019-07-23 | 22d | 2019-06-24 | 2019-07-23 | 395d | 0d | 22% |  | 22 |  | 22 |  |  |  |  |  |  |  |
| 347 | 4.2.1.2.1.3 | Realizar Laudo de Serviços de Coleta e Análise de Água - Nascente 2 (Córrego Barreto) - Captação Principal - Barreto/MG |  | 22d | 2020-08-26 | 2020-09-25 | 345 |  |  | 2019-06-24 | 2019-07-23 | 22d | 2019-06-24 | 2019-07-23 | 783d | 0d | 22% |  | 22 |  | 22 |  |  |  |  |  |  |  |
| 348 | 4.2.1.2.1.4 | Conclusão da Recuperação da Nascente 2 (Córrego Barreto) - Captação Principal - Barreto/MG | milestone | 0d | 2020-09-25 | 2020-09-25 | 347 |  |  | 2019-07-23 | 2019-07-23 | 0d | 2019-07-23 | 2019-07-23 | 783d | 0d | 0% |  |  |  |  |  |  |  |  |  |  |  |
| 349 | 4.2.1.2.2 | Conclusão dos Estudos de Concepção das Melhorias do Sistema de Abastecimento de Água - Barreto/MG | milestone | 0d | 2020-09-25 | 2020-09-25 | 331, 335, 341, 348 |  |  | 2019-07-23 | 2019-07-23 | 0d | 2019-07-23 | 2019-07-23 | 783d |  | 0% |  |  |  |  |  |  |  |  |  |  |  |
| 350 | 4.2.1.3 | **Engenharia Básica e Detalhada** |  | 197d | 2019-11-22 A | 2020-09-09 |  | 12% | 173.21d | 2018-11-30 | 2019-10-25 | 227d | 2018-11-30 | 2019-10-25 | 795d |  | 62% | 38 | 62 | 47 | 81 |  |  |  |  |  |  |  |
| 351 | 4.2.1.3.1 | **Engenharia Captação Principal/Alternativa/ETA/Adução** |  | 177d | 2019-11-22 A | 2020-08-11 |  | 13% | 153.34d | 2018-11-30 | 2019-09-27 | 207d | 2018-11-30 | 2019-09-27 | 482d |  | 69% | 44 | 69 | 45 | 98 | 0% | ok | 0% | Barreto (distrito Barra Longa/MG) | Socioambiental |  |  |
| 352 | 4.2.1.3.1.1 | Aprovar Plano de Trabalho e abrir OSE - Captação Principal/Alternativa/ETA/Adução - Barreto/MG |  | 10d | 2019-11-22 A | 2019-12-05 A | 342FS+120d | 100% |  | 2018-11-30 | 2018-12-14 | 11d | 2018-11-30 | 2018-12-14 |  |  | 100% | 100 | 100 | 100 | 100 | 0% | ok | 0% | Barreto (distrito Barra Longa/MG) |  | 8888888 |  |
| 353 | 4.2.1.3.1.2 | Executar Topografia - Captação Principal/Alternativa/ETA/Adução - Barreto/MG |  | 15d | 2019-12-06 A | 2019-12-31 A | 352 | 100% |  | 2018-11-30 | 2019-01-02 | 23d | 2018-11-30 | 2019-01-02 |  |  | 100% | 100 | 100 | 100 | 100 |  |  |  |  |  | 8888888 |  |
| 354 | 4.2.1.3.1.3 | Elaborar Projeto Básico - Captação Principal/Alternativa/ETA/Adução - Barreto/MG |  | 60d | 2020-01-02 | 2020-03-30 | 353 |  |  | 2018-02-08 | 2018-03-21 | 30d | 2018-02-08 | 2018-03-21 | 382d | 0d | 100% |  | 100 |  | 100 |  |  |  |  |  |  |  |
| 355 | 4.2.1.3.1.4 | Aprovar Projeto Básico - Captação Principal/Alternativa/ETA/Adução - Barreto/MG |  | 22d | 2020-03-31 | 2020-05-04 | 354 |  |  | 2018-03-01 | 2018-03-30 | 22d |  |  | 382d | 0d |  |  |  |  |  |  |  |  |  |  |  |  |
| 356 | 4.2.1.3.1.5 | Emitir RT/PQ para Suprimentos - Captação Principal/Alternativa/ETA/Adução - Barreto/MG |  | 10d | 2020-07-29 | 2020-08-11 | 354, 355, 357FF |  |  | 2019-06-21 | 2019-07-04 | 10d | 2019-06-21 | 2019-07-04 | 382d | 0d | 60% |  | 60 |  | 60 | 0% | ok | 0% | Barreto (distrito Barra Longa/MG) |  |  |  |
| 357 | 4.2.1.3.1.6 | Elaborar Projeto Executivo - Captação Principal/Alternativa/ETA/Adução - Barreto/MG |  | 70d | 2020-05-05 | 2020-08-11 | 354, 339, 340, 355 |  |  | 2019-03-18 | 2019-06-19 | 65d | 2019-03-18 | 2019-06-19 | 382d | 0d | 100% |  | 100 |  | 100 | 0% | Não OK | 0% | Barreto (distrito Barra Longa/MG) | Socioambiental |  | Não OK |
| 358 | 4.2.1.3.1.7 | Elaboração do Projeto Executivo - Captação Alternativa - Nascente 1 - Barreto/MG | milestone | 0d | 2020-08-11 | 2020-08-11 | 354, 357 |  |  | 2019-06-19 | 2019-06-19 | 0d | 2019-06-19 | 2019-06-19 | 470d | 88d | 100% |  | 100 |  | 100 |  |  |  |  |  |  |  |
| 359 | 4.2.1.3.1.8 | Elaboração do Projeto Executivo - Captação Principal - Nascente 2 - Barreto/MG | milestone | 0d | 2020-08-11 | 2020-08-11 | 357 |  |  | 2019-10-22 | 2019-10-22 | 0d | 2019-10-22 | 2019-10-22 | 482d | 0d | 0% |  |  |  |  |  |  |  |  |  |  |  |
| 360 | 4.2.1.3.1.9 | Elaboração do Projeto Executivo - ETA- Barreto/MG | milestone | 0d | 2020-08-11 | 2020-08-11 | 357 |  |  | 2019-07-29 | 2019-07-29 | 0d | 2019-07-29 | 2019-07-29 | 470d | 88d | 0% |  |  |  |  |  |  |  |  |  |  |  |

Notes:
- 332: 14/Dez / - Necessária a anuência da Prefeitura para a solução de SAA proposta para a localidade.
- 333: 22/04/19: Vazão não atende. Poço será tamponado.
- 357: 25/Jan19: / - Projeto Executivo não considerando as datas corretas do Laudo de análise da água (final) e do Relatório Técnico da Nascente.

| ID | WBS | Task | Type | Duration | Start | Finish | Predecessors | Complete | Remaining | Baseline start | Baseline finish | Baseline duration | Baseline 1 start | Baseline 1 finish | Total slack | Free slack | Text3 | Text25 | Text26 | Text27 | Text29 | Text4 | Text5 | Text7 | Text15 | Text23 | Text13 |
| --- | --- | --- | --- | --- | --- | --- | --- | --- | --- | --- | --- | --- | --- | --- | --- | --- | --- | --- | --- | --- | --- | --- | --- | --- | --- | --- | --- |
| 361 | 4.2.1.3.2 | **Validação dos Projetos** |  | 20d | 2020-08-12 | 2020-09-09 |  |  |  | 2019-09-30 | 2019-10-25 | 20d | 2019-09-30 | 2019-10-25 | 795d |  | 0% | 0% | ok | 0% | Barreto (distrito Barra Longa/MG) |  |  |  |  |  |  |
| 362 | 4.2.1.3.2.1 | Validar Projetos com Prefeitura e Operadora - Barreto/MG |  | 20d | 2020-08-12 | 2020-09-09 | 354, 357, 359 |  |  | 2019-09-30 | 2019-10-25 | 20d | 2019-09-30 | 2019-10-25 | 795d | 0d | 0% | 0% | ok | 0% | Barreto (distrito Barra Longa/MG) |  |  |  |  |  |  |
| 363 | 4.2.1.3.2.2 | Validação com Prefeitura e Operadora dos Projetos de Melhoria do Sistema de Abastecimento de Água - Barreto/MG | milestone | 0d | 2020-09-09 | 2020-09-09 | 362 |  |  | 2019-10-25 | 2019-10-25 | 0d | 2019-10-25 | 2019-10-25 | 795d |  | 0% |  |  |  |  |  |  |  |  |  |  |
| 364 | 4.2.1.4 | **Fundiária** |  | 608d | 2018-04-17 A | 2020-09-14 |  | 6% | 573.26d | 2018-04-17 | 2019-09-03 | 352d | 2018-04-17 | 2019-09-03 | 447d |  | 86% | 0% | ok | 0% | Barreto (distrito Barra Longa/MG) | 12 | 86 | 21 | 56 | Socioambiental |  |
| 365 | 4.2.1.4.1 | Obter Termo de Autorização do Superficiário - Captação Alternativa (Nascente 1) - Barreto/MG |  | 10d | 2018-04-17 A | 2018-04-30 A | 327 | 100% |  | 2018-04-17 | 2018-04-30 | 10d | 2018-04-17 | 2018-04-30 |  |  | 100% | 0% | Não OK | 0% | Barreto (distrito Barra Longa/MG) | 100 | 100 | 100 | 100 | Socioambiental |  |
| 366 | 4.2.1.4.2 | Obter Termo de Autorização do Superficiário - Captação Alternativa (Nascente 2) - Barreto/MG |  | 10d | 2020-01-09 | 2020-01-22 | 342FS+150d |  |  | 2019-04-26 | 2019-05-10 | 10d | 2019-04-26 | 2019-05-10 | 395d | 0d | 100% |  |  |  |  |  | 100 |  | 100 |  | 8888888 |
| 367 | 4.2.1.4.3 | Obter Termo de Autorização de Superficiário - ETA / UTR - Barreto/MG |  | 10d | 2018-04-17 A | 2018-04-30 A | 327 | 100% |  | 2018-04-17 | 2018-04-30 | 10d | 2018-04-17 | 2018-04-30 |  |  | 100% | 0% | Não OK | 0% | Barreto (distrito Barra Longa/MG) | 100 | 100 | 100 | 100 | Socioambiental |  |
| 368 | 4.2.1.4.4 | **Captação Alternativa (Nascente 1) - Desimpedimento de Área e Negociação de Servidão** |  | 80d | 2020-01-23 | 2020-05-21 |  |  |  | 2019-05-02 | 2019-08-23 | 80d | 2019-05-02 | 2019-08-23 | 527d |  | 51% | 0% | ok | 0% | Barreto (distrito Barra Longa/MG) |  | 51 |  | 51 |  |  |
| 369 | 4.2.1.4.4.1 | Realizar Levantamento da documentação da propriedade - Barreto/MG |  | 10d | 2020-01-23 | 2020-02-05 | 365, 375SS |  |  | 2019-05-02 | 2019-05-15 | 10d | 2019-05-02 | 2019-05-15 | 527d | 0d | 100% |  |  |  |  |  | 100 |  | 100 |  | 8888888 |
| 370 | 4.2.1.4.4.2 | Obter assinatura do Contrato de servidão pelo proprietário - Barreto/MG |  | 20d | 2020-02-06 | 2020-03-09 | 369 |  |  | 2019-05-16 | 2019-06-12 | 20d | 2019-05-16 | 2019-06-12 | 527d | 0d | 100% |  |  |  |  |  | 100 |  | 100 |  | 8888888 |
| 371 | 4.2.1.4.4.3 | Lavrar Escritura Pública de Servidão no cartório de notas - Barreto/MG |  | 30d | 2020-03-10 | 2020-04-22 | 370 |  |  | 2019-06-13 | 2019-07-25 | 30d | 2019-06-13 | 2019-07-25 | 527d | 0d | 36% |  |  |  |  |  | 36 |  | 36 |  |  |
| 372 | 4.2.1.4.4.4 | Averbar a escritura pública na matrícula do imóvel - Barreto/MG |  | 20d | 2020-04-23 | 2020-05-21 | 371 |  |  | 2019-07-26 | 2019-08-23 | 20d | 2019-07-26 | 2019-08-23 | 527d | 0d | 0% |  |  |  |  |  |  |  |  |  |  |
| 373 | 4.2.1.4.4.5 | Regularização da Servidão - Nascente 1 - Barreto/MG | milestone | 0d | 2020-05-21 | 2020-05-21 | 372 |  |  | 2019-08-23 | 2019-08-23 | 0d | 2019-08-23 | 2019-08-23 | 527d | 80d | 0% |  |  |  |  |  |  |  |  |  |  |
| 374 | 4.2.1.4.5 | **Captação Alternativa (Nascente 2) - Desimpedimento de Área e Negociação de Servidão** |  | 80d | 2020-01-23 | 2020-05-21 |  |  |  | 2019-05-13 | 2019-09-03 | 80d | 2019-05-13 | 2019-09-03 | 447d |  | 42% |  |  |  |  |  | 42 |  | 42 |  |  |
| 375 | 4.2.1.4.5.1 | Realizar Levantamento da documentação da propriedade - Barreto/MG |  | 10d | 2020-01-23 | 2020-02-05 | 366 |  |  | 2019-05-13 | 2019-05-24 | 10d | 2019-05-13 | 2019-05-24 | 447d | 0d | 100% |  |  |  |  |  | 100 |  | 100 |  | 8888888 |
| 376 | 4.2.1.4.5.2 | Obter assinatura do Contrato de servidão pelo proprietário - Barreto/MG |  | 20d | 2020-02-06 | 2020-03-09 | 375 |  |  | 2019-05-27 | 2019-06-24 | 20d | 2019-05-27 | 2019-06-24 | 527d | 0d | 100% |  |  |  |  |  | 100 |  | 100 |  | 8888888 |
| 377 | 4.2.1.4.5.3 | Lavrar Escritura Pública de Servidão no cartório de notas - Barreto/MG |  | 30d | 2020-03-10 | 2020-04-22 | 376 |  |  | 2019-06-25 | 2019-08-05 | 30d | 2019-06-25 | 2019-08-05 | 527d | 0d | 13% |  |  |  |  |  | 13 |  | 13 |  |  |
| 378 | 4.2.1.4.5.4 | Averbar a escritura pública na matrícula do imóvel - Barreto/MG |  | 20d | 2020-04-23 | 2020-05-21 | 377 |  |  | 2019-08-06 | 2019-08-23 | 13d | 2019-08-06 | 2019-09-03 | 527d | 0d | 0% |  |  |  |  |  |  |  |  |  |  |
| 379 | 4.2.1.4.5.5 | Regularização da Servidão (Nascente 2) - Barreto/MG | milestone | 0d | 2020-05-21 | 2020-05-21 | 378 |  |  | 2019-08-23 | 2019-08-23 | 0d | 2019-09-03 | 2019-09-03 | 527d | 80d | 0% |  |  |  |  |  |  |  |  |  |  |
| 380 | 4.2.1.4.6 | **ETA (STA Simplificado)/Adutora - Desimpedimento de Área e Negociação de Servidão** |  | 160d | 2020-01-23 | 2020-09-14 |  |  |  | 2019-05-02 | 2019-08-23 | 80d | 2019-05-02 | 2019-08-23 | 447d |  | 51% | 0% | ok | 0% | Barreto (distrito Barra Longa/MG) |  | 51 |  | 51 |  |  |
| 381 | 4.2.1.4.6.1 | Realizar Levantamento da documentação da propriedade - Barreto/MG |  | 10d | 2020-01-23 | 2020-02-05 | 367, 375SS |  |  | 2019-05-02 | 2019-05-15 | 10d | 2019-05-02 | 2019-05-15 | 447d | 0d | 100% |  |  |  |  |  | 100 |  | 100 |  | 8888888 |
| 382 | 4.2.1.4.6.2 | Obter assinatura do Contrato de servidão pelo proprietário - Barreto/MG |  | 20d | 2020-02-06 | 2020-03-09 | 381 |  |  | 2019-05-16 | 2019-06-12 | 20d | 2019-05-16 | 2019-06-12 | 447d | 0d | 100% |  |  |  |  |  | 100 |  | 100 |  | 8888888 |
| 383 | 4.2.1.4.6.3 | Lavrar Escritura Pública de Servidão no cartório de notas - Barreto/MG |  | 110d | 2020-03-10 | 2020-08-14 | 382 |  |  | 2019-06-13 | 2019-07-25 | 30d | 2019-06-13 | 2019-07-25 | 447d | 0d | 36% |  |  |  |  |  | 36 |  | 36 |  |  |
| 384 | 4.2.1.4.6.4 | Averbar a escritura pública na matrícula do imóvel - Barreto/MG |  | 20d | 2020-08-17 | 2020-09-14 | 383 |  |  | 2019-07-26 | 2019-08-23 | 20d | 2019-07-26 | 2019-08-23 | 447d | 0d | 0% |  |  |  |  |  |  |  |  |  |  |
| 385 | 4.2.1.4.6.5 | Regularização da Servidão - ETA (STA Simplificado)/Adutora - Barreto/MG | milestone | 0d | 2020-09-14 | 2020-09-14 | 384 |  |  | 2019-08-23 | 2019-08-23 | 0d | 2019-08-23 | 2019-08-23 | 447d | 0d | 0% |  |  |  |  |  |  |  |  |  |  |
| 386 | 4.2.1.4.7 | Conclusão da Regularização Fundiária para as obras de Melhoria do Sistema de Abastecimento da Localidade - Barreto/MG | milestone | 0d | 2020-09-14 | 2020-09-14 | 365, 367, 373, 379, 385 |  |  | 2019-09-03 | 2019-09-03 | 0d | 2019-09-03 | 2019-09-03 | 447d | 65d | 0% |  |  |  |  |  |  |  |  |  |  |

| ID | WBS | Task | Type | Duration | Start | Finish | Predecessors | Baseline start | Baseline finish | Baseline duration | Baseline 1 start | Baseline 1 finish | Total slack | Free slack | Text3 | Text4 | Text5 | Text7 | Text15 | Text25 | Text26 | Text27 | Text29 | Text13 | Indicadores MIR |
| --- | --- | --- | --- | --- | --- | --- | --- | --- | --- | --- | --- | --- | --- | --- | --- | --- | --- | --- | --- | --- | --- | --- | --- | --- | --- |
| 387 | 4.2.1.5 | **Licenciamento** |  | 234d | 2020-01-09 | 2020-12-15 |  | 2018-07-04 | 2020-03-13 | 426d | 2018-07-04 | 2020-03-13 | 395d |  | 58% | 25 | 58 | 71 | 35 | 0% | ok | 0% | Barreto (distrito Barra Longa/MG) |  |  |
| 388 | 4.2.1.5.1 | **Captação Alternativa (Nascente 1) - Certidão de Uso Insignificante e DAIA para acumulação de água** |  | 217d | 2020-01-09 | 2020-11-20 |  | 2019-05-02 | 2020-03-13 | 217d | 2019-05-02 | 2020-03-13 | 400d |  | 18% |  | 18 |  | 19 | 0% | ok | 0% | Barreto (distrito Barra Longa/MG) |  |  |
| 389 | 4.2.1.5.1.1 | Enviar a documentação à prefeitura para obter a certidão de uso insignificante - Barreto/MG |  | 1d | 2020-01-09 | 2020-01-09 | 338, 365, 366SS | 2019-05-02 | 2019-05-02 | 1d | 2019-05-02 | 2019-05-02 | 400d | 0d | 100% |  | 100 |  | 100 |  |  |  |  | 8888888 |  |
| 390 | 4.2.1.5.1.2 | Realizar Análise Inicial da Demanda para DAIA para acumulação de água - Barreto/MG |  | 10d | 2020-01-10 | 2020-01-23 | 338, 389 | 2019-05-03 | 2019-05-16 | 10d | 2019-05-03 | 2019-05-16 | 400d | 0d | 100% |  | 100 |  | 100 |  |  |  |  | 8888888 |  |
| 391 | 4.2.1.5.1.3 | Elaborar Estudos Ambientais para DAIA para acumulação de água - Barreto/MG |  | 30d | 2020-01-24 | 2020-03-10 | 390 | 2019-05-17 | 2019-06-28 | 30d | 2019-05-17 | 2019-06-28 | 400d | 0d | 100% |  | 100 |  | 100 |  |  |  |  | 8888888 |  |
| 392 | 4.2.1.5.1.4 | Acompanhar Processo Junto ao Órgão para DAIA para acumulação de água - Barreto/MG |  | 176d | 2020-03-11 | 2020-11-20 | 391 | 2019-07-01 | 2020-03-13 | 176d | 2019-07-01 | 2020-03-13 | 400d | 0d | 0% |  |  |  |  |  |  |  |  |  |  |
| 393 | 4.2.1.5.1.5 | Obtenção de DAIA para acumulação de água - Nascente 1 - Barreto/MG | milestone | 0d | 2020-11-20 | 2020-11-20 | 392 | 2020-03-13 | 2020-03-13 | 0d | 2020-03-13 | 2020-03-13 | 400d | 17d | 0% |  |  |  |  |  |  |  |  |  |  |
| 394 | 4.2.1.5.2 | **Captação Alternativa (Nascente 2) - Certidão de Uso Insignificante e DAIA para acumulação de água** |  | 224d | 2020-01-23 | 2020-12-15 |  | 2019-05-13 | 2019-10-29 | 120d | 2019-05-13 | 2019-10-29 | 395d |  | 28% |  | 28 |  |  |  |  |  |  |  |  |
| 395 | 4.2.1.5.2.1 | Enviar a documentação à prefeitura para obter a certidão de uso insignificante - Barreto/MG |  | 1d | 2020-01-23 | 2020-01-23 | 366 | 2019-05-13 | 2019-05-13 | 1d | 2019-05-13 | 2019-05-13 | 563d | 168d | 100% |  | 100 |  | 100 |  |  |  |  | 8888888 |  |
| 396 | 4.2.1.5.2.2 | Realizar Análise Inicial da Demanda para DAIA para acumulação de água - Barreto/MG |  | 10d | 2020-09-28 | 2020-10-09 | 346, 395 | 2019-07-24 | 2019-08-06 | 10d | 2019-07-24 | 2019-08-06 | 395d | 0d | 0% |  |  |  |  |  |  |  |  |  |  |
| 397 | 4.2.1.5.2.3 | Elaborar Estudos Ambientais para DAIA para acumulação de água - Barreto/MG |  | 15d | 2020-10-13 | 2020-11-03 | 396 | 2019-08-07 | 2019-08-28 | 15d | 2019-08-07 | 2019-08-28 | 395d | 0d | 0% |  |  |  |  |  |  |  |  |  |  |
| 398 | 4.2.1.5.2.4 | Acompanhar Processo Junto ao Órgão para DAIA para acumulação de água - Barreto/MG |  | 30d | 2020-11-04 | 2020-12-15 | 397 | 2019-08-29 | 2019-10-29 | 44d | 2019-08-29 | 2019-10-29 | 395d | 0d | 0% |  |  |  |  |  |  |  |  |  |  |
| 399 | 4.2.1.5.2.5 | Obtenção de DAIA para acumulação de água - Nascente 2 - Barreto/MG | milestone | 0d | 2020-12-15 | 2020-12-15 | 398 | 2019-10-29 | 2019-10-29 | 0d | 2019-10-29 | 2019-10-29 | 395d | 0d | 0% |  |  |  |  |  |  |  |  |  |  |
| 400 | 4.2.1.5.3 | Realizar diagnóstico para verificar a necessidade de licença do SAA - Barreto/MG |  | 22d | 2020-08-12 | 2020-09-11 | 356 | 2019-09-30 | 2019-10-29 | 22d | 2019-09-30 | 2019-10-29 | 448d | 65d | 0% |  |  |  |  | 0% | ok | 0% | Barreto (distrito Barra Longa/MG) |  |  |
| 401 | 4.2.1.5.4 | Conclusão do Licenciamento Ambiental da Localidade - Barreto/MG | milestone | 0d | 2020-12-15 | 2020-12-15 | 393, 399, 400 | 2020-03-13 | 2020-03-13 | 0d | 2020-03-13 | 2020-03-13 | 395d | 1d | 0% |  |  |  |  |  |  |  |  |  |  |
| 402 | 4.2.1.6 | **Suprimentos** |  | 88d | 2020-08-12 | 2020-12-16 |  | 2019-09-27 | 2020-02-04 | 88d | 2019-09-27 | 2020-02-04 | 382d |  | 0% |  |  |  |  |  |  |  |  |  |  |
| 403 | 4.2.1.6.1 | Suprimentos - Captações, ETA, Adução - Barreto/MG |  | 88d | 2020-08-12 | 2020-12-16 | 356 | 2019-09-27 | 2020-02-04 | 88d | 2019-09-27 | 2020-02-04 | 382d | 0d | 0% |  |  |  |  | 0% | ok | 0% | Barreto (distrito Barra Longa/MG) |  |  |
| 404 | 4.2.1.6.2 | Conclusão da Contratação de Suprimentos das obras de Melhoria do Sistema de Abastecimento de Água - Barreto/MG | milestone | 0d | 2020-12-16 | 2020-12-16 | 403 | 2020-02-04 | 2020-02-04 | 0d | 2020-02-04 | 2020-02-04 | 382d | 0d | 0% |  |  |  |  |  |  |  |  |  |  |
| 405 | 4.2.1.7 | **Infraestrutura** |  | 347d | 2020-12-17 | 2022-05-13 |  | 2020-02-04 | 2021-05-28 | 326d | 2020-02-04 | 2021-05-28 | 380d |  | 0% |  |  |  |  | 0% | ok | 0% | Barreto (distrito Barra Longa/MG) |  |  |
| 406 | 4.2.1.7.1 | **Obras** |  | 97d | 2020-12-17 | 2021-05-12 |  | 2020-02-04 | 2020-06-15 | 88d | 2020-02-04 | 2020-06-15 | 382d |  | 0% |  |  |  |  |  |  |  |  |  |  |
| 407 | 4.2.1.7.1.1 | Executar Captação Alternativa/Adução (Nascente 1) / Captação Principal/Adução (Nascente 2) - Barreto/MG |  | 97d | 2020-12-17 | 2021-05-12 | 357, 372, 373, 393, 404, 358 | 2020-02-04 | 2020-05-13 | 66d | 2020-02-04 | 2020-05-13 | 382d | 0d | 0% |  |  |  |  | 0% | ok | 0% | Barreto (distrito Barra Longa/MG) |  | CA |
| 408 | 4.2.1.7.1.2 | Executar Captação Principal/Adução (Nascente 2) - Barreto/MG |  | 85d | 2020-12-17 | 2021-04-26 | 378, 379, 399, 403, 359, 401 | 2020-02-04 | 2020-05-13 | 66d | 2020-02-04 | 2020-05-13 | 394d | 12d | 0% |  |  |  |  |  |  |  |  |  |  |
| 409 | 4.2.1.7.1.3 | Executar ETA (Sistema de Tratamento Simplificado) - Barreto/MG |  | 97d | 2020-12-17 | 2021-05-12 | 384, 385, 400, 404, 360, 386 | 2020-02-04 | 2020-05-13 | 66d | 2020-02-04 | 2020-05-13 | 382d | 0d | 0% |  |  |  |  | 0% | ok | 0% | Barreto (distrito Barra Longa/MG) |  | ETA |
| 410 | 4.2.1.7.1.4 | Assinatura de Termo de Entrega das Obras de Melhoria do Sistema de Abastecimento de Água - Barreto/MG | milestone | 0d | 2021-05-12 | 2021-05-12 | 407, 408, 409 | 2020-06-15 | 2020-06-15 | 0d | 2020-06-15 | 2020-06-15 | 382d | 0d | 0% |  |  |  |  | 0% | ok | 0% | Barreto (distrito Barra Longa/MG) |  |  |

| ID | WBS | Task | Type | Duration | Start | Finish | Predecessors | Complete | Remaining | Baseline start | Baseline finish | Baseline duration | Baseline 1 start | Baseline 1 finish | Total slack | Free slack | Text3 | Text25 | Text26 | Text27 | Text29 | Text4 | Text5 | Text7 | Text15 | Text23 | Text9 |
| --- | --- | --- | --- | --- | --- | --- | --- | --- | --- | --- | --- | --- | --- | --- | --- | --- | --- | --- | --- | --- | --- | --- | --- | --- | --- | --- | --- |
| 411 | 4.2.1.7.2 | **Operação** |  | 250d | 2021-05-13 | 2022-05-13 |  |  |  | 2020-05-14 | 2021-05-28 | 260d | 2020-05-14 | 2021-05-28 | 380d |  | 0% | 0% | ok | 0% | Barreto (distrito Barra Longa/MG) |  |  |  |  |  |  |
| 412 | 4.2.1.7.2.1 | Realizar Treinamento Operacional do Sistema - Barreto/MG |  | 5d | 2021-05-13 | 2021-05-19 | 407, 408, 409, 410 |  |  | 2020-05-14 | 2020-05-20 | 5d | 2020-05-14 | 2020-05-20 | 382d | 0d | 0% | 0% | ok | 0% | Barreto (distrito Barra Longa/MG) |  |  |  |  |  |  |
| 413 | 4.2.1.7.2.2 | Realizar Testes e Pré-operação - Barreto/MG |  | 14d | 2021-05-13 | 2021-06-01 | 412SS |  |  | 2020-05-21 | 2020-06-09 | 14d | 2020-05-21 | 2020-06-09 | 382d | 0d | 0% | 0% | ok | 0% | Barreto (distrito Barra Longa/MG) |  |  |  |  |  |  |
| 414 | 4.2.1.7.2.3 | Realizar Acompanhamento da Funcionalidade do Sistema - Engenharia Captação Principal/Alternativa/ETA/Adução - Barreto (distrito Barra Longa/MG) |  | 365ed | 2021-05-13 | 2022-05-13 | 416SS |  |  | 2020-05-14 | 2021-05-28 | 260d |  |  | 1675.12d | 0d |  |  |  |  |  |  |  |  |  |  |  |
| 415 | 4.2.1.7.2.4 | **Operação Assistida** |  | 63d | 2021-05-13 | 2021-08-11 |  |  |  | 2020-05-14 | 2020-08-12 | 64d | 2020-05-14 | 2020-08-12 | 381d |  | 0% | 0% | ok | 0% | Barreto (distrito Barra Longa/MG) |  |  |  |  |  |  |
| 416 | 4.2.1.7.2.4.1 | Realizar Operação Assistida - Barreto/MG |  | 90ed | 2021-05-13 | 2021-08-11 | 407, 408, 409, 413SS |  |  | 2020-05-14 | 2020-08-12 | 3.2mo | 2020-05-14 | 2020-08-12 | 1675.12d | 0d | 0% | 0% | ok | 0% | Barreto (distrito Barra Longa/MG) |  |  |  |  |  |  |
| 417 | 4.2.1.7.2.5 | Entrega das obras e conclusão do período de acompanhamento da operação - Barreto/MG | milestone | 0d | 2022-05-13 | 2022-05-13 | 414, 416 |  |  | 2021-05-28 | 2021-05-28 | 0d |  |  | 380d |  |  |  |  |  |  |  |  |  |  |  |  |
| 418 | 5 | **Território Calha do Rio Doce** |  | 967d | 2017-11-20 A | 2021-09-21 |  | 37% | 610.48d | 2017-11-20 | 2021-09-06 | 958d | 2017-11-20 | 2021-09-06 | 539d |  | 43% | 0% | ok | 0% | Barreto (distrito Barra Longa/MG) | 33 | 43 | 67 | 49 | Socioambiental |  |
| 419 | 5.1 | **Ipaba do Paraíso (distrito Santana do Paraíso/MG)** |  | 967d | 2017-11-20 A | 2021-09-21 |  | 37% | 610.48d | 2017-11-20 | 2021-09-06 | 958d | 2017-11-20 | 2021-09-06 | 539d |  | 43% | 0% | ok | 0% | Ipaba do Paraíso (distrito Santana do Paraíso/MG) | 33 | 43 | 67 | 49 | Socioambiental |  |
| 420 | 5.1.1 | **Sistemas de Abastecimento Individuais** |  | 967d | 2017-11-20 A | 2021-09-21 |  | 37% | 610.48d | 2017-11-20 | 2021-09-06 | 958d |  |  | 539d |  |  |  |  |  |  |  |  |  |  |  |  |
| 421 | 5.1.1.1 | **Estudos de Concepção do Sistema - Etapa 1** |  | 282d | 2018-03-23 A | 2019-04-30 A |  | 100% |  | 2018-03-23 | 2019-07-26 | 343d | 2018-03-23 | 2019-07-26 |  |  | 94% |  |  |  |  | 76 | 94 | 83 | 92 |  |  |
| 422 | 5.1.1.1.1 | Declaração de Escopo e Premissas de Projeto (DEPP) concluída - Ipaba do Paraíso/MG | milestone | 0d | 2018-03-23 A | 2018-03-23 A | 25, 26 | 100% |  | 2018-03-23 | 2018-03-23 | 0d | 2018-03-23 | 2018-03-23 |  |  | 100% | 0% | ok | 0% | Ipaba do Paraíso (distrito Santana do Paraíso/MG) | 100 | 100 | 100 | 100 |  |  |
| 423 | 5.1.1.1.2 | Obter anuências dos proprietários - Ipaba do Paraíso/MG |  | 282d | 2018-03-23 A | 2019-04-30 A | 25, 26, 422 | 100% |  | 2018-03-23 | 2019-04-30 | 282d | 2018-03-23 | 2019-04-30 |  |  | 100% | 0% | ok | 0% | Ipaba do Paraíso (distrito Santana do Paraíso/MG) | 100 | 100 | 100 | 100 |  |  |
| 424 | 5.1.1.2 | **Engenharia Básica e Detalhada** |  | 194d | 2018-11-05 A | 2019-08-13 A |  | 100% |  | 2018-11-05 | 2020-01-16 | 300d | 2018-11-05 | 2020-01-16 |  |  | 54% |  |  |  |  | 53 | 54 | 57 | 93 |  |  |
| 425 | 5.1.1.2.1 | Aprovar Plano de Trabalho e abrir OSE - Ipaba do Paraíso/MG |  | 15d | 2018-11-05 A | 2018-11-23 A | 422 | 100% |  | 2018-11-05 | 2018-11-23 | 15d | 2018-11-05 | 2018-11-23 |  |  | 100% | 0% | ok | 0% | Ipaba do Paraíso (distrito Santana do Paraíso/MG) | 100 | 100 | 100 | 100 |  |  |
| 426 | 5.1.1.2.2 | Realizar 1º Levantamento Campo - Ipaba do Paraíso/MG |  | 1d | 2018-12-05 A | 2018-12-05 A | 425, 443 | 100% |  | 2018-12-05 | 2018-12-05 | 1d | 2018-12-05 | 2018-12-05 |  |  | 100% |  |  |  |  | 100 | 100 | 100 | 100 |  |  |
| 427 | 5.1.1.2.3 | Realizar 2º Levantamento Campo - Ipaba do Paraíso/MG |  | 1d | 2019-02-01 A | 2019-02-01 A | 425, 443 | 100% |  | 2019-02-01 | 2019-02-01 | 1d | 2019-02-01 | 2019-02-01 |  |  | 100% |  |  |  |  | 100 | 100 | 100 | 100 |  |  |
| 428 | 5.1.1.2.4 | Elaborar arranjo para obtenção de Dados de Entrada Licenciamento e Fundiário - Ipaba do Paraíso/MG |  | 30d | 2019-05-22 A | 2019-07-03 A | 425FS+120d, 443FS+120d | 100% |  | 2019-05-17 | 2019-06-28 | 30d | 2019-05-17 | 2019-06-28 |  |  | 100% |  |  |  |  | 100 | 100 | 100 | 100 |  |  |
| 429 | 5.1.1.2.5 | Elaborar Projeto Executivo (11 casas) - Ipaba do Paraíso/MG |  | 162d | 2018-12-19 A | 2019-08-13 A | 438FF, 439FF, 426FS+9d, 427FF, 444FF | 100% |  | 2018-12-19 | 2019-06-28 | 130d | 2018-12-19 | 2019-06-28 |  |  | 100% | 0% | ok | 0% | Ipaba do Paraíso (distrito Santana do Paraíso/MG) | 58 | 100 | 58 | 100 |  | Não OK |
| 430 | 5.1.1.2.6 | Elaboração do Projeto Executivo (11 casas) - Ipaba do Paraíso/MG | milestone | 0d | 2019-08-13 A | 2019-08-13 A | 428, 429 | 100% |  | 2019-12-16 | 2019-12-16 | 0d | 2019-12-16 | 2019-12-16 |  |  | 0% |  |  |  |  |  |  |  |  |  |  |
| 431 | 5.1.1.3 | **Licenciamento - Cisternas** |  | 21d | 2018-03-23 A | 2018-04-20 A |  | 100% |  | 2018-03-23 | 2020-07-08 | 578d | 2018-03-23 | 2018-04-20 |  |  | 100% | 0% | ok | 0% | Ipaba do Paraíso (distrito Santana do Paraíso/MG) | 100 | 100 | 100 | 100 | Socioambiental |  |
| 432 | 5.1.1.3.1 | Obter Certidão de Uso Insignificante Individuais (Cisternas) - Ipaba do Paraíso/MG |  | 21d | 2018-03-23 A | 2018-04-20 A | 422 | 100% |  | 2018-03-23 | 2018-04-20 | 21d | 2018-03-23 | 2018-04-20 |  |  | 100% | 0% | Não OK | 0% | Ipaba do Paraíso (distrito Santana do Paraíso/MG) | 100 | 100 | 100 | 100 | Socioambiental |  |
| 433 | 5.1.1.4 | **Estudos de Concepção do Sistema - Etapa 2** |  | 88d | 2019-11-19 A | 2020-03-30 |  | 21% | 69.33d | 2019-11-19 | 2020-03-30 | 88d |  |  | 907d |  |  |  |  |  |  |  |  |  |  |  |  |
| 434 | 5.1.1.4.1 | **Serviços em Cisternas e Poços** |  | 88d | 2019-11-19 A | 2020-03-30 |  | 21% | 69.33d | 2019-05-02 | 2019-07-26 | 61d | 2019-05-02 | 2019-07-26 | 659d |  | 67% | 0% | ok | 0% | Ipaba do Paraíso (distrito Santana do Paraíso/MG) |  | 67 |  | 66 | Socioambiental |  |
| 435 | 5.1.1.4.1.1 | Realizar Estudo de Geofísica e emitir relatório - Ipaba do Paraíso/MG |  | 44d | 2019-11-19 A | 2020-01-23 | 451FS+118d | 64% | 16d | 2019-11-01 | 2020-01-08 | 44d |  |  | 659d | 0d |  |  |  |  |  |  |  |  |  |  |  |
| 436 | 5.1.1.4.1.2 | Realizar Limpeza e Desinfecção (13 cisternas/poços existentes) - Ipaba do Paraíso/MG |  | 22d | 2020-01-24 | 2020-02-27 | 423, 450, 437SS |  |  | 2019-05-02 | 2019-06-27 | 40d | 2019-05-02 | 2019-06-27 | 659d | 0d | 100% | 0% | ok | 0% | Ipaba do Paraíso (distrito Santana do Paraíso/MG) |  | 100 |  | 100 |  |  |
| 437 | 5.1.1.4.1.3 | Realizar Perfuração/Instrumentação - Ipaba do Paraíso/MG |  | 22d | 2020-01-24 | 2020-02-27 | 423, 450, 454, 435 |  |  | 2019-06-03 | 2019-06-14 | 10d | 2019-06-03 | 2019-06-14 | 659d | 0d | 100% | 0% | Não OK | 0% | Ipaba do Paraíso (distrito Santana do Paraíso/MG) |  | 100 |  | 100 | Socioambiental |  |
| 438 | 5.1.1.4.1.4 | Elaborar Relatório Técnico dos poços perfurados- Ipaba do Paraíso/MG |  | 22d | 2020-02-28 | 2020-03-30 | 436, 437 |  |  | 2019-06-28 | 2019-07-26 | 21d | 2019-06-28 | 2019-07-26 | 659d | 0d | 4% | 0% | ok | 0% | Ipaba do Paraíso (distrito Santana do Paraíso/MG) |  |  |  |  |  |  |
| 439 | 5.1.1.4.1.5 | Realizar Coleta e Análise de Água - Ipaba do Paraíso/MG |  | 22d | 2020-02-28 | 2020-03-30 | 437 |  |  | 2019-06-17 | 2019-07-15 | 20d | 2019-06-17 | 2019-07-15 | 659d | 0d | 45% | 0% | Não OK | 0% | Ipaba do Paraíso (distrito Santana do Paraíso/MG) |  | 45 |  | 45 | Socioambiental | Não OK |
| 440 | 5.1.1.4.1.6 | Conclusão da Recuperação das Cisternas e Perfuração dos Poços - Ipaba do Paraíso/MG | milestone | 0d | 2020-03-30 | 2020-03-30 | 438, 439 |  |  | 2019-07-15 | 2019-07-15 | 0d | 2019-07-15 | 2019-07-15 | 659d | 0d | 0% |  |  |  |  |  |  |  |  |  |  |
| 441 | 5.1.1.4.2 | Conclusão dos Estudos de Concepção das Melhorias do Sistema de Abastecimento de Água - Ipaba do Paraíso/MG | milestone | 0d | 2020-03-30 | 2020-03-30 | 440 |  |  | 2019-07-15 | 2019-07-15 | 0d | 2019-07-15 | 2019-07-15 | 907d | 82d | 0% |  |  |  |  |  |  |  |  |  |  |

Notes:
- 423: 23/Nov: / - Anuência de 8 proprietários para realizar serviços nos imóveis.
- 429: 28/05/19: / - Projeto executivo da 1a e 2a Entregas previsto para terminar em 10/06. 3a Entrega em 13/08 / 25/Jan19: / - Projeto Executivo dos poços que a Engenharia tem informação: 19/12/18 a 23/04/19. / - Projeto Executivo (3 poços faltantes): 19/03/18 a 13/05/19 (considerando que irá receber as informações de análise da água, etc. até 18/03/19).
- 432: 05/Fev19: / - Informações dos poços foram enviadas ao Licenciamento nesta data pelo Mateus. / 23/Nov: / - Verificar necessidade de licenciamento para os poços das 17 propriedades, há poço existente e novo. / 26/Nov: / - Não iniciado. Aguardando o PG enviar o levantamento detalhado dos poços. Ação em andamento. Ver previsão com o Mateus. / 08/Dez: / - Tipo de licença: Cadastro de uso insignificante.
- 434: 01/Dez: / - Verificar com o PG quais serviços estão sendo previstos nos poços (tubulares/rasos) das propriedades elencadas.
- 437: 22/04/19: Será avaliado se serão 4 poços, já que duas propriedades são no mesmo terreno

| ID | WBS | Task | Type | Duration | Start | Finish | Predecessors | Complete | Remaining | Baseline start | Baseline finish | Baseline duration | Baseline 1 start | Baseline 1 finish | Total slack | Free slack | Text3 | Text4 | Text5 | Text7 | Text15 | Text25 | Text26 | Text27 | Text29 | Text23 | Text9 | Text1 | Text13 | Indicadores MIR |
| --- | --- | --- | --- | --- | --- | --- | --- | --- | --- | --- | --- | --- | --- | --- | --- | --- | --- | --- | --- | --- | --- | --- | --- | --- | --- | --- | --- | --- | --- | --- |
| 442 | 5.1.1.5 | **Engenharia Básica e Detalhada - Poços** |  | 431d | 2018-11-05 A | 2020-07-28 |  | 20% | 346.9d | 2018-11-05 | 2020-07-28 | 431d |  |  | 825d |  |  |  |  |  |  |  |  |  |  |  |  |  |  |  |
| 443 | 5.1.1.5.1 | Aprovar Plano de Trabalho e abrir OSE - Ipaba do Paraíso/MG |  | 15d | 2018-11-05 A | 2018-11-23 A | 422 | 100% |  | 2018-11-05 | 2018-11-23 | 15d | 2018-11-05 | 2018-11-23 |  |  | 100% | 100 | 100 | 100 | 100 | 0% | ok | 0% | Ipaba do Paraíso (distrito Santana do Paraíso/MG) |  |  |  |  |  |
| 444 | 5.1.1.5.2 | Realizar 3º Levantamento Campo - Ipaba do Paraíso/MG |  | 1d | 2019-06-28 A | 2019-06-28 A | 425FS+146d, 443FS+146d | 100% |  | 2019-07-29 | 2019-07-29 | 1d | 2019-07-29 | 2019-07-29 |  |  | 0% |  |  |  |  |  |  |  |  |  |  |  |  |  |
| 445 | 5.1.1.5.3 | Elaborar Projeto Executivo (5 casas - Pendente Perfuração) - Ipaba do Paraíso/MG |  | 66d | 2020-04-24 | 2020-07-28 | 439FS+16d |  |  | 2019-11-27 | 2019-12-31 | 22d |  |  | 825d | 0d |  |  |  |  |  |  |  |  |  |  |  |  |  |  |
| 446 | 5.1.1.5.4 | Elaboração do Projeto Executivo (5 casas - Pendente Perfuração) - Ipaba do Paraíso/MG | milestone | 0d | 2020-07-28 | 2020-07-28 | 445 |  |  | 2019-12-31 | 2019-12-31 | 0d |  |  | 825d | 0d |  |  |  |  |  |  |  |  |  |  |  |  |  |  |
| 447 | 5.1.1.5.5 | Conclusão e Validação da Engenharia - Ipaba do Paraíso/MG | milestone | 0d | 2020-07-28 | 2020-07-28 | 441, 446 |  |  | 2020-01-16 | 2020-01-16 | 0d | 2020-01-16 | 2020-01-16 | 825d |  | 0% |  |  |  |  |  |  |  |  |  |  |  |  |  |
| 448 | 5.1.1.6 | **Fundiária** |  | 443d | 2017-11-20 A | 2019-08-12 A |  | 100% |  | 2017-11-20 | 2019-05-31 | 393d | 2017-11-20 | 2019-05-31 |  |  | 100% | 93 | 100 | 93 | 100 | 0% | ok | 0% | Ipaba do Paraíso (distrito Santana do Paraíso/MG) | Socioambiental |  |  |  |  |
| 449 | 5.1.1.6.1 | Obter Termos de Autorização de Superficiários (Possuidores dos Imóveis) - Ipaba do Paraíso/MG |  | 313d | 2017-11-20 A | 2019-01-31 A | 26 | 100% |  | 2017-11-20 | 2019-01-31 | 313d | 2017-11-20 | 2019-01-31 |  |  | 100% | 100 | 100 | 100 | 100 | 0% | Não OK | 0% | Ipaba do Paraíso (distrito Santana do Paraíso/MG) | Socioambiental | Não OK |  |  |  |
| 450 | 5.1.1.6.2 | Obter confirmação da Vale quanto a posse dos terrenos na área de servidão da empresa - Ipaba do Paraíso/MG |  | 59d | 2019-05-21 A | 2019-08-12 A | 423FS+13d, 449 | 100% |  | 2019-05-02 | 2019-05-31 | 22d | 2019-05-02 | 2019-05-31 |  |  | 100% | 25 | 100 | 25 | 100 |  |  |  |  |  |  |  |  |  |
| 451 | 5.1.1.6.3 | Realizar Cadastro dos Proprietários - Ipaba do Paraíso/MG |  | 102d | 2019-01-02 A | 2019-05-31 A | 26FS+291d | 100% |  | 2019-01-01 | 2019-05-24 | 97d | 2019-01-01 | 2019-05-24 |  |  | 100% | 100 | 100 | 100 | 100 | 0% | Não OK | 0% | Ipaba do Paraíso (distrito Santana do Paraíso/MG) | Socioambiental | Não OK |  |  |  |
| 452 | 5.1.1.6.4 | Conclusão da Regularização Fundiária para as obras de Melhoria do Sistema de Abastecimento da Localidade - Ipaba do Paraíso/MG | milestone | 0d | 2019-08-12 A | 2019-08-12 A | 450, 451, 447 | 100% |  | 2019-05-31 | 2019-05-31 | 0d | 2019-05-31 | 2019-05-31 |  |  | 100% |  | 100 |  | 100 |  |  |  |  |  |  |  |  |  |
| 453 | 5.1.1.7 | **Licenciamento - Poços** |  | 231d | 2019-10-15 A | 2020-09-18 |  | 23% | 176.96d | 2019-10-15 | 2020-09-18 | 231d |  |  | 788d |  |  |  |  |  |  |  |  |  |  |  |  |  |  |  |
| 454 | 5.1.1.7.1 | Obter Autorização para Perfuração (Poços) - Ipaba do Paraíso/MG |  | 51d | 2019-10-15 A | 2019-12-30 A | 450FS+44d, 451FS+44d | 100% |  | 2019-09-13 | 2019-10-14 | 22d |  |  |  |  |  |  |  |  |  |  |  |  |  |  |  | 8888 | 8888888 |  |
| 455 | 5.1.1.7.2 | Obter Outorga/Certidão de Uso Insignificante para Captação Subterrânea (Poços) - Ipaba do Paraíso/MG |  | 167d | 2020-01-20 | 2020-09-18 | 454FS+13d |  |  | 2019-10-15 | 2020-07-08 | 180d |  |  | 540d | 0d |  |  |  |  |  |  |  |  |  |  |  | 8888 | 8888888 |  |
| 456 | 5.1.1.7.3 | Conclusão do Licenciamento Ambiental dos Sistemas Individuais - Ipaba do Paraíso/MG | milestone | 0d | 2020-09-18 | 2020-09-18 | 432, 455 |  |  | 2020-07-08 | 2020-07-08 | 0d | 2018-04-20 | 2018-04-20 | 788d | 0d | 100% | 100 | 100 | 100 | 100 |  |  |  |  |  |  |  |  |  |
| 457 | 5.1.1.8 | **Infraestrutura** |  | 396d | 2020-02-17 | 2021-09-21 |  |  |  | 2020-05-28 | 2021-09-06 | 320d | 2020-05-28 | 2021-09-06 | 539d |  | 0% |  |  |  |  | 0% | ok | 0% | Ipaba do Paraíso (distrito Santana do Paraíso/MG) |  |  |  |  |  |
| 458 | 5.1.1.8.1 | **Obras** |  | 147d | 2020-02-17 | 2020-09-18 |  |  |  | 2020-05-28 | 2020-08-20 | 60d | 2020-05-28 | 2020-08-20 | 617d |  | 0% |  |  |  |  |  |  |  |  |  |  |  |  |  |
| 459 | 5.1.1.8.1.1 | Executar obras dos Sistema Individuais de Abastecimento de Água - Etapa 1 - Ipaba do Paraíso/MG |  | 60d | 2020-02-17 | 2020-05-18 | 430FS+127d |  |  | 2020-05-28 | 2020-08-20 | 60d | 2020-05-28 | 2020-08-20 | 627d | 87d | 0% |  |  |  |  | 0% | ok | 0% | Ipaba do Paraíso (distrito Santana do Paraíso/MG) |  |  |  |  |  |
| 460 | 5.1.1.8.1.2 | Executar obras dos Sistema Individuais de Abastecimento de Água - Etapa 2 - Ipaba do Paraíso/MG |  | 70d | 2020-06-12 | 2020-09-18 | 450, 451, 432, 455FF, 440FF, 430FS+88d, 452 |  |  | 2020-06-12 | 2020-09-18 | 70d |  |  | 540d | 0d |  |  |  |  |  |  |  |  |  |  |  |  |  |  |
| 461 | 5.1.1.8.1.3 | Assinatura de Termo de Entrega das Obras de Melhoria do Sistema de Abastecimento de Água - Ipaba do Paraíso/MG | milestone | 0d | 2020-09-18 | 2020-09-18 | 459, 460, 456 |  |  | 2020-08-20 | 2020-08-20 | 0d | 2020-08-20 | 2020-08-20 | 788d | 540d | 0% |  |  |  |  | 0% | ok | 0% | Ipaba do Paraíso (distrito Santana do Paraíso/MG) |  |  |  |  | CA |
| 462 | 5.1.1.8.2 | **Operação** |  | 249d | 2020-09-21 | 2021-09-21 |  |  |  | 2020-08-21 | 2021-09-06 | 260d | 2020-08-21 | 2021-09-06 | 539d |  | 0% |  |  |  |  | 0% | ok | 0% | Ipaba do Paraíso (distrito Santana do Paraíso/MG) |  |  |  |  |  |
| 463 | 5.1.1.8.2.1 | Realizar Treinamento Operacional do Sistema - Ipaba do Paraíso/MG |  | 5d | 2020-09-21 | 2020-09-25 | 459, 460 |  |  | 2020-08-21 | 2020-08-27 | 5d | 2020-08-21 | 2020-08-27 | 540d | 0d | 0% |  |  |  |  | 0% | ok | 0% | Ipaba do Paraíso (distrito Santana do Paraíso/MG) |  |  |  |  |  |
| 464 | 5.1.1.8.2.2 | Realizar Testes e Pré-operação - Ipaba do Paraíso/MG |  | 14d | 2020-09-28 | 2020-10-16 | 463 |  |  | 2020-08-28 | 2020-09-17 | 14d | 2020-08-28 | 2020-09-17 | 769d |  | 0% |  |  |  |  | 0% | ok | 0% | Ipaba do Paraíso (distrito Santana do Paraíso/MG) |  |  |  |  |  |
| 465 | 5.1.1.8.2.3 | Realizar Acompanhamento da Funcionalidade do Sistema - Sistemas de Abastecimento Individuais - Ipaba do Paraíso (distrito Santana do Paraíso/MG) |  | 365ed | 2020-09-21 | 2021-09-21 | 467SS |  |  | 2020-08-21 | 2021-09-06 | 260d |  |  | 2377.12d | 0d |  |  |  |  |  |  |  |  |  |  |  |  |  |  |

Notes:
- 449: 11/Fev19: / - 17 estruturas em 14 propriedades diferentes. Ex.: dentro de um imóvel mais de uma estrutura. / - Algumas estruturas excluídas por não serem mais elegíveis para receber o SAA (ex.: José de Fátima - não possui necessidade: precisa de água para irrigar plantação). / 01/Fev19: / - Início 18/09/18 / - Fundiário já adquiriu 13/14 Termos de Autorização de Superficiários necessários. / 20/Dez / - Campanha em campo prevista pra iniciar em 15/02/19 e pra terminar em 28/02/19.
- 450: 25/04/19: VALE pediu prazo de 30 dias para autorizar a partir de reunião em 24/04/19 / 21/05/19: Realizado protocolo da documentação fundiária solicitado junto a VALE. VALE não definiu um prazo.
- 451: 21/05/19: Pendente a matrícula dos imóveis / 11/Fev19: / - 17 estruturas em 14 propriedades diferentes. Ex.: dentro de um imóvel mais de uma estrutura. / - Algumas estruturas excluídas por não serem mais elegíveis para receber o SAA (ex.: José de Fátima - não possui necessidade: precisa de água para irrigar plantação). / 01/Fev19: / - Início 18/09/18 - Fim 31/01/19. / - Fundiário já realizou todos os cadastros necessários (14/14). / 20/Dez / - Cadastro necessário para saber quem é o dono da área.
- 452: 03/09: Não há registro dos imóveis (posseiros). Obtidas declarações de posse pelo fundiário. Processo fundiário será reaberto se for necessário para entrega dos Sistemas Individuais
- 455: 03/09/2019: Necessário Verificar se será necessária outorga dos poços ou se pode se considerar Uso Insignificante.
- 462: 23/Nov / - Verificar com o PG como será feita a operação assistida e testes.

| ID | WBS | Task | Type | Duration | Start | Finish | Predecessors | Complete | Remaining | Baseline start | Baseline finish | Baseline duration | Baseline 1 start | Baseline 1 finish | Total slack | Free slack | Text3 | Text25 | Text26 | Text27 | Text29 | Text4 | Text5 | Text7 | Text15 | Text23 | Text9 | Text13 |
| --- | --- | --- | --- | --- | --- | --- | --- | --- | --- | --- | --- | --- | --- | --- | --- | --- | --- | --- | --- | --- | --- | --- | --- | --- | --- | --- | --- | --- |
| 466 | 5.1.1.8.2.4 | **Operação Assistida** |  | 249d | 2020-09-21 | 2021-09-21 |  |  |  | 2020-05-14 | 2020-08-12 | 64d | 2020-05-14 | 2020-08-12 | 539d |  | 0% | 0% | ok | 0% | Pedras (distrito Mariana/MG) |  |  |  |  |  |  |  |
| 467 | 5.1.1.8.2.4.1 | Realizar Operação Assistida |  | 90ed | 2020-09-21 | 2020-12-20 | 463SS |  |  | 2020-05-14 | 2020-08-12 | 3.2mo | 2020-05-14 | 2020-08-12 | 2377.12d | 0d | 0% | 0% | ok | 0% | Pedras (distrito Mariana/MG) |  |  |  |  |  |  |  |
| 468 | 5.1.1.8.2.4.2 | Entrega das obras e conclusão do período de acompanhamento da operação - Barreto/MG | milestone | 0d | 2021-09-21 | 2021-09-21 | 467, 465 |  |  | 2021-09-06 | 2021-09-06 | 0d |  |  | 539d |  |  |  |  |  |  |  |  |  |  |  |  |  |
| 469 | 6 | **Território Médio Rio Doce** |  | 1939d | 2016-03-23 A | 2023-11-22 |  | 28% | 1392.49d | 2016-03-23 | 2022-03-21 | 1523d | 2016-03-23 | 2022-03-21 | 0d |  | 55% | 0% | ok | 0% | Ipaba do Paraíso (distrito Santana do Paraíso/MG) | 30 | 55 | 65 | 46 | Socioambiental |  |  |
| 470 | 6.1 | **Cachoeira Escura (distrito Belo Oriente/MG)** |  | 1249d | 2018-01-16 A | 2023-01-07 |  | 35% | 808.77d | 2016-10-03 | 2022-03-10 | 1378d | 2016-10-03 | 2022-03-10 | 216d |  | 51% | 0% | ok | 0% | Cachoeira Escura (distrito Belo Oriente/MG) | 42 | 51 | 84 | 50 | Socioambiental |  |  |
| 471 | 6.1.1 | **Captação Principal e Melhorias na ETA** |  | 1074d | 2018-03-14 A | 2022-06-25 |  | 29% | 757.92d | 2018-03-14 | 2022-03-10 | 1001d |  |  | 350d |  |  |  |  |  |  |  |  |  |  |  |  |  |
| 472 | 6.1.1.1 | **Estudos de Concepção do Sistema - Etapa 1** |  | 7d | 2018-03-14 A | 2018-03-23 A |  | 100% |  | 2018-03-14 | 2019-05-30 | 310d | 2018-03-14 | 2019-05-30 |  |  | 100% |  |  |  |  | 100 | 100 | 100 | 100 |  |  |  |
| 473 | 6.1.1.1.1 | Declaração de Escopo e Premissas de Projeto (DEPP) concluída - Cachoeira Escura/MG | milestone | 0d | 2018-03-23 A | 2018-03-23 A | 25, 26 | 100% |  | 2018-03-23 | 2018-03-23 | 0d | 2018-03-23 | 2018-03-23 |  |  | 100% | 0% | ok | 0% | Cachoeira Escura (distrito Belo Oriente/MG) | 100 | 100 | 100 | 100 |  |  |  |
| 474 | 6.1.1.1.2 | Aprovação das DEPPs pela Operadora e Prefeitura - Cachoeira Escura/MG | milestone | 0d | 2018-03-14 A | 2018-03-14 A | 25, 26 | 100% |  | 2018-03-14 | 2018-03-14 | 0d | 2018-03-14 | 2018-03-14 |  |  | 100% | 0% | ok | 0% | Cachoeira Escura (distrito Belo Oriente/MG) | 100 | 100 | 100 | 100 |  |  |  |
| 475 | 6.1.1.2 | **Engenharia Básica e Detalhada** |  | 331d | 2018-09-20 A | 2020-01-15 A |  | 100% |  | 2018-07-31 | 2019-09-24 | 292d | 2018-07-31 | 2019-09-24 |  |  | 79% |  |  |  |  | 41 | 79 | 52 | 79 |  |  |  |
| 476 | 6.1.1.2.1 | **Engenharia Captação Principal (Melhorias) - SE 32159** |  | 331d | 2018-09-20 A | 2020-01-15 A |  | 100% |  | 2018-09-20 | 2019-07-23 | 211d | 2018-09-20 | 2019-07-23 |  |  | 91% | 0% | ok | 0% | Cachoeira Escura (distrito Belo Oriente/MG) | 67 | 91 | 88 | 76 | Socioambiental |  |  |
| 477 | 6.1.1.2.1.1 | Aprovar Plano de Trabalho e abrir OSE - Captação Principal - Rio Doce - Cachoeira Escura/MG |  | 35d | 2018-11-22 A | 2019-01-10 A | 473 | 100% |  | 2018-11-22 | 2019-01-10 | 35d | 2018-11-22 | 2019-01-10 |  |  | 100% | 0% | ok | 0% | Cachoeira Escura (distrito Belo Oriente/MG) | 100 | 100 | 100 | 100 |  |  |  |
| 478 | 6.1.1.2.1.2 | Realizar Levantamento de Campo - Captação Principal - Rio Doce - Cachoeira Escura/MG |  | 3d | 2019-02-12 A | 2019-02-14 A | 477 | 100% |  | 2019-02-12 | 2019-02-14 | 3d | 2019-02-12 | 2019-02-14 |  |  | 100% | 0% | Não OK | 0% | Cachoeira Escura (distrito Belo Oriente/MG) | 100 | 100 | 100 | 100 | Socioambiental | Não OK |  |
| 479 | 6.1.1.2.1.3 | Executar Topografia - Captação Principal - Rio Doce - Cachoeira Escura/MG |  | 62d | 2018-09-20 A | 2018-12-14 A | 477 | 100% |  | 2018-09-20 | 2018-12-14 | 62d | 2018-09-20 | 2018-12-14 |  |  | 100% |  |  |  |  | 100 | 100 | 100 | 100 |  |  |  |
| 480 | 6.1.1.2.1.4 | Executar Atividades Preliminares - Projeto Básico - Captação Principal - Rio Doce - Cachoeira Escura/MG |  | 57d | 2019-07-08 A | 2019-09-25 A | 479 | 100% |  | 2018-09-20 | 2018-12-14 | 62d |  |  |  |  |  |  |  |  |  |  |  |  |  |  |  |  |
| 481 | 6.1.1.2.1.5 | Elaborar Projeto Básico - Captação Principal - Rio Doce - Cachoeira Escura/MG |  | 50d | 2019-10-07 A | 2019-12-17 A | 478, 479, 480 | 100% |  | 2018-02-08 | 2018-03-21 | 30d | 2018-02-08 | 2018-03-21 |  |  | 100% |  |  |  |  |  | 100 |  | 100 |  |  |  |
| 482 | 6.1.1.2.1.6 | Aprovar Projeto Básico - Captação Principal - Rio Doce - Cachoeira Escura/MG |  | 18d | 2019-12-18 A | 2020-01-15 A | 481 | 100% |  | 2018-03-01 | 2018-03-30 | 22d |  |  |  |  |  |  |  |  |  |  |  |  |  |  |  | 8888888 |
| 483 | 6.1.1.2.1.7 | Emitir RT/PQ para Suprimentos - Captação Principal - Rio Doce - Cachoeira Escura/MG |  | 10d | 2019-12-03 A | 2019-12-17 A | 481FF | 100% |  | 2019-06-28 | 2019-07-23 | 18d | 2019-06-28 | 2019-07-23 |  |  | 5% | 0% | Não OK | 0% | Cachoeira Escura (distrito Belo Oriente/MG) |  |  |  |  | Socioambiental |  |  |
| 484 | 6.1.1.2.1.8 | Elaborar Projeto Executivo - Captação Principal - Rio Doce - Cachoeira Escura/MG |  | 60d | 2019-09-23 A | 2019-12-17 A | 481FF | 100% |  | 2019-04-22 | 2019-07-23 | 65d | 2019-04-22 | 2019-07-23 |  |  | 73% | 0% | Não OK | 0% | Cachoeira Escura (distrito Belo Oriente/MG) |  | 73 |  | 73 | Socioambiental |  |  |
| 485 | 6.1.1.2.1.9 | Elaboração do Projeto Executivo - Captação Principal - Rio Doce - Cachoeira Escura/MG | milestone | 0d | 2019-12-17 A | 2019-12-17 A | 483, 484 | 100% |  | 2019-07-23 | 2019-07-23 | 0d | 2019-07-23 | 2019-07-23 |  |  | 0% |  |  |  |  |  |  |  |  |  |  |  |
| 486 | 6.1.1.2.2 | **Engenharia Melhorias ETA - Etapa 1** |  | 261d | 2018-10-16 A | 2019-10-28 A |  | 100% |  | 2018-12-10 | 2019-06-28 | 137d | 2018-12-10 | 2019-06-28 |  |  | 100% | 0% | ok | 0% | Cachoeira Escura (distrito Belo Oriente/MG) | 40 | 100 | 40 | 100 | Socioambiental |  |  |
| 487 | 6.1.1.2.2.1 | Aprovar Plano de Trabalho e abrir OSE - Melhorias na ETA - Cachoeira Escura/MG |  | 30d | 2018-12-10 A | 2019-01-21 A |  | 100% |  | 2018-12-10 | 2019-01-30 | 30d | 2018-12-10 | 2019-01-30 |  |  | 100% | 0% | Não OK | 0% | Cachoeira Escura (distrito Belo Oriente/MG) | 100 | 100 | 100 | 100 | Socioambiental | Não OK |  |
| 488 | 6.1.1.2.2.2 | Realizar Levantamento de Campo - Melhorias na ETA - Cachoeira Escura/MG |  | 2d | 2019-02-13 A | 2019-02-14 A | 487 | 100% |  | 2019-02-13 | 2019-02-14 | 2d | 2019-02-13 | 2019-02-14 |  |  | 100% | 0% | ok | 0% | Cachoeira Escura (distrito Belo Oriente/MG) | 100 | 100 | 100 | 100 |  |  |  |
| 489 | 6.1.1.2.2.3 | Executar Topografia - Melhorias na ETA - Cachoeira Escura/MG |  | 30d | 2018-12-19 A | 2019-01-30 A | 487FS-30d | 100% |  | 2018-12-19 | 2019-01-30 | 30d | 2018-12-19 | 2019-01-30 |  |  | 100% |  |  |  |  | 100 | 100 | 100 | 100 |  |  |  |
| 490 | 6.1.1.2.2.4 | Emitir RT/PQ para Suprimentos - Melhorias na ETA - Cachoeira Escura/MG |  | 10d | 2019-10-15 A | 2019-10-28 A | 493FF | 100% |  | 2019-06-14 | 2019-06-28 | 10d | 2019-06-14 | 2019-06-28 |  |  | 100% |  |  |  |  |  | 100 |  | 100 |  |  |  |
| 491 | 6.1.1.2.2.5 | Elaborar Projeto Executivo (Pequenas Melhorias) SE 32219 - Melhorias na ETA - Cachoeira Escura/MG |  | 26d | 2018-10-16 A | 2018-11-20 A |  | 100% |  | 2018-10-16 | 2018-11-20 | 26d | 2018-10-16 | 2018-11-20 |  |  | 100% |  |  |  |  | 100 | 100 | 100 | 100 |  |  |  |

Notes:
- 476: 23/Jan19 / - Será entregue para efeito de Projeto Básico arranjo da estrutura da captação principal. / - Foi acertado com a Engenharia que o projeto básico de captação principal considerará as soluções previstas no DEPP e Diagnóstico, além das alterações já previstas hoje pela ENG (solução de estaqueamento no rio, se plausível).
- 478: 25/Jan19: / - Topografia iniciada em 20/09 e concluída em 14/12/18; Levantamento de campo previsto para iniciar em 12/02 e pra finalizar em 14/02/19.
- 486: 25/Jan19: / - Considerado no Cronograma da Engenharia 2 projetos referentes a ETA: PEQUENAS MELHORIAS NA ETA (concluído em 20/11/18) e REDIMENSIONAR BOMBAS ÁGUA / RELOCAR PAINEL ELEVATÓRIA - ETA (em desenvolvimento). As datas deste último é que estão sendo consideradas no Cronograma Master do PG. / - Não estão previstas nesse CR eventuais alterações que se façam necessárias devido a qualidade da água da captação alternativa a ser definida pela Copasa. Qualquer alteração poderá implicar em aumento de prazo no CR.

| ID | WBS | Task | Type | Duration | Start | Finish | Predecessors | Complete | Remaining | Baseline start | Baseline finish | Baseline duration | Baseline 1 start | Baseline 1 finish | Total slack | Free slack | Text3 | Text4 | Text5 | Text7 | Text15 | Text25 | Text26 | Text27 | Text29 | Text23 | Text9 | Text13 | Indicadores MIR |
| --- | --- | --- | --- | --- | --- | --- | --- | --- | --- | --- | --- | --- | --- | --- | --- | --- | --- | --- | --- | --- | --- | --- | --- | --- | --- | --- | --- | --- | --- |
| 492 | 6.1.1.2.3 | **Engenharia Melhorias ETA - Etapa 2** |  | 164d | 2019-04-01 A | 2019-11-22 A |  | 100% |  | 2019-04-01 | 2019-11-11 | 156d |  |  |  |  |  |  |  |  |  |  |  |  |  |  |  |  |  |
| 493 | 6.1.1.2.3.1 | Elaborar Projeto Executivo (Redimensionamento das Bombas e relocação do painel) SE 32158 - Melhorias na ETA - Cachoeira Escura/MG |  | 164d | 2019-04-01 A | 2019-11-22 A | 488, 489 | 100% |  | 2019-04-23 | 2019-06-28 | 47d | 2019-04-23 | 2019-06-28 |  |  | 100% | 28 | 100 | 28 | 100 | 0% | ok | 0% | Cachoeira Escura (distrito Belo Oriente/MG) |  |  |  |  |
| 494 | 6.1.1.2.3.2 | Elaboração do Projeto Executivo - Melhorias na ETA - Cachoeira Escura/MG | milestone | 0d | 2019-11-22 A | 2019-11-22 A | 491, 493 | 100% |  | 2019-06-28 | 2019-06-28 | 0d | 2019-06-28 | 2019-06-28 |  |  | 100% |  | 100 |  | 100 |  |  |  |  |  |  |  |  |
| 495 | 6.1.1.3 | **Fundiária** |  | 197d | 2018-10-18 A | 2019-07-31 A |  | 100% |  | 2018-03-23 | 2019-10-23 | 405d | 2018-03-23 | 2019-10-23 |  |  | 79% | 60 | 79 | 83 | 72 | 0% | ok | 0% | Cachoeira Escura (distrito Belo Oriente/MG) | Socioambiental |  |  |  |
| 496 | 6.1.1.3.1 | Captação Principal - Anuência Prefeitura para execução da obra no local - Cachoeira Escura/MG |  | 197d | 2018-10-18 A | 2019-07-31 A | 473FS+209ed | 100% |  | 2019-04-29 | 2019-06-10 | 30d | 2019-04-29 | 2019-06-10 |  |  | 100% |  | 100 |  | 100 | 0% | Não OK | 0% | Cachoeira Escura (distrito Belo Oriente/MG) | Socioambiental | Não OK |  |  |
| 497 | 6.1.1.3.2 | Conclusão da Regularização Fundiária para as obras de Melhoria do Sistema de Abastecimento da Localidade - Cachoeira Escura/MG | milestone | 0d | 2019-07-31 A | 2019-07-31 A | 496 | 100% |  | 2019-10-23 | 2019-10-23 | 0d | 2019-10-23 | 2019-10-23 |  |  | 0% |  |  |  |  |  |  |  |  |  |  |  |  |
| 498 | 6.1.1.4 | **Licenciamento** |  | 208d | 2020-01-16 | 2020-11-16 |  |  |  | 2018-01-16 | 2019-10-23 | 453d | 2018-01-16 | 2019-10-23 | 351d |  | 81% | 90 | 81 | 99 | 91 | 0% | ok | 0% | Cachoeira Escura (distrito Belo Oriente/MG) | Socioambiental |  |  |  |
| 499 | 6.1.1.4.1 | Obter Outorga para Adequação da Captação no Rio Doce - Captação Principal - Cachoeira Escura/MG |  | 208d | 2020-01-16 | 2020-11-16 | 482, 496 |  |  | 2019-06-10 | 2019-10-23 | 96d | 2019-06-10 | 2019-10-23 | 351d | 0d | 14% |  | 14 |  | 14 | 0% | Não OK | 0% | Cachoeira Escura (distrito Belo Oriente/MG) | Socioambiental |  |  |  |
| 500 | 6.1.1.4.2 | **DAIA para Captação Principal** |  | 190d | 2020-01-16 | 2020-10-20 |  |  |  | 2019-11-20 | 2020-08-26 | 190d |  |  | 359d |  |  |  |  |  |  |  |  |  |  |  |  |  |  |
| 501 | 6.1.1.4.2.1 | Protocolar FCE e documentos do FOB - Cachoeira Escura/MG |  | 10d | 2020-01-16 | 2020-01-29 | 482 |  |  | 2019-11-20 | 2019-12-03 | 10d |  |  | 359d | 0d |  |  |  |  |  |  |  |  |  |  |  |  |  |
| 502 | 6.1.1.4.2.2 | Acompanhar Processo Junto ao Órgão - Pedido de Informação Complementar - Cachoeira Escura/MG |  | 180d | 2020-01-30 | 2020-10-20 | 501 |  |  | 2019-12-04 | 2020-08-26 | 180d |  |  | 359d | 0d |  |  |  |  |  |  |  |  |  |  |  |  |  |
| 503 | 6.1.1.4.2.3 | Obtenção da DAIA para Captação Principal - Captação rio Doce - Cachoeira Escura/MG | milestone | 0d | 2020-10-20 | 2020-10-20 | 502 |  |  | 2020-08-26 | 2020-08-26 | 0d |  |  | 359d | 8d |  |  |  |  |  |  |  |  |  |  |  |  |  |
| 504 | 6.1.1.4.3 | Conclusão do Licenciamento Ambiental da Localidade - Cahoeira Escura/MG | milestone | 0d | 2020-11-16 | 2020-11-16 | 499, 503 |  |  | 2019-10-23 | 2019-10-23 | 0d | 2019-10-23 | 2019-10-23 | 749d |  | 0% |  |  |  |  |  |  |  |  |  |  |  |  |
| 505 | 6.1.1.5 | **Infraestrutura** |  | 803d | 2019-04-03 A | 2022-06-25 |  | 5% | 763.61d | 2016-10-03 | 2022-03-10 | 1378d | 2016-10-03 | 2022-03-10 | 350d |  | 51% |  | 51 | 20 | 20 | 0% | ok | 0% | Cachoeira Escura (distrito Belo Oriente/MG) |  |  |  |  |
| 506 | 6.1.1.5.1 | **Obras - Etapa 1** |  | 83d | 2019-04-03 A | 2019-08-01 A |  | 100% |  | 2016-10-03 | 2021-02-24 | 1118d | 2016-10-03 | 2021-02-24 |  |  | 63% |  | 63 | 45 | 20 |  |  |  |  |  |  |  |  |
| 507 | 6.1.1.5.1.1 | Executar pequenas Melhorias na ETA (Urbanização)- Cachoeira Escura/MG |  | 83d | 2019-04-03 A | 2019-08-01 A | 491FS+91d | 100% |  | 2019-04-03 | 2019-07-15 | 70d |  |  |  |  |  |  |  |  |  |  |  |  |  |  |  |  |  |
| 508 | 6.1.1.5.2 | **Obras - Etapa 2** |  | 294d | 2020-04-20 | 2021-06-25 |  |  |  | 2019-06-21 | 2020-11-09 | 346d |  |  | 495d |  |  |  |  |  |  |  |  |  |  |  |  |  |  |
| 509 | 6.1.1.5.2.1 | Contrato Guarda-Chuva(Captações e Melhorias ETA) - Cachoeira Escura/MG | milestone | 0d | 2020-04-20 | 2020-04-20 | 483FS+82d, 485, 490, 491, 493, 494 |  |  | 2019-06-21 | 2019-10-23 | 0d | 2019-06-21 | 2019-10-23 | 570d | 0d | 6% |  |  |  |  | 0% | ok | 0% | Cachoeira Escura (distrito Belo Oriente/MG) |  |  | 8888888 |  |
| 510 | 6.1.1.5.2.2 | Executar Captação Principal (Melhorias - rio Doce) - Cachoeira Escura/MG |  | 150d | 2020-11-17 | 2021-06-25 | 484, 496, 499, 503FS+10d, 497 |  |  | 2019-10-23 | 2021-02-24 | 330d | 2019-10-23 | 2021-02-24 | 351d | 0d | 0% |  |  |  |  | 0% | ok | 0% | Cachoeira Escura (distrito Belo Oriente/MG) |  |  |  |  |
| 511 | 6.1.1.5.2.3 | Executar obras de Melhorias de ETA (Elevatórias) - Cachoeira Escura/MG |  | 75d | 2020-04-22 | 2020-08-06 | 493, 509 |  |  | 2019-10-24 | 2020-11-09 | 258d | 2019-10-24 | 2020-11-09 | 570d | 219d | 0% |  |  |  |  | 0% | ok | 0% | Cachoeira Escura (distrito Belo Oriente/MG) |  |  | 8888888 |  |
| 512 | 6.1.1.5.2.4 | Assinatura de Termo de Entrega das Obras de Melhoria do Sistema de Abastecimento de Água - Cachoeira Escura/MG | milestone | 0d | 2021-06-25 | 2021-06-25 | 507, 510, 511 |  |  | 2020-11-09 | 2020-11-09 | 0d | 2021-02-24 | 2021-02-24 | 599d | 351d | 0% |  |  |  |  | 0% | ok | 0% | Cachoeira Escura (distrito Belo Oriente/MG) |  |  |  | ETA |
| 513 | 6.1.1.5.3 | **Operação** |  | 249d | 2021-06-25 | 2022-06-25 |  |  |  | 2021-02-25 | 2022-03-10 | 260d | 2021-02-25 | 2022-03-10 | 350d |  | 0% |  |  |  |  | 0% | ok | 0% | Cachoeira Escura (distrito Belo Oriente/MG) |  |  |  |  |
| 514 | 6.1.1.5.3.1 | Realizar Treinamento Operacional do Sistema - Cachoeira Escura/MG |  | 5d | 2021-06-28 | 2021-07-02 | 510, 511 |  |  | 2021-02-25 | 2021-03-03 | 5d | 2021-02-25 | 2021-03-03 | 580d | 0d | 0% |  |  |  |  | 0% | ok | 0% | Cachoeira Escura (distrito Belo Oriente/MG) |  |  |  |  |
| 515 | 6.1.1.5.3.2 | Realizar Testes e Pré-operação - Cachoeira Escura/MG |  | 14d | 2021-07-05 | 2021-07-22 | 514 |  |  | 2021-03-04 | 2021-03-23 | 14d | 2021-03-04 | 2021-03-23 | 580d |  | 0% |  |  |  |  | 0% | ok | 0% | Cachoeira Escura (distrito Belo Oriente/MG) |  |  |  |  |
| 516 | 6.1.1.5.3.3 | Realizar Acompanhamento da Funcionalidade do Sistema - Captação Principal e Melhorias na ETA - Cachoeira Escura (distrito Belo Oriente/MG) |  | 365ed | 2021-06-25 | 2022-06-25 | 518SS |  |  | 2021-02-25 | 2022-03-10 | 260d |  |  | 1545d |  |  |  |  |  |  |  |  |  |  |  |  |  |  |

Notes:
- 496: 30/Jan19: / - Após pesquisa na SPU (Secretaria de Patrimônio da União) informado que a área pertence a Federação. Jurídico emitirá ofício informativo para Prefeitura de Belo Oriente para confirmar entendimento e continuar as tratativas junto a Federação. / 23/Nov: / - A negociação da locação da captação superficial (em área da CENIBRA) depende APENAS da assinatura pela Prefeitura reconhecendo a área como propriedade do município.
- 499: 22/Nov: / - Data prevista para protocolo do processo na ANA: 28/Mai/19. / 26/Nov: / - Necessário receber o projeto georreferenciado e liberação fundiária (anuência proprietário + documentos do imóvel).

| ID | WBS | Task | Type | Duration | Start | Finish | Predecessors | Complete | Remaining | Baseline start | Baseline finish | Baseline duration | Baseline 1 start | Baseline 1 finish | Total slack | Free slack | Text3 | Text25 | Text26 | Text27 | Text29 | Text4 | Text5 | Text7 | Text15 |
| --- | --- | --- | --- | --- | --- | --- | --- | --- | --- | --- | --- | --- | --- | --- | --- | --- | --- | --- | --- | --- | --- | --- | --- | --- | --- |
| 517 | 6.1.1.5.3.4 | **Operação Assistida** |  | 63d | 2021-06-25 | 2021-09-23 |  |  |  | 2021-02-25 | 2021-05-27 | 64d | 2021-02-25 | 2021-05-27 | 350d |  | 0% | 0% | ok | 0% | Cachoeira Escura (distrito Belo Oriente/MG) |  |  |  |  |
| 518 | 6.1.1.5.3.4.1 | Realizar Operação Assistida - Cachoeira Escura/MG |  | 90ed | 2021-06-25 | 2021-09-23 | 510, 511 |  |  | 2021-02-25 | 2021-05-27 | 3.2mo | 2021-02-25 | 2021-05-27 | 1545d | 0d | 0% | 0% | ok | 0% | Cachoeira Escura (distrito Belo Oriente/MG) |  |  |  |  |
| 519 | 6.1.2 | **Captação Alternativa** |  | 1161d | 2018-01-16 A | 2022-08-30 |  | 55% | 523.33d | 2018-01-16 | 2022-03-10 | 1042d |  |  | 304d |  |  |  |  |  |  |  |  |  |  |
| 520 | 6.1.2.1 | **Estudos de Concepção do Sistema - Etapa 1** |  | 287d | 2018-03-14 A | 2019-04-26 A |  | 100% |  | 2018-03-14 | 2019-05-30 | 310d | 2018-03-14 | 2019-05-30 |  |  | 100% |  |  |  |  | 100 | 100 | 100 | 100 |
| 521 | 6.1.2.1.1 | Declaração de Escopo e Premissas de Projeto (DEPP) concluída - Cachoeira Escura/MG | milestone | 0d | 2018-03-23 A | 2018-03-23 A | 25, 26 | 100% |  | 2018-03-23 | 2018-03-23 | 0d | 2018-03-23 | 2018-03-23 |  |  | 100% | 0% | ok | 0% | Cachoeira Escura (distrito Belo Oriente/MG) | 100 | 100 | 100 | 100 |
| 522 | 6.1.2.1.2 | Aprovação das DEPPs pela Operadora e Prefeitura - Cachoeira Escura/MG | milestone | 0d | 2018-03-14 A | 2018-03-14 A | 25, 26 | 100% |  | 2018-03-14 | 2018-03-14 | 0d | 2018-03-14 | 2018-03-14 |  |  | 100% | 0% | ok | 0% | Cachoeira Escura (distrito Belo Oriente/MG) | 100 | 100 | 100 | 100 |
| 523 | 6.1.2.1.3 | Revisar Definições - Cachoeira Escura/MG |  | 273d | 2018-03-23 A | 2019-04-22 A | 521 | 100% |  | 2018-03-23 | 2019-04-22 | 273d | 2018-03-23 | 2019-04-22 |  |  | 100% | 0% | ok | 0% | Cachoeira Escura (distrito Belo Oriente/MG) | 100 | 100 | 100 | 100 |
| 524 | 6.1.2.1.4 | **Serviços em Poços Tubulares (Poço Interligado a ETA)** |  | 247d | 2018-05-09 A | 2019-04-26 A |  | 100% |  | 2018-05-09 | 2019-05-30 | 270d | 2018-05-09 | 2019-05-30 |  |  | 100% | 0% | ok | 0% | Cachoeira Escura (distrito Belo Oriente/MG) | 100 | 100 | 100 | 100 |
| 525 | 6.1.2.1.4.1 | Realizar Perfilagem 1 (do poço interligado a ETA) - Cachoeira Escura/MG |  | 2d | 2018-05-09 A | 2018-05-10 A | 521FS+33d | 100% |  | 2018-05-09 | 2018-05-10 | 2d | 2018-05-09 | 2018-05-10 |  |  | 100% | 0% | ok | 0% | Cachoeira Escura (distrito Belo Oriente/MG) | 100 | 100 | 100 | 100 |
| 526 | 6.1.2.1.4.2 | Realizar Recuperação do poço interligado a ETA - Cachoeira Escura/MG |  | 7d | 2018-09-04 A | 2018-09-12 A | 525 | 100% |  | 2018-09-04 | 2018-09-12 | 7d | 2018-09-04 | 2018-09-12 |  |  | 100% | 0% | ok | 0% | Cachoeira Escura (distrito Belo Oriente/MG) | 100 | 100 | 100 | 100 |
| 527 | 6.1.2.1.4.3 | Realizar Perfilagem 2 (do poço interligado a ETA) - Cachoeira Escura/MG |  | 2d | 2018-08-23 A | 2018-08-24 A | 526 | 100% |  | 2018-08-23 | 2018-08-24 | 2d | 2018-08-23 | 2018-08-24 |  |  | 100% | 0% | ok | 0% | Cachoeira Escura (distrito Belo Oriente/MG) | 100 | 100 | 100 | 100 |
| 528 | 6.1.2.1.4.4 | Elaborar Relatório Técnico - Cachoeira Escura/MG |  | 6d | 2018-11-13 A | 2018-11-20 A | 525, 526FS+44d, 527 | 100% |  | 2018-11-13 | 2018-11-20 | 6d | 2018-11-13 | 2018-11-20 |  |  | 100% | 0% | ok | 0% | Cachoeira Escura (distrito Belo Oriente/MG) | 100 | 100 | 100 | 100 |
| 529 | 6.1.2.1.4.5 | Realizar Laudo de Serviços de Coleta e Análise de Água - Poço interligado a ETA - 1ª Campanha de amostragem - Cachoeira Escura/MG |  | 22d | 2018-11-07 A | 2018-12-06 A | 527FS+52d | 100% |  | 2018-11-07 | 2018-12-06 | 22d | 2018-11-07 | 2018-12-06 |  |  | 100% | 0% | ok | 0% | Cachoeira Escura (distrito Belo Oriente/MG) | 100 | 100 | 100 | 100 |
| 530 | 6.1.2.1.4.6 | Realizar Laudo de Serviços de Coleta e Análise de Água - Poço interligado a ETA - Nova campanha de amostragem - Cachoeira Escura/MG |  | 19d | 2019-03-29 A | 2019-04-26 A | 523FS-15d, 528 | 100% |  | 2018-12-06 | 2019-01-04 | 22d | 2018-12-06 | 2019-01-04 |  |  | 100% | 0% | ok | 0% | Cachoeira Escura (distrito Belo Oriente/MG) | 100 | 100 | 100 | 100 |
| 531 | 6.1.2.1.4.7 | Conclusão dos Serviços em Poços - Poço interligado a ETA - Cachoeira Escura/MG | milestone | 0d | 2019-04-26 A | 2019-04-26 A | 530 | 100% |  | 2019-05-30 | 2019-05-30 | 0d | 2019-05-30 | 2019-05-30 |  |  | 100% |  |  |  |  | 100 | 100 | 100 | 100 |
| 532 | 6.1.2.2 | **Estudos de Concepção do Sistema - Etapa 2** |  | 33d | 2019-05-02 A | 2019-06-17 A |  | 100% |  | 2019-05-02 | 2019-06-17 | 33d |  |  |  |  |  |  |  |  |  |  |  |  |  |
| 533 | 6.1.2.2.1 | **Serviços em Poços Tubulares (3 poços tubulares: 2 COPASA + 1 CENIBRA)** |  | 33d | 2019-05-02 A | 2019-06-17 A |  | 100% |  | 2019-04-23 | 2019-05-20 | 19d | 2019-04-23 | 2019-05-20 |  |  | 100% |  |  |  |  | 100 | 100 | 100 | 100 |
| 534 | 6.1.2.2.1.1 | Realizar Perfilagem - 3 Poços - Cachoeira Escura/MG |  | 8d | 2019-05-02 A | 2019-05-13 A | 523FS+6d | 100% |  | 2019-04-23 | 2019-04-24 | 2d | 2019-04-23 | 2019-04-24 |  |  | 100% |  |  |  |  | 100 | 100 | 100 | 100 |
| 535 | 6.1.2.2.1.2 | Realizar Recuperação - 3 Poços - Cachoeira Escura/MG |  | 7d | 2019-05-03 A | 2019-05-13 A | 534FS-7d | 100% |  | 2019-04-25 | 2019-05-06 | 7d | 2019-04-25 | 2019-05-06 |  |  | 100% |  |  |  |  | 100 | 100 | 100 | 100 |
| 536 | 6.1.2.2.1.3 | Realizar Teste de bombeamento - 3 Poços - Cachoeira Escura/MG |  | 3d | 2019-05-09 A | 2019-05-13 A | 535FS-3d | 100% |  | 2019-05-07 | 2019-05-09 | 3d | 2019-05-07 | 2019-05-09 |  |  | 100% |  |  |  |  | 100 | 100 | 100 | 100 |
| 537 | 6.1.2.2.1.4 | Realizar Teste de interferência (Poços COPASA) - 3 Poços - Cachoeira Escura/MG |  | 1d | 2019-05-13 A | 2019-05-13 A | 536FS-1d | 100% |  | 2019-05-10 | 2019-05-10 | 1d | 2019-05-10 | 2019-05-10 |  |  | 100% |  |  |  |  | 100 | 100 | 100 | 100 |
| 538 | 6.1.2.2.1.5 | Elaborar Relatóro Técnico - 3 Poços - Cachoeira Escura/MG |  | 25d | 2019-05-14 A | 2019-06-17 A | 537 | 100% |  | 2019-05-13 | 2019-05-20 | 6d | 2019-05-13 | 2019-05-20 |  |  | 100% |  |  |  |  | 100 | 100 | 100 | 100 |
| 539 | 6.1.2.2.1.6 | Conclusão dos Serviços em Poços - 3 Poços - Cachoeira Escura/MG | milestone | 0d | 2019-06-17 A | 2019-06-17 A | 538 | 100% |  | 2019-05-20 | 2019-05-20 | 0d | 2019-05-20 | 2019-05-20 |  |  | 100% |  |  |  |  | 100 | 100 | 100 | 100 |
| 540 | 6.1.2.2.2 | Conclusão dos Estudos de Concepção das Melhorias do Sistema de Abastecimento de Água - Cachoeira Escura/MG | milestone | 0d | 2019-06-17 A | 2019-06-17 A | 531, 539 | 100% |  | 2019-05-20 | 2019-05-20 | 0d | 2019-05-20 | 2019-05-20 |  |  | 100% |  |  |  |  | 100 | 100 | 100 | 100 |

Notes:
- 523: 25/Jan19: / - Aguardando tratativas da Copasa junto a Cenibra referente a disponibilização de um novo poço para executar os serviços necessários (perfilagem, análise da água, etc.) em substituição aos 3 Poços da Copasa. / 06/Dez: / - Aguardando retorno da COPASA.
- 525: 06/Dez: / - Realizada Perfilagem Ótica para diagnosticar o estado interno do poço.
- 526: 06/Dez: / - Realizado novo revestimento do poço com base no resultado da Perfilagem 1.
- 527: 06/Dez: / - Perfilagem realizada para atestar o resultado do serviço de Recuperação.
- 529: 21/Dez / - Não considerado o laudo com resultado da água emitido em 20/12/18. Aguardando a emissão de outro laudo, conforme instruções dadas pelo Thales por e-mail nessa mesma data. / 05/Dez: / - Coleta prevista para 06/12/18, conforme e-mail do Thiago em 30/11/18. / - Poços locados em terras de 3 diferentes proprietários (Fundiário): / COL_BCE_01 : Poço perfurado pela Fundação que se encontra dentro da área da ETA da COPASA (poço existente/interligado a ETA) / COL_BCE_02 : Poço perfurado pela COPASA que se encontra dentro da área da CENIBRA (análise de viabilidade para uso como captação alternativa em complemento ao poço interligado). / COL_BCE_03 : Poço perfurado pela COPASA que se encontra dentro da área do Sr. Agnaldo José de Souza (análise de viabilidade para uso como captação alternativa em complemento ao poço interligado). / COL_BCE_04 : Poço perfurado pela COPASA que se encontra dentro da área do Sr. Agnaldo José de Souza (análise de viabilidade para uso como captação alternativa em complemento ao poço interligado). / 21/Dez / - Não considerado o laudo com resultado da água emitido em 20/12/18. Aguardando a emissão de outro laudo, conforme instruções dadas pelo Thales por e-mail nessa mesma data.
- 530: 23/05/19: Coleta já foi realizada,
- 536: 23/05/19: Foram realizados os testes em dois poços. Será considerado o laudo realizado anteriormente pela copasa para o poço C01.

| ID | WBS | Task | Type | Duration | Start | Finish | Predecessors | Complete | Remaining | Baseline start | Baseline finish | Baseline duration | Baseline 1 start | Baseline 1 finish | Total slack | Free slack | Text3 | Text4 | Text5 | Text7 | Text15 | Text25 | Text26 | Text27 | Text29 | Text23 |
| --- | --- | --- | --- | --- | --- | --- | --- | --- | --- | --- | --- | --- | --- | --- | --- | --- | --- | --- | --- | --- | --- | --- | --- | --- | --- | --- |
| 541 | 6.1.2.3 | **Engenharia Básica e Detalhada** |  | 472d | 2018-07-31 A | 2020-06-18 |  | 52% | 224.35d | 2018-07-31 | 2019-09-24 | 292d | 2018-07-31 | 2019-09-24 | 425d |  | 79% | 41 | 79 | 52 | 79 |  |  |  |  |  |
| 542 | 6.1.2.3.1 | **Engenharia Captação Alternativa (3 novos poços) - SE 32316** |  | 472d | 2018-07-31 A | 2020-06-18 |  | 52% | 224.35d | 2018-07-31 | 2019-09-02 | 276d | 2018-07-31 | 2019-09-02 | 425d |  | 83% | 23 | 83 | 29 | 78 | 0% | ok | 0% | Cachoeira Escura (distrito Belo Oriente/MG) |  |
| 543 | 6.1.2.3.1.1 | Elaboração do Projeto Executivo - Adequação do Poço Interligado a ETA- Cachoeira Escura/MG | milestone | 0d | 2018-07-31 A | 2018-07-31 A | 521 | 100% |  | 2018-07-31 | 2018-07-31 | 0d | 2018-07-31 | 2018-07-31 |  |  | 100% | 100 | 100 | 100 | 100 |  |  |  |  |  |
| 544 | 6.1.2.3.1.2 | Aprovar Plano de Trabalho e abrir OSE - Captação Alternativa - 3 novos poços - Cachoeira Escura/MG |  | 53d | 2019-04-16 A | 2019-07-03 A | 523 | 100% |  | 2019-04-16 | 2019-04-30 | 9d | 2019-04-16 | 2019-04-30 |  |  | 100% | 25 | 100 | 25 | 100 | 0% | ok | 0% | Cachoeira Escura (distrito Belo Oriente/MG) |  |
| 545 | 6.1.2.3.1.3 | Executar Topografia - Captação Alternativa - 3 novos poços - Cachoeira Escura/MG |  | 40d | 2019-01-07 A | 2019-03-01 A | 544 | 100% |  | 2019-01-07 | 2019-03-01 | 40d | 2019-01-07 | 2019-03-01 |  |  | 100% | 100 | 100 | 100 | 100 |  |  |  |  |  |
| 546 | 6.1.2.3.1.4 | Elaborar Arranjo para obtenção de Dados de Entrada Licenciamento e Fundiário - Captação Alternativa - 3 novos poços - Cachoeira Escura/MG |  | 58d | 2019-07-01 A | 2019-09-19 A | 539, 540FS+8d, 545 | 100% |  | 2019-05-17 | 2019-06-21 | 25d | 2019-05-17 | 2019-06-21 |  |  | 100% |  | 100 |  | 100 | 0% | ok | 0% | Cachoeira Escura (distrito Belo Oriente/MG) |  |
| 547 | 6.1.2.3.1.5 | Elaborar Projeto Básico - Captação Alternativa - 3 novos poços - Cachoeira Escura/MG |  | 74d | 2019-11-01 A | 2020-02-19 | 546FS+30d | 20% | 59.2d | 2018-02-08 | 2018-03-21 | 30d | 2018-02-08 | 2018-03-21 | 305d | 0d | 100% |  | 100 |  | 100 |  |  |  |  |  |
| 548 | 6.1.2.3.1.6 | Aprovar Projeto Básico - Captação Alternativa - 3 novos poços - Cachoeira Escura/MG |  | 22d | 2020-02-20 | 2020-03-25 | 547 |  |  | 2020-02-20 | 2020-03-25 | 22d |  |  | 305d | 0d |  |  |  |  |  |  |  |  |  |  |
| 549 | 6.1.2.3.1.7 | Emitir RT/PQ para Suprimentos - Captação Alternativa - 3 novos poços - Cachoeira Escura/MG |  | 12d | 2020-06-02 | 2020-06-18 | 548, 550FF |  |  | 2019-06-14 | 2019-06-28 | 10d | 2019-06-14 | 2019-06-28 | 425d | 0d | 100% |  | 100 |  | 100 | 0% | ok | 0% | Cachoeira Escura (distrito Belo Oriente/MG) |  |
| 550 | 6.1.2.3.1.8 | Elaborar Projeto Executivo - Captação Alternativa - 3 novos poços - Cachoeira Escura/MG |  | 57d | 2020-03-26 | 2020-06-18 | 548 |  |  | 2019-05-31 | 2019-09-02 | 65d | 2019-05-31 | 2019-09-02 | 425d | 0d | 30% |  | 30 |  | 30 | 0% | ok | 0% | Cachoeira Escura (distrito Belo Oriente/MG) |  |
| 551 | 6.1.2.3.1.9 | Elaboração do Projeto Executivo - Captação Alternativa - 3 novos poços - Cachoeira Escura/MG | milestone | 0d | 2020-06-18 | 2020-06-18 | 548, 549, 550 |  |  | 2019-09-02 | 2019-09-02 | 0d | 2019-09-02 | 2019-09-02 | 425d | 0d | 0% |  |  |  |  |  |  |  |  |  |
| 552 | 6.1.2.4 | **Fundiária** |  | 684d | 2018-03-23 A | 2020-12-08 |  | 50% | 342d | 2018-03-23 | 2019-10-23 | 405d | 2018-03-23 | 2019-10-23 | 305d |  | 79% | 60 | 79 | 83 | 72 | 0% | ok | 0% | Cachoeira Escura (distrito Belo Oriente/MG) | Socioambiental |
| 553 | 6.1.2.4.1 | Obter Termo de Autorização para estudos (Poços COPASA) - Captação Alternativa - Cachoeira Escura/MG |  | 177d | 2018-03-23 A | 2018-11-26 A | 521 | 100% |  | 2018-03-23 | 2018-11-26 | 177d | 2018-03-23 | 2018-11-26 |  |  | 100% | 100 | 100 | 100 | 100 | 0% | ok | 0% | Cachoeira Escura (distrito Belo Oriente/MG) |  |
| 554 | 6.1.2.4.2 | Captação Alternativa - Desimpedimento de área adutora (Poços Copasa) - Cachoeira Escura/MG |  | 177d | 2020-03-26 | 2020-12-08 | 546, 548 |  |  | 2019-06-21 | 2019-10-23 | 88d | 2019-06-21 | 2019-10-23 | 305d | 0d | 6% |  |  |  |  | 0% | ok | 0% | Cachoeira Escura (distrito Belo Oriente/MG) |  |
| 555 | 6.1.2.4.3 | Conclusão da Regularização Fundiária para as obras de Melhoria do Sistema de Abastecimento da Localidade - Cachoeira Escura/MG | milestone | 0d | 2020-12-08 | 2020-12-08 | 553, 554 |  |  | 2019-10-23 | 2019-10-23 | 0d | 2019-10-23 | 2019-10-23 | 305d | 0d | 0% |  |  |  |  |  |  |  |  |  |
| 556 | 6.1.2.5 | **Licenciamento** |  | 506d | 2018-01-16 A | 2020-01-13 |  | 99% | 2.62d | 2018-01-16 | 2019-10-23 | 453d | 2018-01-16 | 2019-10-23 | 531d |  | 81% | 90 | 81 | 99 | 91 | 0% | ok | 0% | Cachoeira Escura (distrito Belo Oriente/MG) | Socioambiental |
| 557 | 6.1.2.5.1 | Obter Outorga para Captação Alternativa (Poço dentro da ETA e UTR) - Cachoeira Escura/MG |  | 367ed | 2018-01-16 A | 2019-01-18 A | 553FS-225d | 100% |  | 2018-01-16 | 2019-01-18 | 367ed | 2018-01-16 | 2019-01-18 |  |  | 100% | 100 | 100 | 100 | 100 |  |  |  |  |  |
| 558 | 6.1.2.5.2 | **DAIA para Captação Alternativa (Poço dentro da ETA e UTR)** |  | 506d | 2018-01-16 A | 2020-01-13 |  | 98% | 8.33d | 2018-01-16 | 2019-09-16 | 426d | 2018-01-16 | 2019-09-16 | 531d |  | 87% | 85 | 87 | 98 | 87 | 0% | ok | 0% | Cachoeira Escura (distrito Belo Oriente/MG) |  |
| 559 | 6.1.2.5.2.1 | Protocolar FCE e documentos do FOB - Cachoeira Escura/MG |  | 1d | 2018-01-16 A | 2018-01-16 A |  | 100% |  | 2018-01-16 | 2018-01-16 | 1d | 2018-01-16 | 2018-01-16 |  |  | 100% | 100 | 100 | 100 | 100 |  |  |  |  |  |
| 560 | 6.1.2.5.2.2 | Acompanhar Processo Junto ao Órgão - Pedido de Informação Complementar - Cachoeira Escura/MG |  | 283d | 2018-01-17 A | 2019-02-18 A | 559 | 100% |  | 2018-01-17 | 2019-02-18 | 283d | 2018-01-17 | 2019-02-18 |  |  | 100% | 100 | 100 | 100 | 100 |  |  |  |  |  |
| 561 | 6.1.2.5.2.3 | Definir proposta de compensação ambiental com Prefeitura de GV - Cachoeira Escura/MG |  | 44d | 2019-02-19 A | 2019-04-26 A | 560 | 100% |  | 2019-02-19 | 2019-04-26 | 44d | 2019-02-19 | 2019-04-26 |  |  | 100% | 100 | 100 | 100 | 100 |  |  |  |  |  |
| 562 | 6.1.2.5.2.4 | Protocolar proposta de compensação ambiental - Cachoeira Escura/MG |  | 10d | 2019-05-02 A | 2019-05-15 A | 561FS+2d | 100% |  | 2019-04-29 | 2019-05-13 | 10d | 2019-04-29 | 2019-05-13 |  |  | 100% | 100 | 100 | 100 | 100 |  |  |  |  |  |
| 563 | 6.1.2.5.2.5 | Acompanhar Processo Junto ao Órgão - Cachoeira Escura/MG |  | 166d | 2019-05-16 A | 2020-01-13 | 562 | 95% | 8.3d | 2019-05-14 | 2019-09-16 | 88d | 2019-05-14 | 2019-09-16 | 531d | 0d | 37% | 25 | 37 | 68 | 37 |  |  |  |  |  |
| 564 | 6.1.2.5.2.6 | Obtenção da DAIA para captação - (Poço dentro da ETA e UTR) - Cachoeira Escura/MG | milestone | 0d | 2020-01-13 | 2020-01-13 | 563 |  |  | 2019-09-16 | 2019-09-16 | 0d | 2019-09-16 | 2019-09-16 | 531d | 0d | 0% |  |  |  |  |  |  |  |  |  |
| 565 | 6.1.2.5.3 | Conclusão do Licenciamento Ambiental da Localidade - Cahoeira Escura/MG | milestone | 0d | 2020-01-13 | 2020-01-13 | 557, 563, 564 |  |  | 2019-10-23 | 2019-10-23 | 0d | 2019-10-23 | 2019-10-23 | 531d | 226d | 0% |  |  |  |  |  |  |  |  |  |

Notes:
- 542: 25/Jan19: / - Considerado no Cronograma da Engenharia 2 projetos referentes a Captação Alternativa: ADEQUAÇÃO POÇO (concluído em 31/07/18) e COMPLEMENTO NOVOS POÇOS (em desenvolvimento). As datas deste último é que estão sendo consideradas no Cronograma Master do PG. / - Aguardando tratativas da Copasa junto a Cenibra referente a disponibilização de um novo poço para ser utilizado como Captação Alternativa em substituição aos 3 poços perfurados pela Copasa. / 06/Dez: / - Não será utilizada a solução prevista no DEPP (adutora Córrego do Café). Contudo será utilizado o poço existente e interligado a ETA. Em definição a solução para complementar a vazão desse poço. Aguardando retorno da COPASA. / 05/Dez: / - CR ENG considerando projeto de captação alternativa para adequação de poço existente (concluído em 31/07/18. Entregue ao PG????) e outro projeto para novos poços (datas não confiáveis). / - Considerar projeto de REDIMENCIONAR BOMBAS ÁGUA (captação principal) / - Projeto de RELOCAÇÃO PAINEL ELEVATÓRIA (melhoria ETA).
- 544: 25/Jan19: / - Aguardando tratativas da Copasa junto a Cenibra referente a disponibilização de um novo poço para executar os serviços necessários (perfilagem, análise da água, etc.).
- 553: 11/Fev19: / - Aguardando tratativas da Copasa junto a Cenibra referente a disponibilização de um novo poço para ser utilizado como Captação Alternativa em substituição aos 3 poços perfurados pela Copasa. / 30/Jan19: / - Termos que estão ok são referentes aos 3 Poços perfurados pela Copasa: / . P1 - Cenibra / . P2 e P3 - Agnaldo José de Souza
- 554: 30/Jan19: / - 99% do caminhamento da adutora passará pela faixa de domínio da EFVM (Vale).
- 558: 29/04/19: Foi feito pedido de informação complementar pelo orgão à área de licenciamento em 18/02/19 (ofício 004/2019/AAMA de Ouro Preto) com prazo de 30 dias. Foi feito pedido de prorrogação de prazo em 05/03/19.

| ID | WBS | Task | Type | Duration | Start | Finish | Predecessors | Complete | Remaining | Baseline start | Baseline finish | Baseline duration | Baseline 1 start | Baseline 1 finish | Total slack | Free slack | Text3 | Text5 | Text7 | Text15 | Text25 | Text26 | Text27 | Text29 | Indicadores MIR | Text4 | Text23 | Text9 | Text13 |
| --- | --- | --- | --- | --- | --- | --- | --- | --- | --- | --- | --- | --- | --- | --- | --- | --- | --- | --- | --- | --- | --- | --- | --- | --- | --- | --- | --- | --- | --- |
| 566 | 6.1.2.6 | **Infraestrutura** |  | 549d | 2020-06-18 | 2022-08-30 |  |  |  | 2016-10-03 | 2022-03-10 | 1378d | 2016-10-03 | 2022-03-10 | 304d |  | 51% | 51 | 20 | 20 | 0% | ok | 0% | Cachoeira Escura (distrito Belo Oriente/MG) |  |  |  |  |  |
| 567 | 6.1.2.6.1 | **Obras** |  | 300d | 2020-06-18 | 2021-08-30 |  |  |  | 2019-06-21 | 2021-02-24 | 417d |  |  | 425d |  |  |  |  |  |  |  |  |  |  |  |  |  |  |
| 568 | 6.1.2.6.1.1 | Contrato Guarda-Chuva(Captações e Melhorias ETA) - Cachoeira Escura/MG | milestone | 0d | 2020-06-18 | 2020-06-18 | 549, 551 |  |  | 2019-06-21 | 2019-10-23 | 0d | 2019-06-21 | 2019-10-23 | 425d | 120d | 6% |  |  |  | 0% | ok | 0% | Cachoeira Escura (distrito Belo Oriente/MG) |  |  |  |  |  |
| 569 | 6.1.2.6.1.2 | Executar obras de Captação Alternativa (3 poços + 3km de adutora) - Cachoeira Escura/MG |  | 180d | 2020-12-09 | 2021-08-30 | 543, 550, 554, 557, 563, 564, 568, 555, 565 |  |  | 2019-10-23 | 2021-02-24 | 330d | 2019-10-23 | 2021-02-24 | 305d | 0d | 0% |  |  |  | 0% | ok | 0% | Cachoeira Escura (distrito Belo Oriente/MG) | CA |  |  |  |  |
| 570 | 6.1.2.6.1.3 | Assinatura de Termo de Entrega das Obras de Melhoria do Sistema de Abastecimento de Água - Cachoeira Escura/MG | milestone | 0d | 2021-08-30 | 2021-08-30 | 569 |  |  | 2020-11-09 | 2020-11-09 | 0d | 2021-02-24 | 2021-02-24 | 553d | 305d | 0% |  |  |  | 0% | ok | 0% | Cachoeira Escura (distrito Belo Oriente/MG) |  |  |  |  |  |
| 571 | 6.1.2.6.2 | **Operação** |  | 249d | 2021-08-30 | 2022-08-30 |  |  |  | 2021-02-25 | 2022-03-10 | 260d | 2021-02-25 | 2022-03-10 | 304d |  | 0% |  |  |  | 0% | ok | 0% | Cachoeira Escura (distrito Belo Oriente/MG) |  |  |  |  |  |
| 572 | 6.1.2.6.2.1 | Realizar Treinamento Operacional do Sistema - Cachoeira Escura/MG |  | 5d | 2021-08-31 | 2021-09-06 | 569 |  |  | 2021-02-25 | 2021-03-03 | 5d | 2021-02-25 | 2021-03-03 | 534d | 0d | 0% |  |  |  | 0% | ok | 0% | Cachoeira Escura (distrito Belo Oriente/MG) |  |  |  |  |  |
| 573 | 6.1.2.6.2.2 | Realizar Testes e Pré-operação - Cachoeira Escura/MG |  | 14d | 2021-09-08 | 2021-09-27 | 572 |  |  | 2021-03-04 | 2021-03-23 | 14d | 2021-03-04 | 2021-03-23 | 534d |  | 0% |  |  |  | 0% | ok | 0% | Cachoeira Escura (distrito Belo Oriente/MG) |  |  |  |  |  |
| 574 | 6.1.2.6.2.3 | Realizar Acompanhamento da Funcionalidade do Sistema - Captação Alternativa - Cachoeira Escura (distrito Belo Oriente/MG) |  | 365ed | 2021-08-30 | 2022-08-30 | 576SS |  |  | 2021-02-25 | 2022-03-10 | 260d |  |  | 1347d |  |  |  |  |  |  |  |  |  |  |  |  |  |  |
| 575 | 6.1.2.6.2.4 | **Operação Assistida** |  | 60d | 2021-08-30 | 2021-11-28 |  |  |  | 2021-02-25 | 2021-05-27 | 64d | 2021-02-25 | 2021-05-27 | 305d |  | 0% |  |  |  | 0% | ok | 0% | Cachoeira Escura (distrito Belo Oriente/MG) |  |  |  |  |  |
| 576 | 6.1.2.6.2.4.1 | Realizar Operação Assistida - Cachoeira Escura/MG |  | 90ed | 2021-08-30 | 2021-11-28 | 569 |  |  | 2021-02-25 | 2021-05-27 | 3.2mo | 2021-02-25 | 2021-05-27 | 1347d | 0d | 0% |  |  |  | 0% | ok | 0% | Cachoeira Escura (distrito Belo Oriente/MG) |  |  |  |  |  |
| 577 | 6.1.3 | **UTR** |  | 789d | 2019-11-04 A | 2023-01-07 |  | 2% | 771.07d | 2018-03-14 | 2022-03-10 | 1001d |  |  | 216d |  |  |  |  |  |  |  |  |  |  |  |  |  |  |
| 578 | 6.1.3.1 | **Engenharia** |  | 331d | 2019-11-04 A | 2021-03-09 |  | 13% | 286.59d | 2018-03-14 | 2019-10-22 | 411d | 2018-03-14 | 2019-10-22 | 226d |  | 80% | 80 | 66 | 85 |  | ok |  |  |  | 56 | Socioambiental |  |  |
| 579 | 6.1.3.1.1 | **Engenharia Básica e Detalhada** |  | 331d | 2019-11-04 A | 2021-03-09 |  | 13% | 286.59d | 2018-07-31 | 2019-09-24 | 292d | 2018-07-31 | 2019-09-24 | 226d |  | 79% | 79 | 52 | 79 |  |  |  |  |  | 41 |  |  |  |
| 580 | 6.1.3.1.1.1 | **Engenharia UTR - 40L/s** |  | 331d | 2019-11-04 A | 2021-03-09 |  | 13% | 286.59d | 2018-12-18 | 2019-09-24 | 192d | 2018-12-18 | 2019-09-24 | 226d |  | 68% | 68 | 44 | 64 | 0% | ok | 0% | Cachoeira Escura (distrito Belo Oriente/MG) |  | 28 | Socioambiental |  |  |
| 581 | 6.1.3.1.1.1.1 | Aprovar Plano de Trabalho e abrir OSE - UTR - Cachoeira Escura/MG |  | 21d | 2019-11-04 A | 2019-12-03 A | 523FS+136d | 100% |  | 2018-12-18 | 2019-01-29 | 30d | 2018-12-18 | 2019-01-29 |  |  | 100% | 100 | 100 | 100 | 0% | Não OK | 0% | Cachoeira Escura (distrito Belo Oriente/MG) |  | 100 | Socioambiental | Não OK | 8888888 |
| 582 | 6.1.3.1.1.1.2 | Elaborar arranjo para obtenção de Dados de Entrada Licenciamento e Fundiário - UTR - Cachoeira Escura/MG |  | 99d | 2019-12-04 A | 2020-05-04 | 581 | 25% | 74.25d | 2019-05-08 | 2019-06-07 | 23d | 2019-05-08 | 2019-06-07 | 216d | 0d | 100% | 100 | 80 | 100 |  |  |  |  |  | 80 |  |  | 8888888 |
| 583 | 6.1.3.1.1.1.3 | Elaborar Projeto Básico - UTR - Cachoeira Escura/MG |  | 123d | 2020-05-05 | 2020-10-27 | 582 |  |  | 2018-02-08 | 2018-03-21 | 30d | 2018-02-08 | 2018-03-21 | 216d | 0d | 100% | 100 |  | 100 | 0% | ok | 0% | Cachoeira Escura (distrito Belo Oriente/MG) |  |  |  |  |  |
| 584 | 6.1.3.1.1.1.4 | Aprovar Projeto Básico - UTR - Cachoeira Escura/MG |  | 22d | 2020-10-28 | 2020-11-27 | 583 |  |  | 2018-03-01 | 2018-03-30 | 22d |  |  | 226d | 0d |  |  |  |  |  |  |  |  |  |  |  |  |  |
| 585 | 6.1.3.1.1.1.5 | Emitir RT/PQ para Suprimentos - UTR - Cachoeira Escura/MG |  | 10d | 2020-10-28 | 2020-11-11 | 583 |  |  | 2019-05-29 | 2019-06-14 | 13d | 2019-05-29 | 2019-06-14 | 216d | 0d | 100% | 100 |  | 100 | 0% | ok | 0% | Cachoeira Escura (distrito Belo Oriente/MG) |  |  |  |  |  |
| 586 | 6.1.3.1.1.1.6 | Elaborar Projeto Executivo - UTR - Cachoeira Escura/MG |  | 66d | 2020-11-30 | 2021-03-09 | 583, 584 |  |  | 2019-06-10 | 2019-09-24 | 75d | 2019-06-10 | 2019-09-24 | 226d | 0d | 18% | 18 |  | 18 | 0% | ok | 0% | Cachoeira Escura (distrito Belo Oriente/MG) |  |  |  |  |  |
| 587 | 6.1.3.1.1.1.7 | Elaboração do Projeto Executivo - UTR - Cachoeira Escura/MG | milestone | 0d | 2021-03-09 | 2021-03-09 | 583, 586 |  |  | 2019-09-24 | 2019-09-24 | 0d | 2019-09-24 | 2019-09-24 | 226d | 10d | 0% |  |  |  |  |  |  |  |  |  |  |  |  |
| 588 | 6.1.3.2 | **Suprimentos** |  | 88d | 2020-11-12 | 2021-03-23 |  |  |  | 2019-06-21 | 2019-10-23 | 88d | 2019-06-21 | 2019-10-23 | 216d |  | 6% |  |  |  | 0% | ok | 0% | Cachoeira Escura (distrito Belo Oriente/MG) |  |  |  |  |  |
| 589 | 6.1.3.2.1 | Contratação UTR - Cachoeira Escura/MG |  | 88d | 2020-11-12 | 2021-03-23 | 585 |  |  | 2019-06-21 | 2019-10-23 | 88d | 2019-06-21 | 2019-10-23 | 216d | 0d | 6% |  |  |  | 0% | ok | 0% | Cachoeira Escura (distrito Belo Oriente/MG) |  |  |  |  |  |
| 590 | 6.1.3.2.2 | Conclusão da Contratação de Suprimentos das obras de Melhoria do Sistema de Abastecimento de Água - Cachoeira Escura/MG | milestone | 0d | 2021-03-23 | 2021-03-23 | 589 |  |  | 2019-10-23 | 2019-10-23 | 0d | 2019-10-23 | 2019-10-23 | 216d | 0d | 0% |  |  |  |  |  |  |  |  |  |  |  |  |

Notes:
- 588: 14/Fev19: / - Em reunião de integração entre as áreas nesta data, foi informado pelo Alessandro (Infraestrutura Território II - Calha e Médio Rio Doce), que será utilizado contrato guarda-chuva da infraestrutura para a execução dos projetos da Captação Principal e UTR. Para a de Urbanização de Poço, Elevatórias e Melhorias na ETA, deverá ser realizada RT para nova contratação (MAS).

| ID | WBS | Task | Type | Duration | Start | Finish | Predecessors | Complete | Remaining | Baseline start | Baseline finish | Baseline duration | Baseline 1 start | Baseline 1 finish | Total slack | Free slack | Text3 | Text5 | Text7 | Text15 | Text25 | Text26 | Text27 | Text29 | Text4 | Text23 | Text9 |
| --- | --- | --- | --- | --- | --- | --- | --- | --- | --- | --- | --- | --- | --- | --- | --- | --- | --- | --- | --- | --- | --- | --- | --- | --- | --- | --- | --- |
| 591 | 6.1.3.3 | **Infraestrutura** |  | 448d | 2021-03-24 | 2023-01-07 |  |  |  | 2016-10-03 | 2022-03-10 | 1378d | 2016-10-03 | 2022-03-10 | 216d |  | 51% | 51 | 20 | 20 | 0% | ok | 0% | Cachoeira Escura (distrito Belo Oriente/MG) |  |  |  |
| 592 | 6.1.3.3.1 | **Obras** |  | 200d | 2021-03-24 | 2022-01-07 |  |  |  | 2019-10-24 | 2020-11-09 | 258d |  |  | 216d |  |  |  |  |  |  |  |  |  |  |  |  |
| 593 | 6.1.3.3.1.1 | Executar UTR - Cachoeira Escura/MG |  | 200d | 2021-03-24 | 2022-01-07 | 586, 587, 590 |  |  | 2019-10-24 | 2020-07-08 | 173d | 2019-10-24 | 2020-07-08 | 216d | 0d | 0% |  |  |  | 0% | ok | 0% | Cachoeira Escura (distrito Belo Oriente/MG) |  |  |  |
| 594 | 6.1.3.3.1.2 | Assinatura de Termo de Entrega das Obras de Melhoria do Sistema de Abastecimento de Água - Cachoeira Escura/MG | milestone | 0d | 2022-01-07 | 2022-01-07 | 593 |  |  | 2020-11-09 | 2020-11-09 | 0d | 2021-02-24 | 2021-02-24 | 464d | 216d | 0% |  |  |  | 0% | ok | 0% | Cachoeira Escura (distrito Belo Oriente/MG) |  |  |  |
| 595 | 6.1.3.3.2 | **Operação** |  | 248d | 2022-01-07 | 2023-01-07 |  |  |  | 2021-02-25 | 2022-03-10 | 260d | 2021-02-25 | 2022-03-10 | 216d |  | 0% |  |  |  | 0% | ok | 0% | Cachoeira Escura (distrito Belo Oriente/MG) |  |  |  |
| 596 | 6.1.3.3.2.1 | Realizar Treinamento Operacional do Sistema - Cachoeira Escura/MG |  | 5d | 2022-01-10 | 2022-01-14 | 593 |  |  | 2021-02-25 | 2021-03-03 | 5d | 2021-02-25 | 2021-03-03 | 445d | 0d | 0% |  |  |  | 0% | ok | 0% | Cachoeira Escura (distrito Belo Oriente/MG) |  |  |  |
| 597 | 6.1.3.3.2.2 | Realizar Testes e Pré-operação - Cachoeira Escura/MG |  | 14d | 2022-01-17 | 2022-02-03 | 596 |  |  | 2021-03-04 | 2021-03-23 | 14d | 2021-03-04 | 2021-03-23 | 445d |  | 0% |  |  |  | 0% | ok | 0% | Cachoeira Escura (distrito Belo Oriente/MG) |  |  |  |
| 598 | 6.1.3.3.2.3 | Realizar Acompanhamento da Funcionalidade do Sistema - UTR - Cachoeira Escura (distrito Belo Oriente/MG) |  | 365ed | 2022-01-07 | 2023-01-07 | 600SS |  |  | 2021-02-25 | 2022-03-10 | 260d |  |  | 957d |  |  |  |  |  |  |  |  |  |  |  |  |
| 599 | 6.1.3.3.2.4 | **Operação Assistida** |  | 61d | 2022-01-07 | 2022-04-07 |  |  |  | 2021-02-25 | 2021-05-27 | 64d | 2021-02-25 | 2021-05-27 | 216d |  | 0% |  |  |  | 0% | ok | 0% | Cachoeira Escura (distrito Belo Oriente/MG) |  |  |  |
| 600 | 6.1.3.3.2.4.1 | Realizar Operação Assistida - Cachoeira Escura/MG |  | 90ed | 2022-01-07 | 2022-04-07 | 593 |  |  | 2021-02-25 | 2021-05-27 | 3.2mo | 2021-02-25 | 2021-05-27 | 957d | 0d | 0% |  |  |  | 0% | ok | 0% | Cachoeira Escura (distrito Belo Oriente/MG) |  |  |  |
| 601 | 6.2 | **Senhora da Penha (distrito Fernandes Tourinho/MG)** |  | 1203d | 2017-10-25 A | 2022-08-05 |  | 20% | 963.16d | 2017-10-25 | 2021-12-22 | 1049d | 2017-10-25 | 2021-12-22 | 320d |  | 40% | 40 | 91 | 22 | 0% | ok | 0% | Senhora da Penha (distrito Fernandes Tourinho/MG) | 20 | Socioambiental |  |
| 602 | 6.2.1 | **Engenharia Captação Alternativa - Poço 3** |  | 1159d | 2017-10-25 A | 2022-06-04 |  | 30% | 805.99d | 2017-10-25 | 2021-12-22 | 1049d |  |  | 364d |  |  |  |  |  |  |  |  |  |  |  |  |
| 603 | 6.2.1.1 | **Estudos de Concepção do Sistema - Etapa 1** |  | 335d | 2017-10-25 A | 2019-02-07 A |  | 100% |  | 2017-10-25 | 2019-05-29 | 409d | 2017-10-25 | 2019-05-29 |  |  | 100% | 100 | 94 | 72 |  |  |  |  | 68 |  |  |
| 604 | 6.2.1.1.1 | Declaração de Escopo e Premissas de Projeto (DEPP) concluída - Senhora da Penha/MG | milestone | 0d | 2018-03-23 A | 2018-03-23 A | 25, 26 | 100% |  | 2018-03-23 | 2018-03-23 | 0d | 2018-03-23 | 2018-03-23 |  |  | 100% | 100 | 100 | 100 | 0% | ok | 0% | Senhora da Penha (distrito Fernandes Tourinho/MG) | 100 |  |  |
| 605 | 6.2.1.1.2 | Aprovação das DEPPs pela Operadora e Prefeitura - Senhora da Penha/MG | milestone | 0d | 2017-10-25 A | 2017-10-25 A | 25SS+20d, 26SS+213d | 100% |  | 2017-10-25 | 2017-10-25 | 0d | 2017-10-25 | 2017-10-25 |  |  | 100% | 100 | 100 | 100 | 0% | ok | 0% | Senhora da Penha (distrito Fernandes Tourinho/MG) | 100 |  |  |
| 606 | 6.2.1.1.3 | Revisar Revisão de Definições - Senhora da Penha/MG |  | 81d | 2018-10-17 A | 2019-02-07 A | 615 | 100% |  | 2018-10-17 | 2019-02-07 | 81d | 2018-10-17 | 2019-02-07 |  |  | 100% | 100 | 100 | 100 | 0% | Não OK | 0% | Senhora da Penha (distrito Fernandes Tourinho/MG) | 100 | Socioambiental | Não OK |
| 607 | 6.2.1.1.4 | Aprovação da Revisão de Definição pela Prefeitura - Senhora da Penha/MG | milestone | 0d | 2019-02-07 A | 2019-02-07 A | 606 | 100% |  | 2019-02-07 | 2019-02-07 | 0d | 2019-02-07 | 2019-02-07 |  |  | 100% | 100 | 100 | 100 | 0% | ok | 0% | Senhora da Penha (distrito Fernandes Tourinho/MG) | 100 |  |  |
| 608 | 6.2.1.1.5 | **Estudos de Geofísica para Poço Tubular - Poço 2** |  | 150d | 2018-05-08 A | 2018-12-03 A |  | 100% |  | 2018-05-08 | 2018-05-21 | 10d | 2018-05-08 | 2018-05-21 |  |  | 100% | 100 | 100 | 100 | 0% | ok | 0% | Senhora da Penha (distrito Fernandes Tourinho/MG) | 100 |  |  |
| 609 | 6.2.1.1.5.1 | Executar Levantamento de Campo - Poço 2 - Senhora da Penha/MG |  | 3d | 2018-05-08 A | 2018-05-10 A | 604 | 100% |  | 2018-05-08 | 2018-05-10 | 3d | 2018-05-08 | 2018-05-10 |  |  | 100% | 100 | 100 | 100 | 0% | ok | 0% | Senhora da Penha (distrito Fernandes Tourinho/MG) | 100 |  |  |
| 610 | 6.2.1.1.5.2 | Emitir Relatório - Poço 2 - Senhora da Penha/MG |  | 7d | 2018-05-11 A | 2018-05-21 A | 609 | 100% |  | 2018-05-11 | 2018-05-21 | 7d | 2018-05-11 | 2018-05-21 |  |  | 100% | 100 | 100 | 100 | 0% | ok | 0% | Senhora da Penha (distrito Fernandes Tourinho/MG) | 100 |  |  |
| 611 | 6.2.1.1.5.3 | Conclusão dos Estudos de Geofísica para Poço Tubular - Poço 2 - Senhora da Penha/MG | milestone | 0d | 2018-05-21 A | 2018-05-21 A | 610 | 100% |  | 2018-05-21 | 2018-05-21 | 0d | 2018-05-21 | 2018-05-21 |  |  | 100% | 100 | 100 | 100 |  |  |  |  | 100 |  |  |
| 612 | 6.2.1.1.5.4 | **Serviços em Poços Tubulares (Poço 2 - Tamponado)** |  | 58d | 2018-09-13 A | 2018-12-03 A |  | 100% |  | 2018-09-13 | 2018-12-03 | 58d | 2018-09-13 | 2018-12-03 |  |  | 100% | 100 | 100 | 100 | 0% | ok | 0% | Senhora da Penha (distrito Fernandes Tourinho/MG) | 100 |  |  |
| 613 | 6.2.1.1.5.4.1 | Realizar Perfuração - Poço 2 - Senhora da Penha/MG |  | 3d | 2018-09-13 A | 2018-09-17 A | 610, 611 | 100% |  | 2018-09-13 | 2018-09-17 | 3d | 2018-09-13 | 2018-09-17 |  |  | 100% | 100 | 100 | 100 | 0% | ok | 0% | Senhora da Penha (distrito Fernandes Tourinho/MG) | 100 |  |  |
| 614 | 6.2.1.1.5.4.2 | Realizar Teste de Bombeamento - Poço 2 - Senhora da Penha/MG |  | 2d | 2018-09-17 A | 2018-09-18 A | 613 | 100% |  | 2018-09-17 | 2018-09-18 | 2d | 2018-09-17 | 2018-09-18 |  |  | 100% | 100 | 100 | 100 | 0% | ok | 0% | Senhora da Penha (distrito Fernandes Tourinho/MG) | 100 |  |  |
| 615 | 6.2.1.1.5.4.3 | Realizar Laudo dos Serviços de Coleta e Análise de Água - Poço 2 - Senhora da Penha/MG |  | 20d | 2018-09-19 A | 2018-10-16 A | 614 | 100% |  | 2018-09-19 | 2018-10-16 | 20d | 2018-09-19 | 2018-10-16 |  |  | 100% | 100 | 100 | 100 | 0% | ok | 0% | Senhora da Penha (distrito Fernandes Tourinho/MG) | 100 |  |  |
| 616 | 6.2.1.1.5.4.4 | Realizar Tamponamento - Poço 2 - Senhora da Penha/MG |  | 6d | 2018-11-24 A | 2018-12-03 A | 615 | 100% |  | 2018-11-24 | 2018-12-03 | 6d | 2018-11-24 | 2018-12-03 |  |  | 100% | 100 | 100 | 100 | 0% | ok | 0% | Senhora da Penha (distrito Fernandes Tourinho/MG) | 100 |  |  |
| 617 | 6.2.1.1.5.4.5 | Conclusão dos Serviços em poço tubular - Poço 2 - Senhora da Penha/MG | milestone | 0d | 2018-12-03 A | 2018-12-03 A | 616 | 100% |  | 2018-12-03 | 2018-12-03 | 0d | 2018-12-03 | 2018-12-03 |  |  | 100% | 100 | 100 | 100 |  |  |  |  | 100 |  |  |

Notes:
- 606: 22/Nov: / - análise de potabilidade negativa no poço verificado / - PG deve redefinir locação / - locação da captação no Rio Doce pendente / - A nova proposta de captação deverá ser aprovada junto a Prefeitura pelo PG. Solicitado por este à ENG uma estimativa de custo operacional da nova solução proposta para apresentar ao prefeito. Verificar prazo com a ENG.
- 607: 22/Jan19 / - Ver e-mail do Thales com a aprovação da revisão de definição pelo Prefeito de Fernandes Tourinho.
- 608: 07/Dez: / - Para perfuração do poço que seria a captação alternativa.
- 615: 07/Dez: / - Resultado do laudo mostrou inviável a utilização desse poço.

| ID | WBS | Task | Type | Duration | Start | Finish | Predecessors | Complete | Remaining | Baseline start | Baseline finish | Baseline duration | Baseline 1 start | Baseline 1 finish | Total slack | Free slack | Text1 | Text3 | Text4 | Text5 | Text7 | Text15 | Text25 | Text26 | Text27 | Text29 | Text23 | Text9 |
| --- | --- | --- | --- | --- | --- | --- | --- | --- | --- | --- | --- | --- | --- | --- | --- | --- | --- | --- | --- | --- | --- | --- | --- | --- | --- | --- | --- | --- |
| 618 | 6.2.1.2 | **Estudos de Concepção do Sistema - Etapa 2** |  | 264d | 2019-04-08 A | 2020-04-30 |  | 45% | 145.2d | 2019-04-08 | 2020-04-30 | 264d |  |  | 508d |  |  |  |  |  |  |  |  |  |  |  |  |  |
| 619 | 6.2.1.2.1 | **Estudos de Geofísica para Poço Tubular - Poço 3** |  | 16d | 2019-07-09 A | 2019-07-30 A |  | 100% |  | 2019-07-09 | 2019-07-30 | 16d |  |  |  |  | 8888 | 100% | 25 | 100 | 25 | 100 |  |  |  |  |  |  |
| 620 | 6.2.1.2.1.1 | Executar Levantamento de Campo - Poço 3 - Senhora da Penha/MG |  | 4d | 2019-07-09 A | 2019-07-12 A | 654FS+6d | 100% |  | 2019-07-09 | 2019-07-12 | 4d |  |  |  |  | 8888 | 100% | 100 | 100 | 100 | 100 |  |  |  |  |  |  |
| 621 | 6.2.1.2.1.2 | Emitir Relatório - Poço 3 - Senhora da Penha/MG |  | 12d | 2019-07-15 A | 2019-07-30 A | 620 | 100% |  | 2019-07-15 | 2019-07-30 | 12d |  |  |  |  | 8888 | 100% |  | 100 |  | 100 |  |  |  |  |  |  |
| 622 | 6.2.1.2.1.3 | Conclusão dos Estudos de Geofísica para Poço Tubular - Poço 3 - Senhora da Penha/MG | milestone | 0d | 2019-07-30 A | 2019-07-30 A | 621 | 100% |  | 2019-07-30 | 2019-07-30 | 0d |  |  |  |  | 8888 | 100% |  | 100 |  | 100 |  |  |  |  |  |  |
| 623 | 6.2.1.2.2 | **Serviços em Poços Tubulares (Poço 1 Existente) - Vazão Insuficiente** |  | 38d | 2019-04-08 A | 2019-06-03 A |  | 100% |  | 2019-04-08 | 2019-05-29 | 35d | 2019-04-08 | 2019-05-29 |  |  |  | 100% | 100 | 100 | 100 | 100 |  |  |  |  |  |  |
| 624 | 6.2.1.2.2.1 | Realizar Perfilagem (Poço 1 existente) - Captação Alternativa) - Vazão Insuficiente - Senhora da Penha/MG |  | 5d | 2019-04-08 A | 2019-04-12 A | 607FS+15d | 100% |  | 2019-04-08 | 2019-04-12 | 5d | 2019-04-08 | 2019-04-12 |  |  |  | 100% | 100 | 100 | 100 | 100 | 0% | ok | 0% | Senhora da Penha (distrito Fernandes Tourinho/MG) |  |  |
| 625 | 6.2.1.2.2.2 | Realizar Recuperação (Poço 1 existente) - Captação Alternativa) - Vazão Insuficiente - Senhora da Penha/MG |  | 5d | 2019-04-08 A | 2019-04-12 A | 624SS | 100% |  | 2019-04-08 | 2019-04-12 | 5d | 2019-04-08 | 2019-04-12 |  |  |  | 100% | 100 | 100 | 100 | 100 | 0% | ok | 0% | Senhora da Penha (distrito Fernandes Tourinho/MG) |  |  |
| 626 | 6.2.1.2.2.3 | Elaborar Relatório Técnico (Poço 1 existente) - Captação Alternativa) - Vazão Insuficiente - Senhora da Penha/MG |  | 23d | 2019-05-02 A | 2019-06-03 A | 624FS+10d, 625 | 100% |  | 2019-05-02 | 2019-05-29 | 20d | 2019-05-02 | 2019-05-29 |  |  |  | 100% | 100 | 100 | 100 | 100 | 0% | ok | 0% | Senhora da Penha (distrito Fernandes Tourinho/MG) |  |  |
| 627 | 6.2.1.2.2.4 | Realizar Laudo dos Serviços de Coleta e Análise de Água (Poço 1 existente) - Captação Alternativa) - Vazão Insuficiente - Senhora da Penha/MG |  | 5d | 2019-04-15 A | 2019-04-23 A | 625SS | 100% |  | 2019-04-15 | 2019-04-23 | 5d | 2019-04-15 | 2019-04-23 |  |  |  | 100% | 100 | 100 | 100 | 100 | 0% | ok | 0% | Senhora da Penha (distrito Fernandes Tourinho/MG) |  |  |
| 628 | 6.2.1.2.2.5 | Conclusão dos Serviços em poço tubular - Captação Alternativa) - Vazão Insuficiente - Senhora da Penha/MG | milestone | 0d | 2019-06-03 A | 2019-06-03 A | 626 | 100% |  | 2019-05-29 | 2019-05-29 | 0d | 2019-05-29 | 2019-05-29 |  |  |  | 100% | 100 | 100 | 100 | 100 |  |  |  |  |  |  |
| 629 | 6.2.1.2.3 | **Serviços em Poços Tubulares (Poço 3 - Captação Alternativa)** |  | 42d | 2020-03-02 | 2020-04-30 |  |  |  | 2020-01-09 | 2020-03-11 | 42d |  |  | 366d |  | 8888 | 0% |  |  |  |  |  |  |  |  |  |  |
| 630 | 6.2.1.2.3.1 | Realizar Perfuração - Captação Alternativa - Poço 3 - Senhora da Penha/MG |  | 10d | 2020-03-02 | 2020-03-13 | 622, 658, 655 |  |  | 2020-01-09 | 2020-01-22 | 10d |  |  | 366d | 0d | 8888 | 0% |  |  |  |  |  |  |  |  |  |  |
| 631 | 6.2.1.2.3.2 | Realizar Teste de bombeamento - Captação Alternativa - Poço 3 - Senhora da Penha/MG |  | 5d | 2020-03-16 | 2020-03-20 | 630 |  |  | 2020-01-23 | 2020-01-29 | 5d |  |  | 366d | 0d | 8888 | 0% |  |  |  |  |  |  |  |  |  |  |
| 632 | 6.2.1.2.3.3 | Realizar Serviços de Coleta e Análise de Água - Captação Alternativa - Poço 3 - Senhora da Penha/MG |  | 24d | 2020-03-23 | 2020-04-27 | 631 |  |  | 2020-01-30 | 2020-03-06 | 24d |  |  | 366d | 0d | 8888 | 0% |  |  |  |  |  |  |  |  |  |  |
| 633 | 6.2.1.2.3.4 | Elaborar Relatório Técnico - Captação Alternativa - Poço 3 - Senhora da Penha/MG |  | 24d | 2020-03-23 | 2020-04-27 | 631 |  |  | 2020-01-30 | 2020-03-06 | 24d |  |  | 508d | 0d | 8888 | 0% |  |  |  |  |  |  |  |  |  |  |
| 634 | 6.2.1.2.3.5 | Realizar Instrumentação - Captação Alternativa - Poço 3 - Senhora da Penha/MG |  | 3d | 2020-04-28 | 2020-04-30 | 633 |  |  | 2020-03-09 | 2020-03-11 | 3d |  |  | 508d | 0d | 8888 | 0% |  |  |  |  |  |  |  |  |  |  |
| 635 | 6.2.1.2.3.6 | Conclusão dos Serviços em poço tubular - Captação Alternativa - Poço 3 - Senhora da Penha/MG | milestone | 0d | 2020-04-30 | 2020-04-30 | 632, 634 |  |  | 2019-12-20 | 2019-12-20 | 0d |  |  | 508d | 0d |  | 0% |  |  |  |  |  |  |  |  |  |  |
| 636 | 6.2.1.2.4 | Conclusão dos Estudos de Concepção das Melhorias do Sistema de Abastecimento de Água - Senhora da Penha/MG | milestone | 0d | 2020-04-30 | 2020-04-30 | 611, 617, 628, 635 |  |  | 2019-05-29 | 2019-05-29 | 0d | 2019-05-29 | 2019-05-29 | 508d | 142d |  | 100% |  | 100 |  | 100 |  |  |  |  |  |  |
| 637 | 6.2.1.3 | **Engenharia Básica e Detalhada (Conceito Antigo) - Poço 1** |  | 422d | 2018-01-17 A | 2019-09-11 A |  | 100% |  | 2018-01-17 | 2019-09-05 | 418d | 2018-01-17 | 2019-09-05 |  |  |  | 88% | 77 | 88 | 89 | 87 | 0% | ok | 0% | Senhora da Penha (distrito Fernandes Tourinho/MG) | Socioambiental |  |
| 638 | 6.2.1.3.1 | Aprovar Plano de Trabalho e abrir OSE - Captação Alternativa - Senhora da Penha/MG |  | 233d | 2018-01-17 A | 2018-12-07 A | 26 | 100% |  | 2018-01-17 | 2018-12-07 | 233d | 2018-01-17 | 2018-12-07 |  |  |  | 100% | 100 | 100 | 100 | 100 | 0% | ok | 0% | Senhora da Penha (distrito Fernandes Tourinho/MG) |  |  |
| 639 | 6.2.1.3.2 | Realizar Levantamento de Campo - Captação Alternativa - Avaliação Poços - Senhora da Penha/MG |  | 15d | 2018-06-20 A | 2018-07-10 A | 638 | 100% |  | 2018-06-20 | 2018-07-10 | 15d | 2018-06-20 | 2018-07-10 |  |  |  | 100% | 100 | 100 | 100 | 100 | 0% | Não OK | 0% | Senhora da Penha (distrito Fernandes Tourinho/MG) | Socioambiental | Não OK |
| 640 | 6.2.1.3.3 | Elaborar Projeto As Built do Poço - Captação Alternativa - Senhora da Penha/MG |  | 225d | 2018-07-11 A | 2019-05-30 A | 639 | 100% |  | 2018-07-11 | 2019-06-04 | 228d | 2018-07-11 | 2019-06-04 |  |  |  | 100% | 100 | 100 | 100 | 100 | 0% | Não OK | 0% | Senhora da Penha (distrito Fernandes Tourinho/MG) | Socioambiental | Não OK |
| 641 | 6.2.1.3.4 | Elaborar Projeto Executivo - Poço 1 - STA - Senhora da Penha/MG |  | 65d | 2019-04-15 A | 2019-09-11 A | 627FS-50d, 628FS-50d, 639FS-50d, 640FS-50d | 100% |  | 2019-06-05 | 2019-09-05 | 65d | 2019-06-05 | 2019-09-05 |  |  |  | 26% | 60 | 26 | 231 | 26 | 0% | ok | 0% | Senhora da Penha (distrito Fernandes Tourinho/MG) |  |  |
| 642 | 6.2.1.3.5 | Elaboração do Projeto Executivo - Poço 1 e STA (Não será Utilizado) - Senhora da Penha/MG | milestone | 0d | 2019-09-11 A | 2019-09-11 A | 641 | 100% |  | 2019-09-05 | 2019-09-05 | 0d | 2019-09-05 | 2019-09-05 |  |  |  | 0% |  |  |  |  |  |  |  |  |  |  |

Notes:
- 623: 23/05/19: Poço deu vazão insuficiente para atender o TTAC. Será necessário furar outro poço.
- 624: 07/Dez: / - Depende da aprovação da nova definição das captações. / - Por se tratar da única fonte de abastecimento da localidade, para execução dos serviços nesse poço deverá ser prevista uma fonte de abastecimento durante o prazo da atividade.
- 627: 22/04: Análise foi concluída anteriormente a recuperação do poço.
- 629: 23/05/19: Poço 2 deu vazão insuficiente para atender o TTAC.
- 638: 25/Jan19: / - Considerado no Cronograma da Engenharia a elaboração/aprovação do Plano Trabalho com a inclusão do STA.
- 639: 25/Jan19: / - Levantamento de campo (avaliação poços) iniciado em 20/06 e concluído em 10/07/18; Levantamento de campo (avaliação STA) previsto para iniciar em 01/02 e pra finalizar em 07/02/19; Topografia iniciada em 20/09/18 e concluída em 17/01/19; Sondagem prevista para iniciar em 27/03 e pra finalizar em 26/04/19.
- 641: 25/Jan19: / - Considerado no Cronograma da Engenharia que o Laudo contendo o resultado da água seria emitido em 15/02/19. Informado através de e-mail em 29/01/19 à área, que a previsão de emissão é 29/03/19.

| ID | WBS | Task | Type | Duration | Start | Finish | Predecessors | Complete | Remaining | Baseline start | Baseline finish | Baseline duration | Baseline 1 start | Baseline 1 finish | Total slack | Free slack | Text1 | Text3 | Text4 | Text5 | Text7 | Text15 | Text25 | Text26 | Text27 | Text29 | Text13 | Indicadores MIR |
| --- | --- | --- | --- | --- | --- | --- | --- | --- | --- | --- | --- | --- | --- | --- | --- | --- | --- | --- | --- | --- | --- | --- | --- | --- | --- | --- | --- | --- |
| 643 | 6.2.1.4 | **Engenharia Básica e Detalhada Captação Alternativa - Poço 3** |  | 145d | 2020-04-28 | 2020-11-23 |  |  |  | 2020-03-09 | 2020-07-29 | 99d |  |  | 366d |  | 8888 |  |  |  |  |  |  |  |  |  |  |  |
| 644 | 6.2.1.4.1 | Aprovar Plano de Trabalho e abrir OSE - Captação Alternativa - Senhora da Penha/MG |  | 5d | 2020-04-28 | 2020-05-05 | 631, 632 |  |  | 2020-03-09 | 2020-03-13 | 5d |  |  | 366d | 0d | 8888 |  |  |  |  |  |  |  |  |  |  |  |
| 645 | 6.2.1.4.2 | Realizar Levantamento de Campo - Captação Alternativa - Avaliação Poços - Senhora da Penha/MG |  | 6d | 2020-05-06 | 2020-05-13 | 644 |  |  | 2020-03-16 | 2020-03-23 | 6d |  |  | 421d | 0d | 8888 |  |  |  |  |  |  |  |  |  |  |  |
| 646 | 6.2.1.4.3 | Realizar Sondagem - Captação Alternativa - Senhora da Penha/MG |  | 22d | 2020-07-08 | 2020-08-06 | 648FF |  |  | 2020-05-28 | 2020-06-29 | 22d |  |  | 388d | 22d | 8888 |  |  |  |  |  |  |  |  |  |  |  |
| 647 | 6.2.1.4.4 | Executar Topografia - Captação Alternativa - Senhora da Penha/MG |  | 5d | 2020-05-14 | 2020-05-20 | 645 |  |  | 2020-03-24 | 2020-04-24 | 22d |  |  | 421d | 55d | 8888 |  |  |  |  |  |  |  |  |  |  |  |
| 648 | 6.2.1.4.5 | Elaborar Projeto Básico - Captação Alternativa Poço 3 - Senhora da Penha/MG |  | 71d | 2020-04-28 | 2020-08-06 | 644SS, 647FF |  |  | 2020-04-27 | 2020-06-29 | 44d |  |  | 366d | 0d | 8888 |  |  |  |  |  |  |  |  |  |  |  |
| 649 | 6.2.1.4.6 | Aprovar Projeto Básico - Captação Alternativa Poço 3 - Senhora da Penha/MG |  | 22d | 2020-08-07 | 2020-09-08 | 648 |  |  | 2018-03-01 | 2018-03-30 | 22d |  |  | 366d | 0d |  |  |  |  |  |  |  |  |  |  |  |  |
| 650 | 6.2.1.4.7 | Emitir RT/PQ para Suprimentos - Captação Alternativa - Senhora da Penha/MG |  | 10d | 2020-11-10 | 2020-11-23 | 648, 651FF |  |  | 2020-06-30 | 2020-07-13 | 10d |  |  | 366d | 0d | 8888 |  |  |  |  |  |  |  |  |  |  |  |
| 651 | 6.2.1.4.8 | Elaborar Projeto Executivo - Captação Alternativa - Poço 3 - Senhora da Penha/MG |  | 52d | 2020-09-09 | 2020-11-23 | 646, 648, 649 |  |  | 2020-06-30 | 2020-07-29 | 22d |  |  | 366d | 0d | 8888 |  |  |  |  |  |  |  |  |  |  |  |
| 652 | 6.2.1.4.9 | Elaboração do Projeto Executivo - Captação Alternativa - Senhora da Penha/MG | milestone | 0d | 2020-11-23 | 2020-11-23 | 651, 650, 636 |  |  | 2020-07-29 | 2020-07-29 | 0d |  |  | 366d | 0d | 8888 |  |  |  |  |  |  |  |  |  |  |  |
| 653 | 6.2.1.5 | **Fundiária** |  | 143d | 2019-06-10 A | 2020-01-03 |  | 99% | 0d | 2018-06-07 | 2019-11-06 | 361d | 2018-06-07 | 2019-11-06 | 4d |  |  | 74% | 14 | 74 | 117 | 12 | 0% | ok | 0% | Senhora da Penha (distrito Fernandes Tourinho/MG) |  |  |
| 654 | 6.2.1.5.1 | [Cancelada] Obter Termo de Autorização do Superficiário (Poço 3) - Geofísica - Captação Alternativa - Senhora da Penha/MG |  | 14d | 2019-06-10 A | 2019-06-28 A | 607FS+80d | 100% |  | 2019-06-10 | 2019-06-28 | 14d |  |  |  |  | 8888 | 100% | 100 | 100 | 100 | 100 |  |  |  |  |  |  |
| 655 | 6.2.1.5.2 | [Cancelada] Obter Termo de Autorização do Superficiário (Poço 3) - Perfuração - Captação Alternativa - Senhora da Penha/MG |  | 52d | 2019-10-08 A | 2019-12-20 A | 654FS+70d | 100% |  | 2019-09-10 | 2019-10-31 | 38d |  |  |  |  | 8888 |  |  |  |  |  |  |  |  |  | 8888888 |  |
| 656 | 6.2.1.5.3 | Conclusão da Regularização Fundiária para as obras de Melhoria do Sistema de Abastecimento da Localidade - Senhora da Penha/MG | milestone | 0d | 2020-01-03 | 2020-01-03 | 655FS+7d |  |  | 2019-11-06 | 2019-11-06 | 0d | 2019-11-06 | 2019-11-06 | 4d | 0d |  | 0% |  |  |  |  |  |  |  |  | 8888888 |  |
| 657 | 6.2.1.6 | **Licenciamento** |  | 44d | 2019-12-23 A | 2020-02-28 |  | 25% | 33d | 2018-04-12 | 2020-03-27 | 495d | 2018-04-12 | 2020-03-27 | 680d |  |  | 62% | 21 | 62 | 95 | 22 | 0% | ok | 0% | Senhora da Penha (distrito Fernandes Tourinho/MG) |  |  |
| 658 | 6.2.1.6.1 | [Cancelada] Captação Alternativa - Autorização de perfuração (Poço 3) - Senhora da Penha/MG |  | 44d | 2019-12-23 A | 2020-02-28 | 622, 655, 656 | 25% | 33d | 2019-11-01 | 2020-01-08 | 44d |  |  | 366d | 0d | 8888 | 7% |  |  |  |  |  |  |  |  | 8888888 |  |
| 659 | 6.2.1.6.2 | Conclusão do Licenciamento Ambiental da Localidade - Senhora da Penha/MG | milestone | 0d | 2020-02-28 | 2020-02-28 | 658 |  |  | 2020-03-27 | 2020-03-27 | 0d | 2020-03-27 | 2020-03-27 | 680d | 314d |  | 0% |  |  |  |  |  |  |  |  |  |  |
| 660 | 6.2.1.7 | **Infraestrutura** |  | 380d | 2020-11-23 | 2022-06-04 |  |  |  | 2020-03-27 | 2021-12-22 | 434d | 2020-03-27 | 2021-12-22 | 364d |  |  | 0% |  |  |  |  | 0% | ok | 0% | Senhora da Penha (distrito Fernandes Tourinho/MG) |  |  |
| 661 | 6.2.1.7.1 | **Obras** |  | 130d | 2020-11-23 | 2021-06-04 |  |  |  | 2020-03-27 | 2020-12-06 | 174d | 2020-03-27 | 2020-12-06 | 366d |  |  | 0% |  |  |  |  |  |  |  |  |  |  |
| 662 | 6.2.1.7.1.1 | Captação Alternativa (Aditivo contrato guarda-chuva existente - Infraestrutura) - Senhora da Penha/MG | milestone | 0d | 2020-11-23 | 2020-11-23 | 642, 652 |  |  | 2019-10-17 | 2019-12-03 | 0d | 2019-10-17 | 2019-12-03 | 366d | 0d |  | 0% |  |  |  |  | 0% | ok | 0% | Senhora da Penha (distrito Fernandes Tourinho/MG) |  |  |
| 663 | 6.2.1.7.1.2 | Executar Captação Alternativa - Senhora da Penha/MG |  | 130d | 2020-11-24 | 2021-06-04 | 641, 662, 659FF |  |  | 2020-03-27 | 2020-12-06 | 174d | 2020-03-27 | 2020-12-06 | 366d | 0d |  | 0% |  |  |  |  | 0% | ok | 0% | Senhora da Penha (distrito Fernandes Tourinho/MG) |  | CA |
| 664 | 6.2.1.7.1.3 | Assinatura de Termo de Entrega das Obras de Melhoria do Sistema de Abastecimento de Água - Senhora da Penha/MG | milestone | 0d | 2021-06-04 | 2021-06-04 | 663 |  |  | 2020-12-06 | 2020-12-06 | 0d | 2020-12-06 | 2020-12-06 | 614d | 366d |  | 0% |  |  |  |  | 0% | ok | 0% | Senhora da Penha (distrito Fernandes Tourinho/MG) |  |  |
| 665 | 6.2.1.7.2 | **Operação** |  | 250d | 2021-06-04 | 2022-06-04 |  |  |  | 2020-12-07 | 2021-12-22 | 260d | 2020-12-07 | 2021-12-22 | 364d |  |  | 0% |  |  |  |  | 0% | ok | 0% | Senhora da Penha (distrito Fernandes Tourinho/MG) |  |  |
| 666 | 6.2.1.7.2.1 | Realizar Treinamento Operacional do Sistema - Senhora da Penha/MG |  | 5d | 2021-06-07 | 2021-06-11 | 663 |  |  | 2020-12-07 | 2020-12-11 | 5d | 2020-12-07 | 2020-12-11 | 595d | 0d |  | 0% |  |  |  |  | 0% | ok | 0% | Senhora da Penha (distrito Fernandes Tourinho/MG) |  |  |
| 667 | 6.2.1.7.2.2 | Realizar Testes e Pré-operação - Senhora da Penha/MG |  | 14d | 2021-06-14 | 2021-07-01 | 666 |  |  | 2020-12-14 | 2021-01-05 | 14d | 2020-12-14 | 2021-01-05 | 595d |  |  | 0% |  |  |  |  | 0% | ok | 0% | Senhora da Penha (distrito Fernandes Tourinho/MG) |  |  |
| 668 | 6.2.1.7.2.3 | Realizar Acompanhamento da Funcionalidade do Sistema - Engenharia Captação Alternativa - Poço 3 - Senhora da Penha (distrito Fernandes Tourinho/MG) |  | 365ed | 2021-06-04 | 2022-06-04 | 670SS |  |  | 2020-12-07 | 2021-12-22 | 260d |  |  | 1608d |  |  |  |  |  |  |  |  |  |  |  |  |  |

| ID | WBS | Task | Type | Duration | Start | Finish | Predecessors | Complete | Remaining | Baseline start | Baseline finish | Baseline duration | Baseline 1 start | Baseline 1 finish | Total slack | Free slack | Text3 | Text25 | Text26 | Text27 | Text29 | Text4 | Text5 | Text7 | Text15 | Text9 | Text23 | Text13 |
| --- | --- | --- | --- | --- | --- | --- | --- | --- | --- | --- | --- | --- | --- | --- | --- | --- | --- | --- | --- | --- | --- | --- | --- | --- | --- | --- | --- | --- |
| 669 | 6.2.1.7.2.4 | **Operação Assistida** |  | 64d | 2021-06-04 | 2021-09-02 |  |  |  | 2020-12-07 | 2021-03-12 | 64d | 2020-12-07 | 2021-03-12 | 364d |  | 0% | 0% | ok | 0% | Senhora da Penha (distrito Fernandes Tourinho/MG) |  |  |  |  |  |  |  |
| 670 | 6.2.1.7.2.4.1 | Realizar Operação Assistida - Senhora da Penha/MG |  | 90ed | 2021-06-04 | 2021-09-02 | 663 |  |  | 2020-12-07 | 2021-03-12 | 3.2mo | 2020-12-07 | 2021-03-12 | 1608d | 0d | 0% | 0% | ok | 0% | Senhora da Penha (distrito Fernandes Tourinho/MG) |  |  |  |  |  |  |  |
| 671 | 6.2.2 | **Engenharia Captação Principal, Nova ETA e UTR** |  | 1097d | 2018-03-23 A | 2022-08-05 |  | 9% | 999.15d | 2017-10-25 | 2021-12-22 | 1049d |  |  | 320d |  |  |  |  |  |  |  |  |  |  |  |  |  |
| 672 | 6.2.2.1 | **Estudos de Concepção do Sistema - Etapa 1** |  | 229d | 2018-03-23 A | 2019-02-07 A |  | 100% |  | 2017-10-25 | 2019-05-29 | 409d | 2017-10-25 | 2019-05-29 |  |  | 100% |  |  |  |  | 68 | 100 | 94 | 72 |  |  |  |
| 673 | 6.2.2.1.1 | Declaração de Escopo e Premissas de Projeto (DEPP) concluída - Senhora da Penha/MG | milestone | 0d | 2018-03-23 A | 2018-03-23 A | 25, 26 | 100% |  | 2018-03-23 | 2018-03-23 | 0d | 2018-03-23 | 2018-03-23 |  |  | 100% | 0% | ok | 0% | Senhora da Penha (distrito Fernandes Tourinho/MG) | 100 | 100 | 100 | 100 |  |  |  |
| 674 | 6.2.2.1.2 | Aprovação das DEPPs pela Operadora e Prefeitura - Senhora da Penha/MG | milestone | 0d | 2018-03-23 A | 2018-03-23 A | 673 | 100% |  | 2017-10-25 | 2017-10-25 | 0d | 2017-10-25 | 2017-10-25 |  |  | 100% | 0% | ok | 0% | Senhora da Penha (distrito Fernandes Tourinho/MG) | 100 | 100 | 100 | 100 |  |  |  |
| 675 | 6.2.2.1.3 | Revisar Revisão de Definições - Senhora da Penha/MG |  | 81d | 2018-10-17 A | 2019-02-07 A |  | 100% |  | 2018-10-17 | 2019-02-07 | 81d | 2018-10-17 | 2019-02-07 |  |  | 100% | 0% | Não OK | 0% | Senhora da Penha (distrito Fernandes Tourinho/MG) | 100 | 100 | 100 | 100 | Não OK | Socioambiental |  |
| 676 | 6.2.2.1.4 | Aprovação da Revisão de Definição pela Prefeitura - Senhora da Penha/MG | milestone | 0d | 2019-02-07 A | 2019-02-07 A | 675 | 100% |  | 2019-02-07 | 2019-02-07 | 0d | 2019-02-07 | 2019-02-07 |  |  | 100% | 0% | ok | 0% | Senhora da Penha (distrito Fernandes Tourinho/MG) | 100 | 100 | 100 | 100 |  |  |  |
| 677 | 6.2.2.2 | **Engenharia Básica e Detalhada** |  | 177d | 2019-12-27 A | 2020-09-11 |  | 1% | 175.16d | 2018-01-17 | 2019-11-13 | 467d | 2018-01-17 | 2019-11-13 | 415d |  | 79% |  |  |  |  | 48 | 79 | 66 | 73 |  |  |  |
| 678 | 6.2.2.2.1 | **Engenharia Captação Principal, Nova ETA e UTR** |  | 177d | 2019-12-27 A | 2020-09-11 |  | 1% | 175.16d | 2019-05-06 | 2019-10-16 | 116d | 2019-05-06 | 2019-10-16 | 415d |  | 33% | 0% | ok | 0% | Senhora da Penha (distrito Fernandes Tourinho/MG) |  | 33 |  | 51 |  |  |  |
| 679 | 6.2.2.2.1.1 | Aprovar Plano de Trabalho e abrir OSE - Captação Principal, ETA/UTR - Senhora da Penha/MG |  | 33d | 2019-12-27 A | 2020-02-12 | 676FS+218d | 9% | 30d | 2019-05-06 | 2019-05-17 | 10d | 2019-05-06 | 2019-05-17 | 435d | 0d | 100% |  |  |  |  |  | 100 |  | 100 |  |  | 8888888 |
| 680 | 6.2.2.2.1.2 | Realizar Levantamento de Campo - Captação Principal, ETA/UTR - Senhora da Penha/MG |  | 5d | 2020-02-13 | 2020-02-19 | 679 |  |  | 2019-05-20 | 2019-05-24 | 5d | 2019-05-20 | 2019-05-24 | 461d | 139d | 100% | 0% | ok | 0% | Senhora da Penha (distrito Fernandes Tourinho/MG) |  | 100 |  | 100 |  |  |  |
| 681 | 6.2.2.2.1.3 | Realizar Sondagem - Captação Principal, ETA/UTR - Senhora da Penha/MG |  | 22d | 2020-03-02 | 2020-03-31 | 679FS+9d |  |  | 2019-05-20 | 2019-06-18 | 22d | 2019-05-20 | 2019-06-18 | 435d | 113d | 100% |  |  |  |  |  | 100 |  | 100 |  |  |  |
| 682 | 6.2.2.2.1.4 | Executar Topografia - Captação Principal, ETA/UTR - Senhora da Penha/MG |  | 30d | 2020-02-13 | 2020-03-30 | 679 |  |  | 2019-05-20 | 2019-07-01 | 30d | 2019-05-20 | 2019-07-01 | 436d | 114d | 96% |  |  |  |  |  | 96 |  | 96 |  |  |  |
| 683 | 6.2.2.2.1.5 | Elaborar arranjo para obtenção de Dados de Entrada Licenciamento e Fundiário - Captação Principal, ETA/UTR - Senhora da Penha/MG |  | 22d | 2020-01-20 | 2020-02-18 | 679SS+15d |  |  | 2019-07-02 | 2019-08-05 | 25d | 2019-07-02 | 2019-08-05 | 322d | 0d | 0% | 0% | ok | 0% | Senhora da Penha (distrito Fernandes Tourinho/MG) |  |  |  |  |  |  |  |
| 684 | 6.2.2.2.1.6 | Elaborar Projeto Básico - Captação Principal, ETA/UTR - Senhora da Penha/MG |  | 85d | 2020-01-20 | 2020-05-25 | 683SS |  |  | 2018-02-08 | 2018-03-21 | 30d | 2018-02-08 | 2018-03-21 | 322d | 0d | 100% |  |  |  |  |  | 100 |  | 100 |  |  |  |
| 685 | 6.2.2.2.1.7 | Aprovar projeto básico - Captação Principal, ETA/UTR - Senhora da Penha/MG |  | 22d | 2020-05-26 | 2020-06-25 | 684 |  |  | 2018-03-01 | 2018-03-30 | 22d |  |  | 322d | 0d |  |  |  |  |  |  |  |  |  |  |  |  |
| 686 | 6.2.2.2.1.8 | Emitir RT/PQ para Suprimentos - Captação Principal, ETA/UTR - Senhora da Penha/MG |  | 15d | 2020-08-21 | 2020-09-11 | 684, 687FF |  |  | 2019-09-26 | 2019-10-16 | 15d | 2019-09-26 | 2019-10-16 | 322d | 0d | 0% | 0% | ok | 0% | Senhora da Penha (distrito Fernandes Tourinho/MG) |  |  |  |  |  |  |  |
| 687 | 6.2.2.2.1.9 | Elaborar Projeto Executivo - Captação Principal, ETA/UTR - Senhora da Penha/MG |  | 55d | 2020-06-26 | 2020-09-11 | 683, 685, 680FF, 681FF, 682FF |  |  | 2019-08-06 | 2019-10-16 | 51d | 2019-08-06 | 2019-10-16 | 322d | 0d | 0% | 0% | ok | 0% | Senhora da Penha (distrito Fernandes Tourinho/MG) |  |  |  |  |  |  |  |
| 688 | 6.2.2.2.1.10 | Elaboração do Projeto Executivo - Captação Principal, ETA/UTR - Senhora da Penha/MG | milestone | 0d | 2020-09-11 | 2020-09-11 | 687 |  |  | 2019-10-16 | 2019-10-16 | 0d | 2019-10-16 | 2019-10-16 | 415d | 93d | 0% |  |  |  |  |  |  |  |  |  |  |  |
| 689 | 6.2.2.3 | **Fundiária** |  | 334d | 2019-01-22 A | 2020-05-28 |  | 41% | 195.97d | 2018-06-07 | 2019-11-06 | 361d | 2018-06-07 | 2019-11-06 | 489d |  | 74% | 0% | ok | 0% | Senhora da Penha (distrito Fernandes Tourinho/MG) | 14 | 74 | 117 | 12 |  |  |  |
| 690 | 6.2.2.3.1 | Obter Termo de Autorização de Superficiário - Captação Principal (Rio Doce) - Senhora da Penha/MG |  | 105d | 2019-01-22 A | 2019-06-26 A | 676FS-13d | 100% |  | 2019-06-03 | 2019-06-07 | 5d | 2019-06-03 | 2019-06-07 |  |  | 100% | 0% | ok | 0% | Senhora da Penha (distrito Fernandes Tourinho/MG) |  | 100 |  | 100 |  |  |  |
| 691 | 6.2.2.3.2 | Captação Principal - rio Doce - Desimpedimento de área - Senhora da Penha/MG |  | 161d | 2019-06-27 A | 2020-02-14 | 690 | 20% | 128.8d | 2019-08-06 | 2019-10-07 | 44d | 2019-08-06 | 2019-10-07 | 557d | 68d | 0% | 0% | ok | 0% | Senhora da Penha (distrito Fernandes Tourinho/MG) |  |  |  |  |  |  |  |
| 692 | 6.2.2.3.3 | Obter Termo de Autorização de Superficiário / Desimpedimento de área - Nova ETA / UTR - Senhora da Penha/MG |  | 66d | 2020-02-19 | 2020-05-28 | 683 |  |  | 2019-08-06 | 2019-11-06 | 66d | 2019-08-06 | 2019-11-06 | 489d | 0d | 0% | 0% | ok | 0% | Senhora da Penha (distrito Fernandes Tourinho/MG) |  |  |  |  |  |  |  |
| 693 | 6.2.2.3.4 | Conclusão da Regularização Fundiária para as obras de Melhoria do Sistema de Abastecimento da Localidade - Senhora da Penha/MG | milestone | 0d | 2020-05-28 | 2020-05-28 | 690, 691, 692 |  |  | 2019-11-06 | 2019-11-06 | 0d | 2019-11-06 | 2019-11-06 | 489d | 167d | 0% |  |  |  |  |  |  |  |  |  |  |  |

Notes:
- 675: 22/Nov: / - análise de potabilidade negativa no poço verificado / - PG deve redefinir locação / - locação da captação no Rio Doce pendente / - A nova proposta de captação deverá ser aprovada junto a Prefeitura pelo PG. Solicitado por este à ENG uma estimativa de custo operacional da nova solução proposta para apresentar ao prefeito. Verificar prazo com a ENG.
- 676: 22/Jan19 / - Ver e-mail do Thales com a aprovação da revisão de definição pelo Prefeito de Fernandes Tourinho.
- 678: 25/Jan19: / - Enviado à Engenharia aprovação da Prefeitura para a definição do SAA. Verificar no próximo mês se as datas do cronograma irão mudar em função dessa revisão de definição. / - Laudo da água não está sendo considerado uma vez que a captação será no rio Doce. / 02/Dez: / - Segundo planilha de detalhamento Engenharia/DEPP, deverá ser projetada e instalada nova adutora de interligação entre poços, sistema e de tratamento ao reservatório elevado de água tratada existente, bem como desinfecção do reservatório de água tratada. / 23/Nov: / - Melhoria de ETA não prevista no DEPP do PG, mas sim na planilha de detalhamento do DEPP/ Engenharia. ENG irá verificar necessidade.
- 690: 11/Fev19: / - Ponto de captação será enviado ao Willer pelo Programa ainda nesta data. / 30/Jan19: / - Aguardando definição do Programa quanto ao local do ponto de captação.

| ID | WBS | Task | Type | Duration | Start | Finish | Predecessors | Complete | Remaining | Baseline start | Baseline finish | Baseline duration | Baseline 1 start | Baseline 1 finish | Total slack | Free slack | Text3 | Text4 | Text5 | Text7 | Text15 | Text25 | Text26 | Text27 | Text29 | Indicadores MIR | Text23 |
| --- | --- | --- | --- | --- | --- | --- | --- | --- | --- | --- | --- | --- | --- | --- | --- | --- | --- | --- | --- | --- | --- | --- | --- | --- | --- | --- | --- |
| 694 | 6.2.2.4 | **Licenciamento** |  | 176d | 2020-02-19 | 2020-11-04 |  |  |  | 2018-04-12 | 2020-03-27 | 495d | 2018-04-12 | 2020-03-27 | 509d |  | 62% | 21 | 62 | 95 | 22 | 0% | ok | 0% | Senhora da Penha (distrito Fernandes Tourinho/MG) |  |  |
| 695 | 6.2.2.4.1 | Captação Principal + Nova ETA (mais adução) e UTR - Outorga/DAIA - Senhora da Penha/MG |  | 176d | 2020-02-19 | 2020-11-04 | 683 |  |  | 2019-07-15 | 2020-03-27 | 176d | 2019-07-15 | 2020-03-27 | 509d | 0d | 0% |  |  |  |  | 0% | ok | 0% | Senhora da Penha (distrito Fernandes Tourinho/MG) |  |  |
| 696 | 6.2.2.4.2 | Conclusão do Licenciamento Ambiental da Localidade - Senhora da Penha/MG | milestone | 0d | 2020-11-04 | 2020-11-04 | 695 |  |  | 2020-03-27 | 2020-03-27 | 0d | 2020-03-27 | 2020-03-27 | 757d | 187d | 0% |  |  |  |  |  |  |  |  |  |  |
| 697 | 6.2.2.5 | **Suprimentos** |  | 88d | 2020-09-14 | 2021-01-20 |  |  |  | 2019-10-17 | 2020-02-27 | 88d | 2019-10-17 | 2020-02-27 | 322d |  | 0% |  |  |  |  | 0% | ok | 0% | Senhora da Penha (distrito Fernandes Tourinho/MG) |  |  |
| 698 | 6.2.2.5.1 | Contratação (Captação rio Doce, STA, Nova ETA's/UTR's) - Senhora da Penha/MG |  | 88d | 2020-09-14 | 2021-01-20 | 686 |  |  | 2019-10-17 | 2020-02-27 | 88d | 2019-10-17 | 2020-02-27 | 322d | 0d | 0% |  |  |  |  | 0% | ok | 0% | Senhora da Penha (distrito Fernandes Tourinho/MG) |  |  |
| 699 | 6.2.2.5.2 | Conclusão da Contratação de Suprimentos das obras de Melhoria do Sistema de Abastecimento de Água - Senhora da Penha/MG | milestone | 0d | 2021-01-20 | 2021-01-20 | 698 |  |  | 2020-02-27 | 2020-02-27 | 0d | 2020-02-27 | 2020-02-27 | 705d | 135d | 0% |  |  |  |  |  |  |  |  |  |  |
| 700 | 6.2.2.6 | **Infraestrutura** |  | 380d | 2021-01-28 | 2022-08-05 |  |  |  | 2020-03-27 | 2021-12-22 | 434d | 2020-03-27 | 2021-12-22 | 320d |  | 0% |  |  |  |  | 0% | ok | 0% | Senhora da Penha (distrito Fernandes Tourinho/MG) |  |  |
| 701 | 6.2.2.6.1 | **Obras** |  | 130d | 2021-01-28 | 2021-08-05 |  |  |  | 2020-03-27 | 2020-12-06 | 174d | 2020-03-27 | 2020-12-06 | 322d |  | 0% |  |  |  |  |  |  |  |  |  |  |
| 702 | 6.2.2.6.1.1 | Executar Captação Principal (Balsa, Adutora 1,5km), Nova ETA e UTR - Senhora da Penha/MG |  | 130d | 2021-01-28 | 2021-08-05 | 691, 695FF, 698FS+5d, 754, 688, 693 |  |  | 2020-03-27 | 2020-12-06 | 174d | 2020-03-27 | 2020-12-06 | 322d | 0d | 0% |  |  |  |  | 0% | ok | 0% | Senhora da Penha (distrito Fernandes Tourinho/MG) | ETA |  |
| 703 | 6.2.2.6.1.2 | Assinatura de Termo de Entrega das Obras de Melhoria do Sistema de Abastecimento de Água - Senhora da Penha/MG | milestone | 0d | 2021-08-05 | 2021-08-05 | 702, 696, 699 |  |  | 2020-12-06 | 2020-12-06 | 0d | 2020-12-06 | 2020-12-06 | 570d | 322d | 0% |  |  |  |  | 0% | ok | 0% | Senhora da Penha (distrito Fernandes Tourinho/MG) |  |  |
| 704 | 6.2.2.6.2 | **Operação** |  | 250d | 2021-08-05 | 2022-08-05 |  |  |  | 2020-12-07 | 2021-12-22 | 260d | 2020-12-07 | 2021-12-22 | 320d |  | 0% |  |  |  |  | 0% | ok | 0% | Senhora da Penha (distrito Fernandes Tourinho/MG) |  |  |
| 705 | 6.2.2.6.2.1 | Realizar Treinamento Operacional do Sistema - Senhora da Penha/MG |  | 5d | 2021-08-06 | 2021-08-12 | 702 |  |  | 2020-12-07 | 2020-12-11 | 5d | 2020-12-07 | 2020-12-11 | 551d | 0d | 0% |  |  |  |  | 0% | ok | 0% | Senhora da Penha (distrito Fernandes Tourinho/MG) |  |  |
| 706 | 6.2.2.6.2.2 | Realizar Testes e Pré-operação - Senhora da Penha/MG |  | 14d | 2021-08-13 | 2021-09-01 | 705 |  |  | 2020-12-14 | 2021-01-05 | 14d | 2020-12-14 | 2021-01-05 | 551d |  | 0% |  |  |  |  | 0% | ok | 0% | Senhora da Penha (distrito Fernandes Tourinho/MG) |  |  |
| 707 | 6.2.2.6.2.3 | Realizar Acompanhamento da Funcionalidade do Sistema - Engenharia Captação Principal, Nova ETA e UTR - Senhora da Penha (distrito Fernandes Tourinho/MG) |  | 365ed | 2021-08-05 | 2022-08-05 | 709SS |  |  | 2020-12-07 | 2021-12-22 | 260d |  |  | 1422d |  |  |  |  |  |  |  |  |  |  |  |  |
| 708 | 6.2.2.6.2.4 | **Operação Assistida** |  | 61d | 2021-08-05 | 2021-11-03 |  |  |  | 2020-12-07 | 2021-03-12 | 64d | 2020-12-07 | 2021-03-12 | 322d |  | 0% |  |  |  |  | 0% | ok | 0% | Senhora da Penha (distrito Fernandes Tourinho/MG) |  |  |
| 709 | 6.2.2.6.2.4.1 | Realizar Operação Assistida - Senhora da Penha/MG |  | 90ed | 2021-08-05 | 2021-11-03 | 702 |  |  | 2020-12-07 | 2021-03-12 | 3.2mo | 2020-12-07 | 2021-03-12 | 1422d | 0d | 0% |  |  |  |  | 0% | ok | 0% | Senhora da Penha (distrito Fernandes Tourinho/MG) |  |  |
| 710 | 6.3 | **Pedra Corrida (distrito Periquito/MG)** |  | 1274d | 2018-01-16 A | 2023-02-10 |  | 36% | 811.09d | 2016-10-03 | 2021-12-15 | 1321d | 2016-10-03 | 2021-12-15 | 191d |  | 53% | 40 | 53 | 85 | 47 | 0% | ok | 0% | Pedra Corrida (distrito Periquito/MG) |  | Socioambiental |
| 711 | 6.3.1 | **Captação Principal, Alternativa e Melhorias em ETA** |  | 752d | 2018-01-16 A | 2021-01-09 |  | 56% | 329.95d | 2018-01-16 | 2021-01-02 | 747d |  |  | 713d |  |  |  |  |  |  |  |  |  |  |  |  |
| 712 | 6.3.1.1 | **Estudos de Concepção do Sistema** |  | 198d | 2018-03-14 A | 2018-12-14 A |  | 100% |  | 2018-03-14 | 2019-05-13 | 297d | 2018-03-14 | 2019-05-13 |  |  | 100% | 100 | 100 | 100 | 100 |  |  |  |  |  |  |
| 713 | 6.3.1.1.1 | Declaração de Escopo e Premissas de Projeto (DEPP) concluída - Pedra Corrida/MG | milestone | 0d | 2018-03-23 A | 2018-03-23 A | 25, 26 | 100% |  | 2018-03-23 | 2018-03-23 | 0d | 2018-03-23 | 2018-03-23 |  |  | 100% | 100 | 100 | 100 | 100 | 0% | ok | 0% | Pedra Corrida (distrito Periquito/MG) |  |  |
| 714 | 6.3.1.1.2 | Aprovação das DEPPs pela Operadora e Prefeitura - Pedra Corrida/MG | milestone | 0d | 2018-03-14 A | 2018-03-14 A | 25, 26 | 100% |  | 2018-03-14 | 2018-03-14 | 0d | 2018-03-14 | 2018-03-14 |  |  | 100% | 100 | 100 | 100 | 100 | 0% | ok | 0% | Pedra Corrida (distrito Periquito/MG) |  |  |
| 715 | 6.3.1.1.3 | **Serviços em Poços Tubulares - Captação Alternativa** |  | 36d | 2018-10-26 A | 2018-12-14 A |  | 100% |  | 2018-10-26 | 2018-12-14 | 36d | 2018-10-26 | 2018-12-14 |  |  | 100% | 100 | 100 | 100 | 100 | 0% | ok | 0% | Pedra Corrida (distrito Periquito/MG) |  |  |
| 716 | 6.3.1.1.3.1 | Realizar Perfilagem (Poço 1) - Captação Alternativa - Pedra Corrida/MG |  | 1d | 2018-10-26 A | 2018-10-26 A | 713 | 100% |  | 2018-10-26 | 2018-10-26 | 1d | 2018-10-26 | 2018-10-26 |  |  | 100% | 100 | 100 | 100 | 100 | 0% | ok | 0% | Pedra Corrida (distrito Periquito/MG) |  |  |
| 717 | 6.3.1.1.3.2 | Realizar Recuperação (Poço 1) - Captação Alternativa - Pedra Corrida/MG |  | 1d | 2018-10-26 A | 2018-10-26 A | 716SS | 100% |  | 2018-10-26 | 2018-10-26 | 1d | 2018-10-26 | 2018-10-26 |  |  | 100% | 100 | 100 | 100 | 100 | 0% | ok | 0% | Pedra Corrida (distrito Periquito/MG) |  |  |
| 718 | 6.3.1.1.3.3 | Realizar Teste de Interferência entre o Poço 1 (captação alternativa) e poço vizinho particular - Captação Alternativa - Pedra Corrida/MG |  | 7d | 2018-11-23 A | 2018-12-03 A | 713 | 100% |  | 2018-11-23 | 2018-12-03 | 7d | 2018-11-23 | 2018-12-03 |  |  | 100% | 100 | 100 | 100 | 100 | 0% | ok | 0% | Pedra Corrida (distrito Periquito/MG) |  |  |
| 719 | 6.3.1.1.3.4 | Elaborar Relatório Técnico - Captação Alternativa - Pedra Corrida/MG |  | 9d | 2018-12-04 A | 2018-12-14 A | 716, 717, 718 | 100% |  | 2018-12-04 | 2018-12-14 | 9d | 2018-12-04 | 2018-12-14 |  |  | 100% | 100 | 100 | 100 | 100 | 0% | ok | 0% | Pedra Corrida (distrito Periquito/MG) |  |  |
| 720 | 6.3.1.1.3.5 | Realizar Instrumentação - Captação Alternativa - Pedra Corrida/MG |  | 12d | 2018-11-15 A | 2018-11-30 A | 719FS-60d | 100% |  | 2018-11-15 | 2018-11-30 | 12d | 2018-11-15 | 2018-11-30 |  |  | 100% | 100 | 100 | 100 | 100 | 0% | ok | 0% | Pedra Corrida (distrito Periquito/MG) |  |  |
| 721 | 6.3.1.1.3.6 | Realizar Laudo de Serviços de Coleta e Análise de Água - Captação Alternativa - Pedra Corrida/MG |  | 15d | 2018-11-20 A | 2018-12-10 A | 717FS+16d | 100% |  | 2018-11-20 | 2018-12-10 | 15d | 2018-11-20 | 2018-12-10 |  |  | 100% | 100 | 100 | 100 | 100 | 0% | ok | 0% | Pedra Corrida (distrito Periquito/MG) |  |  |
| 722 | 6.3.1.1.3.7 | Conclusão dos Serviços em poço tubular - Captação Alternativa - Pedra Corrida/MG | milestone | 0d | 2018-12-10 A | 2018-12-10 A | 721 | 100% |  | 2018-12-10 | 2018-12-10 | 0d | 2018-12-10 | 2018-12-10 |  |  | 100% | 100 | 100 | 100 | 100 |  |  |  |  |  |  |

Notes:
- 697: 14/Fev19: / - Em reunião de integração entre as áreas nesta data, foi informado pelo Alessandro (Infraestrutura Território II - Calha e Médio Rio Doce) o abaixo: / . RT para nova contratação de STA Poços Tubulares para: Pedra Corrida, Tumiritinga (sede), Senhora da Penha e São Vitor (GV); e para construções de novas ETA's/UTR's de Senhora da Penha e São Tomé do Rio Doce (Tumiritinga). / . Contrato guarda-chuva existente da Infraestrutura: execução de pequenas melhorias.
- 718: 06/Dez: / - Esclarecimento IGAM para outorga do Poço 1. Necessário para liberação da outorga do Poço 1 em função da proximidade com o poço vizinho.
- 720: 18/Dez / - Planejado para essa data com a Hidropoços (informar data da programação à COPASA).

| ID | WBS | Task | Type | Duration | Start | Finish | Predecessors | Complete | Baseline start | Baseline finish | Baseline duration | Baseline 1 start | Baseline 1 finish | Text3 | Text4 | Text5 | Text7 | Text15 | Text23 | Text25 | Text26 | Text27 | Text29 | Text9 |
| --- | --- | --- | --- | --- | --- | --- | --- | --- | --- | --- | --- | --- | --- | --- | --- | --- | --- | --- | --- | --- | --- | --- | --- | --- |
| 723 | 6.3.1.2 | **Engenharia Básica e Detalhada** |  | 258d | 2018-07-04 A | 2019-07-10 A |  | 100% | 2018-07-04 | 2019-09-09 | 300d | 2018-07-04 | 2019-09-09 | 83% | 73 | 83 | 79 | 92 |  |  |  |  |  |  |
| 724 | 6.3.1.2.1 | **Engenharia Captação Principal (Pequenas Melhorias)** |  | 168d | 2018-09-25 A | 2019-05-27 A |  | 100% | 2018-09-25 | 2019-06-03 | 173d | 2018-09-25 | 2019-06-03 | 100% | 84 | 100 | 84 | 100 | Socioambiental | 0% | ok | 0% | Pedra Corrida (distrito Periquito/MG) |  |
| 725 | 6.3.1.2.1.1 | Aprovar Plano de Trabalho e abrir OSE - Captação Principal - Pedra Corrida/MG |  | 79d | 2018-09-25 A | 2019-01-14 A | 713 | 100% | 2018-09-25 | 2019-01-14 | 79d | 2018-09-25 | 2019-01-14 | 100% | 100 | 100 | 100 | 100 |  | 0% | ok | 0% | Pedra Corrida (distrito Periquito/MG) |  |
| 726 | 6.3.1.2.1.2 | Realizar Levantamento de Campo - Captação Principal - Pedra Corrida/MG |  | 1d | 2018-12-07 A | 2018-12-07 A | 725 | 100% | 2018-12-07 | 2018-12-07 | 1d | 2018-12-07 | 2018-12-07 | 100% | 100 | 100 | 100 | 100 |  | 0% | ok | 0% | Pedra Corrida (distrito Periquito/MG) |  |
| 727 | 6.3.1.2.1.3 | Emitir RT/PQ para Suprimentos - Captação Principal - Pedra Corrida/MG |  | 10d | 2019-05-14 A | 2019-05-27 A | 728FF | 100% | 2019-05-21 | 2019-06-03 | 10d | 2019-05-21 | 2019-06-03 | 100% | 100 | 100 | 100 | 100 |  |  |  |  |  |  |
| 728 | 6.3.1.2.1.4 | Elaborar Projeto Executivo - Captação Principal - Pedra Corrida/MG |  | 125d | 2018-11-23 A | 2019-05-27 A | 726FS-20d | 100% | 2018-11-23 | 2019-06-03 | 130d | 2018-11-23 | 2019-06-03 | 100% | 100 | 100 | 100 | 100 | Socioambiental | 0% | Não OK | 0% | Pedra Corrida (distrito Periquito/MG) | Não OK |
| 729 | 6.3.1.2.1.5 | Elaboração do Projeto Executivo - Captação Principal - Pedra Corrida/MG | milestone | 0d | 2019-05-27 A | 2019-05-27 A | 728 | 100% | 2019-06-03 | 2019-06-03 | 0d | 2019-06-03 | 2019-06-03 | 100% |  | 100 |  | 100 |  |  |  |  |  |  |
| 730 | 6.3.1.2.2 | **Engenharia Captação Alternativa (Poço 1 + STA)** |  | 258d | 2018-07-04 A | 2019-07-10 A |  | 100% | 2018-07-04 | 2019-05-24 | 226d | 2018-07-04 | 2019-05-24 | 100% | 87 | 100 | 87 | 100 | Socioambiental | 0% | ok | 0% | Pedra Corrida (distrito Periquito/MG) |  |
| 731 | 6.3.1.2.2.1 | Aprovar Plano de Trabalho /abertura OSE + Levantamento de Campo - Captação Alternativa - Poço 1 + STA - Pedra Corrida/MG |  | 15d | 2018-07-04 A | 2018-07-24 A | 713 | 100% | 2018-07-04 | 2018-07-24 | 15d | 2018-07-04 | 2018-07-24 | 100% | 100 | 100 | 100 | 100 |  | 0% | ok | 0% | Pedra Corrida (distrito Periquito/MG) |  |
| 732 | 6.3.1.2.2.2 | Levantar Dados de Entrada (topografia) - Captação Alternativa - Poço 1 + STA - Pedra Corrida/MG |  | 29d | 2018-07-25 A | 2018-09-03 A | 731 | 100% | 2018-07-25 | 2018-09-03 | 29d | 2018-07-25 | 2018-09-03 | 100% | 100 | 100 | 100 | 100 | Socioambiental | 0% | Não OK | 0% | Pedra Corrida (distrito Periquito/MG) | Não OK |
| 733 | 6.3.1.2.2.3 | Elaborar Projeto As Built do Poço - Captação Alternativa - Poço 1 + STA - Pedra Corrida/MG |  | 63d | 2018-07-25 A | 2018-10-19 A | 731 | 100% | 2018-07-25 | 2018-10-19 | 63d | 2018-07-25 | 2018-10-19 | 100% | 100 | 100 | 100 | 100 |  | 0% | ok | 0% | Pedra Corrida (distrito Periquito/MG) |  |
| 734 | 6.3.1.2.2.4 | Emitir RT/PQ para Infra (CGC) - Captação Alternativa - Poço 1 + STA - Pedra Corrida/MG |  | 10d | 2019-05-20 A | 2019-07-10 A | 735FF | 100% | 2019-05-13 | 2019-05-24 | 10d | 2019-05-13 | 2019-05-24 | 100% | 97 | 100 | 97 | 100 |  |  |  |  |  |  |
| 735 | 6.3.1.2.2.5 | Elaborar Projeto Executivo - Captação Alternativa - Poço 1 + STA - Pedra Corrida/MG |  | 236d | 2018-07-25 A | 2019-07-01 A | 719FF, 731, 732FF | 100% | 2018-07-25 | 2019-05-24 | 211d | 2018-07-25 | 2019-05-24 | 100% | 97 | 100 | 97 | 100 | Socioambiental | 0% | Não OK | 0% | Pedra Corrida (distrito Periquito/MG) | Não OK |
| 736 | 6.3.1.2.2.6 | Elaboração do Projeto Executivo - Captação Alternativa - Poço 1 + STA - Pedra Corrida/MG | milestone | 0d | 2019-07-01 A | 2019-07-01 A | 735, 729 | 100% | 2019-05-24 | 2019-05-24 | 0d | 2019-05-24 | 2019-05-24 | 100% |  | 100 |  | 100 |  |  |  |  |  |  |
| 737 | 6.3.1.2.3 | **Engenharia Melhorias ETA** |  | 168d | 2018-09-25 A | 2019-05-27 A |  | 100% | 2018-09-25 | 2019-06-03 | 173d | 2018-09-25 | 2019-06-03 | 100% | 84 | 100 | 84 | 100 | Socioambiental | 0% | ok | 0% | Pedra Corrida (distrito Periquito/MG) |  |
| 738 | 6.3.1.2.3.1 | Aprovar Plano de Trabalho /abertura OSE - Melhorias na ETA - Pedra Corrida/MG |  | 79d | 2018-09-25 A | 2019-01-14 A | 713 | 100% | 2018-09-25 | 2019-01-14 | 79d | 2018-09-25 | 2019-01-14 | 100% | 100 | 100 | 100 | 100 |  | 0% | ok | 0% | Pedra Corrida (distrito Periquito/MG) |  |
| 739 | 6.3.1.2.3.2 | Realizar Levantamento de Campo - Melhorias na ETA - Pedra Corrida/MG |  | 1d | 2018-12-07 A | 2018-12-07 A | 738SS+53d | 100% | 2018-12-07 | 2018-12-07 | 1d | 2018-12-07 | 2018-12-07 | 100% | 100 | 100 | 100 | 100 |  | 0% | ok | 0% | Pedra Corrida (distrito Periquito/MG) |  |
| 740 | 6.3.1.2.3.3 | Emitir RT/PQ para Suprimentos - Melhorias na ETA - Pedra Corrida/MG |  | 10d | 2019-05-14 A | 2019-05-27 A | 741FF | 100% | 2019-05-21 | 2019-06-03 | 10d | 2019-05-21 | 2019-06-03 | 100% | 100 | 100 | 100 | 100 |  |  |  |  |  |  |
| 741 | 6.3.1.2.3.4 | Elaborar Projeto Executivo - Melhorias na ETA - Pedra Corrida/MG |  | 125d | 2018-11-23 A | 2019-05-27 A | 721, 722, 739 | 100% | 2018-11-23 | 2019-06-03 | 130d | 2018-11-23 | 2019-06-03 | 100% | 100 | 100 | 100 | 100 | Socioambiental | 0% | Não OK | 0% | Pedra Corrida (distrito Periquito/MG) | Não OK |
| 742 | 6.3.1.2.3.5 | Elaboração do Projeto Executivo - Melhorias na ETA - Pedra Corrida/MG | milestone | 0d | 2019-05-27 A | 2019-05-27 A | 740, 741 | 100% | 2019-06-03 | 2019-06-03 | 0d | 2019-06-03 | 2019-06-03 | 100% |  | 100 |  | 100 |  |  |  |  |  |  |
| 743 | 6.3.1.3 | **Fundiária** |  | 332d | 2018-05-21 A | 2019-09-09 A |  | 100% | 2018-05-21 | 2019-08-28 | 324d | 2018-05-21 | 2019-08-28 | 87% | 69 | 87 | 86 | 80 |  | 0% | ok | 0% | Pedra Corrida (distrito Periquito/MG) |  |
| 744 | 6.3.1.3.1 | Obter Declaração de posse Prefeitura - Desimpedimento de área - Captação Alternativa (Poço 1) - Pedra Corrida/MG |  | 145d | 2018-05-21 A | 2018-12-07 A | 713FS+41d | 100% | 2018-05-21 | 2018-12-07 | 145d | 2018-05-21 | 2018-12-07 | 100% | 100 | 100 | 100 | 100 |  | 0% | ok | 0% | Pedra Corrida (distrito Periquito/MG) |  |
| 745 | 6.3.1.3.2 | Realizar Desimpedimento de área - Captação Alternativa - Adutora - Pedra Corrida/MG |  | 49d | 2019-07-02 A | 2019-09-09 A | 735, 744 | 100% | 2019-05-27 | 2019-08-28 | 66d | 2019-05-27 | 2019-08-28 | 36% |  | 36 |  | 36 |  | 0% | ok | 0% | Pedra Corrida (distrito Periquito/MG) |  |
| 746 | 6.3.1.3.3 | Conclusão da Regularização Fundiária para as obras de Melhoria do Sistema de Abastecimento da Localidade - Pedra Corrida/MG | milestone | 0d | 2019-09-09 A | 2019-09-09 A | 744, 745 | 100% | 2019-08-28 | 2019-08-28 | 0d | 2019-08-28 | 2019-08-28 | 0% |  |  |  |  |  |  |  |  |  |  |

Notes:
- 724: 24/Jan19: / - Segundo Engenharia, Projeto Básico não aplicável por se tratar apenas de pequenas melhorias.
- 730: 25/Jan19: / - Engenharia considerando no Cronograma para Captação Alternativa, projeto de AS BUILT DO POÇO E STA (Sistema Tratamento de Água). / 02/Dez: / - No cronograma da Engenharia consta, além do as built do poço, "adução poço/ETA". Refere-se a captação alternativa. (23/Jan19 - Item não consta mais no CR ENG). / - Considerar no CR do PG - Captação Alternativa - data de início do as built do poço. / 23/Nov: / - Segunda planilha de detalhamento da Engenharia/DEPP, deverá ser feita a urbanização e as built do poço. E pelo DEPP outras "melhorias" no SAA.
- 737: 24/Jan19: / - Segundo a Engenharia, Projeto Básico não aplicável por se tratar apenas de pequenas melhorias.
- 744: 02/Dez: / - Segundo planilha Fundiário, imóvel sob posse da UHE Baguari conforme Lei Municipal nº 276/2008. Porém, sem registro imobiliário identificado. UHE se nega a prestar maiores esclarecimentos devido aos litígios referentes ao evento de Mariana. Já foi tentado obter informações acerca dos terrenos nos Cartórios, Prefeitura Municipal e SIGEF.
- 745: 11/Fev19: / - Aguardando mapas (Engenharia - traçado + faixa de servidão) e parecer jurídico para iniciar os trabalhos.

| ID | WBS | Task | Type | Duration | Start | Finish | Predecessors | Complete | Remaining | Baseline start | Baseline finish | Baseline duration | Baseline 1 start | Baseline 1 finish | Total slack | Free slack | Text3 | Text4 | Text5 | Text7 | Text15 | Text23 | Text25 | Text26 | Text27 | Text29 | Text9 | Text1 | Text13 | Indicadores MIR |
| --- | --- | --- | --- | --- | --- | --- | --- | --- | --- | --- | --- | --- | --- | --- | --- | --- | --- | --- | --- | --- | --- | --- | --- | --- | --- | --- | --- | --- | --- | --- |
| 747 | 6.3.1.4 | **Licenciamento** |  | 513d | 2018-01-16 A | 2020-01-22 |  | 80% | 101.61d | 2018-01-16 | 2019-05-10 | 337d | 2018-01-16 | 2019-05-10 | 952d |  | 100% | 97 | 100 | 97 | 100 | Socioambiental | 0% | ok | 0% | Pedra Corrida (distrito Periquito/MG) |  |  |  |  |
| 748 | 6.3.1.4.1 | Obter Outorga para Captação Alternativa (Poço 1) - Pedra Corrida/MG |  | 264d | 2018-01-16 A | 2019-01-21 A | 26FS+41d | 100% |  | 2018-01-16 | 2019-01-21 | 264d | 2018-01-16 | 2019-01-21 |  |  | 100% | 100 | 100 | 100 | 100 | Socioambiental | 0% | Não OK | 0% | Pedra Corrida (distrito Periquito/MG) |  |  |  |  |
| 749 | 6.3.1.4.2 | Obter DAIA para Captação Alternativa (Poço 1) - Pedra Corrida/MG |  | 513d | 2018-01-16 A | 2020-01-22 | 26FS+41d | 70% | 153.9d | 2018-01-16 | 2019-05-10 | 337d | 2018-01-16 | 2019-05-10 | 952d | 0d | 100% | 95 | 100 | 95 | 100 | Socioambiental | 0% | Não OK | 0% | Pedra Corrida (distrito Periquito/MG) | Não OK |  |  |  |
| 750 | 6.3.1.4.3 | Conclusão do Licenciamento Ambiental da Localidade - Pedra Corrida/MG | milestone | 0d | 2020-01-22 | 2020-01-22 | 748, 749 |  |  | 2019-05-10 | 2019-05-10 | 0d | 2019-05-10 | 2019-05-10 | 952d | 0d | 100% |  | 100 |  | 100 |  |  |  |  |  |  |  |  |  |
| 751 | 6.3.1.5 | **Infraestrutura** |  | 404d | 2019-05-27 A | 2021-01-09 |  | 22% | 314.03d | 2016-10-03 | 2021-12-15 | 1321d | 2016-10-03 | 2021-12-15 | 713d |  | 53% |  | 53 | 100 |  |  | 0% | ok | 0% | Pedra Corrida (distrito Periquito/MG) |  |  |  |  |
| 752 | 6.3.1.5.1 | **Obras** |  | 232d | 2019-05-27 A | 2020-05-04 |  | 85% | 35.29d | 2016-10-03 | 2021-01-04 | 1084d | 2016-10-03 | 2021-01-04 | 885d |  | 65% | 10 | 65 | 100 | 10 |  |  |  |  |  |  |  |  |  |
| 753 | 6.3.1.5.1.1 | **Captação Principal e Melhorias em ETA** |  | 165d | 2019-05-27 A | 2020-01-22 |  | 99% | 0d | 2019-07-08 | 2019-11-28 | 102d |  |  | 952d |  |  |  |  |  |  |  |  |  |  |  |  | 8888 |  |  |
| 754 | 6.3.1.5.1.1.1 | Captação Principal e Melhorias na ETA (contrato guarda-chuva existente - Infraestrutura) - Pedra Corrida/MG | milestone | 0d | 2019-05-27 A | 2019-05-27 A | 727, 728, 741, 742 | 100% |  | 2019-08-12 | 2019-09-26 | 0d | 2019-08-12 | 2019-09-26 |  |  | 0% |  |  |  |  |  | 0% | ok | 0% | Pedra Corrida (distrito Periquito/MG) |  |  |  |  |
| 755 | 6.3.1.5.1.1.2 | Executar Captação Principal (Melhorias) - Pedra Corrida/MG |  | 98d | 2019-07-08 A | 2019-11-22 A | 728FS+28d, 754 | 100% |  | 2019-11-21 | 2020-03-02 | 66d | 2019-11-21 | 2020-03-02 |  |  | 0% |  |  |  |  |  | 0% | ok | 0% | Pedra Corrida (distrito Periquito/MG) |  |  |  |  |
| 756 | 6.3.1.5.1.1.3 | Executar Melhorias de ETA - Pedra Corrida/MG |  | 129d | 2019-07-08 A | 2020-01-10 A | 741FS+28d, 754 | 100% |  | 2019-11-21 | 2020-11-06 | 238d | 2019-11-21 | 2020-11-06 |  |  | 0% |  |  |  |  |  | 0% | ok | 0% | Pedra Corrida (distrito Periquito/MG) |  |  | 8888888 |  |
| 757 | 6.3.1.5.1.1.4 | Realizar fornecimento dos Pallets de Contenção de Químicos (Melhorias em ETA) - Pedra Corrida/MG |  | 31d | 2019-10-04 A | 2019-11-18 A | 756SS+63d | 100% |  | 2019-10-04 | 2019-11-28 | 39d |  |  |  |  |  |  |  |  |  |  |  |  |  |  |  | 8888 |  |  |
| 758 | 6.3.1.5.1.1.5 | Conclusão das Obras de Captação Principal e Melhorias em ETA - Pedra Corrida/MG | milestone | 0d | 2020-01-22 | 2020-01-22 | 755, 756, 757, 746, 750 |  |  | 2019-11-28 | 2019-11-28 | 0d |  |  | 952d | 67d |  |  |  |  |  |  |  |  |  |  |  | 8888 |  | ETA |
| 759 | 6.3.1.5.1.2 | **Captação Alternativa** |  | 155d | 2019-09-16 A | 2020-05-04 |  | 68% | 49.47d | 2019-09-16 | 2020-01-03 | 75d |  |  | 885d |  |  |  |  |  |  |  |  |  |  |  |  | 8888 |  |  |
| 760 | 6.3.1.5.1.2.1 | Executar Captação Alternativa (Adutora - Poço 1) - Pedra Corrida/MG |  | 80d | 2019-09-16 A | 2020-01-10 A | 720, 734, 735, 744, 745, 748, 749FF, 736 | 100% |  | 2019-12-17 | 2020-03-25 | 66d | 2019-12-17 | 2020-03-25 |  |  | 0% |  |  |  |  |  | 0% | ok | 0% | Pedra Corrida (distrito Periquito/MG) |  |  | 8888888 | CA |
| 761 | 6.3.1.5.1.2.2 | Executar Urbanização do Poço 1 - Pedra Corrida/MG |  | 80d | 2019-09-16 A | 2020-01-10 A | 760SS | 100% |  | 2019-09-16 | 2020-01-03 | 75d |  |  |  |  |  |  |  |  |  |  |  |  |  |  |  | 8888 | 8888888 |  |
| 762 | 6.3.1.5.1.2.3 | Executar Instalação do Filtro - Poço 1 - Pedra Corrida/MG |  | 75d | 2020-01-13 | 2020-05-04 | 760SS, 761 |  |  | 2019-09-16 | 2020-01-03 | 75d |  |  | 885d | 0d |  |  |  |  |  |  |  |  |  |  |  | 8888 |  |  |
| 763 | 6.3.1.5.1.2.4 | Conclusão das Obras de Captação Alternativa - Pedra Corrida/MG | milestone | 0d | 2020-05-04 | 2020-05-04 | 760, 761, 762 |  |  | 2020-01-03 | 2020-01-03 | 0d |  |  | 885d | 0d |  |  |  |  |  |  |  |  |  |  |  | 8888 |  |  |
| 764 | 6.3.1.5.1.3 | Assinatura de Termo de Entrega das Obras de Melhoria do Sistema de Abastecimento de Água - Pedra Corrida/MG | milestone | 0d | 2020-05-04 | 2020-05-04 | 755, 756, 758, 760, 763 |  |  | 2021-01-04 | 2021-01-04 | 0d | 2021-01-04 | 2021-01-04 | 885d | 637d | 0% |  |  |  |  |  | 0% | ok | 0% | Pedra Corrida (distrito Periquito/MG) |  |  |  |  |
| 765 | 6.3.1.5.2 | **Operação** |  | 247d | 2020-01-10 | 2021-01-09 |  |  |  | 2020-11-30 | 2021-12-15 | 260d | 2020-11-30 | 2021-12-15 | 712d |  | 0% |  |  |  |  |  | 0% | ok | 0% | Pedra Corrida (distrito Periquito/MG) |  |  |  |  |
| 766 | 6.3.1.5.2.1 | Realizar Treinamento Operacional do Sistema - Pedra Corrida/MG |  | 5d | 2020-01-13 | 2020-01-17 | 755, 756, 760 |  |  | 2020-11-30 | 2020-12-04 | 5d | 2020-11-30 | 2020-12-04 | 941d | 0d | 0% |  |  |  |  |  | 0% | ok | 0% | Pedra Corrida (distrito Periquito/MG) |  |  |  |  |
| 767 | 6.3.1.5.2.2 | Realizar Testes e Pré-operação - Pedra Corrida/MG |  | 14d | 2020-01-20 | 2020-02-06 | 766 |  |  | 2020-12-07 | 2020-12-28 | 14d | 2020-12-07 | 2020-12-28 | 941d |  | 0% |  |  |  |  |  | 0% | ok | 0% | Pedra Corrida (distrito Periquito/MG) |  |  |  |  |
| 768 | 6.3.1.5.2.3 | Realizar Acompanhamento da Funcionalidade do Sistema - Captação Principal, Alternativa e Melhorias em ETA - Pedra Corrida (distrito Periquito/MG) |  | 365ed | 2020-01-10 | 2021-01-09 | 770SS |  |  | 2020-01-03 | 2021-01-02 | 365ed |  |  | 3141d |  |  |  |  |  |  |  |  |  |  |  |  |  |  |  |
| 769 | 6.3.1.5.2.4 | **Operação Assistida** |  | 61d | 2020-01-10 | 2020-04-09 |  |  |  | 2020-11-30 | 2021-03-05 | 64d | 2020-11-30 | 2021-03-05 | 712d |  | 0% |  |  |  |  |  | 0% | ok | 0% | Pedra Corrida (distrito Periquito/MG) |  |  |  |  |
| 770 | 6.3.1.5.2.4.1 | Realizar Operação Assistida - Pedra Corrida/MG |  | 90ed | 2020-01-10 | 2020-04-09 | 755, 756, 760 |  |  | 2020-11-30 | 2021-03-05 | 3.2mo | 2020-11-30 | 2021-03-05 | 3141d | 0d | 0% |  |  |  |  |  | 0% | ok | 0% | Pedra Corrida (distrito Periquito/MG) |  |  |  |  |

Notes:
- 747: 02/Dez: / - Não está prevista outra Licença para a localidade (ETA, etc.). Apenas para captação alternativa.
- 749: 06/06/19: Em análise pelo órgão. / 26/04/19: Em pedido de informação complementar.

| ID | WBS | Task | Type | Duration | Start | Finish | Predecessors | Complete | Remaining | Baseline start | Baseline finish | Baseline duration | Baseline 1 start | Baseline 1 finish | Total slack | Free slack | Text3 | Text4 | Text5 | Text7 | Text15 | Text25 | Text26 | Text27 | Text29 | Text13 | Text23 | Text1 |
| --- | --- | --- | --- | --- | --- | --- | --- | --- | --- | --- | --- | --- | --- | --- | --- | --- | --- | --- | --- | --- | --- | --- | --- | --- | --- | --- | --- | --- |
| 771 | 6.3.2 | **UTR** |  | 932d | 2019-05-20 A | 2023-02-10 |  | 1% | 921.18d | 2018-03-14 | 2021-12-15 | 944d |  |  | 191d |  |  |  |  |  |  |  |  |  |  |  |  |  |
| 772 | 6.3.2.1 | **Estudos de Concepção do Sistema** |  | 10d | 2019-05-20 A | 2019-05-31 A |  | 100% |  | 2018-03-14 | 2019-05-13 | 297d | 2018-03-14 | 2019-05-13 |  |  | 100% | 100 | 100 | 100 | 100 |  |  |  |  |  |  |  |
| 773 | 6.3.2.1.1 | **Coleta e Análise do Lodo de ETA** |  | 10d | 2019-05-20 A | 2019-05-31 A |  | 100% |  | 2019-04-29 | 2019-05-13 | 10d | 2019-04-29 | 2019-05-13 |  |  | 100% | 100 | 100 | 100 | 100 |  |  |  |  |  |  |  |
| 774 | 6.3.2.1.1.1 | Executar Coleta e Análise do Lodo de ETA - Pedra Corrida/MG |  | 10d | 2019-05-20 A | 2019-05-31 A |  | 100% |  | 2019-04-29 | 2019-05-13 | 10d | 2019-04-29 | 2019-05-13 |  |  | 100% | 100 | 100 | 100 | 100 |  |  |  |  |  |  |  |
| 775 | 6.3.2.1.1.2 | Conclusão das Coletas e Análises de Lodo de ETA - Pedra Corrida/MG | milestone | 0d | 2019-05-31 A | 2019-05-31 A | 774 | 100% |  | 2019-05-13 | 2019-05-13 | 0d | 2019-05-13 | 2019-05-13 |  |  | 100% | 100 | 100 | 100 | 100 |  |  |  |  |  |  |  |
| 776 | 6.3.2.1.2 | Conclusão dos Estudos de Concepção das Melhorias do Sistema de Abastecimento de Água - Pedra Corrida/MG | milestone | 0d | 2019-05-31 A | 2019-05-31 A | 775 | 100% |  | 2018-12-10 | 2018-12-10 | 0d | 2018-12-10 | 2018-12-10 |  |  | 100% | 100 | 100 | 100 | 100 |  |  |  |  |  |  |  |
| 777 | 6.3.2.2 | **Engenharia Básica e Detalhada** |  | 284d | 2019-10-24 A | 2020-12-15 |  | 7% | 264.7d | 2018-07-04 | 2019-09-09 | 300d | 2018-07-04 | 2019-09-09 | 728d |  | 83% | 73 | 83 | 79 | 92 |  |  |  |  |  |  |  |
| 778 | 6.3.2.2.1 | **Engenharia UTR** |  | 284d | 2019-10-24 A | 2020-12-15 |  | 7% | 264.7d | 2018-12-10 | 2019-08-09 | 167d | 2018-12-10 | 2019-08-09 | 728d |  | 82% | 17 | 82 | 27 | 62 | 0% | ok | 0% | Pedra Corrida (distrito Periquito/MG) |  |  |  |
| 779 | 6.3.2.2.1.1 | Aprovar Plano de Trabalho /abertura OSE - UTR - Pedra Corrida/MG |  | 8d | 2019-10-24 A | 2019-11-04 A |  | 100% |  | 2018-12-10 | 2018-12-21 | 10d | 2018-12-10 | 2018-12-21 |  |  | 100% | 100 | 100 | 100 | 100 | 0% | ok | 0% | Pedra Corrida (distrito Periquito/MG) | 8888888 |  |  |
| 780 | 6.3.2.2.1.2 | Realizar Sondagem - UTR - Pedra Corrida/MG |  | 6d | 2019-11-05 A | 2019-11-12 A | 779 | 100% |  | 2019-11-05 | 2019-11-12 | 6d |  |  |  |  |  |  |  |  |  |  |  |  |  | 8888888 |  |  |
| 781 | 6.3.2.2.1.3 | Elaborar arranjo para obtenção de Dados de Entrada Licenciamento - UTR - Pedra Corrida/MG |  | 38d | 2020-03-26 | 2020-05-21 | 775, 779, 780FS+88d |  |  | 2019-05-14 | 2019-06-17 | 25d | 2019-05-14 | 2019-06-17 | 192d | 0d | 100% | 80 | 100 | 80 | 100 | 0% | ok | 0% | Pedra Corrida (distrito Periquito/MG) |  |  |  |
| 782 | 6.3.2.2.1.4 | Elaborar Projeto Básico - UTR - Pedra Corrida/MG |  | 65d | 2020-05-22 | 2020-08-21 | 781 |  |  | 2018-02-08 | 2018-03-21 | 30d | 2018-02-08 | 2018-03-21 | 192d | 0d | 100% |  | 100 |  | 100 |  |  |  |  |  |  |  |
| 783 | 6.3.2.2.1.5 | Aprovar Projeto Básico - UTR - Pedra Corrida/MG |  | 22d | 2020-08-24 | 2020-09-23 | 782 |  |  | 2018-03-01 | 2018-03-30 | 22d |  |  | 192d | 0d |  |  |  |  |  |  |  |  |  |  |  |  |
| 784 | 6.3.2.2.1.6 | Emitir RT/PQ para Suprimentos - UTR - Pedra Corrida/MG |  | 10d | 2020-12-02 | 2020-12-15 | 782, 785FF |  |  | 2019-06-18 | 2019-07-05 | 13d | 2019-06-18 | 2019-07-05 | 192d | 0d | 61% |  | 61 |  | 61 | 0% | ok | 0% | Pedra Corrida (distrito Periquito/MG) |  |  |  |
| 785 | 6.3.2.2.1.7 | Elaborar Projeto Executivo - UTR - Pedra Corrida/MG |  | 57d | 2020-09-24 | 2020-12-15 | 782, 783 |  |  | 2019-05-10 | 2019-08-09 | 65d | 2019-05-10 | 2019-08-09 | 192d | 0d | 53% |  | 53 |  | 53 | 0% | ok | 0% | Pedra Corrida (distrito Periquito/MG) |  |  |  |
| 786 | 6.3.2.2.1.8 | Elaboração do Projeto Executivo - UTR - Pedra Corrida/MG | milestone | 0d | 2020-12-15 | 2020-12-15 | 782, 785, 776 |  |  | 2019-08-09 | 2019-08-09 | 0d | 2019-08-09 | 2019-08-09 | 728d | 88d | 0% |  |  |  |  |  |  |  |  |  |  |  |
| 787 | 6.3.2.3 | **Licenciamento** |  | 180d | 2020-05-22 | 2021-02-08 |  |  |  | 2018-01-16 | 2019-05-10 | 337d | 2018-01-16 | 2019-05-10 | 444d |  | 100% | 97 | 100 | 97 | 100 | 0% | ok | 0% | Pedra Corrida (distrito Periquito/MG) |  | Socioambiental |  |
| 788 | 6.3.2.3.1 | Obter DAIA para execução da UTR - Pedra Corrida/MG |  | 180d | 2020-05-22 | 2021-02-08 | 781 |  |  | 2020-01-30 | 2020-10-20 | 180d |  |  | 444d | 0d |  |  |  |  |  |  |  |  |  |  |  | 8888 |
| 789 | 6.3.2.3.2 | Conclusão do Licenciamento Ambiental da Localidade - Pedra Corrida/MG | milestone | 0d | 2021-02-08 | 2021-02-08 | 788 |  |  | 2019-05-10 | 2019-05-10 | 0d | 2019-05-10 | 2019-05-10 | 692d | 252d | 100% |  | 100 |  | 100 |  |  |  |  |  |  |  |
| 790 | 6.3.2.4 | **Suprimentos** |  | 88d | 2020-12-16 | 2021-04-28 |  |  |  | 2019-08-09 | 2019-12-16 | 89d | 2019-08-09 | 2019-12-16 | 192d |  | 0% |  |  |  |  | 0% | ok | 0% | Pedra Corrida (distrito Periquito/MG) |  |  |  |
| 791 | 6.3.2.4.1 | Contratação MAS 2 (UTR's) - Pedra Corrida/MG |  | 88d | 2020-12-16 | 2021-04-28 | 784 |  |  | 2019-08-09 | 2019-12-13 | 88d | 2019-08-09 | 2019-12-13 | 192d | 0d | 0% |  |  |  |  | 0% | ok | 0% | Pedra Corrida (distrito Periquito/MG) |  |  |  |
| 792 | 6.3.2.4.2 | Conclusão da Contratação de Suprimentos das obras de Melhoria do Sistema de Abastecimento de Água - Pedra Corrida/MG | milestone | 0d | 2021-04-28 | 2021-04-28 | 791, 786 |  |  | 2019-12-16 | 2019-12-16 | 0d | 2019-12-16 | 2019-12-16 | 640d | 200d | 0% |  |  |  |  |  |  |  |  |  |  |  |
| 793 | 6.3.2.5 | **Infraestrutura** |  | 449d | 2021-04-29 | 2023-02-10 |  |  |  | 2016-10-03 | 2021-12-15 | 1321d | 2016-10-03 | 2021-12-15 | 191d |  | 53% |  | 53 | 100 |  | 0% | ok | 0% | Pedra Corrida (distrito Periquito/MG) |  |  |  |
| 794 | 6.3.2.5.1 | **Obras** |  | 200d | 2021-04-29 | 2022-02-10 |  |  |  | 2016-10-03 | 2021-01-04 | 1084d | 2016-10-03 | 2021-01-04 | 192d |  | 65% | 10 | 65 | 100 | 10 |  |  |  |  |  |  |  |
| 795 | 6.3.2.5.1.1 | Executar UTR - Pedra Corrida/MG |  | 200d | 2021-04-29 | 2022-02-10 | 785, 791, 1204, 788FF |  |  | 2019-12-13 | 2020-11-27 | 238d | 2019-12-13 | 2020-11-27 | 192d | 0d | 0% |  |  |  |  | 0% | ok | 0% | Pedra Corrida (distrito Periquito/MG) |  |  |  |
| 796 | 6.3.2.5.1.2 | Assinatura de Termo de Entrega das Obras de Melhoria do Sistema de Abastecimento de Água - Pedra Corrida/MG | milestone | 0d | 2022-02-10 | 2022-02-10 | 795, 789, 792 |  |  | 2021-01-04 | 2021-01-04 | 0d | 2021-01-04 | 2021-01-04 | 440d | 192d | 0% |  |  |  |  | 0% | ok | 0% | Pedra Corrida (distrito Periquito/MG) |  |  |  |

Notes:
- 787: 02/Dez: / - Não está prevista outra Licença para a localidade (ETA, etc.). Apenas para captação alternativa.
- 790: 14/Fev19: / - RT contratação junto com Senhora da Penha e São Vítor, conforme abaixo: / - Em reunião de integração entre as áreas nesta data, foi informado pelo Alessandro (Infraestrutura Território II - Calha e Médio Rio Doce) o abaixo: / . RT para nova contratação de STA Poços Tubulares para: Pedra Corrida, Tumiritinga (sede), Senhora da Penha e São Vitor (GV); e para construções de novas ETA's/UTR's de Senhora da Penha e São Tomé do Rio Doce (Tumiritinga). / . Contrato guarda-chuva existente da Infraestrutura: execução de pequenas melhorias (ETA, Captação Principal).

| ID | WBS | Task | Type | Duration | Start | Finish | Predecessors | Complete | Remaining | Baseline start | Baseline finish | Baseline duration | Baseline 1 start | Baseline 1 finish | Total slack | Free slack | Text3 | Text25 | Text26 | Text27 | Text29 | Text4 | Text5 | Text7 | Text15 | Text23 | Text1 | Text9 |
| --- | --- | --- | --- | --- | --- | --- | --- | --- | --- | --- | --- | --- | --- | --- | --- | --- | --- | --- | --- | --- | --- | --- | --- | --- | --- | --- | --- | --- |
| 797 | 6.3.2.5.2 | **Operação** |  | 249d | 2022-02-10 | 2023-02-10 |  |  |  | 2020-11-30 | 2021-12-15 | 260d | 2020-11-30 | 2021-12-15 | 191d |  | 0% | 0% | ok | 0% | Pedra Corrida (distrito Periquito/MG) |  |  |  |  |  |  |  |
| 798 | 6.3.2.5.2.1 | Realizar Treinamento Operacional do Sistema - Pedra Corrida/MG |  | 5d | 2022-02-11 | 2022-02-17 | 795 |  |  | 2020-11-30 | 2020-12-04 | 5d | 2020-11-30 | 2020-12-04 | 421d | 0d | 0% | 0% | ok | 0% | Pedra Corrida (distrito Periquito/MG) |  |  |  |  |  |  |  |
| 799 | 6.3.2.5.2.2 | Realizar Testes e Pré-operação - Pedra Corrida/MG |  | 14d | 2022-02-18 | 2022-03-14 | 798 |  |  | 2020-12-07 | 2020-12-28 | 14d | 2020-12-07 | 2020-12-28 | 421d |  | 0% | 0% | ok | 0% | Pedra Corrida (distrito Periquito/MG) |  |  |  |  |  |  |  |
| 800 | 6.3.2.5.2.3 | Realizar Acompanhamento da Funcionalidade do Sistema - UTR - Pedra Corrida (distrito Periquito/MG) |  | 365ed | 2022-02-10 | 2023-02-10 | 802SS |  |  | 2020-11-30 | 2021-12-15 | 260d |  |  | 855d |  |  |  |  |  |  |  |  |  |  |  |  |  |
| 801 | 6.3.2.5.2.4 | **Operação Assistida** |  | 59d | 2022-02-10 | 2022-05-11 |  |  |  | 2020-11-30 | 2021-03-05 | 64d | 2020-11-30 | 2021-03-05 | 192d |  | 0% | 0% | ok | 0% | Pedra Corrida (distrito Periquito/MG) |  |  |  |  |  |  |  |
| 802 | 6.3.2.5.2.4.1 | Realizar Operação Assistida - Pedra Corrida/MG |  | 90ed | 2022-02-10 | 2022-05-11 | 795 |  |  | 2020-11-30 | 2021-03-05 | 3.2mo | 2020-11-30 | 2021-03-05 | 855d | 0d | 0% | 0% | ok | 0% | Pedra Corrida (distrito Periquito/MG) |  |  |  |  |  |  |  |
| 803 | 6.4 | **Alpercata/MG (sede)** |  | 1360d | 2018-03-23 A | 2023-08-29 |  | 1% | 1347.09d | 2018-03-23 | 2022-01-24 | 964d | 2018-03-23 | 2022-01-24 | 57d |  | 33% | 0% | ok | 0% | Alpercata/MG (sede) | 10 | 33 | 30 | 33 | Socioambiental |  |  |
| 804 | 6.4.1 | **Captação Principal, Nova ETA e UTR** |  | 1360d | 2018-03-23 A | 2023-08-29 |  | 1% | 1347.09d | 2018-03-23 | 2022-01-24 | 964d |  |  | 57d |  |  |  |  |  |  |  |  |  |  |  |  |  |
| 805 | 6.4.1.1 | Declaração de Escopo e Premissas de Projeto (DEPP) concluída - Alpercata/MG | milestone | 0d | 2018-03-23 A | 2018-03-23 A | 25, 26 | 100% |  | 2018-03-23 | 2018-03-23 | 0d | 2018-03-23 | 2018-03-23 |  |  | 100% | 0% | ok | 0% | Alpercata/MG (sede) | 100 | 100 | 100 | 100 |  |  |  |
| 806 | 6.4.1.2 | Aprovação das DEPPs pela Operadora e Prefeitura - Alpercata/MG | milestone | 0d | 2018-03-23 A | 2018-03-23 A | 25, 26 | 100% |  | 2018-03-23 | 2018-03-23 | 0d | 2018-03-23 | 2018-03-23 |  |  | 100% | 0% | ok | 0% | Alpercata/MG (sede) | 100 | 100 | 100 | 100 |  |  |  |
| 807 | 6.4.1.3 | **Estudos de Concepção do Sistema** |  | 128d | 2019-07-09 A | 2020-01-10 |  | 30% | 90d | 2019-07-09 | 2020-01-10 | 128d |  |  | 57d |  |  |  |  |  |  |  |  |  |  |  |  |  |
| 808 | 6.4.1.3.1 | Pleito da COPASA no CIF de nova solução para a localidade - Alpercata/MG | milestone | 0d | 2019-07-09 A | 2019-07-09 A | 806 | 100% |  | 2019-07-09 | 2019-07-09 | 0d |  |  |  |  |  |  |  |  |  |  |  |  |  |  | 8888 |  |
| 809 | 6.4.1.3.2 | Obter aprovação do CIF da solução pleiteada pela COPASA - Alpercata/MG |  | 128d | 2019-07-09 A | 2020-01-10 | 808 | 30% | 90d | 2019-05-02 | 2019-05-02 | 1d |  |  | 57d | 0d |  |  |  |  |  |  |  |  |  |  |  |  |
| 810 | 6.4.1.3.3 | Conclusão da Definição da Concepção - Alpercata/MG | milestone | 0d | 2020-01-10 | 2020-01-10 | 809 |  |  | 2019-06-27 | 2019-06-27 | 0d | 2019-06-27 | 2019-06-27 | 57d | 0d | 100% |  |  |  |  |  | 100 |  | 100 |  |  |  |
| 811 | 6.4.1.4 | **Engenharia Básica e Detalhada** |  | 236d | 2020-02-28 | 2021-02-05 |  |  |  | 2018-09-25 | 2019-11-01 | 280d | 2018-09-25 | 2019-11-01 | 57d |  | 68% | 0% | ok | 0% | Alpercata/MG (sede) | 16 | 68 | 18 | 87 | Socioambiental |  |  |
| 812 | 6.4.1.4.1 | **Engenharia Captação Principal, Nova ETA e UTR (Pleito COPASA)** |  | 236d | 2020-02-28 | 2021-02-05 |  |  |  | 2018-10-29 | 2019-05-20 | 139d | 2018-10-29 | 2019-05-20 | 57d |  | 100% | 0% | ok | 0% | Alpercata/MG (sede) | 27 | 100 | 27 | 100 | Socioambiental |  |  |
| 813 | 6.4.1.4.1.1 | Aprovar Plano de Trabalho e abrir OSE - Captação Principal, Nova ETA e UTR - Alpercata/MG |  | 11d | 2020-03-06 | 2020-03-20 | 810FS+36d |  |  | 2018-12-18 | 2018-12-31 | 10d | 2018-12-18 | 2018-12-31 | 57d | 0d | 100% | 0% | Não OK | 0% | Alpercata/MG (sede) |  | 100 |  | 100 | Socioambiental |  | Não OK |
| 814 | 6.4.1.4.1.2 | Realizar Levantamento de Campo - Captação Principal, Nova ETA e UTR - Alpercata/MG |  | 6d | 2020-03-23 | 2020-03-30 | 813 |  |  | 2018-12-24 | 2018-12-31 | 6d | 2018-12-24 | 2018-12-31 | 71d | 0d | 100% | 0% | Não OK | 0% | Alpercata/MG (sede) |  | 100 |  | 100 | Socioambiental |  | Não OK |
| 815 | 6.4.1.4.1.3 | Executar Topografia - Captação Principal, Nova ETA e UTR - Alpercata/MG |  | 22d | 2020-02-28 | 2020-03-30 | 813FF+6d |  |  | 2018-10-29 | 2019-01-14 | 55d | 2018-10-29 | 2019-01-14 | 57d | 0d | 100% |  |  |  |  | 100 | 100 | 100 | 100 |  |  |  |
| 816 | 6.4.1.4.1.4 | Executar Sondagem - Captação Principal, Nova ETA e UTR - Alpercata/MG |  | 26d | 2020-04-23 | 2020-05-29 | 814FS+15d |  |  | 2020-03-31 | 2020-05-04 | 22d |  |  | 71d | 14d |  |  |  |  |  |  |  |  |  |  | 8888 |  |
| 817 | 6.4.1.4.1.5 | Elaborar arranjo conceitual para obtenção de Dados de Entrada Licenciamento e Fundiário - Captação Principal, Nova ETA e UTR - Alpercata/MG |  | 55d | 2020-03-31 | 2020-06-19 | 815 |  |  | 2018-12-31 | 2019-02-11 | 30d | 2018-12-31 | 2019-02-11 | 57d | 0d | 100% | 0% | Não OK | 0% | Alpercata/MG (sede) |  | 100 |  | 100 | Socioambiental |  |  |
| 818 | 6.4.1.4.1.6 | Elaborar Projeto Básico - Captação Principal, Nova ETA e UTR - Alpercata/MG |  | 70d | 2020-06-22 | 2020-09-28 | 817, 816 |  |  | 2018-02-08 | 2018-03-21 | 30d | 2018-02-08 | 2018-03-21 | 57d | 0d | 100% |  |  |  |  |  | 100 |  | 100 |  |  |  |
| 819 | 6.4.1.4.1.7 | Aprovar Projeto Básico - Captação Principal, Nova ETA e UTR - Alpercata/MG |  | 22d | 2020-09-29 | 2020-10-29 | 818 |  |  | 2018-03-01 | 2018-03-30 | 22d |  |  | 57d | 0d |  |  |  |  |  |  |  |  |  |  |  |  |
| 820 | 6.4.1.4.1.8 | Emitir RT/PQ para Suprimentos - Captação Principal, Nova ETA e UTR - Alpercata/MG |  | 10d | 2021-01-25 | 2021-02-05 | 818, 821FF |  |  | 2019-05-07 | 2019-05-20 | 10d | 2019-05-07 | 2019-05-20 | 57d | 0d | 100% | 0% | Não OK | 0% | Alpercata/MG (sede) |  | 100 |  | 100 | Socioambiental |  |  |
| 821 | 6.4.1.4.1.9 | Elaborar Projeto Executivo - Captação Principal, Nova ETA e UTR - Alpercata/MG |  | 67d | 2020-10-30 | 2021-02-05 | 818, 819 |  |  | 2019-02-11 | 2019-05-20 | 65d | 2019-02-11 | 2019-05-20 | 57d | 0d | 100% | 0% | Não OK | 0% | Alpercata/MG (sede) |  | 100 |  | 100 | Socioambiental |  |  |
| 822 | 6.4.1.4.1.10 | Elaboração do Projeto Executivo - Captação Principal, Nova ETA e UTR - Alpercata/MG | milestone | 0d | 2021-02-05 | 2021-02-05 | 821 |  |  | 2019-05-20 | 2019-05-20 | 0d | 2019-05-20 | 2019-05-20 | 145d | 88d | 100% |  |  |  |  |  | 100 |  | 100 |  |  |  |

Notes:
- 806: 21/Nov / - Identificada aprovação apenas pela COPASA, pendente aprovação da prefeitura.
- 814: 25/Jan19: / - Topografia iniciada em 29/10/18 e concluída em 14/01/19; Levantamento de Campo previsto para iniciar em 07/02 e finalizar em 13/02/19.

| ID | WBS | Task | Type | Duration | Start | Finish | Predecessors | Baseline start | Baseline finish | Baseline duration | Baseline 1 start | Baseline 1 finish | Total slack | Free slack | Text3 | Text5 | Text25 | Text26 | Text27 | Text29 | Text1 | Text15 | Indicadores MIR |
| --- | --- | --- | --- | --- | --- | --- | --- | --- | --- | --- | --- | --- | --- | --- | --- | --- | --- | --- | --- | --- | --- | --- | --- |
| 823 | 6.4.1.5 | **Fundiária** |  | 134d | 2020-06-22 | 2020-12-31 |  | 2019-05-09 | 2019-08-09 | 66d | 2019-05-09 | 2019-08-09 | 170d |  | 54% | 54 | 0% | ok | 0% | Alpercata/MG (sede) |  |  |  |
| 824 | 6.4.1.5.1 | Regularização Fundiária (Captação, ETA e UTR) - Alpercata/MG |  | 134d | 2020-06-22 | 2020-12-31 | 817 | 2020-01-22 | 2020-08-05 | 134d |  |  | 170d | 0d |  |  |  |  |  |  | 8888 |  |  |
| 825 | 6.4.1.5.2 | Conclusão da Regularização Fundiária para as obras de Melhoria do Sistema de Abastecimento da Localidade - Alpercata/MG | milestone | 0d | 2020-12-31 | 2020-12-31 | 824 | 2020-08-05 | 2020-08-05 | 0d |  |  | 170d | 113d | 0% |  |  |  |  |  | 8888 |  |  |
| 826 | 6.4.1.6 | **Licenciamento** |  | 180d | 2020-06-22 | 2021-03-11 |  | 2019-01-08 | 2019-09-20 | 176d | 2019-01-08 | 2019-09-20 | 124d |  | 66% | 66 | 0% | ok | 0% | Alpercata/MG (sede) |  | 68 |  |
| 827 | 6.4.1.6.1 | Licenciamento Ambiental (Captação, ETA e UTR) - Alpercata/MG |  | 180d | 2020-06-22 | 2021-03-11 | 817 | 2020-01-22 | 2020-10-09 | 180d |  |  | 124d | 0d |  |  |  |  |  |  | 8888 |  |  |
| 828 | 6.4.1.6.2 | Conclusão do Licenciamento Ambiental da Localidade - Alpercata/MG | milestone | 0d | 2021-03-11 | 2021-03-11 | 827 | 2019-09-20 | 2019-09-20 | 0d | 2019-09-20 | 2019-09-20 | 124d | 67d | 0% |  |  |  |  |  |  |  |  |
| 829 | 6.4.1.7 | **Suprimentos** |  | 88d | 2021-02-08 | 2021-06-17 |  | 2019-05-20 | 2020-02-12 | 186d | 2019-05-20 | 2020-02-12 | 57d |  | 15% | 15 | 0% | ok | 0% | Alpercata/MG (sede) |  | 16 |  |
| 830 | 6.4.1.7.1 | Processo contratação (Captação, ETA e UTR) - Alpercata/MG |  | 88d | 2021-02-08 | 2021-06-17 | 820 | 2019-05-20 | 2019-09-20 | 88d | 2019-05-20 | 2019-09-20 | 57d | 0d | 32% | 32 | 0% | ok | 0% | Alpercata/MG (sede) |  | 32 |  |
| 831 | 6.4.1.7.2 | Conclusão da Contratação de Suprimentos das obras de Melhoria do Sistema de Abastecimento de Água - Alpercata/MG | milestone | 0d | 2021-06-17 | 2021-06-17 | 830 | 2020-02-12 | 2020-02-12 | 0d | 2020-02-12 | 2020-02-12 | 57d | 0d | 0% |  |  |  |  |  |  |  |  |
| 832 | 6.4.1.8 | **Infraestrutura** |  | 548d | 2021-06-18 | 2023-08-29 |  | 2019-09-20 | 2022-01-24 | 583d | 2019-09-20 | 2022-01-24 | 57d |  | 0% |  | 0% | ok | 0% | Alpercata/MG (sede) |  |  |  |
| 833 | 6.4.1.8.1 | **Obras** |  | 323d | 2021-06-18 | 2022-09-30 |  | 2019-09-20 | 2021-01-09 | 323d | 2019-09-20 | 2021-01-09 | 57d |  | 0% |  |  |  |  |  |  |  |  |
| 834 | 6.4.1.8.1.1 | Executar Melhorias na Captação Principal - Alpercata/MG |  | 300d | 2021-06-18 | 2022-08-29 | 821, 822, 825, 828, 831 | 2019-09-20 | 2021-01-09 | 323d | 2019-09-20 | 2021-01-09 | 57d | 0d | 0% |  | 0% | ok | 0% | Alpercata/MG (sede) |  |  |  |
| 835 | 6.4.1.8.1.2 | Executar Nova ETA - Alpercata/MG |  | 300d | 2021-06-18 | 2022-08-29 | 822, 825, 828, 831 | 2019-09-23 | 2020-10-05 | 258d | 2019-09-23 | 2020-10-05 | 57d | 0d | 0% |  | 0% | ok | 0% | Alpercata/MG (sede) |  |  | ETA |
| 836 | 6.4.1.8.1.3 | Executar UTR - Alpercata/MG |  | 300d | 2021-06-18 | 2022-08-29 | 822, 825, 828, 831 | 2020-02-13 | 2020-10-23 | 173d | 2020-02-13 | 2020-10-23 | 57d | 0d | 0% |  | 0% | ok | 0% | Alpercata/MG (sede) |  |  |  |
| 837 | 6.4.1.8.1.4 | Executar Reservatório - Alpercata/MG |  | 300d | 2021-06-18 | 2022-08-29 | 822, 825, 828, 831 | 2019-09-23 | 2020-10-05 | 258d | 2019-09-23 | 2020-10-05 | 57d | 0d | 0% |  | 0% | ok | 0% | Alpercata/MG (sede) |  |  | ETA |
| 838 | 6.4.1.8.1.5 | Executar Adutora - Alpercata/MG |  | 300d | 2021-06-18 | 2022-08-29 | 822, 825, 828, 831 | 2020-02-13 | 2020-10-23 | 173d | 2020-02-13 | 2020-10-23 | 57d | 0d | 0% |  | 0% | ok | 0% | Alpercata/MG (sede) |  |  |  |
| 839 | 6.4.1.8.1.6 | Executar Elevatória - Alpercata/MG |  | 300d | 2021-06-18 | 2022-08-29 | 825, 828, 831 | 2019-09-23 | 2020-10-05 | 258d | 2019-09-23 | 2020-10-05 | 57d | 0d | 0% |  | 0% | ok | 0% | Alpercata/MG (sede) |  |  | ETA |
| 840 | 6.4.1.8.1.7 | Assinatura de Termo de Entrega das Obras de Melhoria do Sistema de Abastecimento de Água - Alpercata/MG | milestone | 0d | 2022-09-30 | 2022-09-30 | 834, 835, 836FS+23d, 837, 838FS+23d, 839 | 2021-01-09 | 2021-01-09 | 0d | 2021-01-09 | 2021-01-09 | 282d | 34d | 0% |  | 0% | ok | 0% | Alpercata/MG (sede) |  |  |  |
| 841 | 6.4.1.8.2 | **Operação** |  | 248d | 2022-08-29 | 2023-08-29 |  | 2021-01-11 | 2022-01-24 | 260d | 2021-01-11 | 2022-01-24 | 57d |  | 0% |  | 0% | ok | 0% | Alpercata/MG (sede) |  |  |  |
| 842 | 6.4.1.8.2.1 | Realizar Treinamento Operacional do Sistema - Alpercata/MG |  | 5d | 2022-08-30 | 2022-09-05 | 834, 835, 836, 837, 838, 839 | 2021-01-11 | 2021-01-15 | 5d | 2021-01-11 | 2021-01-15 | 286d | 0d | 0% |  | 0% | ok | 0% | Alpercata/MG (sede) |  |  |  |
| 843 | 6.4.1.8.2.2 | Realizar Testes e Pré-operação - Alpercata/MG |  | 14d | 2022-09-06 | 2022-09-26 | 842 | 2021-01-18 | 2021-02-04 | 14d | 2021-01-18 | 2021-02-04 | 286d |  | 0% |  | 0% | ok | 0% | Alpercata/MG (sede) |  |  |  |
| 844 | 6.4.1.8.2.3 | Realizar Acompanhamento da Funcionalidade do Sistema - Captação Principal, Nova ETA e UTR - Alpercata/MG (sede) |  | 365ed | 2022-08-29 | 2023-08-29 | 846SS | 2021-01-11 | 2022-01-24 | 260d |  |  | 255d |  |  |  |  |  |  |  |  |  |  |
| 845 | 6.4.1.8.2.4 | **Operação Assistida** |  | 60d | 2022-08-29 | 2022-11-27 |  | 2021-01-11 | 2021-04-14 | 64d | 2021-01-11 | 2021-04-14 | 57d |  | 0% |  | 0% | ok | 0% | Alpercata/MG (sede) |  |  |  |
| 846 | 6.4.1.8.2.4.1 | Realizar Operação Assistida - Alpercata/MG |  | 90ed | 2022-08-29 | 2022-11-27 | 834, 835, 836, 837, 838, 839 | 2021-01-11 | 2021-04-14 | 3.2mo | 2021-01-11 | 2021-04-14 | 255d | 0d | 0% |  | 0% | ok | 0% | Alpercata/MG (sede) |  |  |  |

Notes:
- 823: 20/Dez: / - Aguardando revisão da definição (captação alternativa).
- 826: 11/Fev19: / - Aguardando revisão da definição para verificar se há outras licenças para iniciar.

| ID | WBS | Task | Type | Duration | Start | Finish | Predecessors | Complete | Remaining | Baseline start | Baseline finish | Baseline duration | Baseline 1 start | Baseline 1 finish | Total slack | Free slack | Text3 | Text4 | Text5 | Text7 | Text15 | Text23 | Text25 | Text26 | Text27 | Text29 | Text28 | Text9 | Indicadores MIR |
| --- | --- | --- | --- | --- | --- | --- | --- | --- | --- | --- | --- | --- | --- | --- | --- | --- | --- | --- | --- | --- | --- | --- | --- | --- | --- | --- | --- | --- | --- |
| 847 | 6.5 | **Governador Valadares/MG (sede)** |  | 1939d | 2016-03-23 A | 2023-11-22 |  | 29% | 1381.37d | 2016-03-23 | 2022-03-21 | 1523d | 2016-03-23 | 2022-03-21 | 0d |  | 55% | 28 | 55 | 52 | 54 | Socioambiental | 0% | ok | 0% | Governador Valadares/MG (sede) |  |  |  |
| 848 | 6.5.1 | **Captação Alternativa** |  | 1468d | 2016-03-23 A | 2021-12-30 |  | 46% | 796.49d | 2016-03-23 | 2022-03-21 | 1523d |  |  | 471d |  |  |  |  |  |  |  |  |  |  |  |  |  |  |
| 849 | 6.5.1.1 | **Estudos de Concepção do Sistema** |  | 100d | 2017-11-03 A | 2018-03-23 A |  | 100% |  | 2018-03-08 | 2019-05-29 | 313d | 2018-03-08 | 2019-05-29 |  |  | 100% | 100 | 100 | 100 | 100 | Socioambiental | 0% | ok | 0% | Governador Valadares/MG (sede) |  |  |  |
| 850 | 6.5.1.1.1 | Declaração de Escopo e Premissas de Projeto (DEPP) concluída - Governador Valadares/MG | milestone | 0d | 2018-03-23 A | 2018-03-23 A | 25, 26 | 100% |  | 2018-03-23 | 2018-03-23 | 0d | 2018-03-23 | 2018-03-23 |  |  | 100% | 100 | 100 | 100 | 100 |  | 0% | ok | 0% | Governador Valadares/MG (sede) |  |  |  |
| 851 | 6.5.1.1.2 | Aprovação das DEPPs pela Operadora e Prefeitura - Governador Valadares/MG | milestone | 0d | 2018-03-08 A | 2018-03-08 A | 25, 26 | 100% |  | 2018-03-08 | 2018-03-08 | 0d | 2018-03-08 | 2018-03-08 |  |  | 100% | 100 | 100 | 100 | 100 |  | 0% | ok | 0% | Governador Valadares/MG (sede) |  |  |  |
| 852 | 6.5.1.1.3 | **Captação Superficial - Rio Corrente Grande** |  | 20d | 2017-11-03 A | 2017-11-30 A |  | 100% |  | 2019-05-02 | 2019-05-29 | 20d | 2019-05-02 | 2019-05-29 |  |  | 100% | 100 | 100 | 100 | 100 | Socioambiental | 0% | ok | 0% | Governador Valadares/MG (sede) |  |  |  |
| 853 | 6.5.1.1.3.1 | Realizar Laudo de Serviços de Coleta e Análise de Água - Rio Corrente Grande - Governador Valadares/MG |  | 20d | 2017-11-03 A | 2017-11-30 A | 850FS-100d | 100% |  | 2017-11-03 | 2017-11-30 | 20d | 2017-11-03 | 2017-11-30 |  |  | 100% | 100 | 100 | 100 | 100 | Socioambiental | 0% | Não OK | 0% | Governador Valadares/MG (sede) | Não OK |  |  |
| 854 | 6.5.1.1.3.2 | Conclusão do Laudo de Serviços de Coleta e Análise de Água- Rio Corrente Grande - Governador Valadares/MG | milestone | 0d | 2017-11-30 A | 2017-11-30 A | 853 | 100% |  | 2017-11-30 | 2017-11-30 | 0d | 2017-11-30 | 2017-11-30 |  |  | 100% | 100 | 100 | 100 | 100 |  |  |  |  |  |  |  |  |
| 855 | 6.5.1.2 | **Engenharia Básica e Detalhada** |  | 432d | 2016-03-23 A | 2017-11-16 A |  | 100% |  | 2016-03-23 | 2019-11-08 | 939d | 2016-03-23 | 2019-11-08 |  |  | 89% | 69 | 89 | 76 | 91 | Socioambiental | 0% | ok | 0% | Governador Valadares/MG (sede) |  |  |  |
| 856 | 6.5.1.2.1 | Engenharia Captação Alternativa (rio Corrente Grande) - Governador Valadares/MG |  | 432d | 2016-03-23 A | 2017-11-16 A | 24 | 100% |  | 2016-03-23 | 2017-11-16 | 21.6mo | 2016-03-23 | 2017-11-16 |  |  | 100% | 100 | 100 | 100 | 100 | Socioambiental | 0% | Não OK | 0% | Governador Valadares/MG (sede) |  | Não OK |  |
| 857 | 6.5.1.3 | **Fundiária** |  | 395d | 2018-03-23 A | 2019-10-09 A |  | 100% |  | 2018-03-23 | 2019-10-07 | 393d | 2018-03-23 | 2019-10-07 |  |  | 82% | 87 | 82 | 99 | 88 | Socioambiental | 0% | ok | 0% | Governador Valadares/MG (sede) |  |  |  |
| 858 | 6.5.1.3.1 | Obter Termos de Autorização de Superficiário e Desimpedimento de área - Captação Alternativa - rio Corrente Grande - Governador Valadares/MG |  | 244d | 2018-10-22 A | 2019-10-09 A | 856FS+241d, 26 | 100% |  | 2018-10-22 | 2019-10-07 | 242d | 2018-10-22 | 2019-10-07 |  |  | 71% | 80 | 71 | 113 | 71 | Socioambiental | 0% | Não OK | 0% | Governador Valadares/MG (sede) |  | Não OK |  |
| 859 | 6.5.1.3.2 | Obter Termos de Autorização de Superficiário - Captação Alternativa - rio Suaçuí Grande (ETA Recanto dos Sonhos) - Governador Valadares/MG |  | 115d | 2018-03-23 A | 2018-08-30 A | 850 | 100% |  | 2018-03-23 | 2018-08-30 | 115d | 2018-03-23 | 2018-08-30 |  |  | 100% | 100 | 100 | 100 | 100 | Socioambiental | 0% | Não OK | 0% | Governador Valadares/MG (sede) |  | Não OK |  |
| 860 | 6.5.1.3.3 | Conclusão da Regularização Fundiária para as obras de Melhoria do Sistema de Abastecimento da Localidade - Governador Valadares/MG | milestone | 0d | 2019-10-09 A | 2019-10-09 A | 858, 859 | 100% |  | 2019-10-07 | 2019-10-07 | 0d | 2019-10-07 | 2019-10-07 |  |  | 0% |  |  |  |  |  |  |  |  |  |  |  |  |
| 861 | 6.5.1.4 | **Licenciamento** |  | 845d | 2016-03-23 A | 2019-06-28 A |  | 100% |  | 2016-03-23 | 2019-06-27 | 844d | 2016-03-23 | 2019-06-27 |  |  | 100% | 98 | 100 | 98 | 100 | Socioambiental | 0% | ok | 0% | Governador Valadares/MG (sede) |  |  |  |
| 862 | 6.5.1.4.1 | Obter Outorga para Captação Alternativa - Rio Corrente Grande - Governador Valadares/MG |  | 342d | 2016-03-23 A | 2017-07-13 A | 24 | 100% |  | 2016-03-23 | 2017-07-13 | 342d | 2016-03-23 | 2017-07-13 |  |  | 100% | 100 | 100 | 100 | 100 | Socioambiental | 0% | Não OK | 0% | Governador Valadares/MG (sede) |  | Não OK |  |
| 863 | 6.5.1.4.2 | **DAIA para Supressão de Vegetação e intervenção em APP - Adutora GV - Captação Alternativa Rio Corrente Grande** |  | 46d | 2019-04-24 A | 2019-06-28 A |  | 100% |  | 2019-04-24 | 2019-06-27 | 45d | 2019-04-24 | 2019-06-27 |  |  | 100% | 100 | 100 | 100 | 100 |  |  |  |  |  |  |  |  |
| 864 | 6.5.1.4.2.1 | Protocolar pedido de informação complementar - Governador Valadares/MG |  | 1d | 2019-04-24 A | 2019-04-24 A | 24 | 100% |  | 2019-04-24 | 2019-04-24 | 1d | 2019-04-24 | 2019-04-24 |  |  | 100% | 100 | 100 | 100 | 100 |  |  |  |  |  |  |  |  |
| 865 | 6.5.1.4.2.2 | Acompanhar Processo Junto ao Órgão - Governador Valadares/MG |  | 45d | 2019-04-25 A | 2019-06-28 A | 864 | 100% |  | 2019-04-25 | 2019-06-27 | 44d | 2019-04-25 | 2019-06-27 |  |  | 100% | 100 | 100 | 100 | 100 |  |  |  |  |  |  |  |  |
| 866 | 6.5.1.4.2.3 | Obtenção de DAIA para Supressão de Vegetação e intervenção em APP - Governador Valadares/MG | milestone | 0d | 2019-06-28 A | 2019-06-28 A | 865 | 100% |  | 2019-06-27 | 2019-06-27 | 0d | 2019-06-27 | 2019-06-27 |  |  | 100% | 100 | 100 | 100 | 100 |  |  |  |  |  |  |  |  |
| 867 | 6.5.1.4.3 | Conclusão do Licenciamento Ambiental da Localidade - Governador Valadares/MG | milestone | 0d | 2019-06-28 A | 2019-06-28 A | 862, 866 | 100% |  | 2020-10-20 | 2020-10-20 | 0d | 2019-06-27 | 2019-06-27 |  |  | 100% |  | 100 |  | 100 |  |  |  |  |  |  |  |  |
| 868 | 6.5.1.5 | **Infraestrutura** |  | 885d | 2018-06-18 A | 2021-12-30 |  | 14% | 765.18d | 2016-03-23 | 2022-03-21 | 1523d | 2016-03-23 | 2022-03-21 | 471d |  | 55% |  | 55 | 67 |  |  | 0% | ok | 0% | Governador Valadares/MG (sede) |  |  |  |
| 869 | 6.5.1.5.1 | **Obras** |  | 636d | 2018-06-18 A | 2020-12-29 |  | 43% | 362.52d | 2016-03-23 | 2021-03-06 | 1263d | 2016-03-23 | 2021-03-06 | 720d |  | 66% |  | 66 | 86 |  |  |  |  |  |  |  |  |  |
| 870 | 6.5.1.5.1.1 | Captação Alternativa (Adutora Rio Corrente Grande) - Governador Valadares/MG |  | 636d | 2018-06-18 A | 2020-12-29 | 856SS, 858SS, 862SS, 854, 860FF, 867FF | 43% | 362.52d | 2018-06-18 | 2020-12-07 | 622d | 2018-06-18 | 2020-12-07 | 472d | 0d | 42% | 27 | 42 | 64 | 42 |  | 0% | ok | 0% | Governador Valadares/MG (sede) |  |  | CA |
| 871 | 6.5.1.5.1.2 | Assinatura de Termo de Entrega das Obras de Melhoria do Sistema de Abastecimento de Água - Governador Valadares/MG | milestone | 0d | 2020-12-29 | 2020-12-29 | 870 |  |  | 2021-03-06 | 2021-03-06 | 0d | 2021-03-06 | 2021-03-06 | 720d | 472d | 0% |  |  |  |  |  |  |  |  |  |  |  |  |

Notes:
- 853: 15/Fev19: / - Essa atividade está sem Sucessoras (deveriam ser os Projetos Executivos das Melhorias de ETA da ETA Central; nova ETA e Melhorias de ETA da ETA Santa Rita; e Melhorias de ETA da ETA Vila ISA), em função da Engenharia não ter respeitado o sequenciamento de atividades definido. (Ver e-mail enviado em 03/02/19 "Considerações Relevantes: Cronograma Engenharia X Cronograma Master PG 32" e Relato Gerências").
- 856: 19/Fev19: / - Datas informadas pela Camila, planejadora da Engenaharia (Adutora de GV) nesta data.
- 857: 26/Nov: / - Verificar a que se refere o Fundiário da ETA Recanto dos Santos, pois para o Licenciamento não há previsão de licença (é melhoria de ETA? Se for, não requer licenciamento). / 01/Dez: / - Na planilha do Fundiário, há 3 imóveis previsto para adutora + captação. Se referem a qual projeto?
- 858: 30/Jan19: / - Aguardando definições do CIF quanto ao Termo de Cooperação entre FR, Prefeitura de GV e SAAE. Este Termo é um documento necessário para constituição da servidão. Sem ele não há como avançar nos trabalhos (nem judicialmente). / 01/Dez: / - Concluída as etapas de Obtenção de Autorização de Acesso p/ Estudos (em 26/10/18) e em andamento a Verificação Documental das Áreas.
- 859: 30/Jan19: / - Aguardando Jurídico a emitir a minuta do contrato da servidão a ser enviada para avaliação da Piracanjuba (superficiário).
- 865: 29/04/19: Se análise jurídica do IEF entender que a resposta atendeu ao pedido de informação complementar, o prazo para atendimento é de 30 dias.

| ID | WBS | Task | Type | Duration | Start | Finish | Predecessors | Complete | Remaining | Baseline start | Baseline finish | Baseline duration | Baseline 1 start | Baseline 1 finish | Total slack | Free slack | Text3 | Text25 | Text26 | Text27 | Text29 | Text4 | Text5 | Text7 | Text15 | Text23 | Text9 |
| --- | --- | --- | --- | --- | --- | --- | --- | --- | --- | --- | --- | --- | --- | --- | --- | --- | --- | --- | --- | --- | --- | --- | --- | --- | --- | --- | --- |
| 872 | 6.5.1.5.2 | **Operação** |  | 249d | 2020-12-30 | 2021-12-30 |  |  |  | 2020-11-19 | 2022-03-21 | 331d | 2020-11-19 | 2022-03-21 | 471d |  | 0% | 0% | ok | 0% | Governador Valadares/MG (sede) |  |  |  |  |  |  |
| 873 | 6.5.1.5.2.1 | Realizar Treinamento Operacional do Sistema - Governador Valadares/MG |  | 5d | 2020-12-30 | 2021-01-06 | 870 |  |  | 2021-03-08 | 2021-03-12 | 5d | 2021-03-08 | 2021-03-12 | 472d | 0d | 0% | 0% | ok | 0% | Governador Valadares/MG (sede) |  |  |  |  |  |  |
| 874 | 6.5.1.5.2.2 | Realizar Testes e Pré-operação - Governador Valadares/MG |  | 14d | 2021-01-07 | 2021-01-26 | 873 |  |  | 2021-03-15 | 2021-04-01 | 14d | 2021-03-15 | 2021-04-01 | 701d |  | 0% | 0% | ok | 0% | Governador Valadares/MG (sede) |  |  |  |  |  |  |
| 875 | 6.5.1.5.2.3 | Realizar Acompanhamento da Funcionalidade do Sistema - Captação Alternativa - Governador Valadares/MG (sede) |  | 365ed | 2020-12-30 | 2021-12-30 | 876SS |  |  | 2020-11-19 | 2022-03-21 | 331d |  |  | 2077.12d |  |  |  |  |  |  |  |  |  |  |  |  |
| 876 | 6.5.1.5.2.4 | Realizar Operação Assistida - Governador Valadares/MG |  | 90ed | 2020-12-30 | 2021-03-30 | 873SS |  |  | 2021-03-08 | 2021-06-08 | 3.2mo | 2021-03-08 | 2021-06-08 | 2077.12d | 0d | 0% | 0% | ok | 0% | Governador Valadares/MG (sede) |  |  |  |  |  |  |
| 877 | 6.5.2 | **ETA Central** |  | 1428d | 2018-03-08 A | 2023-11-22 |  | 20% | 1144.92d | 2018-03-08 | 2022-03-21 | 1012d |  |  | 0d |  |  |  |  |  |  |  |  |  |  |  |  |
| 878 | 6.5.2.1 | **Engenharia** |  | 710d | 2018-03-08 A | 2020-12-31 |  | 56% | 310.1d | 2016-03-23 | 2019-11-08 | 939d | 2016-03-23 | 2019-11-08 | 270d |  | 89% |  | ok |  |  | 69 | 89 | 76 | 91 | Socioambiental |  |
| 879 | 6.5.2.1.1 | **Estudos de Concepção do Sistema** |  | 11d | 2018-03-08 A | 2018-03-23 A |  | 100% |  | 2018-03-08 | 2019-05-29 | 313d | 2018-03-08 | 2019-05-29 |  |  | 100% | 0% | ok | 0% | Governador Valadares/MG (sede) | 100 | 100 | 100 | 100 | Socioambiental |  |
| 880 | 6.5.2.1.1.1 | Declaração de Escopo e Premissas de Projeto (DEPP) concluída - Governador Valadares/MG | milestone | 0d | 2018-03-23 A | 2018-03-23 A | 25, 26 | 100% |  | 2018-03-23 | 2018-03-23 | 0d | 2018-03-23 | 2018-03-23 |  |  | 100% | 0% | ok | 0% | Governador Valadares/MG (sede) | 100 | 100 | 100 | 100 |  |  |
| 881 | 6.5.2.1.1.2 | Aprovação das DEPPs pela Operadora e Prefeitura - Governador Valadares/MG | milestone | 0d | 2018-03-08 A | 2018-03-08 A | 25, 26 | 100% |  | 2018-03-08 | 2018-03-08 | 0d | 2018-03-08 | 2018-03-08 |  |  | 100% | 0% | ok | 0% | Governador Valadares/MG (sede) | 100 | 100 | 100 | 100 |  |  |
| 882 | 6.5.2.1.2 | **Engenharia Básica e Detalhada** |  | 661d | 2018-05-16 A | 2020-12-31 |  | 56% | 288.7d | 2016-03-23 | 2019-11-08 | 939d | 2016-03-23 | 2019-11-08 | 270d |  | 89% | 0% | ok | 0% | Governador Valadares/MG (sede) | 69 | 89 | 76 | 91 | Socioambiental |  |
| 883 | 6.5.2.1.2.1 | **Engenharia Captação Principal - ETA Central (Melhorias) - SE 32008** |  | 596d | 2018-05-16 A | 2020-09-25 |  | 56% | 261.55d | 2018-05-16 | 2019-05-10 | 251d | 2018-05-16 | 2019-05-10 | 335d |  | 100% | 0% | ok | 0% | Governador Valadares/MG (sede) | 62 | 100 | 62 | 100 | Socioambiental |  |
| 884 | 6.5.2.1.2.1.1 | Levantar Dados de Entrada (levantamento de campo, topografia e sondagem) - Captação Principal - ETA Central - Governador Valadares/MG |  | 81d | 2018-05-16 A | 2018-09-05 A | 880 | 100% |  | 2018-05-16 | 2018-09-05 | 81d | 2018-05-16 | 2018-09-05 |  |  | 100% | 0% | ok | 0% | Governador Valadares/MG (sede) | 100 | 100 | 100 | 100 |  |  |
| 885 | 6.5.2.1.2.1.2 | Elaborar arranjo conceitual - Captação Principal - ETA Central - Governador Valadares/MG |  | 216d | 2018-09-06 A | 2019-07-16 A | 884 | 100% |  | 2018-09-06 | 2018-10-17 | 30d | 2018-09-06 | 2019-05-10 |  |  | 100% | 0% | Não OK | 0% | Governador Valadares/MG (sede) | 90 | 100 | 90 | 100 | Socioambiental | Não OK |
| 886 | 6.5.2.1.2.1.3 | Realizar testes para definição do dimensionamento do novo conjunto flutuante - Captação Principal - ETA Central - Governador Valadares/MG |  | 154d | 2019-07-17 A | 2020-02-28 | 885 | 25% | 115.5d | 2019-07-17 | 2019-10-01 | 54d |  |  | 335d | 0d |  |  |  |  |  |  |  |  |  |  |  |
| 887 | 6.5.2.1.2.1.4 | Realizar Sondagem Mista - Captação Principal - ETA Central - Governador Valadares/MG |  | 4d | 2019-11-11 A | 2019-11-14 A | 885, 886FF-10d | 100% |  | 2019-08-01 | 2019-09-02 | 22d |  |  |  |  | 0% |  |  |  |  |  |  |  |  |  |  |
| 888 | 6.5.2.1.2.1.5 | Elaborar Projeto Básico - Captação Principal - ETA Central - Governador Valadares/MG |  | 70d | 2020-03-10 | 2020-06-19 | 885, 886FS+6d |  |  | 2018-02-08 | 2018-03-21 | 30d | 2018-02-08 | 2018-03-21 | 335d | 0d | 100% |  |  |  |  |  | 100 |  | 100 |  |  |
| 889 | 6.5.2.1.2.1.6 | Aprovar Projeto Básico - Captação Principal - ETA Central - Governador Valadares/MG |  | 22d | 2020-06-22 | 2020-07-21 | 888 |  |  | 2018-03-01 | 2018-03-30 | 22d |  |  | 335d | 0d |  |  |  |  |  |  |  |  |  |  |  |
| 890 | 6.5.2.1.2.1.7 | Emitir RT/PQ para Suprimentos - Captação Principal - ETA Central - Governador Valadares/MG |  | 11d | 2020-09-11 | 2020-09-25 | 891FF |  |  | 2019-04-12 | 2019-05-10 | 18d | 2019-04-12 | 2019-05-10 | 335d | 0d | 100% | 0% | Não OK | 0% | Governador Valadares/MG (sede) |  | 100 |  | 100 | Socioambiental | Não OK |
| 891 | 6.5.2.1.2.1.8 | Elaborar Projeto Executivo - Captação Principal - ETA Central - Governador Valadares/MG |  | 47d | 2020-07-22 | 2020-09-25 | 885, 886, 887FF, 888SS+30d, 889 |  |  | 2018-11-15 | 2019-05-10 | 120d | 2018-11-15 | 2019-05-10 | 335d | 0d | 100% | 0% | Não OK | 0% | Governador Valadares/MG (sede) |  | 100 |  | 100 | Socioambiental |  |
| 892 | 6.5.2.1.2.1.9 | Elaboração do Projeto Executivo - Captação Principal - ETA Central - Governador Valadares/MG | milestone | 0d | 2020-09-25 | 2020-09-25 | 890, 891 |  |  | 2019-05-10 | 2019-05-10 | 0d | 2019-05-10 | 2019-05-10 | 335d | 165d | 100% |  |  |  |  |  | 100 |  | 100 |  |  |
| 893 | 6.5.2.1.2.2 | **Engenharia Melhorias ETA - ETA Central - SE 32260** |  | 244d | 2018-12-10 A | 2019-11-28 A |  | 100% |  | 2018-12-10 | 2019-06-11 | 125d | 2018-12-10 | 2019-06-11 |  |  | 100% | 0% | ok | 0% | Governador Valadares/MG (sede) | 66 | 100 | 66 | 100 | Socioambiental |  |
| 894 | 6.5.2.1.2.2.1 | Levantar Dados de Entrada (levantamento de campo, topografia e sondagem) - Melhorias na ETA - ETA Central - Governador Valadares/MG |  | 4d | 2018-12-10 A | 2018-12-13 A | 880 | 100% |  | 2018-12-10 | 2018-12-13 | 4d | 2018-12-10 | 2018-12-13 |  |  | 100% | 0% | ok | 0% | Governador Valadares/MG (sede) | 100 | 100 | 100 | 100 |  |  |
| 895 | 6.5.2.1.2.2.2 | Emitir RT/PQ para Suprimentos - Melhorias na ETA - ETA Central - Governador Valadares/MG |  | 5d | 2019-09-09 A | 2019-09-13 A | 896FF | 100% |  | 2019-04-26 | 2019-05-10 | 10d | 2019-04-26 | 2019-05-10 |  |  | 100% |  |  |  |  |  | 100 |  | 100 |  |  |
| 896 | 6.5.2.1.2.2.3 | Elaborar Projeto Executivo - Melhorias na ETA - ETA Central - Governador Valadares/MG |  | 187d | 2018-12-14 A | 2019-09-13 A | 894 | 100% |  | 2018-12-14 | 2019-05-10 | 102d | 2018-12-14 | 2019-05-10 |  |  | 100% | 0% | Não OK | 0% | Governador Valadares/MG (sede) | 90 | 100 | 90 | 100 | Socioambiental |  |
| 897 | 6.5.2.1.2.2.4 | Elaborar Projeto Executivo (Acréscimo do Macromedidor na SE) - Melhorias na ETA - ETA Central - Governador Valadares/MG |  | 53d | 2019-09-16 A | 2019-11-28 A | 896 | 100% |  | 2019-09-16 | 2019-10-30 | 33d |  |  |  |  |  |  |  |  |  |  |  |  |  |  |  |
| 898 | 6.5.2.1.2.2.5 | Elaboração do Projeto Executivo - Melhorias na ETA - ETA Central - Governador Valadares/MG | milestone | 0d | 2019-11-28 A | 2019-11-28 A | 895, 896, 897 | 100% |  | 2019-05-10 | 2019-05-10 | 0d | 2019-05-10 | 2019-05-10 |  |  | 100% |  |  |  |  |  | 100 |  | 100 |  |  |

Notes:
- 888: 17/09/19: Verificar se será realizada a partir dessa data a contratação da obra
- 896: 29/Jan19: / - Engenharia não está considerando Laudo de resultado da água para elaboração do Projeto Executivo. Retirado do link do Cronograma Mater do PG.

| ID | WBS | Task | Type | Duration | Start | Finish | Predecessors | Complete | Remaining | Baseline start | Baseline finish | Baseline duration | Baseline 1 start | Baseline 1 finish | Total slack | Free slack | Text3 | Text4 | Text5 | Text7 | Text15 | Text23 | Text25 | Text26 | Text27 | Text29 | Text1 | Indicadores MIR |
| --- | --- | --- | --- | --- | --- | --- | --- | --- | --- | --- | --- | --- | --- | --- | --- | --- | --- | --- | --- | --- | --- | --- | --- | --- | --- | --- | --- | --- |
| 899 | 6.5.2.1.2.3 | **Engenharia UTR - ETA Central** |  | 546d | 2018-10-24 A | 2020-12-31 |  | 25% | 411.11d | 2018-10-24 | 2019-05-10 | 136d | 2018-10-24 | 2019-05-10 | 100d |  | 100% | 24 | 100 | 24 | 100 | Socioambiental | 0% | ok | 0% | Governador Valadares/MG (sede) |  |  |
| 900 | 6.5.2.1.2.3.1 | Aprovar Plano de Trabalho e abrir OSE - UTR - ETA Central - Governador Valadares/MG |  | 3d | 2018-12-19 A | 2018-12-21 A | 880 | 100% |  | 2018-12-19 | 2018-12-21 | 3d | 2018-12-19 | 2018-12-21 |  |  | 100% | 100 | 100 | 100 | 100 |  | 0% | ok | 0% | Governador Valadares/MG (sede) |  |  |
| 901 | 6.5.2.1.2.3.2 | Realizar Levantamento de Campo - UTR - ETA Central - Governador Valadares/MG |  | 2d | 2019-02-01 A | 2019-02-04 A | 900 | 100% |  | 2019-02-01 | 2019-02-04 | 2d | 2019-02-01 | 2019-02-04 |  |  | 100% | 100 | 100 | 100 | 100 | Socioambiental | 0% | Não OK | 0% | Governador Valadares/MG (sede) |  |  |
| 902 | 6.5.2.1.2.3.3 | Elaborar arranjo para obtenção de Dados de Entrada Licenciamento e Fundiário - UTR - ETA Central - Governador Valadares/MG |  | 30d | 2018-10-24 A | 2018-12-04 A |  | 100% |  | 2018-10-24 | 2018-12-04 | 30d | 2018-10-24 | 2018-12-04 |  |  | 100% | 100 | 100 | 100 | 100 |  |  |  |  |  |  |  |
| 903 | 6.5.2.1.2.3.4 | Elaborar Projeto Conceitual - UTR - ETA Central - Governador Valadares/MG |  | 49d | 2019-07-18 A | 2019-09-25 A | 901FS+110d | 100% |  | 2019-07-18 | 2019-08-05 | 13d |  |  |  |  | 0% |  |  |  |  |  |  |  |  |  |  |  |
| 904 | 6.5.2.1.2.3.5 | Elaborar Projeto Básico - UTR - ETA Central - Governador Valadares/MG |  | 115d | 2020-01-09 | 2020-06-26 | 903FS+70d |  |  | 2018-02-08 | 2018-03-21 | 30d | 2018-02-08 | 2018-03-21 | 0d |  | 100% |  | 100 |  | 100 |  |  |  |  |  |  |  |
| 905 | 6.5.2.1.2.3.6 | Aprovar Projeto Básico - UTR - ETA Central - Governador Valadares/MG |  | 22d | 2020-06-29 | 2020-07-28 | 904 |  |  | 2018-03-01 | 2018-03-30 | 22d |  |  | 0d |  |  |  |  |  |  |  |  |  |  |  |  |  |
| 906 | 6.5.2.1.2.3.7 | Emitir RT/PQ para Suprimentos - UTR - ETA Central - Governador Valadares/MG |  | 12d | 2020-12-14 | 2020-12-31 | 904, 907FF |  |  | 2019-04-26 | 2019-05-10 | 10d | 2019-04-26 | 2019-05-10 | 0d |  | 100% |  | 100 |  | 100 |  |  |  |  |  |  |  |
| 907 | 6.5.2.1.2.3.8 | Elaborar Projeto Executivo - UTR - ETA Central - Governador Valadares/MG |  | 107d | 2020-07-29 | 2020-12-31 | 901, 902, 904, 905 |  |  | 2019-02-01 | 2019-05-10 | 65d | 2019-02-01 | 2019-05-10 | 0d |  | 100% |  | 100 |  | 100 | Socioambiental | 0% | Não OK | 0% | Governador Valadares/MG (sede) |  |  |
| 908 | 6.5.2.1.2.3.9 | Elaboração do Projeto Executivo - UTR - ETA Central - Governador Valadares/MG | milestone | 0d | 2020-12-31 | 2020-12-31 | 907 |  |  | 2019-05-10 | 2019-05-10 | 0d | 2019-05-10 | 2019-05-10 | 100d |  | 100% |  | 100 |  | 100 |  |  |  |  |  |  |  |
| 909 | 6.5.2.2 | **Licenciamento** |  | 199d | 2020-06-29 | 2021-04-15 |  |  |  | 2016-03-23 | 2019-06-27 | 844d | 2016-03-23 | 2019-06-27 | 30d |  | 100% | 98 | 100 | 98 | 100 | Socioambiental | 0% | ok | 0% | Governador Valadares/MG (sede) |  |  |
| 910 | 6.5.2.2.1 | Obter DAIA para UTR - ETA Central - Governador Valadares/MG |  | 199d | 2020-06-29 | 2021-04-15 | 903, 904 |  |  | 2019-08-30 | 2020-06-19 | 199d |  |  | 30d | 0d |  |  |  |  |  |  |  |  |  |  | 8888 |  |
| 911 | 6.5.2.2.2 | Conclusão do Licenciamento Ambiental da Localidade - Governador Valadares/MG | milestone | 0d | 2021-04-15 | 2021-04-15 | 910 |  |  | 2020-10-20 | 2020-10-20 | 0d | 2019-06-27 | 2019-06-27 | 30d |  | 100% |  | 100 |  | 100 |  |  |  |  |  |  |  |
| 912 | 6.5.2.3 | **Suprimentos** |  | 422d | 2019-09-16 A | 2021-05-28 |  | 25% | 314.93d | 2019-02-05 | 2020-01-28 | 243d | 2019-02-05 | 2020-01-28 | 0d |  | 39% |  | 39 |  | 49 |  | 0% | ok | 0% | Governador Valadares/MG (sede) |  |  |
| 913 | 6.5.2.3.1 | **Central** |  | 422d | 2019-09-16 A | 2021-05-28 |  | 25% | 314.93d | 2019-05-10 | 2019-09-12 | 88d | 2019-05-10 | 2019-09-12 | 0d |  | 39% |  | 39 |  | 39 |  | 0% | ok | 0% | Governador Valadares/MG (sede) |  |  |
| 914 | 6.5.2.3.1.1 | Realizar análise da RT/PQ pela Infra - Captação Principal e UTR - Governador Valadares/MG |  | 22d | 2021-01-04 | 2021-02-02 | 903FS-22d, 906 |  |  | 2019-10-30 | 2019-11-29 | 22d |  |  | 0d |  |  |  |  |  |  |  |  |  |  |  | 8888 |  |
| 915 | 6.5.2.3.1.2 | Processo contratação CGC (ETA Central - Captação Principal e UTR/ Vila Isa UTR) - Governador Valadares/MG |  | 78d | 2021-02-03 | 2021-05-28 | 914 |  |  | 2019-05-10 | 2019-09-12 | 88d | 2019-05-10 | 2019-09-12 | 0d |  | 39% |  | 39 |  | 39 |  | 0% | ok | 0% | Governador Valadares/MG (sede) |  |  |
| 916 | 6.5.2.3.1.3 | Aprovar aditivo do contrato guarda-chuva - Melhorias ETA Central - Governador Valadares/MG |  | 34d | 2019-09-16 A | 2019-10-31 A | 895 | 100% |  | 2019-09-16 | 2019-10-15 | 22d |  |  |  |  |  |  |  |  |  |  |  |  |  |  | 8888 |  |
| 917 | 6.5.2.3.1.4 | Conclusão da Contratação de Suprimentos - ETA Central - Governador Valadares/MG | milestone | 0d | 2021-05-28 | 2021-05-28 | 915, 916 |  |  | 2019-05-10 | 2019-05-10 | 0d | 2019-05-10 | 2019-05-10 | 0d |  | 100% |  | 100 |  | 100 |  |  |  |  |  |  |  |
| 918 | 6.5.2.4 | **Infraestrutura** |  | 932d | 2020-02-20 | 2023-11-22 |  |  |  | 2016-03-23 | 2022-03-21 | 1523d | 2016-03-23 | 2022-03-21 | 0d |  | 55% |  | 55 | 67 |  |  | 0% | ok | 0% | Governador Valadares/MG (sede) |  |  |
| 919 | 6.5.2.4.1 | **Obras** |  | 684d | 2020-02-20 | 2022-11-22 |  |  |  | 2016-03-23 | 2021-03-06 | 1263d | 2016-03-23 | 2021-03-06 | 248d |  | 66% |  | 66 | 86 |  |  |  |  |  |  |  |  |
| 920 | 6.5.2.4.1.1 | **ETA Central** |  | 684d | 2020-02-20 | 2022-11-22 |  |  |  | 2019-09-12 | 2021-03-06 | 366d | 2019-09-12 | 2021-03-06 | 248d |  | 0% |  |  |  |  |  | 0% | ok | 0% | Governador Valadares/MG (sede) |  |  |
| 921 | 6.5.2.4.1.1.1 | Execução Captação Principal - ETA Central - Governador Valadares/MG |  | 200d | 2021-05-31 | 2022-03-17 | 892, 915 |  |  | 2019-09-12 | 2021-03-06 | 366d | 2019-09-12 | 2021-03-06 | 170d |  | 0% |  |  |  |  |  | 0% | ok | 0% | Governador Valadares/MG (sede) |  |  |
| 922 | 6.5.2.4.1.1.2 | Executar Melhorias ETA - ETA Central - Governador Valadares/MG |  | 83d | 2020-02-20 | 2020-06-24 | 898, 916FS+74d |  |  | 2019-09-12 | 2021-03-06 | 366d | 2019-09-12 | 2021-03-06 | 601d |  | 0% |  |  |  |  |  | 0% | ok | 0% | Governador Valadares/MG (sede) |  | ETA |
| 923 | 6.5.2.4.1.1.3 | Executar UTR - ETA Central - Governador Valadares/MG |  | 370d | 2021-05-31 | 2022-11-22 | 910FF, 917, 908, 911 |  |  | 2019-09-12 | 2021-03-06 | 366d | 2019-09-12 | 2021-03-06 | 0d |  | 0% |  |  |  |  |  | 0% | ok | 0% | Governador Valadares/MG (sede) |  |  |
| 924 | 6.5.2.4.1.1.4 | Assinatura de Termo de Entrega das Obras de Melhoria do Sistema de Abastecimento de Água ETA Central - Governador Valadares/MG | milestone | 0d | 2022-11-22 | 2022-11-22 | 921, 922, 923 |  |  | 2021-03-06 | 2021-03-06 | 0d | 2021-03-06 | 2021-03-06 | 248d | 0d | 0% |  |  |  |  |  | 0% | ok | 0% | Governador Valadares/MG (sede) |  |  |

Notes:
- 899: 25/Jan19: / - Já realizado projeto de UTR Conceitual (Tecnosul): iniciado em 03/01 e concluído em 16/08/18.
- 910: 18/09/19: Prazo da DAIA extraído do cronograma do Licenciamento de 18-09-19
- 915: 03/10/19: Será realizada contratação a partir dos projetos conceituais do Marcos Vianna, que ocorrerá em paralelo à elaboração dos projetos pela Engenharia

| ID | WBS | Task | Type | Duration | Start | Finish | Predecessors | Complete | Remaining | Baseline start | Baseline finish | Baseline duration | Baseline 1 start | Baseline 1 finish | Total slack | Free slack | Text3 | Text25 | Text26 | Text27 | Text29 | Text4 | Text5 | Text7 | Text15 | Text23 | Text9 | Text1 |
| --- | --- | --- | --- | --- | --- | --- | --- | --- | --- | --- | --- | --- | --- | --- | --- | --- | --- | --- | --- | --- | --- | --- | --- | --- | --- | --- | --- | --- |
| 925 | 6.5.2.4.2 | **Operação** |  | 248d | 2022-11-22 | 2023-11-22 |  |  |  | 2020-11-19 | 2022-03-21 | 331d | 2020-11-19 | 2022-03-21 | 0d |  | 0% | 0% | ok | 0% | Governador Valadares/MG (sede) |  |  |  |  |  |  |  |
| 926 | 6.5.2.4.2.1 | **ETA Central** |  | 248d | 2022-11-22 | 2023-11-22 |  |  |  | 2021-03-08 | 2022-03-21 | 260d | 2021-03-08 | 2022-03-21 | 0d |  | 0% | 0% | ok | 0% | Governador Valadares/MG (sede) |  |  |  |  |  |  |  |
| 927 | 6.5.2.4.2.1.1 | Realizar Treinamento Operacional do Sistema - Governador Valadares/MG |  | 5d | 2022-11-23 | 2022-11-29 | 921, 922, 923 |  |  | 2021-03-08 | 2021-03-12 | 5d | 2021-03-08 | 2021-03-12 | 229d | 0d | 0% | 0% | ok | 0% | Governador Valadares/MG (sede) |  |  |  |  |  |  |  |
| 928 | 6.5.2.4.2.1.2 | Realizar Testes e Pré-operação - Governador Valadares/MG |  | 14d | 2022-11-30 | 2022-12-20 | 927 |  |  | 2021-03-15 | 2021-04-01 | 14d | 2021-03-15 | 2021-04-01 | 229d |  | 0% | 0% | ok | 0% | Governador Valadares/MG (sede) |  |  |  |  |  |  |  |
| 929 | 6.5.2.4.2.1.3 | Realizar Acompanhamento da Funcionalidade do Sistema - ETA Central - Governador Valadares/MG (sede) |  | 365ed | 2022-11-22 | 2023-11-22 | 931SS |  |  | 2021-03-08 | 2022-03-21 | 260d |  |  | 0d |  |  |  |  |  |  |  |  |  |  |  |  |  |
| 930 | 6.5.2.4.2.1.4 | **Operação Assistida** |  | 62d | 2022-11-22 | 2023-02-20 |  |  |  | 2021-03-08 | 2021-06-08 | 64d | 2021-03-08 | 2021-06-08 | 0d |  | 0% | 0% | ok | 0% | Governador Valadares/MG (sede) |  |  |  |  |  |  |  |
| 931 | 6.5.2.4.2.1.4.1 | Realizar Operação Assistida - Governador Valadares/MG |  | 90ed | 2022-11-22 | 2023-02-20 | 921, 922, 923 |  |  | 2021-03-08 | 2021-06-08 | 3.2mo | 2021-03-08 | 2021-06-08 | 0d |  | 0% | 0% | ok | 0% | Governador Valadares/MG (sede) |  |  |  |  |  |  |  |
| 932 | 6.5.3 | **ETA Santa Rita** |  | 1158d | 2017-08-16 A | 2022-03-22 |  | 37% | 727.99d | 2016-03-23 | 2022-03-21 | 1523d |  |  | 415d |  |  |  |  |  |  |  |  |  |  |  |  |  |
| 933 | 6.5.3.1 | **Engenharia** |  | 411d | 2018-03-05 A | 2019-10-11 A |  | 100% |  | 2016-03-23 | 2019-11-08 | 939d | 2016-03-23 | 2019-11-08 |  |  | 89% |  | ok |  |  | 69 | 89 | 76 | 91 | Socioambiental |  |  |
| 934 | 6.5.3.1.1 | **Estudos de Concepção do Sistema** |  | 11d | 2018-03-08 A | 2018-03-23 A |  | 100% |  | 2018-03-08 | 2019-05-29 | 313d | 2018-03-08 | 2019-05-29 |  |  | 100% | 0% | ok | 0% | Governador Valadares/MG (sede) | 100 | 100 | 100 | 100 | Socioambiental |  |  |
| 935 | 6.5.3.1.1.1 | Declaração de Escopo e Premissas de Projeto (DEPP) concluída - Governador Valadares/MG | milestone | 0d | 2018-03-23 A | 2018-03-23 A | 25, 26 | 100% |  | 2018-03-23 | 2018-03-23 | 0d | 2018-03-23 | 2018-03-23 |  |  | 100% | 0% | ok | 0% | Governador Valadares/MG (sede) | 100 | 100 | 100 | 100 |  |  |  |
| 936 | 6.5.3.1.1.2 | Aprovação das DEPPs pela Operadora e Prefeitura - Governador Valadares/MG | milestone | 0d | 2018-03-08 A | 2018-03-08 A | 25, 26 | 100% |  | 2018-03-08 | 2018-03-08 | 0d | 2018-03-08 | 2018-03-08 |  |  | 100% | 0% | ok | 0% | Governador Valadares/MG (sede) | 100 | 100 | 100 | 100 |  |  |  |
| 937 | 6.5.3.1.2 | **Engenharia Básica e Detalhada** |  | 411d | 2018-03-05 A | 2019-10-11 A |  | 100% |  | 2016-03-23 | 2019-11-08 | 939d | 2016-03-23 | 2019-11-08 |  |  | 89% | 0% | ok | 0% | Governador Valadares/MG (sede) | 69 | 89 | 76 | 91 | Socioambiental |  |  |
| 938 | 6.5.3.1.2.1 | **Engenharia Nova ETA / Captação Principal / Alternativa / UTR - ETA Santa Rita** |  | 304d | 2018-03-05 A | 2019-05-13 A |  | 100% |  | 2018-03-05 | 2019-04-25 | 293d | 2018-03-05 | 2019-04-25 |  |  | 100% | 0% | ok | 0% | Governador Valadares/MG (sede) | 94 | 100 | 94 | 100 | Socioambiental |  |  |
| 939 | 6.5.3.1.2.1.1 | Levantar Dados de Entrada (levantamento de campo, topografia, sondagem) - Captação Principal / Alternativa / Nova ETA / UTR - ETA Santa Rita - Governador Valadares/MG |  | 110d | 2018-03-05 A | 2018-08-03 A | 26 | 100% |  | 2018-03-05 | 2018-08-03 | 110d | 2018-03-05 | 2018-08-03 |  |  | 100% | 0% | ok | 0% | Governador Valadares/MG (sede) | 100 | 100 | 100 | 100 |  |  |  |
| 940 | 6.5.3.1.2.1.2 | Elaborar arranjo para obtenção de Dados de Entrada Licenciamento e Fundiário - Captação Principal / Alternativa / Nova ETA / UTR - ETA Santa Rita - Governador Valadares/MG |  | 117d | 2018-03-05 A | 2018-08-14 A | 939FF+7d | 100% |  | 2018-03-05 | 2018-08-14 | 117d | 2018-03-05 | 2018-08-14 |  |  | 100% | 0% | ok | 0% | Governador Valadares/MG (sede) | 100 | 100 | 100 | 100 |  |  |  |
| 941 | 6.5.3.1.2.1.3 | Emitir RT/PQ para Suprimentos - Captação Principal / Alternativa / Nova ETA / UTR - ETA Santa Rita - Governador Valadares/MG |  | 10d | 2019-04-29 A | 2019-05-13 A | 942FF | 100% |  | 2019-03-18 | 2019-03-29 | 10d | 2019-03-18 | 2019-03-29 |  |  | 100% |  |  |  |  | 100 | 100 | 100 | 100 |  |  |  |
| 942 | 6.5.3.1.2.1.4 | Elaborar Projeto Executivo - Captação Principal / Alternativa / Nova ETA / UTR - ETA Santa Rita - Governador Valadares/MG |  | 267d | 2018-04-25 A | 2019-05-13 A | 940FS-80d | 100% |  | 2018-03-28 | 2019-03-29 | 366ed | 2018-03-28 | 2019-03-29 |  |  | 100% | 0% | Não OK | 0% | Governador Valadares/MG (sede) | 100 | 100 | 100 | 100 | Socioambiental |  |  |
| 943 | 6.5.3.1.2.1.5 | Elaboração do Projeto Executivo - Captação Principal / Alternativa / Nova ETA / UTR - ETA Santa Rita - Governador Valadares/MG | milestone | 0d | 2019-05-13 A | 2019-05-13 A | 941, 942 | 100% |  | 2019-04-25 | 2019-04-25 | 0d | 2019-04-25 | 2019-04-25 |  |  | 100% |  |  |  |  | 100 | 100 | 100 | 100 |  |  |  |
| 944 | 6.5.3.1.2.2 | **Engenharia Melhorias ETA existente - ETA Santa Rita** |  | 226d | 2018-11-19 A | 2019-10-11 A |  | 100% |  | 2018-11-19 | 2019-03-29 | 91d | 2018-11-19 | 2019-03-29 |  |  | 100% | 0% | ok | 0% | Governador Valadares/MG (sede) | 75 | 100 | 75 | 100 | Socioambiental |  |  |
| 945 | 6.5.3.1.2.2.1 | Aprovar Plano de Trabalho e abrir OSE - Melhorias na ETA - ETA Santa Rita - Governador Valadares/MG |  | 43d | 2018-11-19 A | 2019-01-17 A | 26 | 100% |  | 2018-11-19 | 2019-01-17 | 43d | 2018-11-19 | 2019-01-17 |  |  | 100% | 0% | ok | 0% | Governador Valadares/MG (sede) | 100 | 100 | 100 | 100 |  |  |  |
| 946 | 6.5.3.1.2.2.2 | Realizar Levantamento de Campo - Melhorias na ETA - ETA Santa Rita - Governador Valadares/MG |  | 4d | 2019-01-18 A | 2019-01-23 A | 945 | 100% |  | 2019-01-18 | 2019-01-23 | 4d | 2019-01-18 | 2019-01-23 |  |  | 100% | 0% | Não OK | 0% | Governador Valadares/MG (sede) | 100 | 100 | 100 | 100 | Socioambiental | Não OK |  |
| 947 | 6.5.3.1.2.2.3 | Elaborar arranjo para obtenção de Dados de Entrada Licenciamento e Fundiário - Melhorias na ETA - ETA Santa Rita - Governador Valadares/MG |  | 108d | 2019-01-28 A | 2019-07-05 A | 946FS+2d | 100% |  | 2019-01-28 | 2019-03-13 | 30d | 2019-01-28 | 2019-03-13 |  |  | 100% | 0% | ok | 0% | Governador Valadares/MG (sede) | 80 | 100 | 80 | 100 |  |  |  |
| 948 | 6.5.3.1.2.2.4 | Emitir RT/PQ para Suprimentos - Melhorias na ETA - ETA Santa Rita - Governador Valadares/MG |  | 5d | 2019-06-24 A | 2019-06-28 A | 949FF | 100% |  | 2019-01-07 | 2019-02-04 | 21d | 2019-01-07 | 2019-02-04 |  |  | 100% | 0% | ok | 0% | Governador Valadares/MG (sede) | 100 | 100 | 100 | 100 |  |  |  |
| 949 | 6.5.3.1.2.2.5 | Elaborar Projeto Executivo - Melhorias na ETA - ETA Santa Rita - Governador Valadares/MG |  | 57d | 2019-04-04 A | 2019-06-27 A | 945, 947FS-30d | 100% |  | 2019-01-07 | 2019-03-29 | 57d | 2019-01-07 | 2019-03-29 |  |  | 100% | 0% | Não OK | 0% | Governador Valadares/MG (sede) | 80 | 100 | 80 | 100 | Socioambiental |  |  |
| 950 | 6.5.3.1.2.2.6 | Elaboração do Projeto Executivo - Melhorias na ETA - ETA Santa Rita - Governador Valadares/MG | milestone | 0d | 2019-06-28 A | 2019-06-28 A | 948, 949 | 100% |  | 2019-03-29 | 2019-03-29 | 0d | 2019-03-29 | 2019-03-29 |  |  | 100% |  |  |  |  |  | 100 |  | 100 |  |  |  |
| 951 | 6.5.3.1.2.2.7 | Aprovar Projeto Executivo - Melhorias na ETA existente - ETA Santa Rita - Governador Valadares/MG |  | 19d | 2019-09-17 A | 2019-10-11 A | 950FS+55d | 100% |  | 2019-09-17 | 2019-10-11 | 19d |  |  |  |  |  |  |  |  |  |  |  |  |  |  |  | 8888 |
| 952 | 6.5.3.1.2.2.8 | Aprovação do Projeto Executivo - Melhorias na ETA - ETA Santa Rita - Governador Valadares/MG | milestone | 0d | 2019-10-11 A | 2019-10-11 A | 951 | 100% |  | 2019-10-11 | 2019-10-11 | 0d |  |  |  |  |  |  |  |  |  |  |  |  |  |  |  | 8888 |

Notes:
- 938: 25/Jan19: / - Considerando aqui as datas do projeto CAPTAÇÃO PRINCIPAL, SECUNDÁRIA, NOVA ETA / UTR. / 19/Dez: / - Considerando aqui as datas do projeto "nova ETA / UTR" constantes no CR ENG 14/12/18.
- 944: 25/Jan19: / - Considerando aqui as datas dos projetos de "Pequenas Melhorias na ETA" e "ETA 120 L/s - Validação da Capacidade". / 19/Dez: / - Considerando aqui as datas dos projetos da "nova ETA / UTR" e "ETA 120 L/s - Validação da Capacidade" constantes no CR ENG 14/12/18.
- 945: 25/Jan19: / - Plano de Trabalho referente ao Projeto de Pequenas Melhorias na ETA iniciado em 10/12/18 e concluído em 16/01/19; do projeto da ETA 120 L/s iniciado em 19/11 e finalizado em 21/12/18.
- 946: 25/Jan19: / - O projeto de ETA 120 L/s não contempla dados de entrada. Considerando aqui apenas as datas do projeto de Pequenas Melhorias na ETA. / 19/Dez / - O projeto de ETA 120 L/s não contempla dados de entrada. Considerando aqui apenas as datas do projeto de Nova ETA / UTR.
- 947: 25/Jan19: / - O projeto de ETA 120 L/s não contempla Projeto Conceitual. Considerando aqui apenas as datas do projeto de Pequenas Melhorias na ETA. / 19/Dez / - O projeto de ETA 120 L/s não contempla projeto conceitual. Considerando aqui apenas as datas do projeto de Nova ETA / UTR.
- 948: 25/Jan19: / - O projeto de ETA 120 L/s não contempla Emissão de PQ/RT Preliminar para Suprimentos. Considerando aqui apenas as datas do projeto de Pequenas Melhorias na ETA.
- 949: 25/Jan19: / - Está sendo considerado como Projeto Executivo referente ao projeto da ETA 120 L/s - Validação da Capacidade a emissão/elaboração de um Relatório Técnico, iniciado em 26/12/18 com previsão de término para 31/01/19; o de Pequenas Melhorias na ETA está previsto para iniciar em 27/02 e finalizar em 13/05/19. / 19/Dez: / - Considerando aqui os Projetos Executivos de Nova ETA / UTR (início em 13/04/18 com previsão de término para 04/01/19), e de ETA 120 L/s (início previsto para 02/01 e término 31/01/19), segundo CR ENG de 14/12/18. Sendo este último um Relatório Técnico.

| ID | WBS | Task | Type | Duration | Start | Finish | Predecessors | Complete | Remaining | Baseline start | Baseline finish | Baseline duration | Baseline 1 start | Baseline 1 finish | Total slack | Free slack | Text3 | Text4 | Text5 | Text7 | Text15 | Text23 | Text25 | Text26 | Text27 | Text29 | Text9 | Text1 | Indicadores MIR |
| --- | --- | --- | --- | --- | --- | --- | --- | --- | --- | --- | --- | --- | --- | --- | --- | --- | --- | --- | --- | --- | --- | --- | --- | --- | --- | --- | --- | --- | --- |
| 953 | 6.5.3.2 | **Fundiária** |  | 184d | 2019-01-15 A | 2019-10-09 A |  | 100% |  | 2018-03-23 | 2019-10-07 | 393d | 2018-03-23 | 2019-10-07 |  |  | 82% | 87 | 82 | 99 | 88 | Socioambiental | 0% | ok | 0% | Governador Valadares/MG (sede) |  |  |  |
| 954 | 6.5.3.2.1 | Obter Termo de Autorização para Vistoria Cautelar - UTR - ETA Santa Rita - Governador Valadares/MG |  | 142d | 2019-01-15 A | 2019-08-09 A | 935FS+211d | 100% |  | 2019-02-27 | 2019-06-03 | 63d | 2019-02-27 | 2019-06-03 |  |  | 100% | 63 | 100 | 63 | 100 | Socioambiental | 0% | Não OK | 0% | Governador Valadares/MG (sede) | Não OK |  |  |
| 955 | 6.5.3.2.2 | Conclusão da Regularização Fundiária para as obras de Melhoria do Sistema de Abastecimento da Localidade - Governador Valadares/MG | milestone | 0d | 2019-10-09 A | 2019-10-09 A | 954 | 100% |  | 2019-10-07 | 2019-10-07 | 0d | 2019-10-07 | 2019-10-07 |  |  | 0% |  |  |  |  |  |  |  |  |  |  |  |  |
| 956 | 6.5.3.3 | **Licenciamento** |  | 494d | 2017-08-16 A | 2019-07-19 A |  | 100% |  | 2016-03-23 | 2019-06-27 | 844d | 2016-03-23 | 2019-06-27 |  |  | 100% | 98 | 100 | 98 | 100 | Socioambiental | 0% | ok | 0% | Governador Valadares/MG (sede) |  |  |  |
| 957 | 6.5.3.3.1 | Emissão Autorização Ambiental de Funcionamento - ETA Santa Rita - Governador Valadares/MG | milestone | 0d | 2017-08-16 A | 2017-08-16 A | 24FS+366d | 100% |  | 2017-08-16 | 2017-08-16 | 0d | 2017-08-16 | 2017-08-16 |  |  | 100% | 100 | 100 | 100 | 100 |  | 0% | ok | 0% | Governador Valadares/MG (sede) |  |  |  |
| 958 | 6.5.3.3.2 | Obter DAIA para UTR - ETA Santa Rita - Governador Valadares/MG |  | 36d | 2019-05-30 A | 2019-07-19 A | 943FS+12d | 100% |  | 2019-05-30 | 2019-07-19 | 36d |  |  |  |  |  |  |  |  |  |  |  |  |  |  |  | 8888 |  |
| 959 | 6.5.3.3.3 | Conclusão do Licenciamento Ambiental da Localidade - Governador Valadares/MG | milestone | 0d | 2019-07-19 A | 2019-07-19 A | 957, 958 | 100% |  | 2020-10-20 | 2020-10-20 | 0d | 2019-06-27 | 2019-06-27 |  |  | 100% |  | 100 |  | 100 |  |  |  |  |  |  |  |  |
| 960 | 6.5.3.4 | **Suprimentos** |  | 172d | 2019-05-14 A | 2020-01-17 |  | 70% | 51d | 2019-02-05 | 2020-01-28 | 243d | 2019-02-05 | 2020-01-28 | 417d |  | 39% |  | 39 |  | 49 |  | 0% | ok | 0% | Governador Valadares/MG (sede) |  |  |  |
| 961 | 6.5.3.4.1 | **Santa Rita** |  | 172d | 2019-05-14 A | 2020-01-17 |  | 70% | 51d | 2019-02-05 | 2019-08-05 | 123d | 2019-02-05 | 2019-08-05 | 417d |  | 78% | 13 | 78 | 15 | 85 |  | 0% | ok | 0% | Governador Valadares/MG (sede) |  |  |  |
| 962 | 6.5.3.4.1.1 | Realizar análise da RT/PQ pela Infra - Nova ETA - ETA Santa Rita - Governador Valadares/MG |  | 22d | 2019-05-14 A | 2019-06-12 A | 941 | 100% |  | 2019-05-14 | 2019-06-12 | 22d |  |  |  |  |  |  |  |  |  |  |  |  |  |  |  | 8888 |  |
| 963 | 6.5.3.4.1.2 | Processo contratação Nova ETA (Captações, nova ETA e UTR) - ETA Santa Rita - Governador Valadares/MG |  | 150d | 2019-06-13 A | 2020-01-17 | 962 | 66% | 51d | 2019-03-29 | 2019-08-05 | 88d | 2019-03-29 | 2019-08-05 | 417d | 0d | 70% | 25 | 70 | 36 | 70 |  | 0% | ok | 0% | Governador Valadares/MG (sede) |  |  |  |
| 964 | 6.5.3.4.1.3 | Conclusão da Contratação de Suprimentos - ETA Santa Rita - Governador Valadares/MG | milestone | 0d | 2020-01-17 | 2020-01-17 | 963 |  |  | 2019-08-05 | 2019-08-05 | 0d | 2019-08-05 | 2019-08-05 | 417d | 0d | 0% |  |  |  |  |  |  |  |  |  |  |  |  |
| 965 | 6.5.3.5 | **Infraestrutura** |  | 517d | 2020-02-20 | 2022-03-22 |  |  |  | 2016-03-23 | 2022-03-21 | 1523d | 2016-03-23 | 2022-03-21 | 415d |  | 55% |  | 55 | 67 |  |  | 0% | ok | 0% | Governador Valadares/MG (sede) |  |  |  |
| 966 | 6.5.3.5.1 | **Obras** |  | 267d | 2020-02-20 | 2021-03-22 |  |  |  | 2016-03-23 | 2021-03-06 | 1263d | 2016-03-23 | 2021-03-06 | 434d |  | 66% |  | 66 | 86 |  |  |  |  |  |  |  |  |  |
| 967 | 6.5.3.5.1.1 | **ETA Santa Rita** |  | 267d | 2020-02-20 | 2021-03-22 |  |  |  | 2019-06-17 | 2021-03-05 | 427d | 2019-06-17 | 2021-03-05 | 434d |  | 2% |  |  |  |  |  | 0% | ok | 0% | Governador Valadares/MG (sede) |  |  |  |
| 968 | 6.5.3.5.1.1.1 | Obter aprovação da OS - Melhorias na ETA exixtente - ETA Santa Rita - Governador Valadares/MG |  | 14d | 2020-02-20 | 2020-03-13 | 952FS+88d |  |  | 2020-02-20 | 2020-03-13 | 14d |  |  | 610d | 0d |  |  |  |  |  |  |  |  |  |  |  |  |  |
| 969 | 6.5.3.5.1.1.2 | Executar Melhorias na ETA existente (36L/s) - ETA Santa Rita - Governador Valadares/MG |  | 60d | 2020-03-16 | 2020-06-10 | 943, 952, 954, 957, 963, 968 |  |  | 2019-08-05 | 2021-03-05 | 393d | 2019-08-05 | 2021-03-05 | 610d | 193d | 0% |  |  |  |  |  | 0% | ok | 0% | Governador Valadares/MG (sede) |  |  |  |
| 970 | 6.5.3.5.1.1.3 | Executar Nova ETA/Captação Principal/UTR (120L/s) - ETA Santa Rita - Governador Valadares/MG |  | 250d | 2020-03-19 | 2021-03-22 | 943, 958, 963, 955, 964FS+40d, 959 |  |  | 2019-06-17 | 2021-01-13 | 393d | 2019-06-17 | 2021-01-13 | 417d | 0d | 2% |  |  |  |  |  | 0% | ok | 0% | Governador Valadares/MG (sede) |  |  | ETA |
| 971 | 6.5.3.5.1.1.4 | Assinatura de Termo de Entrega das Obras de Melhoria do Sistema de Abastecimento de Água ETA Santa Rita - Governador Valadares/MG | milestone | 0d | 2021-03-22 | 2021-03-22 | 969, 970 |  |  | 2021-03-05 | 2021-03-05 | 0d | 2021-03-05 | 2021-03-05 | 665d | 0d | 0% |  |  |  |  |  | 0% | ok | 0% | Governador Valadares/MG (sede) |  |  |  |
| 972 | 6.5.3.5.1.2 | Assinatura de Termo de Entrega das Obras de Melhoria do Sistema de Abastecimento de Água - Governador Valadares/MG | milestone | 0d | 2021-03-22 | 2021-03-22 | 971 |  |  | 2021-03-06 | 2021-03-06 | 0d | 2021-03-06 | 2021-03-06 | 665d | 417d | 0% |  |  |  |  |  |  |  |  |  |  |  |  |
| 973 | 6.5.3.5.2 | **Operação** |  | 250d | 2021-03-22 | 2022-03-22 |  |  |  | 2020-11-19 | 2022-03-21 | 331d | 2020-11-19 | 2022-03-21 | 415d |  | 0% |  |  |  |  |  | 0% | ok | 0% | Governador Valadares/MG (sede) |  |  |  |
| 974 | 6.5.3.5.2.1 | **ETA Santa Rita** |  | 250d | 2021-03-22 | 2022-03-22 |  |  |  | 2021-03-08 | 2022-03-21 | 260d | 2021-03-08 | 2022-03-21 | 415d |  | 0% |  |  |  |  |  | 0% | ok | 0% | Governador Valadares/MG (sede) |  |  |  |
| 975 | 6.5.3.5.2.1.1 | Realizar Treinamento Operacional do Sistema - Governador Valadares/MG |  | 5d | 2021-03-23 | 2021-03-29 | 969, 970 |  |  | 2021-03-08 | 2021-03-12 | 5d | 2021-03-08 | 2021-03-12 | 646d | 0d | 0% |  |  |  |  |  | 0% | ok | 0% | Governador Valadares/MG (sede) |  |  |  |
| 976 | 6.5.3.5.2.1.2 | Realizar Testes e Pré-operação - Governador Valadares/MG |  | 14d | 2021-03-30 | 2021-04-19 | 975 |  |  | 2021-03-15 | 2021-04-01 | 14d | 2021-03-15 | 2021-04-01 | 646d |  | 0% |  |  |  |  |  | 0% | ok | 0% | Governador Valadares/MG (sede) |  |  |  |
| 977 | 6.5.3.5.2.1.3 | Realizar Acompanhamento da Funcionalidade do Sistema - ETA Santa Rita - Governador Valadares/MG (sede) |  | 365ed | 2021-03-22 | 2022-03-22 | 979SS |  |  | 2021-03-08 | 2022-03-21 | 260d |  |  | 1830d |  |  |  |  |  |  |  |  |  |  |  |  |  |  |

Notes:
- 953: 26/Nov: / - Verificar a que se refere o Fundiário da ETA Recanto dos Santos, pois para o Licenciamento não há previsão de licença (é melhoria de ETA? Se for, não requer licenciamento). / 01/Dez: / - Na planilha do Fundiário, há 3 imóveis previsto para adutora + captação. Se referem a qual projeto?
- 958: 18/09/19: Prazo da DAIA extraído do cronograma do Licenciamento de 18-09-19
- 961: 14/Fev19: / - Em reunião de integração entre as áreas nesta data, foi informado pelo Alessandro (Infraestrutura Território II - Calha e Médio Rio Doce) o abaixo: / . RT única para contratação de Captação Principal, Alternativa, nova ETA e UTR da ETA Santa Rita. / . Contrato guarda-chuva existente da Infraestrutura: execução de pequenas melhorias na ETA.

| ID | WBS | Task | Type | Duration | Start | Finish | Predecessors | Complete | Remaining | Baseline start | Baseline finish | Baseline duration | Baseline 1 start | Baseline 1 finish | Total slack | Free slack | Text3 | Text25 | Text26 | Text27 | Text29 | Text4 | Text5 | Text7 | Text15 | Text23 | Text13 | Text9 | Text1 |
| --- | --- | --- | --- | --- | --- | --- | --- | --- | --- | --- | --- | --- | --- | --- | --- | --- | --- | --- | --- | --- | --- | --- | --- | --- | --- | --- | --- | --- | --- |
| 978 | 6.5.3.5.2.1.4 | **Operação Assistida** |  | 61d | 2021-03-22 | 2021-06-20 |  |  |  | 2021-03-08 | 2021-06-08 | 64d | 2021-03-08 | 2021-06-08 | 417d |  | 0% | 0% | ok | 0% | Governador Valadares/MG (sede) |  |  |  |  |  |  |  |  |
| 979 | 6.5.3.5.2.1.4.1 | Realizar Operação Assistida - Governador Valadares/MG |  | 90ed | 2021-03-22 | 2021-06-20 | 969, 970 |  |  | 2021-03-08 | 2021-06-08 | 3.2mo | 2021-03-08 | 2021-06-08 | 1830d | 0d | 0% | 0% | ok | 0% | Governador Valadares/MG (sede) |  |  |  |  |  |  |  |  |
| 980 | 6.5.4 | **ETA Vila Isa** |  | 1287d | 2018-03-08 A | 2023-04-28 |  | 17% | 1065.85d | 2016-03-23 | 2022-03-21 | 1523d |  |  | 141d |  |  |  |  |  |  |  |  |  |  |  |  |  |  |
| 981 | 6.5.4.1 | **Engenharia** |  | 688d | 2018-03-08 A | 2020-11-27 |  | 59% | 284.44d | 2016-03-23 | 2019-11-08 | 939d | 2016-03-23 | 2019-11-08 | 242d |  | 89% |  | ok |  |  | 69 | 89 | 76 | 91 | Socioambiental |  |  |  |
| 982 | 6.5.4.1.1 | **Estudos de Concepção do Sistema** |  | 11d | 2018-03-08 A | 2018-03-23 A |  | 100% |  | 2018-03-08 | 2019-05-29 | 313d | 2018-03-08 | 2019-05-29 |  |  | 100% | 0% | ok | 0% | Governador Valadares/MG (sede) | 100 | 100 | 100 | 100 | Socioambiental |  |  |  |
| 983 | 6.5.4.1.1.1 | Declaração de Escopo e Premissas de Projeto (DEPP) concluída - Governador Valadares/MG | milestone | 0d | 2018-03-23 A | 2018-03-23 A | 25, 26 | 100% |  | 2018-03-23 | 2018-03-23 | 0d | 2018-03-23 | 2018-03-23 |  |  | 100% | 0% | ok | 0% | Governador Valadares/MG (sede) | 100 | 100 | 100 | 100 |  |  |  |  |
| 984 | 6.5.4.1.1.2 | Aprovação das DEPPs pela Operadora e Prefeitura - Governador Valadares/MG | milestone | 0d | 2018-03-08 A | 2018-03-08 A | 25, 26 | 100% |  | 2018-03-08 | 2018-03-08 | 0d | 2018-03-08 | 2018-03-08 |  |  | 100% | 0% | ok | 0% | Governador Valadares/MG (sede) | 100 | 100 | 100 | 100 |  |  |  |  |
| 985 | 6.5.4.1.2 | **Engenharia Básica e Detalhada** |  | 506d | 2018-11-19 A | 2020-11-27 |  | 59% | 209.19d | 2016-03-23 | 2019-11-08 | 939d | 2016-03-23 | 2019-11-08 | 242d |  | 89% | 0% | ok | 0% | Governador Valadares/MG (sede) | 69 | 89 | 76 | 91 | Socioambiental |  |  |  |
| 986 | 6.5.4.1.2.1 | **Engenharia Melhorias na ETA e Captação Principal - ETA Vila Isa** |  | 239d | 2018-11-19 A | 2019-10-30 A |  | 100% |  | 2018-11-19 | 2019-03-29 | 91d | 2018-11-19 | 2019-03-29 |  |  | 100% | 0% | ok | 0% | Governador Valadares/MG (sede) | 55 | 100 | 55 | 100 | Socioambiental |  |  |  |
| 987 | 6.5.4.1.2.1.1 | Aprovar Plano de Trabalho /abertura OSE - Melhorias na ETA e Captação Principal - ETA Vila Isa - Governador Valadares/MG |  | 4d | 2018-11-19 A | 2018-11-22 A | 983 | 100% |  | 2018-11-19 | 2018-11-22 | 4d | 2018-11-19 | 2018-11-22 |  |  | 100% | 0% | ok | 0% | Governador Valadares/MG (sede) | 100 | 100 | 100 | 100 |  |  |  |  |
| 988 | 6.5.4.1.2.1.2 | Realizar Levantamento de Campo - Melhorias na ETA e Captação Principal - ETA Vila Isa - Governador Valadares/MG |  | 1d | 2018-12-13 A | 2018-12-13 A | 987 | 100% |  | 2018-12-13 | 2018-12-13 | 1d | 2018-12-13 | 2018-12-13 |  |  | 100% | 0% | ok | 0% | Governador Valadares/MG (sede) | 100 | 100 | 100 | 100 |  |  |  |  |
| 989 | 6.5.4.1.2.1.3 | Elaborar arranjo para obtenção de Dados de Entrada Licenciamento e Fundiário - Melhorias na ETA - ETA Vila Isa - Governador Valadares/MG |  | 13d | 2019-10-14 A | 2019-10-30 A | 993FF+30d | 100% |  | 2018-12-14 | 2019-01-25 | 30d | 2018-12-14 | 2019-01-25 |  |  | 100% |  |  |  |  |  | 100 |  | 100 |  |  |  |  |
| 990 | 6.5.4.1.2.1.4 | Emitir RT/PQ para Suprimentos - Captação Principal - ETA Vila Isa - Governador Valadares/MG |  | 5d | 2019-04-15 A | 2019-04-23 A | 991FF | 100% |  | 2019-03-18 | 2019-03-29 | 10d | 2019-03-18 | 2019-03-29 |  |  | 100% |  |  |  |  |  | 100 |  | 100 |  |  |  |  |
| 991 | 6.5.4.1.2.1.5 | Elaborar Projeto Executivo - Captação Principal - ETA Vila Isa - Governador Valadares/MG |  | 28d | 2019-03-13 A | 2019-04-23 A |  | 100% |  | 2019-01-11 | 2019-03-29 | 53d | 2019-01-11 | 2019-03-29 |  |  | 100% | 0% | Não OK | 0% | Governador Valadares/MG (sede) | 80 | 100 | 80 | 100 | Socioambiental |  |  |  |
| 992 | 6.5.4.1.2.1.6 | Elaboração do Projeto Executivo - Captação Principal - ETA Vila Isa - Governador Valadares/MG | milestone | 0d | 2019-04-23 A | 2019-04-23 A | 990, 991 | 100% |  | 2019-03-29 | 2019-03-29 | 0d | 2019-03-29 | 2019-03-29 |  |  | 100% |  |  |  |  |  | 100 |  | 100 |  |  |  |  |
| 993 | 6.5.4.1.2.1.7 | Aprovar Projeto Executivo - Melhorias na ETA - ETA Vila Isa - Governador Valadares/MG |  | 124d | 2019-04-04 A | 2019-10-01 A | 988, 992 | 100% |  | 2019-01-11 | 2019-03-29 | 53d | 2019-01-11 | 2019-03-29 |  |  | 100% | 0% | Não OK | 0% | Governador Valadares/MG (sede) | 80 | 100 | 80 | 100 | Socioambiental |  |  |  |
| 994 | 6.5.4.1.2.1.8 | Elaboração do Projeto Executivo - Melhorias na ETA - ETA Vila Isa - Governador Valadares/MG | milestone | 0d | 2019-10-01 A | 2019-10-01 A | 993, 989FS-22d | 100% |  | 2019-03-29 | 2019-03-29 | 0d | 2019-03-29 | 2019-03-29 |  |  | 100% |  |  |  |  |  | 100 |  | 100 |  |  |  |  |
| 995 | 6.5.4.1.2.2 | **Engenharia Captação Alternativa (Derivação da Adutora de GV) - ETA Vila Isa** |  | 197d | 2019-03-01 A | 2019-12-16 A |  | 100% |  | 2019-05-27 | 2019-09-27 | 88d | 2019-05-27 | 2019-09-27 |  |  | 27% | 0% | ok | 0% | Governador Valadares/MG (sede) | 49 | 27 | 98 | 50 | Socioambiental |  |  |  |
| 996 | 6.5.4.1.2.2.1 | Aprovar Plano de Trabalho e abrir OSE - Captação Alternativa - ETA Vila Isa - Governador Valadares/MG |  | 60d | 2019-03-01 A | 2019-05-31 A | 983FS+343ed | 100% |  | 2019-05-27 | 2019-06-14 | 15d | 2019-05-27 | 2019-06-14 |  |  | 100% | 0% | Não OK | 0% | Governador Valadares/MG (sede) | 100 | 100 | 100 | 100 | Socioambiental |  |  |  |
| 997 | 6.5.4.1.2.2.2 | Definir ponto de entrega da tubulação - Captação Alternativa - ETA Vila Isa - Governador Valadares/MG |  | 1d | 2019-10-02 A | 2019-10-02 A | 993 | 100% |  | 2019-07-08 | 2019-07-08 | 1d |  |  |  |  | 0% |  |  |  |  |  |  |  |  |  |  |  |  |
| 998 | 6.5.4.1.2.2.3 | Emitir RT/PQ para Suprimentos - Captação Alternativa - ETA Vila Isa - Governador Valadares/MG |  | 10d | 2019-12-02 A | 2019-12-16 A | 999FF | 100% |  | 2019-07-11 | 2019-07-24 | 10d | 2019-07-11 | 2019-07-24 |  |  | 0% | 0% | Não OK | 0% | Governador Valadares/MG (sede) |  |  |  |  | Socioambiental | 8888888 |  |  |
| 999 | 6.5.4.1.2.2.4 | Elaborar Projeto Executivo - Captação Alternativa - ETA Vila Isa - Governador Valadares/MG |  | 51d | 2019-10-03 A | 2019-12-16 A | 996, 997 | 100% |  | 2019-07-18 | 2019-09-27 | 51d | 2019-07-18 | 2019-09-27 |  |  | 0% | 0% | Não OK | 0% | Governador Valadares/MG (sede) |  |  |  |  | Socioambiental | 8888888 |  |  |
| 1000 | 6.5.4.1.2.2.5 | Elaboração do Projeto Executivo - Captação Alternativa - ETA Vila Isa - Governador Valadares/MG | milestone | 0d | 2019-12-16 A | 2019-12-16 A | 998, 999 | 100% |  | 2019-09-27 | 2019-09-27 | 0d | 2019-09-27 | 2019-09-27 |  |  | 0% |  |  |  |  |  |  |  |  |  | 8888888 |  |  |
| 1001 | 6.5.4.1.2.3 | **Engenharia UTR - ETA Vila Isa** |  | 262d | 2019-11-07 A | 2020-11-27 |  | 13% | 227.91d | 2018-10-26 | 2019-04-15 | 118d | 2018-10-26 | 2019-04-15 | 242d |  | 100% | 0% | ok | 0% | Governador Valadares/MG (sede) | 13 | 100 | 13 | 100 | Socioambiental |  |  |  |
| 1002 | 6.5.4.1.2.3.1 | Aprovar Plano de Trabalho e abrir OSE - UTR - ETA Vila Isa - Governador Valadares/MG |  | 12d | 2019-11-07 A | 2019-11-25 A | 983FS+415d | 100% |  | 2018-10-26 | 2018-11-22 | 20d | 2018-10-26 | 2018-11-22 |  |  | 100% | 0% | Não OK | 0% | Governador Valadares/MG (sede) | 100 | 100 | 100 | 100 | Socioambiental | 8888888 | Não OK |  |
| 1003 | 6.5.4.1.2.3.2 | Realizar Levantamento de Campo - UTR - ETA Vila Isa - Governador Valadares/MG |  | 1d | 2019-11-26 A | 2019-11-26 A | 1002 | 100% |  | 2018-11-23 | 2018-11-26 | 2d | 2018-11-23 | 2018-11-26 |  |  | 100% | 0% | ok | 0% | Governador Valadares/MG (sede) | 100 | 100 | 100 | 100 |  | 8888888 |  |  |
| 1004 | 6.5.4.1.2.3.3 | Elaborar projeto conceitual - UTR - ETA Vila Isa - Governador Valadares/MG |  | 94d | 2019-11-27 A | 2020-04-16 | 1003 | 23% | 72d | 2019-10-30 | 2019-11-29 | 22d |  |  | 142d | 0d |  |  |  |  |  |  |  |  |  |  | 8888888 |  | 8888 |
| 1005 | 6.5.4.1.2.3.4 | Elaborar Projeto Básico - UTR - ETA Vila Isa - Governador Valadares/MG |  | 65d | 2020-04-17 | 2020-07-21 | 1004 |  |  | 2018-02-08 | 2018-03-21 | 30d | 2018-02-08 | 2018-03-21 | 142d | 0d | 100% | 0% | ok | 0% | Governador Valadares/MG (sede) |  | 100 |  | 100 |  |  |  |  |
| 1006 | 6.5.4.1.2.3.5 | Aprovar Projeto Básico - UTR - ETA Vila Isa - Governador Valadares/MG |  | 22d | 2020-07-22 | 2020-08-20 | 1005 |  |  | 2018-03-01 | 2018-03-30 | 22d |  |  | 142d | 0d |  |  |  |  |  |  |  |  |  |  |  |  |  |
| 1007 | 6.5.4.1.2.3.6 | Emitir RT/PQ para Suprimentos - UTR - ETA Vila Isa - Governador Valadares/MG |  | 7d | 2020-11-19 | 2020-11-27 | 1008FF |  |  | 2018-12-20 | 2019-01-03 | 10d | 2018-12-20 | 2019-01-03 | 142d | 0d | 100% | 0% | ok | 0% | Governador Valadares/MG (sede) |  | 100 |  | 100 |  |  |  |  |
| 1008 | 6.5.4.1.2.3.7 | Elaborar Projeto Executivo - UTR - ETA Vila Isa - Governador Valadares/MG |  | 68d | 2020-08-21 | 2020-11-27 | 1005, 1006 |  |  | 2018-12-26 | 2019-04-15 | 75d | 2018-12-26 | 2019-04-15 | 142d | 0d | 100% | 0% | ok | 0% | Governador Valadares/MG (sede) |  | 100 |  | 100 |  |  |  |  |
| 1009 | 6.5.4.1.2.3.8 | Elaboração do Projeto Executivo - UTR - ETA Vila Isa - Governador Valadares/MG | milestone | 0d | 2020-11-27 | 2020-11-27 | 1008 |  |  | 2019-04-15 | 2019-04-15 | 0d | 2019-04-15 | 2019-04-15 | 242d | 100d | 100% |  |  |  |  |  | 100 |  | 100 |  |  |  |  |

| ID | WBS | Task | Type | Duration | Start | Finish | Predecessors | Complete | Remaining | Baseline start | Baseline finish | Baseline duration | Baseline 1 start | Baseline 1 finish | Total slack | Free slack | Text3 | Text4 | Text5 | Text7 | Text15 | Text23 | Text25 | Text26 | Text27 | Text29 | Text9 | Text1 | Indicadores MIR |
| --- | --- | --- | --- | --- | --- | --- | --- | --- | --- | --- | --- | --- | --- | --- | --- | --- | --- | --- | --- | --- | --- | --- | --- | --- | --- | --- | --- | --- | --- |
| 1010 | 6.5.4.2 | **Fundiária** |  | 193d | 2019-01-02 A | 2019-10-09 A |  | 100% |  | 2018-03-23 | 2019-10-07 | 393d | 2018-03-23 | 2019-10-07 |  |  | 82% | 87 | 82 | 99 | 88 | Socioambiental | 0% | ok | 0% | Governador Valadares/MG (sede) |  |  |  |
| 1011 | 6.5.4.2.1 | Obter Termo de Autorização para Vistoria Cautelar - UTR - ETA Vila Isa - Governador Valadares/MG |  | 74d | 2019-01-02 A | 2019-04-22 A | 983FS+202d | 100% |  | 2019-01-02 | 2019-04-22 | 74d | 2019-01-02 | 2019-04-22 |  |  | 100% | 100 | 100 | 100 | 100 | Socioambiental | 0% | Não OK | 0% | Governador Valadares/MG (sede) | Não OK |  |  |
| 1012 | 6.5.4.2.2 | Conclusão da Regularização Fundiária para as obras de Melhoria do Sistema de Abastecimento da Localidade - Governador Valadares/MG | milestone | 0d | 2019-10-09 A | 2019-10-09 A | 1011 | 100% |  | 2019-10-07 | 2019-10-07 | 0d | 2019-10-07 | 2019-10-07 |  |  | 0% |  |  |  |  |  |  |  |  |  |  |  |  |
| 1013 | 6.5.4.3 | **Licenciamento** |  | 199d | 2020-04-17 | 2021-02-02 |  |  |  | 2016-03-23 | 2019-06-27 | 844d | 2016-03-23 | 2019-06-27 | 198d |  | 100% | 98 | 100 | 98 | 100 | Socioambiental | 0% | ok | 0% | Governador Valadares/MG (sede) |  |  |  |
| 1014 | 6.5.4.3.1 | Obter DAIA para UTR - ETA Vila Isa - Governador Valadares/MG |  | 199d | 2020-04-17 | 2021-02-02 | 1004 |  |  | 2019-12-02 | 2020-09-21 | 199d |  |  | 198d | 0d |  |  |  |  |  |  |  |  |  |  |  | 8888 |  |
| 1015 | 6.5.4.3.2 | Conclusão do Licenciamento Ambiental da Localidade - Governador Valadares/MG | milestone | 0d | 2021-02-02 | 2021-02-02 | 1014 |  |  | 2020-10-20 | 2020-10-20 | 0d | 2019-06-27 | 2019-06-27 | 198d | 56d | 100% |  | 100 |  | 100 |  |  |  |  |  |  |  |  |
| 1016 | 6.5.4.4 | **Suprimentos** |  | 100d | 2020-11-30 | 2021-04-28 |  |  |  | 2019-02-05 | 2020-01-28 | 243d | 2019-02-05 | 2020-01-28 | 142d |  | 39% |  | 39 |  | 49 |  | 0% | ok | 0% | Governador Valadares/MG (sede) |  |  |  |
| 1017 | 6.5.4.4.1 | **Vila Isa** |  | 100d | 2020-11-30 | 2021-04-28 |  |  |  | 2019-04-15 | 2019-08-21 | 88d | 2019-04-15 | 2019-08-21 | 142d |  | 57% |  | 57 |  | 57 |  | 0% | ok | 0% | Governador Valadares/MG (sede) |  |  |  |
| 1018 | 6.5.4.4.1.1 | Realizar análise da RT/PQ pela Infra - UTR - ETA Vila Isa - Governador Valadares/MG |  | 22d | 2020-11-30 | 2020-12-31 | 1004FS-22d, 1007 |  |  | 2019-10-30 | 2019-11-29 | 22d |  |  | 142d | 0d |  |  |  |  |  |  |  |  |  |  |  | 8888 |  |
| 1019 | 6.5.4.4.1.2 | Processo contratação CGC (ETA Central - Captação Principal e UTR/ Vila Isa UTR) - Governador Valadares/MG |  | 78d | 2021-01-04 | 2021-04-28 | 1018 |  |  | 2019-04-15 | 2019-08-21 | 88d | 2019-04-15 | 2019-08-21 | 142d | 0d | 57% |  | 57 |  | 57 |  | 0% | ok | 0% | Governador Valadares/MG (sede) |  |  |  |
| 1020 | 6.5.4.4.1.3 | Conclusão da Contratação de Suprimentos - ETA Vila Isa - Governador Valadares/MG | milestone | 0d | 2021-04-28 | 2021-04-28 | 1019 |  |  | 2019-08-21 | 2019-08-21 | 0d | 2019-08-21 | 2019-08-21 | 640d | 0d | 0% |  |  |  |  |  |  |  |  |  |  |  |  |
| 1021 | 6.5.4.4.2 | Conclusão da Contratação de Suprimentos das obras de Melhoria do Sistema de Abastecimento de Água - Governador Valadares/MG | milestone | 0d | 2021-04-28 | 2021-04-28 | 1020 |  |  | 2020-01-28 | 2020-01-28 | 0d | 2020-01-28 | 2020-01-28 | 640d | 250d | 0% |  |  |  |  |  |  |  |  |  |  |  |  |
| 1022 | 6.5.4.5 | **Infraestrutura** |  | 1061d | 2019-01-21 A | 2023-04-28 |  | 4% | 1022.73d | 2016-03-23 | 2022-03-21 | 1523d | 2016-03-23 | 2022-03-21 | 141d |  | 55% |  | 55 | 67 |  |  | 0% | ok | 0% | Governador Valadares/MG (sede) |  |  |  |
| 1023 | 6.5.4.5.1 | **Obras** |  | 812d | 2019-01-21 A | 2022-04-28 |  | 16% | 685.73d | 2016-03-23 | 2021-03-06 | 1263d | 2016-03-23 | 2021-03-06 | 390d |  | 66% |  | 66 | 86 |  |  |  |  |  |  |  |  |  |
| 1024 | 6.5.4.5.1.1 | **ETA Vila Isa** |  | 812d | 2019-01-21 A | 2022-04-28 |  | 16% | 685.73d | 2019-07-02 | 2021-01-27 | 393d | 2019-07-02 | 2021-01-27 | 390d |  | 0% |  |  |  |  |  | 0% | ok | 0% | Governador Valadares/MG (sede) |  |  |  |
| 1025 | 6.5.4.5.1.1.1 | Executar Melhorias na captação Principal - ETA Vila Isa - Governador Valadares/MG |  | 41d | 2019-01-21 A | 2019-03-21 A | 991FS-62d | 100% |  | 2019-01-21 | 2019-03-21 | 41d |  |  |  |  |  |  |  |  |  |  |  |  |  |  |  |  |  |
| 1026 | 6.5.4.5.1.1.2 | Executar Melhorias ETA - ETA Vila Isa - Governador Valadares/MG |  | 127d | 2019-11-25 A | 2020-06-02 | 994FS+37d | 19% | 103d | 2019-08-21 | 2021-01-27 | 358d | 2019-08-21 | 2021-01-27 | 616d | 474d | 0% |  |  |  |  |  | 0% | ok | 0% | Governador Valadares/MG (sede) |  |  | ETA |
| 1027 | 6.5.4.5.1.1.3 | Executar UTR - ETA Vila Isa - Governador Valadares/MG |  | 250d | 2021-04-29 | 2022-04-28 | 1008, 1009, 1011, 1014FF, 1019, 1015, 1012 |  |  | 2019-07-02 | 2021-01-27 | 393d | 2019-07-02 | 2021-01-27 | 142d | 0d | 0% |  |  |  |  |  | 0% | ok | 0% | Governador Valadares/MG (sede) |  |  |  |
| 1028 | 6.5.4.5.1.1.4 | Assinatura de Termo de Entrega das Obras de Melhoria do Sistema de Abastecimento de Água ETA Vila Isa - Governador Valadares/MG | milestone | 0d | 2022-04-28 | 2022-04-28 | 1025, 1026, 1027, 1021, 1000 |  |  | 2021-01-27 | 2021-01-27 | 0d | 2021-01-27 | 2021-01-27 | 390d | 0d | 0% |  |  |  |  |  | 0% | ok | 0% | Governador Valadares/MG (sede) |  |  |  |
| 1029 | 6.5.4.5.1.2 | Assinatura de Termo de Entrega das Obras de Melhoria do Sistema de Abastecimento de Água - Governador Valadares/MG | milestone | 0d | 2022-04-28 | 2022-04-28 | 1028 |  |  | 2021-03-06 | 2021-03-06 | 0d | 2021-03-06 | 2021-03-06 | 390d | 142d | 0% |  |  |  |  |  |  |  |  |  |  |  |  |
| 1030 | 6.5.4.5.2 | **Operação** |  | 249d | 2022-04-28 | 2023-04-28 |  |  |  | 2020-11-19 | 2022-03-21 | 331d | 2020-11-19 | 2022-03-21 | 141d |  | 0% |  |  |  |  |  | 0% | ok | 0% | Governador Valadares/MG (sede) |  |  |  |
| 1031 | 6.5.4.5.2.1 | **ETA Vila Isa** |  | 249d | 2022-04-28 | 2023-04-28 |  |  |  | 2021-01-28 | 2022-02-10 | 260d | 2021-01-28 | 2022-02-10 | 141d |  | 0% |  |  |  |  |  | 0% | ok | 0% | Governador Valadares/MG (sede) |  |  |  |
| 1032 | 6.5.4.5.2.1.1 | Realizar Treinamento Operacional do Sistema - Governador Valadares/MG |  | 5d | 2022-04-29 | 2022-05-05 | 1026, 1027 |  |  | 2021-01-28 | 2021-02-03 | 5d | 2021-01-28 | 2021-02-03 | 371d | 0d | 0% |  |  |  |  |  | 0% | ok | 0% | Governador Valadares/MG (sede) |  |  |  |
| 1033 | 6.5.4.5.2.1.2 | Realizar Testes e Pré-operação - Governador Valadares/MG |  | 14d | 2022-05-06 | 2022-05-25 | 1032 |  |  | 2021-02-04 | 2021-02-26 | 14d | 2021-02-04 | 2021-02-26 | 371d |  | 0% |  |  |  |  |  | 0% | ok | 0% | Governador Valadares/MG (sede) |  |  |  |
| 1034 | 6.5.4.5.2.1.3 | Realizar Acompanhamento da Funcionalidade do Sistema - ETA Vila Isa - Governador Valadares/MG (sede) |  | 365ed | 2022-04-28 | 2023-04-28 | 1036SS |  |  | 2021-01-28 | 2022-02-10 | 260d |  |  | 624d |  |  |  |  |  |  |  |  |  |  |  |  |  |  |

Notes:
- 1010: 26/Nov: / - Verificar a que se refere o Fundiário da ETA Recanto dos Santos, pois para o Licenciamento não há previsão de licença (é melhoria de ETA? Se for, não requer licenciamento). / 01/Dez: / - Na planilha do Fundiário, há 3 imóveis previsto para adutora + captação. Se referem a qual projeto?
- 1014: 18/09/19: Prazo da DAIA extraído do cronograma do Licenciamento de 18-09-19
- 1025: 17/09: Projeto de Bacia de Contenção e Melhorias

| ID | WBS | Task | Type | Duration | Start | Finish | Predecessors | Complete | Remaining | Baseline start | Baseline finish | Baseline duration | Baseline 1 start | Baseline 1 finish | Total slack | Free slack | Text3 | Text25 | Text26 | Text27 | Text29 | Text4 | Text5 | Text7 | Text15 | Text23 | Text9 | Text1 |
| --- | --- | --- | --- | --- | --- | --- | --- | --- | --- | --- | --- | --- | --- | --- | --- | --- | --- | --- | --- | --- | --- | --- | --- | --- | --- | --- | --- | --- |
| 1035 | 6.5.4.5.2.1.4 | **Operação Assistida** |  | 63d | 2022-04-28 | 2022-07-27 |  |  |  | 2021-01-28 | 2021-05-04 | 64d | 2021-01-28 | 2021-05-04 | 141d |  | 0% | 0% | ok | 0% | Governador Valadares/MG (sede) |  |  |  |  |  |  |  |
| 1036 | 6.5.4.5.2.1.4.1 | Realizar Operação Assistida - Governador Valadares/MG |  | 90ed | 2022-04-28 | 2022-07-27 | 1026, 1027 |  |  | 2021-01-28 | 2021-05-04 | 3.2mo | 2021-01-28 | 2021-05-04 | 624d | 0d | 0% | 0% | ok | 0% | Governador Valadares/MG (sede) |  |  |  |  |  |  |  |
| 1037 | 6.5.5 | **Captação Principal e Melhorias na ETA Recanto dos Sonhos** |  | 1167d | 2018-03-08 A | 2022-11-01 |  | 24% | 892.49d | 2016-03-23 | 2022-03-21 | 1523d |  |  | 261d |  |  |  |  |  |  |  |  |  |  |  |  |  |
| 1038 | 6.5.5.1 | **Engenharia** |  | 677d | 2018-03-08 A | 2020-11-12 |  | 57% | 289.12d | 2016-03-23 | 2019-11-08 | 939d | 2016-03-23 | 2019-11-08 | 303d |  | 89% |  | ok |  |  | 69 | 89 | 76 | 91 | Socioambiental |  |  |
| 1039 | 6.5.5.1.1 | **Estudos de Concepção do Sistema** |  | 11d | 2018-03-08 A | 2018-03-23 A |  | 100% |  | 2018-03-08 | 2019-05-29 | 313d | 2018-03-08 | 2019-05-29 |  |  | 100% | 0% | ok | 0% | Governador Valadares/MG (sede) | 100 | 100 | 100 | 100 | Socioambiental |  |  |
| 1040 | 6.5.5.1.1.1 | Declaração de Escopo e Premissas de Projeto (DEPP) concluída - Governador Valadares/MG | milestone | 0d | 2018-03-23 A | 2018-03-23 A | 25, 26 | 100% |  | 2018-03-23 | 2018-03-23 | 0d | 2018-03-23 | 2018-03-23 |  |  | 100% | 0% | ok | 0% | Governador Valadares/MG (sede) | 100 | 100 | 100 | 100 |  |  |  |
| 1041 | 6.5.5.1.1.2 | Aprovação das DEPPs pela Operadora e Prefeitura - Governador Valadares/MG | milestone | 0d | 2018-03-08 A | 2018-03-08 A | 25, 26 | 100% |  | 2018-03-08 | 2018-03-08 | 0d | 2018-03-08 | 2018-03-08 |  |  | 100% | 0% | ok | 0% | Governador Valadares/MG (sede) | 100 | 100 | 100 | 100 |  |  |  |
| 1042 | 6.5.5.1.2 | **Engenharia Básica e Detalhada** |  | 522d | 2018-10-11 A | 2020-11-12 |  | 57% | 222.93d | 2016-03-23 | 2019-11-08 | 939d | 2016-03-23 | 2019-11-08 | 303d |  | 89% | 0% | ok | 0% | Governador Valadares/MG (sede) | 69 | 89 | 76 | 91 | Socioambiental |  |  |
| 1043 | 6.5.5.1.2.1 | **Engenharia Melhorias ETA - ETA Recanto dos Sonhos** |  | 285d | 2018-10-11 A | 2019-11-27 A |  | 100% |  | 2018-10-11 | 2019-07-01 | 180d | 2018-10-11 | 2019-07-01 |  |  | 99% | 0% | ok | 0% | Governador Valadares/MG (sede) | 80 | 99 | 81 | 99 | Socioambiental |  |  |
| 1044 | 6.5.5.1.2.1.1 | Aprovar Plano de Trabalho e abrir OSE - Melhorias na ETA - ETA Recanto dos Sonhos - Governador Valadares/MG |  | 15d | 2018-11-05 A | 2018-11-23 A | 1040 | 100% |  | 2018-11-05 | 2018-11-23 | 15d | 2018-11-05 | 2018-11-23 |  |  | 100% | 0% | ok | 0% | Governador Valadares/MG (sede) | 100 | 100 | 100 | 100 |  |  |  |
| 1045 | 6.5.5.1.2.1.2 | Realizar Levantamento de Campo - Melhorias na ETA - ETA Recanto dos Sonhos - Governador Valadares/MG |  | 1d | 2018-12-13 A | 2018-12-13 A | 1044 | 100% |  | 2018-12-13 | 2018-12-13 | 1d | 2018-12-13 | 2018-12-13 |  |  | 100% | 0% | Não OK | 0% | Governador Valadares/MG (sede) | 100 | 100 | 100 | 100 | Socioambiental | Não OK |  |
| 1046 | 6.5.5.1.2.1.3 | Realizar Sondagem - Melhorias na ETA - ETA Recanto dos Sonhos - Governador Valadares/MG |  | 22d | 2019-01-18 A | 2019-02-18 A | 1044 | 100% |  | 2019-01-18 | 2019-02-18 | 22d | 2019-01-18 | 2019-02-18 |  |  | 100% |  |  |  |  | 100 | 100 | 100 | 100 |  |  |  |
| 1047 | 6.5.5.1.2.1.4 | Executar Topografia - Melhorias na ETA - ETA Recanto dos Sonhos - Governador Valadares/MG |  | 72d | 2018-10-11 A | 2019-01-21 A | 1044 | 100% |  | 2018-10-11 | 2019-01-21 | 72d | 2018-10-11 | 2019-01-21 |  |  | 100% |  |  |  |  | 100 | 100 | 100 | 100 |  |  |  |
| 1048 | 6.5.5.1.2.1.5 | Emitir RT/PQ para Suprimentos - Melhorias na ETA - ETA Recanto dos Sonhos - Governador Valadares/MG |  | 10d | 2019-05-17 A | 2019-05-30 A | 1049FF | 100% |  | 2019-06-17 | 2019-07-01 | 10d | 2019-06-17 | 2019-07-01 |  |  | 90% |  |  |  |  | 100 | 90 | 111 | 90 |  |  |  |
| 1049 | 6.5.5.1.2.1.6 | Elaborar Projeto Executivo - Melhorias na ETA - ETA Recanto dos Sonhos - Governador Valadares/MG |  | 113d | 2018-12-14 A | 2019-05-30 A | 1045FF, 1046FF, 1047FF+30d | 100% |  | 2018-12-14 | 2019-07-01 | 134d | 2018-12-14 | 2019-07-01 |  |  | 99% | 0% | Não OK | 0% | Governador Valadares/MG (sede) | 100 | 99 | 101 | 99 | Socioambiental |  |  |
| 1050 | 6.5.5.1.2.1.7 | Elaboração do Projeto Executivo - Melhorias na ETA - ETA Recanto dos Sonhos - Governador Valadares/MG | milestone | 0d | 2019-05-30 A | 2019-05-30 A | 1048, 1049 | 100% |  | 2019-07-01 | 2019-07-01 | 0d | 2019-07-01 | 2019-07-01 |  |  | 0% |  |  |  |  | 100 |  |  |  |  |  |  |
| 1051 | 6.5.5.1.2.1.8 | Elaborar Projeto Executivo (Acréscimo do Macromedidor na SE) - Melhorias na ETA - ETA Recanto dos Sonhos - Governador Valadares/MG |  | 38d | 2019-10-04 A | 2019-11-27 A | 1050FS+88d | 100% |  | 2019-10-04 | 2019-11-18 | 31d |  |  |  |  |  |  |  |  |  |  |  |  |  |  |  | 8888 |
| 1052 | 6.5.5.1.2.1.9 | Acréscimo no escopo do Projeto Executivo (Macromedidor) - Melhorias na ETA - ETA Recanto dos Sonhos - Governador Valadares/MG | milestone | 0d | 2019-11-27 A | 2019-11-27 A | 1051 | 100% |  | 2019-11-18 | 2019-11-18 | 0d |  |  |  |  |  |  |  |  |  |  |  |  |  |  |  | 8888 |
| 1053 | 6.5.5.1.2.2 | **Engenharia UTR - ETA Recanto dos Sonhos** |  | 214d | 2020-01-06 | 2020-11-12 |  |  |  | 2019-01-02 | 2019-10-11 | 195d | 2019-01-02 | 2019-10-11 | 262d |  | 62% | 0% | ok | 0% | Governador Valadares/MG (sede) | 25 | 62 | 45 | 56 | Socioambiental |  |  |
| 1054 | 6.5.5.1.2.2.1 | Aprovar Plano de Trabalho /abertura OSE - UTR - ETA Recanto dos Sonhos - Governador Valadares/MG |  | 10d | 2020-01-06 | 2020-01-17 | 1040FS+452d |  |  | 2019-01-02 | 2019-01-29 | 20d | 2019-01-02 | 2019-01-29 | 262d | 0d | 100% | 0% | Não OK | 0% | Governador Valadares/MG (sede) | 100 | 100 | 100 | 100 | Socioambiental | Não OK |  |
| 1055 | 6.5.5.1.2.2.2 | Realizar Sondagem - UTR - ETA Recanto dos Sonhos - Governador Valadares/MG |  | 14d | 2020-03-25 | 2020-04-14 | 1054FS+44d |  |  | 2019-05-14 | 2019-06-12 | 22d | 2019-05-14 | 2019-06-12 | 262d | 0d | 100% |  |  |  |  | 100 | 100 | 100 | 100 |  |  |  |
| 1056 | 6.5.5.1.2.2.3 | Elaborar Projeto Básico - UTR - ETA Recanto dos Sonhos - Governador Valadares/MG |  | 67d | 2020-04-15 | 2020-07-21 | 1055 |  |  | 2018-02-08 | 2018-03-21 | 30d | 2018-02-08 | 2018-03-21 | 262d | 0d | 100% | 0% | ok | 0% | Governador Valadares/MG (sede) |  | 100 |  | 100 |  |  |  |
| 1057 | 6.5.5.1.2.2.4 | Aprovar Projeto Básico - UTR - ETA Recanto dos Sonhos - Governador Valadares/MG |  | 22d | 2020-07-22 | 2020-08-20 | 1056 |  |  | 2018-03-01 | 2018-03-30 | 22d |  |  | 262d | 0d |  |  |  |  |  |  |  |  |  |  |  |  |
| 1058 | 6.5.5.1.2.2.5 | Emitir RT/PQ para Suprimentos - UTR - ETA Recanto dos Sonhos - Governador Valadares/MG |  | 10d | 2020-08-21 | 2020-09-03 | 1056FS+22d, 1057 |  |  | 2019-07-26 | 2019-08-08 | 10d | 2019-07-26 | 2019-08-08 | 262d | 0d | 0% | 0% | ok | 0% | Governador Valadares/MG (sede) |  |  |  |  |  |  |  |
| 1059 | 6.5.5.1.2.2.6 | Elaborar Projeto Executivo - UTR - ETA Recanto dos Sonhos - Governador Valadares/MG |  | 79d | 2020-07-22 | 2020-11-12 | 1055, 1056 |  |  | 2019-06-28 | 2019-10-11 | 75d | 2019-06-28 | 2019-10-11 | 303d | 0d | 1% | 0% | ok | 0% | Governador Valadares/MG (sede) |  |  |  |  |  |  |  |
| 1060 | 6.5.5.1.2.2.7 | Elaboração do Projeto Executivo - UTR - ETA Recanto dos Sonhos - Governador Valadares/MG | milestone | 0d | 2020-11-12 | 2020-11-12 | 1059 |  |  | 2019-10-11 | 2019-10-11 | 0d | 2019-10-11 | 2019-10-11 | 303d | 41d | 0% |  |  |  |  |  |  |  |  |  |  |  |

Notes:
- 1043: 06/Dez: / - Captação alternativa de Recanto dos Sonhos não é a Adutora de GV (rio Corrente) é uma adutora construída pela Samarco no rio Suaçuí Grande e já entregue formalmente ao SAAE de GV.
- 1044: 23/Jan19: / - PT aprovado pela ENG em 23/11/18.
- 1045: 25/Jan19: / - Levantamento de campo realizado/concluído em 13/12/18; Topografia iniciada em 11/10/18 e concluída em 21/01/19; Sondagem iniciada em 18/01 e prevista pra finalizar em 18/02/19.

| ID | WBS | Task | Type | Duration | Start | Finish | Predecessors | Complete | Remaining | Baseline start | Baseline finish | Baseline duration | Baseline 1 start | Baseline 1 finish | Total slack | Free slack | Text3 | Text4 | Text5 | Text7 | Text15 | Text23 | Text25 | Text26 | Text27 | Text29 | Text9 | Text1 | Indicadores MIR |
| --- | --- | --- | --- | --- | --- | --- | --- | --- | --- | --- | --- | --- | --- | --- | --- | --- | --- | --- | --- | --- | --- | --- | --- | --- | --- | --- | --- | --- | --- |
| 1061 | 6.5.5.2 | **Fundiária** |  | 395d | 2018-03-23 A | 2019-10-09 A |  | 100% |  | 2018-03-23 | 2019-10-07 | 393d | 2018-03-23 | 2019-10-07 |  |  | 82% | 87 | 82 | 99 | 88 | Socioambiental | 0% | ok | 0% | Governador Valadares/MG (sede) |  |  |  |
| 1062 | 6.5.5.2.1 | Obter Termos de Autorização de Superficiário - Captação Alternativa - rio Suaçuí Grande (ETA Recanto dos Sonhos) - Governador Valadares/MG |  | 115d | 2018-03-23 A | 2018-08-30 A | 1040 | 100% |  | 2018-03-23 | 2018-08-30 | 115d | 2018-03-23 | 2018-08-30 |  |  | 100% | 100 | 100 | 100 | 100 | Socioambiental | 0% | Não OK | 0% | Governador Valadares/MG (sede) | Não OK |  |  |
| 1063 | 6.5.5.2.2 | Captação Alternativa - rio Suaçuí Grande (ETA Recanto dos Sonhos) - Desimpedimentos de área - Governador Valadares/MG |  | 115d | 2018-03-23 A | 2018-08-30 A | 1062 | 100% |  | 2018-03-23 | 2018-08-30 | 115d | 2018-03-23 | 2018-08-30 |  |  | 100% | 100 | 100 | 100 | 100 | Socioambiental | 0% | Não OK | 0% | Governador Valadares/MG (sede) | Não OK |  |  |
| 1064 | 6.5.5.2.3 | Conclusão da Regularização Fundiária para as obras de Melhoria do Sistema de Abastecimento da Localidade - Governador Valadares/MG | milestone | 0d | 2019-10-09 A | 2019-10-09 A | 1062, 1063 | 100% |  | 2019-10-07 | 2019-10-07 | 0d | 2019-10-07 | 2019-10-07 |  |  | 0% |  |  |  |  |  |  |  |  |  |  |  |  |
| 1065 | 6.5.5.3 | **Licenciamento** |  | 199d | 2020-07-22 | 2021-05-11 |  |  |  | 2016-03-23 | 2019-06-27 | 844d | 2016-03-23 | 2019-06-27 | 383d |  | 100% | 98 | 100 | 98 | 100 | Socioambiental | 0% | ok | 0% | Governador Valadares/MG (sede) |  |  |  |
| 1066 | 6.5.5.3.1 | Obter DAIA para UTR - ETA Recanto dos Sonhos - Governador Valadares/MG |  | 199d | 2020-07-22 | 2021-05-11 | 1056 |  |  | 2020-01-03 | 2020-10-20 | 199d |  |  | 383d | 0d |  |  |  |  |  |  |  |  |  |  |  | 8888 |  |
| 1067 | 6.5.5.3.2 | Conclusão do Licenciamento Ambiental da Localidade - Governador Valadares/MG | milestone | 0d | 2021-05-11 | 2021-05-11 | 1066 |  |  | 2020-10-20 | 2020-10-20 | 0d | 2019-06-27 | 2019-06-27 | 383d | 121d | 100% |  | 100 |  | 100 |  |  |  |  |  |  |  |  |
| 1068 | 6.5.5.4 | **Suprimentos** |  | 88d | 2020-09-04 | 2021-01-13 |  |  |  | 2019-02-05 | 2020-01-28 | 243d | 2019-02-05 | 2020-01-28 | 262d |  | 39% |  | 39 |  | 49 |  | 0% | ok | 0% | Governador Valadares/MG (sede) |  |  |  |
| 1069 | 6.5.5.4.1 | **Recanto dos Sonhos** |  | 88d | 2020-09-04 | 2021-01-13 |  |  |  | 2019-09-20 | 2020-01-28 | 88d | 2019-09-20 | 2020-01-28 | 262d |  | 0% |  |  |  |  |  | 0% | ok | 0% | Governador Valadares/MG (sede) |  |  |  |
| 1070 | 6.5.5.4.1.1 | Processo contratação MAS 1 (Captação, ETA e UTR) - Governador Valadares/MG |  | 88d | 2020-09-04 | 2021-01-13 | 1048, 1058, 1064 |  |  | 2019-09-20 | 2020-01-28 | 88d | 2019-09-20 | 2020-01-28 | 262d | 0d | 0% |  |  |  |  |  | 0% | ok | 0% | Governador Valadares/MG (sede) |  |  |  |
| 1071 | 6.5.5.4.1.2 | Conclusão da Contratação de Suprimentos - ETA Recanto dos Sonhos - Governador Valadares/MG | milestone | 0d | 2021-01-13 | 2021-01-13 | 1070 |  |  | 2020-01-28 | 2020-01-28 | 0d | 2020-01-28 | 2020-01-28 | 262d | 0d | 0% |  |  |  |  |  |  |  |  |  |  |  |  |
| 1072 | 6.5.5.4.2 | Conclusão da Contratação de Suprimentos das obras de Melhoria do Sistema de Abastecimento de Água - Governador Valadares/MG | milestone | 0d | 2021-01-13 | 2021-01-13 | 1071 |  |  | 2020-01-28 | 2020-01-28 | 0d | 2020-01-28 | 2020-01-28 | 262d | 0d | 0% |  |  |  |  |  |  |  |  |  |  |  |  |
| 1073 | 6.5.5.5 | **Infraestrutura** |  | 921d | 2019-02-18 A | 2022-11-01 |  | 9% | 842.62d | 2016-03-23 | 2022-03-21 | 1523d | 2016-03-23 | 2022-03-21 | 261d |  | 55% |  | 55 | 67 |  |  | 0% | ok | 0% | Governador Valadares/MG (sede) |  |  |  |
| 1074 | 6.5.5.5.1 | **Obras** |  | 672d | 2019-02-18 A | 2021-11-01 |  | 38% | 417.91d | 2016-03-23 | 2021-03-06 | 1263d | 2016-03-23 | 2021-03-06 | 510d |  | 66% |  | 66 | 86 |  |  |  |  |  |  |  |  |  |
| 1075 | 6.5.5.5.1.1 | **ETA Recanto dos Sonhos** |  | 672d | 2019-02-18 A | 2021-11-01 |  | 38% | 417.91d | 2020-01-29 | 2020-11-18 | 201d | 2020-01-29 | 2020-11-18 | 510d |  | 0% |  |  |  |  |  | 0% | ok | 0% | Governador Valadares/MG (sede) |  |  |  |
| 1076 | 6.5.5.5.1.1.1 | Executar Captação Principal - ETA Recanto dos Sonhos - Governador Valadares/MG |  | 20d | 2019-02-18 A | 2019-03-20 A |  | 100% |  | 2020-01-29 | 2020-11-18 | 201d | 2020-01-29 | 2020-11-18 |  |  | 0% |  |  |  |  |  | 0% | ok | 0% | Governador Valadares/MG (sede) |  |  |  |
| 1077 | 6.5.5.5.1.1.2 | **Melhorias na ETA Recanto do Sonhos** |  | 234d | 2019-04-05 A | 2020-03-16 |  | 73% | 64.29d | 2019-04-05 | 2020-11-18 | 404d |  |  | 917d |  | 14% | 20 | 14 |  |  |  |  |  |  |  |  |  |  |
| 1078 | 6.5.5.5.1.1.2.1 | Executar Obras de Urbanização da ETA Recanto dos Sonhos - Governador Valadares/MG |  | 111d | 2019-04-05 A | 2019-09-13 A | 1049FS-37d | 100% |  | 2019-04-05 | 2019-05-21 | 30d |  |  |  |  | 100% | 71 | 100 |  |  |  |  |  |  |  |  |  |  |
| 1079 | 6.5.5.5.1.1.2.2 | Executar Obras de Melhorias na ETA (Macromedidor, Móveis e Leito Filtrante) - ETA Recanto dos Sonhos - Governador Valadares/MG |  | 71d | 2019-11-28 A | 2020-03-16 | 1052 | 30% | 50d | 2019-11-19 | 2020-03-16 | 78d |  |  | 917d | 0d |  |  |  |  |  |  |  |  |  |  |  |  |  |
| 1080 | 6.5.5.5.1.1.2.3 | Conclusão das Obras de Melhoria na ETA Recanto dos Sonhos - Governador Valadares/MG | milestone | 0d | 2020-03-16 | 2020-03-16 | 1078, 1079 |  |  | 2020-11-18 | 2020-11-18 | 0d |  |  | 917d | 407d | 0% |  |  |  |  |  |  |  |  |  |  |  | ETA |
| 1081 | 6.5.5.5.1.1.3 | Executar UTR - ETA Recanto dos Sonhos - Governador Valadares/MG |  | 200d | 2021-01-14 | 2021-11-01 | 1059, 1066FF, 1071, 1060, 1072, 1067FF |  |  | 2020-01-29 | 2020-11-18 | 201d | 2020-01-29 | 2020-11-18 | 262d | 0d | 0% |  |  |  |  |  | 0% | ok | 0% | Governador Valadares/MG (sede) |  |  |  |
| 1082 | 6.5.5.5.1.1.4 | Assinatura de Termo de Entrega das Obras de Melhoria do Sistema de Abastecimento de Água ETA Reacanto dos Sonhos - Governador Valadares/MG | milestone | 0d | 2021-11-01 | 2021-11-01 | 1076, 1080, 1081 |  |  | 2020-11-18 | 2020-11-18 | 0d | 2020-11-18 | 2020-11-18 | 510d | 0d | 0% |  |  |  |  |  | 0% | ok | 0% | Governador Valadares/MG (sede) |  |  |  |
| 1083 | 6.5.5.5.1.2 | Assinatura de Termo de Entrega das Obras de Melhoria do Sistema de Abastecimento de Água - Governador Valadares/MG | milestone | 0d | 2021-11-01 | 2021-11-01 | 1082 |  |  | 2021-03-06 | 2021-03-06 | 0d | 2021-03-06 | 2021-03-06 | 510d | 262d | 0% |  |  |  |  |  |  |  |  |  |  |  |  |
| 1084 | 6.5.5.5.2 | **Operação** |  | 249d | 2021-11-01 | 2022-11-01 |  |  |  | 2020-11-19 | 2022-03-21 | 331d | 2020-11-19 | 2022-03-21 | 261d |  | 0% |  |  |  |  |  | 0% | ok | 0% | Governador Valadares/MG (sede) |  |  |  |
| 1085 | 6.5.5.5.2.1 | **ETA Recanto dos Sonhos** |  | 249d | 2021-11-01 | 2022-11-01 |  |  |  | 2020-11-19 | 2021-12-06 | 260d | 2020-11-19 | 2021-12-06 | 261d |  | 0% |  |  |  |  |  | 0% | ok | 0% | Governador Valadares/MG (sede) |  |  |  |
| 1086 | 6.5.5.5.2.1.1 | Realizar Treinamento Operacional do Sistema - Governador Valadares/MG |  | 5d | 2021-11-03 | 2021-11-09 | 1076, 1081 |  |  | 2020-11-19 | 2020-11-25 | 5d | 2020-11-19 | 2020-11-25 | 491d | 0d | 0% |  |  |  |  |  | 0% | ok | 0% | Governador Valadares/MG (sede) |  |  |  |
| 1087 | 6.5.5.5.2.1.2 | Realizar Testes e Pré-operação - Governador Valadares/MG |  | 14d | 2021-11-10 | 2021-11-30 | 1086 |  |  | 2020-11-26 | 2020-12-15 | 14d | 2020-11-26 | 2020-12-15 | 491d |  | 0% |  |  |  |  |  | 0% | ok | 0% | Governador Valadares/MG (sede) |  |  |  |
| 1088 | 6.5.5.5.2.1.3 | Realizar Acompanhamento da Funcionalidade do Sistema - Captação Principal e Melhorias na ETA Recanto dos Sonhos - Governador Valadares/MG (sede) |  | 365ed | 2021-11-01 | 2022-11-01 | 1090SS |  |  | 2020-11-19 | 2021-12-06 | 260d |  |  | 1158d |  |  |  |  |  |  |  |  |  |  |  |  |  |  |

Notes:
- 1061: 26/Nov: / - Verificar a que se refere o Fundiário da ETA Recanto dos Santos, pois para o Licenciamento não há previsão de licença (é melhoria de ETA? Se for, não requer licenciamento). / 01/Dez: / - Na planilha do Fundiário, há 3 imóveis previsto para adutora + captação. Se referem a qual projeto?
- 1062: 30/Jan19: / - Aguardando Jurídico a emitir a minuta do contrato da servidão a ser enviada para avaliação da Piracanjuba (superficiário).
- 1066: 18/09/19: Prazo da DAIA extraído do cronograma do Licenciamento de 18-09-19
- 1079: 15/nov/19: Inclui prazo de compra e fabricação

| ID | WBS | Task | Type | Duration | Start | Finish | Predecessors | Complete | Remaining | Baseline start | Baseline finish | Baseline duration | Baseline 1 start | Baseline 1 finish | Total slack | Free slack | Text3 | Text25 | Text26 | Text27 | Text29 | Text4 | Text5 | Text7 | Text15 | Text23 | Text9 |
| --- | --- | --- | --- | --- | --- | --- | --- | --- | --- | --- | --- | --- | --- | --- | --- | --- | --- | --- | --- | --- | --- | --- | --- | --- | --- | --- | --- |
| 1089 | 6.5.5.5.2.1.4 | **Operação Assistida** |  | 61d | 2021-11-01 | 2022-01-30 |  |  |  | 2020-11-19 | 2021-02-24 | 64d | 2020-11-19 | 2021-02-24 | 262d |  | 0% | 0% | ok | 0% | Governador Valadares/MG (sede) |  |  |  |  |  |  |
| 1090 | 6.5.5.5.2.1.4.1 | Realizar Operação Assistida - Governador Valadares/MG |  | 90ed | 2021-11-01 | 2022-01-30 | 1076, 1081 |  |  | 2020-11-19 | 2021-02-24 | 3.2mo | 2020-11-19 | 2021-02-24 | 1158d | 0d | 0% | 0% | ok | 0% | Governador Valadares/MG (sede) |  |  |  |  |  |  |
| 1091 | 6.6 | **São Vítor (distrito Governador Valadares/MG)** |  | 1149d | 2018-01-10 A | 2022-08-05 |  | 23% | 881.02d | 2016-03-23 | 2021-08-27 | 1385d | 2016-03-23 | 2021-08-27 | 320d |  | 61% | 0% | ok | 0% | São Vítor (distrito Governador Valadares/MG) | 30 | 61 | 62 | 48 | Socioambiental |  |
| 1092 | 6.6.1 | **Captação Principal e Melhorias na ETA** |  | 923d | 2018-03-23 A | 2021-11-25 |  | 39% | 567.29d | 2018-03-23 | 2021-01-30 | 719d |  |  | 494d |  |  |  |  |  |  |  |  |  |  |  |  |
| 1093 | 6.6.1.1 | **Estudos de Concepção do Sistema** |  | 336d | 2018-03-23 A | 2019-07-17 A |  | 100% |  | 2018-03-23 | 2019-03-07 | 246d | 2018-03-23 | 2019-03-07 |  |  | 100% | 0% | ok | 0% | São Vítor (distrito Governador Valadares/MG) | 100 | 100 | 100 | 100 | Socioambiental |  |
| 1094 | 6.6.1.1.1 | Declaração de Escopo e Premissas de Projeto (DEPP) concluída - São Vítor/MG | milestone | 0d | 2018-03-23 A | 2018-03-23 A | 25, 26 | 100% |  | 2018-03-23 | 2018-03-23 | 0d | 2018-03-23 | 2018-03-23 |  |  | 100% | 0% | ok | 0% | São Vítor (distrito Governador Valadares/MG) | 100 | 100 | 100 | 100 |  |  |
| 1095 | 6.6.1.1.2 | Aprovação das DEPPs pela Operadora e Prefeitura - São Vítor/MG |  | 10d | 2019-02-19 A | 2019-03-07 A | 1105 | 100% |  | 2019-02-19 | 2019-03-07 | 10d | 2019-02-19 | 2019-03-07 |  |  | 100% | 0% | ok | 0% | São Vítor (distrito Governador Valadares/MG) | 100 | 100 | 100 | 100 |  |  |
| 1096 | 6.6.1.1.3 | Executar Coleta e Análise do Lodo da ETA - São Vítor/MG |  | 9d | 2019-05-21 A | 2019-05-31 A | 1095FS+49d | 100% |  | 2019-05-21 | 2019-05-29 | 7d | 2019-05-21 | 2019-05-29 |  |  | 100% |  |  |  |  | 100 | 100 | 100 | 100 |  |  |
| 1097 | 6.6.1.1.4 | **Captações Subterrâneas - Serviços em Poços Tubulares (Captação Alternativa)** |  | 280d | 2018-06-11 A | 2019-07-17 A |  | 100% |  | 2018-06-11 | 2019-02-25 | 185d | 2018-06-11 | 2019-02-25 |  |  | 100% | 0% | ok | 0% | São Vítor (distrito Governador Valadares/MG) | 100 | 100 | 100 | 100 | Socioambiental |  |
| 1098 | 6.6.1.1.4.1 | Realizar Perfilagem 1 (parcial) - Captação Alternativa - São Vítor/MG |  | 2d | 2018-06-11 A | 2018-06-12 A | 1094 | 100% |  | 2018-06-11 | 2018-06-12 | 2d | 2018-06-11 | 2018-06-12 |  |  | 100% | 0% | ok | 0% | São Vítor (distrito Governador Valadares/MG) | 100 | 100 | 100 | 100 |  |  |
| 1099 | 6.6.1.1.4.2 | Realizar Recuperação 1 (parcial) - Captação Alternativa - São Vítor/MG |  | 7d | 2018-06-13 A | 2018-06-21 A | 1098 | 100% |  | 2018-06-13 | 2018-06-21 | 7d | 2018-06-13 | 2018-06-21 |  |  | 100% | 0% | ok | 0% | São Vítor (distrito Governador Valadares/MG) | 100 | 100 | 100 | 100 |  |  |
| 1100 | 6.6.1.1.4.3 | Realizar Perfuração (reabertura de poço existente) - Captação Alternativa - São Vítor/MG |  | 2d | 2019-01-15 A | 2019-01-16 A | 1099FS+147d | 100% |  | 2019-01-15 | 2019-01-16 | 2d | 2019-01-15 | 2019-01-16 |  |  | 100% | 0% | ok | 0% | São Vítor (distrito Governador Valadares/MG) | 100 | 100 | 100 | 100 |  |  |
| 1101 | 6.6.1.1.4.4 | Realizar Recuperação - Captação Alternativa - São Vítor/MG |  | 2d | 2019-01-16 A | 2019-01-17 A | 1100SS+1d | 100% |  | 2019-01-16 | 2019-01-17 | 2d | 2019-01-16 | 2019-01-17 |  |  | 100% | 0% | ok | 0% | São Vítor (distrito Governador Valadares/MG) | 100 | 100 | 100 | 100 |  |  |
| 1102 | 6.6.1.1.4.5 | Realizar Perfilagem 2 - Captação Alternativa - São Vítor/MG |  | 1d | 2019-01-18 A | 2019-01-18 A | 1101 | 100% |  | 2019-01-18 | 2019-01-18 | 1d | 2019-01-18 | 2019-01-18 |  |  | 100% | 0% | ok | 0% | São Vítor (distrito Governador Valadares/MG) | 100 | 100 | 100 | 100 |  |  |
| 1103 | 6.6.1.1.4.6 | Elaborar Relatório Técnico - Captação Alternativa - São Vítor/MG |  | 23d | 2019-01-21 A | 2019-02-20 A | 1098, 1099, 1100, 1101, 1102 | 100% |  | 2019-01-21 | 2019-02-20 | 23d | 2019-01-21 | 2019-02-20 |  |  | 100% | 0% | ok | 0% | São Vítor (distrito Governador Valadares/MG) | 100 | 100 | 100 | 100 |  |  |
| 1104 | 6.6.1.1.4.7 | Realizar Instrumentação - Captação Alternativa - São Vítor/MG |  | 2d | 2019-07-16 A | 2019-07-17 A | 1103FS+96d | 100% |  | 2019-02-22 | 2019-02-25 | 2d | 2019-02-22 | 2019-02-25 |  |  | 100% | 0% | ok | 0% | São Vítor (distrito Governador Valadares/MG) | 100 | 100 | 100 | 100 |  |  |
| 1105 | 6.6.1.1.4.8 | Realizar Laudo de Serviços de Coleta, Análise de Água - Captação Alternativa - São Vítor/MG |  | 22d | 2019-01-18 A | 2019-02-18 A | 1101 | 100% |  | 2019-01-18 | 2019-02-18 | 22d | 2019-01-18 | 2019-02-18 |  |  | 100% | 0% | Não OK | 0% | São Vítor (distrito Governador Valadares/MG) | 100 | 100 | 100 | 100 | Socioambiental | Não OK |
| 1106 | 6.6.1.1.4.9 | Conclusão dos Serviços em poço tubular - Captação Alternativa - São Vítor/MG | milestone | 0d | 2019-02-18 A | 2019-02-18 A | 1105, 1104 | 100% |  | 2019-02-18 | 2019-02-18 | 0d | 2019-02-18 | 2019-02-18 |  |  | 100% |  |  |  |  | 100 | 100 | 100 | 100 |  |  |
| 1107 | 6.6.1.2 | **Engenharia Básica e Detalhada** |  | 281d | 2018-10-08 A | 2019-11-18 A |  | 100% |  | 2016-03-23 | 2019-06-21 | 840d | 2016-03-23 | 2019-06-21 |  |  | 100% | 0% | ok | 0% | São Vítor (distrito Governador Valadares/MG) | 66 | 100 | 66 | 100 | Socioambiental |  |
| 1108 | 6.6.1.2.1 | **Engenharia Captação Principal (Melhorias) - SE 32262** |  | 162d | 2018-10-08 A | 2019-05-30 A |  | 100% |  | 2018-10-08 | 2019-06-03 | 164d | 2018-10-08 | 2019-06-03 |  |  | 100% | 0% | ok | 0% | São Vítor (distrito Governador Valadares/MG) | 77 | 100 | 77 | 100 | Socioambiental |  |
| 1109 | 6.6.1.2.1.1 | Aprovar Plano de Trabalho e abrir OSE - Captação Principal - Rio Doce - São Vítor/MG |  | 6d | 2018-11-19 A | 2018-11-26 A | 1094 | 100% |  | 2018-11-19 | 2018-11-26 | 6d | 2018-11-19 | 2018-11-26 |  |  | 100% | 0% | ok | 0% | São Vítor (distrito Governador Valadares/MG) | 100 | 100 | 100 | 100 |  |  |
| 1110 | 6.6.1.2.1.2 | Realizar Levantamento de Campo - Captação Principal - Rio Doce - São Vítor/MG |  | 1d | 2018-12-14 A | 2018-12-14 A | 1094, 1109FF | 100% |  | 2018-12-14 | 2018-12-14 | 1d | 2018-12-14 | 2018-12-14 |  |  | 100% | 0% | Não OK | 0% | São Vítor (distrito Governador Valadares/MG) | 100 | 100 | 100 | 100 | Socioambiental | Não OK |
| 1111 | 6.6.1.2.1.3 | Executar Topografia - Captação Principal - Rio Doce - São Vítor/MG |  | 75d | 2018-10-08 A | 2019-01-21 A | 1094 | 100% |  | 2018-10-08 | 2019-01-21 | 75d | 2018-10-08 | 2019-01-21 |  |  | 100% |  |  |  |  | 100 | 100 | 100 | 100 |  |  |
| 1112 | 6.6.1.2.1.4 | Emitir RT/PQ para Suprimentos - Captação Principal - Rio Doce - São Vítor/MG |  | 8d | 2019-05-21 A | 2019-05-30 A | 1113FF | 100% |  | 2019-04-22 | 2019-05-02 | 8d | 2019-04-22 | 2019-05-02 |  |  | 100% |  |  |  |  | 100 | 100 | 100 | 100 |  |  |
| 1113 | 6.6.1.2.1.5 | Elaborar Projeto Executivo - Captação Principal - Rio Doce - São Vítor/MG |  | 113d | 2018-12-14 A | 2019-05-30 A | 1110, 1111FS-60d | 100% |  | 2018-12-14 | 2019-05-02 | 93d | 2018-12-14 | 2019-05-02 |  |  | 100% | 0% | Não OK | 0% | São Vítor (distrito Governador Valadares/MG) | 100 | 100 | 100 | 100 | Socioambiental | Não OK |
| 1114 | 6.6.1.2.1.6 | Elaboração do Projeto Executivo - Captação Principal - Rio Doce - São Vítor/MG | milestone | 0d | 2019-05-30 A | 2019-05-30 A | 1113, 1106, 1096 | 100% |  | 2019-06-03 | 2019-06-03 | 0d | 2019-06-03 | 2019-06-03 |  |  | 100% |  |  |  |  |  | 100 |  | 100 |  |  |

Notes:
- 1094: 21/Nov / - Considerado que não há revisão de DEPP para essa localidade conforme planilha de controle da engenharia.
- 1095: 03/Dez: / - O Termo de Anuência constante na pasta não é claro quanto ao aceite pela Operadora do proposto pelo DEPP para São Vítor. Verificar com o PG.
- 1098: 06/Dez: / - Poço obstruído, não foi possível concluir a Perfilagem.
- 1099: 06/Dez: / - Foi realizada a tentativa de descida de um gabarito para desobstrução do Poço.
- 1110: 25/Jan19: / - Levantamento de campo realizado/concluído em 14/12/18; Topografia iniciada em 08/10/18 e concluída em 21/01/19.

| ID | WBS | Task | Type | Duration | Start | Finish | Predecessors | Complete | Remaining | Baseline start | Baseline finish | Baseline duration | Baseline 1 start | Baseline 1 finish | Total slack | Free slack | Text3 | Text4 | Text5 | Text7 | Text15 | Text23 | Text25 | Text26 | Text27 | Text29 | Text9 | Text1 | Text13 | Indicadores MIR |
| --- | --- | --- | --- | --- | --- | --- | --- | --- | --- | --- | --- | --- | --- | --- | --- | --- | --- | --- | --- | --- | --- | --- | --- | --- | --- | --- | --- | --- | --- | --- |
| 1115 | 6.6.1.2.2 | **Engenharia Melhorias ETA - SE 32262** |  | 281d | 2018-10-08 A | 2019-11-18 A |  | 100% |  | 2018-10-08 | 2019-06-04 | 165d | 2018-10-08 | 2019-06-04 |  |  | 100% | 77 | 100 | 77 | 100 | Socioambiental | 0% | ok | 0% | São Vítor (distrito Governador Valadares/MG) |  |  |  |  |
| 1116 | 6.6.1.2.2.1 | Aprovar Plano de Trabalho e abrir OSE - Melhorias na ETA - São Vítor/MG |  | 6d | 2018-11-19 A | 2018-11-26 A | 1094 | 100% |  | 2018-11-19 | 2018-11-26 | 6d | 2018-11-19 | 2018-11-26 |  |  | 100% | 100 | 100 | 100 | 100 |  | 0% | ok | 0% | São Vítor (distrito Governador Valadares/MG) |  |  |  |  |
| 1117 | 6.6.1.2.2.2 | Realizar Levantamento de Campo - Melhorias na ETA - São Vítor/MG |  | 1d | 2018-12-14 A | 2018-12-14 A | 1094, 1116FF | 100% |  | 2018-12-14 | 2018-12-14 | 1d | 2018-12-14 | 2018-12-14 |  |  | 100% | 100 | 100 | 100 | 100 | Socioambiental | 0% | Não OK | 0% | São Vítor (distrito Governador Valadares/MG) | Não OK |  |  |  |
| 1118 | 6.6.1.2.2.3 | Executar Topografia - Melhorias na ETA - São Vítor/MG |  | 75d | 2018-10-08 A | 2019-01-21 A | 1094 | 100% |  | 2018-10-08 | 2019-01-21 | 75d | 2018-10-08 | 2019-01-21 |  |  | 100% | 100 | 100 | 100 | 100 |  |  |  |  |  |  |  |  |  |
| 1119 | 6.6.1.2.2.4 | Emitir RT/PQ para Suprimentos - Melhorias na ETA - São Vítor/MG |  | 10d | 2019-05-17 A | 2019-05-30 A | 1120FF | 100% |  | 2019-05-02 | 2019-05-15 | 10d | 2019-05-02 | 2019-05-15 |  |  | 100% | 100 | 100 | 100 | 100 |  |  |  |  |  |  |  |  |  |
| 1120 | 6.6.1.2.2.5 | Elaborar Projeto Executivo - Melhorias na ETA - São Vítor/MG |  | 112d | 2018-12-17 A | 2019-05-30 A | 1105FF, 1117, 1118 | 100% |  | 2018-12-17 | 2019-04-30 | 91d | 2018-12-17 | 2019-04-30 |  |  | 100% | 100 | 100 | 100 | 100 | Socioambiental | 0% | Não OK | 0% | São Vítor (distrito Governador Valadares/MG) | Não OK |  |  |  |
| 1121 | 6.6.1.2.2.6 | Elaboração do Projeto Executivo - Melhorias na ETA - São Vítor/MG | milestone | 0d | 2019-05-30 A | 2019-05-30 A | 1120 | 100% |  | 2019-04-30 | 2019-04-30 | 0d | 2019-04-30 | 2019-04-30 |  |  | 100% | 100 | 100 | 100 | 100 |  |  |  |  |  |  |  |  |  |
| 1122 | 6.6.1.2.2.7 | Elaborar Projeto Executivo (Acréscimo do Macromedidor na SE) - Melhorias na ETA - São Vítor/MG |  | 53d | 2019-09-04 A | 2019-11-18 A | 1121FS+66d | 100% |  | 2019-09-04 | 2019-10-18 | 33d |  |  |  |  |  |  |  |  |  |  |  |  |  |  |  | 8888 |  |  |
| 1123 | 6.6.1.2.2.8 | Acréscimo no escopo do Projeto Executivo (Macromedidor) - Melhorias na ETA - São Vítor/MG | milestone | 0d | 2019-11-18 A | 2019-11-18 A | 1122 | 100% |  | 2019-10-18 | 2019-10-18 | 0d |  |  |  |  |  |  |  |  |  |  |  |  |  |  |  | 8888 |  |  |
| 1124 | 6.6.1.3 | **Fundiária** |  | 143d | 2018-06-06 A | 2018-12-21 A |  | 100% |  | 2018-06-06 | 2018-12-21 | 143d | 2018-06-06 | 2018-12-21 |  |  | 100% | 100 | 100 | 909 | 11 |  |  | ok |  |  |  |  |  |  |
| 1125 | 6.6.1.3.1 | Obter Termo de Autorização de Superficiário - ETA/Captação Alternativa - São Vítor/MG |  | 143d | 2018-06-06 A | 2018-12-21 A | 1094FS+53d | 100% |  | 2019-06-06 | 2019-12-21 | 143d | 2018-06-06 | 2018-12-21 |  |  | 11% | 100 | 11 | 909 | 11 |  | 0% | ok | 0% | São Vítor (distrito Governador Valadares/MG) |  |  |  |  |
| 1126 | 6.6.1.3.2 | Conclusão da Regularização Fundiária para as obras de Melhoria do Sistema de Abastecimento da Localidade - São Vítor/MG | milestone | 0d | 2018-12-21 A | 2018-12-21 A | 1125 | 100% |  | 2018-12-21 | 2018-12-21 | 0d | 2018-12-21 | 2018-12-21 |  |  | 100% | 100 | 100 | 100 | 100 |  |  |  |  |  |  |  |  |  |
| 1127 | 6.6.1.4 | **Suprimentos** |  | 8d | 2019-06-03 A | 2019-06-12 A |  | 100% |  | 2019-03-18 | 2019-09-18 | 128d | 2019-03-18 | 2019-09-18 |  |  | 55% |  | 55 |  | 72 |  | 0% | ok | 0% | São Vítor (distrito Governador Valadares/MG) |  |  |  |  |
| 1128 | 6.6.1.4.1 | **Captação Principal e Melhorias na ETA (contrato guarda-chuva existente - Infraestrutura)** |  | 8d | 2019-06-03 A | 2019-06-12 A |  | 100% |  | 2019-05-16 | 2019-09-18 | 88d | 2019-05-16 | 2019-09-18 |  |  | 35% | 100 | 35 | 100 | 100 |  | 0% | ok | 0% | São Vítor (distrito Governador Valadares/MG) |  |  |  |  |
| 1129 | 6.6.1.4.1.1 | Incluir PQ no CGC existente - São Vítor/MG |  | 8d | 2019-06-03 A | 2019-06-12 A | 1112FS+1d, 1113, 1119, 1120 | 100% |  | 2019-05-16 | 2019-05-27 | 8d | 2019-05-16 | 2019-05-27 |  |  | 100% | 100 | 100 | 100 | 100 |  |  |  |  |  |  |  |  |  |
| 1130 | 6.6.1.4.1.2 | Conclusão da Contratação de Suprimentos - São Vítor/MG | milestone | 0d | 2019-06-12 A | 2019-06-12 A | 1129 | 100% |  | 2019-09-18 | 2019-09-18 | 0d | 2019-09-18 | 2019-09-18 |  |  | 0% | 100 |  |  |  |  |  |  |  |  |  |  |  |  |
| 1131 | 6.6.1.5 | **Infraestrutura** |  | 626d | 2019-05-23 A | 2021-11-25 |  | 16% | 527.61d | 2016-10-03 | 2021-08-27 | 1247d | 2016-10-03 | 2021-08-27 | 494d |  | 56% |  | 56 | 40 | 20 |  | 0% | ok | 0% | São Vítor (distrito Governador Valadares/MG) |  |  |  |  |
| 1132 | 6.6.1.5.1 | **Obras** |  | 378d | 2019-05-23 A | 2020-11-25 |  | 61% | 146.21d | 2016-10-03 | 2020-08-12 | 987d | 2016-10-03 | 2020-08-12 | 723d |  | 71% | 24 | 71 | 120 | 20 |  |  |  |  |  |  |  |  |  |
| 1133 | 6.6.1.5.1.1 | Executar obras de Melhorias na Captação Principal - São Vítor/MG |  | 126d | 2019-05-23 A | 2019-11-19 A | 1113FS-15d, 1130FS-15d, 1114 | 100% |  | 2019-11-21 | 2020-06-02 | 129d | 2019-11-21 | 2020-06-02 |  |  | 0% | 37 |  |  |  |  | 0% | ok | 0% | São Vítor (distrito Governador Valadares/MG) |  |  |  |  |
| 1134 | 6.6.1.5.1.2 | Executar ajuste da Captação Principal (Pendente prazo de revisão do projeto) - São Vítor/MG |  | 126d | 2020-05-28 | 2020-11-25 | 1113FS-15d, 1130FS-15d, 1114, 1133FS+126d |  |  | 2019-11-21 | 2020-06-02 | 129d | 2019-11-21 | 2020-06-02 | 494d | 0d | 0% | 37 |  |  |  |  | 0% | ok | 0% | São Vítor (distrito Governador Valadares/MG) |  |  | 8888888 |  |
| 1135 | 6.6.1.5.1.3 | **Melhorias na ETA** |  | 203d | 2019-05-23 A | 2020-03-16 |  | 74% | 52.78d | 2019-05-23 | 2020-02-12 | 183d |  |  | 898d |  |  |  |  |  |  |  |  |  |  |  |  | 8888 |  |  |
| 1136 | 6.6.1.5.1.3.1 | Executar Melhorias na ETA - São Vítor/MG |  | 147d | 2019-05-23 A | 2019-12-19 A | 1120FS-15d, 1130FS-15d, 1126 | 100% |  | 2019-11-21 | 2020-08-04 | 173d | 2019-11-21 | 2020-08-04 |  |  | 0% | 37 |  |  |  |  | 0% | ok | 0% | São Vítor (distrito Governador Valadares/MG) |  |  |  |  |
| 1137 | 6.6.1.5.1.3.2 | Executar Melhorias na ETA (Acréscimo do Macromedidor) - São Vítor/MG |  | 78d | 2019-11-19 A | 2020-03-16 | 1122, 1123 | 25% | 58.5d | 2019-10-21 | 2020-02-12 | 78d |  |  | 898d | 0d |  |  |  |  |  |  |  |  |  |  |  | 8888 | 8888888 |  |
| 1138 | 6.6.1.5.1.3.3 | Conclusão das Obras de Melhorias na ETA - São Vítor/MG | milestone | 0d | 2020-03-16 | 2020-03-16 | 1137 |  |  | 2020-08-04 | 2020-08-04 | 0d |  |  | 898d | 0d |  |  |  |  |  |  |  |  |  |  |  | 8888 |  | ETA |

Notes:
- 1115: 25/Jan19: / - ENG não considerando Laudo.
- 1117: 25/Jan19: / - Levantamento de campo realizado/concluído em 14/12/18; Topografia iniciada em 08/10/18 e concluída em 21/01/19.
- 1125: 20/Dez: / - Refere-se a Captação Alternativa - Poço São Vítor - Termo de Autorização de Superficiário.
- 1127: 14/Fev19: / - Em reunião de integração entre as áreas nesta data, foi informado pelo Alessandro (Infraestrutura Território II - Calha e Médio Rio Doce) o abaixo: / . RT para contratação de STA Poços Tubulares para: Pedra Corrida, Tumiritinga (sede), Senhora da Penha e São Vitor (GV); e para construções de novas ETA's/UTR's de Senhora da Penha e São Tomé do Rio Doce (Tumiritinga). / . Contrato guarda-chuva existente da Infraestrutura: execução de pequenas melhorias (ETA, Captação Principal). / - Deverá ser elaborada outra RT para a UTR.
- 1137: 15/nov/19: Inclui prazo de compra, fabricação, entrega e instalação.

| ID | WBS | Task | Type | Duration | Start | Finish | Predecessors | Complete | Remaining | Baseline start | Baseline finish | Baseline duration | Baseline 1 start | Baseline 1 finish | Total slack | Free slack | Text3 | Text25 | Text26 | Text27 | Text29 | Text13 | Text4 | Text5 | Text7 | Text15 | Text23 | Text9 |
| --- | --- | --- | --- | --- | --- | --- | --- | --- | --- | --- | --- | --- | --- | --- | --- | --- | --- | --- | --- | --- | --- | --- | --- | --- | --- | --- | --- | --- |
| 1139 | 6.6.1.5.2 | **Operação** |  | 248d | 2020-11-25 | 2021-11-25 |  |  |  | 2020-08-13 | 2021-08-27 | 260d | 2020-08-13 | 2021-08-27 | 494d |  | 0% | 0% | ok | 0% | São Vítor (distrito Governador Valadares/MG) |  |  |  |  |  |  |  |
| 1140 | 6.6.1.5.2.1 | Realizar Treinamento Operacional do Sistema - São Vítor/MG |  | 5d | 2020-11-26 | 2020-12-02 | 1133, 1136, 1138, 1134 |  |  | 2020-08-13 | 2020-08-19 | 5d | 2020-08-13 | 2020-08-19 | 723d | 0d | 0% | 0% | ok | 0% | São Vítor (distrito Governador Valadares/MG) |  |  |  |  |  |  |  |
| 1141 | 6.6.1.5.2.2 | Realizar Testes e Pré-operação - São Vítor/MG |  | 14d | 2020-12-03 | 2020-12-22 | 1140 |  |  | 2020-08-20 | 2020-09-09 | 14d | 2020-08-20 | 2020-09-09 | 723d |  | 0% | 0% | ok | 0% | São Vítor (distrito Governador Valadares/MG) |  |  |  |  |  |  |  |
| 1142 | 6.6.1.5.2.3 | Realizar Acompanhamento da Funcionalidade do Sistema - Captação Principal e Melhorias na ETA - São Vítor (distrito Governador Valadares/MG) |  | 365ed | 2020-11-25 | 2021-11-25 | 1144SS |  |  | 2020-01-31 | 2021-01-30 | 365ed |  |  | 2181d |  |  |  |  |  |  | 8888888 |  |  |  |  |  |  |
| 1143 | 6.6.1.5.2.4 | **Operação Assistida** |  | 58d | 2020-11-25 | 2021-02-23 |  |  |  | 2020-08-13 | 2020-11-13 | 64d | 2020-08-13 | 2020-11-13 | 494d |  | 0% | 0% | ok | 0% | São Vítor (distrito Governador Valadares/MG) |  |  |  |  |  |  |  |
| 1144 | 6.6.1.5.2.4.1 | Realizar Operação Assistida - São Vítor/MG |  | 90ed | 2020-11-25 | 2021-02-23 | 1133, 1136, 1134 |  |  | 2020-08-13 | 2020-11-13 | 3.2mo | 2020-08-13 | 2020-11-13 | 2181d | 0d | 0% | 0% | ok | 0% | São Vítor (distrito Governador Valadares/MG) | 8888888 |  |  |  |  |  |  |
| 1145 | 6.6.2 | **Captação Alternativa** |  | 803d | 2018-01-10 A | 2021-03-19 |  | 26% | 590.49d | 2018-01-10 | 2021-03-12 | 798d |  |  | 666d |  |  |  |  |  |  |  |  |  |  |  |  |  |
| 1146 | 6.6.2.1 | **Estudos de Concepção do Sistema** |  | 336d | 2018-03-23 A | 2019-07-17 A |  | 100% |  | 2018-03-23 | 2019-03-07 | 246d | 2018-03-23 | 2019-03-07 |  |  | 100% | 0% | ok | 0% | São Vítor (distrito Governador Valadares/MG) |  | 100 | 100 | 100 | 100 | Socioambiental |  |
| 1147 | 6.6.2.1.1 | Declaração de Escopo e Premissas de Projeto (DEPP) concluída - São Vítor/MG | milestone | 0d | 2018-03-23 A | 2018-03-23 A | 25, 26 | 100% |  | 2018-03-23 | 2018-03-23 | 0d | 2018-03-23 | 2018-03-23 |  |  | 100% | 0% | ok | 0% | São Vítor (distrito Governador Valadares/MG) |  | 100 | 100 | 100 | 100 |  |  |
| 1148 | 6.6.2.1.2 | **Captações Subterrâneas - Serviços em Poços Tubulares (Captação Alternativa)** |  | 280d | 2018-06-11 A | 2019-07-17 A |  | 100% |  | 2018-06-11 | 2019-02-25 | 185d | 2018-06-11 | 2019-02-25 |  |  | 100% | 0% | ok | 0% | São Vítor (distrito Governador Valadares/MG) |  | 100 | 100 | 100 | 100 | Socioambiental |  |
| 1149 | 6.6.2.1.2.1 | Realizar Perfilagem 1 (parcial) - Captação Alternativa - São Vítor/MG |  | 2d | 2018-06-11 A | 2018-06-12 A | 1147 | 100% |  | 2018-06-11 | 2018-06-12 | 2d | 2018-06-11 | 2018-06-12 |  |  | 100% | 0% | ok | 0% | São Vítor (distrito Governador Valadares/MG) |  | 100 | 100 | 100 | 100 |  |  |
| 1150 | 6.6.2.1.2.2 | Realizar Recuperação 1 (parcial) - Captação Alternativa - São Vítor/MG |  | 7d | 2018-06-13 A | 2018-06-21 A | 1149 | 100% |  | 2018-06-13 | 2018-06-21 | 7d | 2018-06-13 | 2018-06-21 |  |  | 100% | 0% | ok | 0% | São Vítor (distrito Governador Valadares/MG) |  | 100 | 100 | 100 | 100 |  |  |
| 1151 | 6.6.2.1.2.3 | Realizar Perfuração (reabertura de poço existente) - Captação Alternativa - São Vítor/MG |  | 2d | 2019-01-15 A | 2019-01-16 A | 1150FS+147d | 100% |  | 2019-01-15 | 2019-01-16 | 2d | 2019-01-15 | 2019-01-16 |  |  | 100% | 0% | ok | 0% | São Vítor (distrito Governador Valadares/MG) |  | 100 | 100 | 100 | 100 |  |  |
| 1152 | 6.6.2.1.2.4 | Realizar Recuperação - Captação Alternativa - São Vítor/MG |  | 2d | 2019-01-16 A | 2019-01-17 A | 1151SS+1d | 100% |  | 2019-01-16 | 2019-01-17 | 2d | 2019-01-16 | 2019-01-17 |  |  | 100% | 0% | ok | 0% | São Vítor (distrito Governador Valadares/MG) |  | 100 | 100 | 100 | 100 |  |  |
| 1153 | 6.6.2.1.2.5 | Realizar Perfilagem 2 - Captação Alternativa - São Vítor/MG |  | 1d | 2019-01-18 A | 2019-01-18 A | 1152 | 100% |  | 2019-01-18 | 2019-01-18 | 1d | 2019-01-18 | 2019-01-18 |  |  | 100% | 0% | ok | 0% | São Vítor (distrito Governador Valadares/MG) |  | 100 | 100 | 100 | 100 |  |  |
| 1154 | 6.6.2.1.2.6 | Elaborar Relatório Técnico - Captação Alternativa - São Vítor/MG |  | 23d | 2019-01-21 A | 2019-02-20 A | 1149, 1150, 1151, 1152, 1153 | 100% |  | 2019-01-21 | 2019-02-20 | 23d | 2019-01-21 | 2019-02-20 |  |  | 100% | 0% | ok | 0% | São Vítor (distrito Governador Valadares/MG) |  | 100 | 100 | 100 | 100 |  |  |
| 1155 | 6.6.2.1.2.7 | Realizar Instrumentação - Captação Alternativa - São Vítor/MG |  | 2d | 2019-07-16 A | 2019-07-17 A | 1154FS+96d | 100% |  | 2019-02-22 | 2019-02-25 | 2d | 2019-02-22 | 2019-02-25 |  |  | 100% | 0% | ok | 0% | São Vítor (distrito Governador Valadares/MG) |  | 100 | 100 | 100 | 100 |  |  |
| 1156 | 6.6.2.1.2.8 | Realizar Laudo de Serviços de Coleta, Análise de Água - Captação Alternativa - São Vítor/MG |  | 22d | 2019-01-18 A | 2019-02-18 A | 1152 | 100% |  | 2019-01-18 | 2019-02-18 | 22d | 2019-01-18 | 2019-02-18 |  |  | 100% | 0% | Não OK | 0% | São Vítor (distrito Governador Valadares/MG) |  | 100 | 100 | 100 | 100 | Socioambiental | Não OK |
| 1157 | 6.6.2.1.2.9 | Conclusão dos Serviços em poço tubular - Captação Alternativa - São Vítor/MG | milestone | 0d | 2019-02-18 A | 2019-02-18 A | 1156 | 100% |  | 2019-02-18 | 2019-02-18 | 0d | 2019-02-18 | 2019-02-18 |  |  | 100% |  |  |  |  |  | 100 | 100 | 100 | 100 |  |  |
| 1158 | 6.6.2.1.3 | Conclusão dos Estudos de Concepção das Melhorias do Sistema de Abastecimento de Água - São Vítor/MG | milestone | 0d | 2019-02-18 A | 2019-02-18 A | 1157 | 100% |  | 2019-02-18 | 2019-02-18 | 0d | 2019-02-18 | 2019-02-18 |  |  | 100% |  |  |  |  |  | 100 | 100 | 100 | 100 |  |  |
| 1159 | 6.6.2.2 | **Engenharia Básica e Detalhada** |  | 478d | 2018-01-10 A | 2019-11-22 A |  | 100% |  | 2016-03-23 | 2019-06-21 | 840d | 2016-03-23 | 2019-06-21 |  |  | 100% | 0% | ok | 0% | São Vítor (distrito Governador Valadares/MG) |  | 66 | 100 | 66 | 100 | Socioambiental |  |
| 1160 | 6.6.2.2.1 | **Engenharia Captação Alternativa (Poço São Vítor) - SE 32012** |  | 478d | 2018-01-10 A | 2019-11-22 A |  | 100% |  | 2016-03-23 | 2018-10-31 | 681d | 2016-03-23 | 2018-10-31 |  |  | 100% | 0% | ok | 0% | São Vítor (distrito Governador Valadares/MG) |  | 78 | 100 | 78 | 100 |  |  |
| 1161 | 6.6.2.2.1.1 | Dados de Entrada (levantamento de campo, topografia, sondagem) - Captação Alternativa - Poço São Vítor - São Vítor/MG |  | 15d | 2018-01-10 A | 2018-01-30 A | 26 | 100% |  | 2018-01-10 | 2018-01-30 | 15d | 2018-01-10 | 2018-01-30 |  |  | 100% | 0% | ok | 0% | São Vítor (distrito Governador Valadares/MG) |  | 100 | 100 | 100 | 100 |  |  |
| 1162 | 6.6.2.2.1.2 | Elaborar arranjo para obtenção de Dados de Entrada Licenciamento e Fundiário - Captação Alternativa - Poço São Vítor - São Vítor/MG |  | 44d | 2018-01-31 A | 2018-04-02 A | 1161 | 100% |  | 2018-01-31 | 2018-04-02 | 44d | 2018-01-31 | 2018-04-02 |  |  | 100% | 0% | ok | 0% | São Vítor (distrito Governador Valadares/MG) |  | 100 | 100 | 100 | 100 |  |  |
| 1163 | 6.6.2.2.1.3 | Elaborar Projeto Executivo (Adequação da Infraestrutura do Poço) - Captação Alternativa - Poço São Vítor - São Vítor/MG |  | 152d | 2018-04-03 A | 2018-10-31 A | 1162 | 100% |  | 2018-04-03 | 2018-10-31 | 152d | 2018-04-03 | 2018-10-31 |  |  | 100% | 0% | ok | 0% | São Vítor (distrito Governador Valadares/MG) |  | 100 | 100 | 100 | 100 |  |  |
| 1164 | 6.6.2.2.1.4 | Elaboração do Projeto Executivo (Adequação da Infraestrutura do Poço) - Captação Alternativa - Poço São Vítor - São Vítor/MG | milestone | 0d | 2018-10-31 A | 2018-10-31 A | 1163 | 100% |  | 2016-03-23 | 2016-03-23 | 0d | 2016-03-23 | 2016-03-23 |  |  | 100% |  |  |  |  |  | 100 | 100 | 100 | 100 |  |  |
| 1165 | 6.6.2.2.1.5 | Elaborar e Aprovar Projeto Executivo para incluir o STA do poço - Captação Alternativa - Poço São Vítor - São Vítor/MG |  | 88d | 2019-07-22 A | 2019-11-22 A | 1156FS+102d | 100% |  | 2019-07-02 | 2019-09-30 | 64d |  |  |  |  | 0% |  |  |  |  |  |  |  |  |  |  |  |
| 1166 | 6.6.2.2.1.6 | Elaboração do Projeto Executivo - Captação Alternativa - Poço São Vítor - São Vítor/MG | milestone | 0d | 2019-11-22 A | 2019-11-22 A | 1165, 1164 | 100% |  | 2019-09-30 | 2019-09-30 | 0d |  |  |  |  | 0% |  |  |  |  |  |  |  |  |  |  |  |

Notes:
- 1147: 21/Nov / - Considerado que não há revisão de DEPP para essa localidade conforme planilha de controle da engenharia.
- 1149: 06/Dez: / - Poço obstruído, não foi possível concluir a Perfilagem.
- 1150: 06/Dez: / - Foi realizada a tentativa de descida de um gabarito para desobstrução do Poço.
- 1160: 25/Jan19: / - Engenharia considerando como Captação Alternativa, projeto de Adequação do Poço Existente, concluído em 31/10/18. / - Não foi considerado como input para desenvolvimento do projeto de Captação Alternativa, o Relatório Técnico dos serviços realizados no poço e o Laudo de Serviços de Coleta e Análise de Água (previstos para serem emitidos em 21/02 e 18/02/19, respectivamente). / 18/Dez / - No CR do PG não concluí o projeto. Linkei o desenvolvimento do Projeto Detalhado com o Relatório Técnico do Poço. / 06/Dez: / - Projeto incluído no CR ENG (03/12/18). Porém apresenta-se como concluído em 31/10/18. Comunicar ao PG uma vez que a captação alternativa de São Vítor depende do resultado dos serviços a serem realizados no poço. / 03/Dez:/ / - Não previsto projeto no cronograma da Engenharia (apenas melhorias na ETA existente e UTR). / - Localidade não consta na planilha detalhada da Engenharia/DEPP.

| ID | WBS | Task | Type | Duration | Start | Finish | Predecessors | Complete | Remaining | Baseline start | Baseline finish | Baseline duration | Baseline 1 start | Baseline 1 finish | Total slack | Free slack | Text3 | Text4 | Text5 | Text7 | Text15 | Text26 | Text25 | Text27 | Text29 | Text23 | Text9 | Text13 |
| --- | --- | --- | --- | --- | --- | --- | --- | --- | --- | --- | --- | --- | --- | --- | --- | --- | --- | --- | --- | --- | --- | --- | --- | --- | --- | --- | --- | --- |
| 1167 | 6.6.2.3 | **Fundiária** |  | 143d | 2018-06-06 A | 2018-12-21 A |  | 100% |  | 2018-06-06 | 2018-12-21 | 143d | 2018-06-06 | 2018-12-21 |  |  | 100% | 100 | 100 | 909 | 11 | ok |  |  |  |  |  |  |
| 1168 | 6.6.2.3.1 | Obter Termo de Autorização de Superficiário - ETA/Captação Alternativa - São Vítor/MG |  | 143d | 2018-06-06 A | 2018-12-21 A | 1147FS+53d | 100% |  | 2019-06-06 | 2019-12-21 | 143d | 2018-06-06 | 2018-12-21 |  |  | 11% | 100 | 11 | 909 | 11 | ok | 0% | 0% | São Vítor (distrito Governador Valadares/MG) |  |  |  |
| 1169 | 6.6.2.3.2 | Conclusão da Regularização Fundiária para as obras de Melhoria do Sistema de Abastecimento da Localidade - São Vítor/MG | milestone | 0d | 2018-12-21 A | 2018-12-21 A | 1168 | 100% |  | 2018-12-21 | 2018-12-21 | 0d | 2018-12-21 | 2018-12-21 |  |  | 100% | 100 | 100 | 100 | 100 |  |  |  |  |  |  |  |
| 1170 | 6.6.2.4 | **Licenciamento** |  | 176d | 2019-06-12 A | 2020-02-21 |  | 25% | 132d | 2019-02-21 | 2019-11-05 | 176d | 2019-02-21 | 2019-11-05 | 930d |  | 48% | 25 | 48 | 52 | 48 | ok | 0% | 0% | São Vítor (distrito Governador Valadares/MG) |  |  |  |
| 1171 | 6.6.2.4.1 | Obter Outorga/DAIA para Captação Alternativa (Poço São Vítor) - São Vítor/MG |  | 176d | 2019-06-12 A | 2020-02-21 | 1154FS+73d, 1162, 1168 | 25% | 132d | 2019-02-21 | 2019-11-05 | 176d | 2019-02-21 | 2019-11-05 | 930d | 0d | 48% | 25 | 48 | 52 | 48 | ok | 0% | 0% | São Vítor (distrito Governador Valadares/MG) |  |  |  |
| 1172 | 6.6.2.4.2 | Conclusão do Licenciamento Ambiental da Localidade - São Vítor/MG | milestone | 0d | 2020-02-21 | 2020-02-21 | 1171 |  |  | 2019-11-05 | 2019-11-05 | 0d | 2019-11-05 | 2019-11-05 | 930d | 16d | 0% |  |  |  |  |  |  |  |  |  |  |  |
| 1173 | 6.6.2.5 | **Infraestrutura** |  | 318d | 2019-12-04 A | 2021-03-19 |  | 1% | 314.17d | 2016-10-03 | 2021-08-27 | 1247d | 2016-10-03 | 2021-08-27 | 666d |  | 56% |  | 56 | 40 | 20 | ok | 0% | 0% | São Vítor (distrito Governador Valadares/MG) |  |  |  |
| 1174 | 6.6.2.5.1 | **Obras** |  | 70d | 2019-12-04 A | 2020-03-19 |  | 25% | 52.5d | 2016-10-03 | 2020-08-12 | 987d | 2016-10-03 | 2020-08-12 | 914d |  | 71% | 24 | 71 | 120 | 20 |  |  |  |  |  |  |  |
| 1175 | 6.6.2.5.1.1 | Executar Captação Alternativa (Poço São Vítor) - Interligação do poço a ETA e STA - São Vítor/MG |  | 70d | 2019-12-04 A | 2020-03-19 | 1155, 1163, 1166FS+7d, 1168 | 25% | 52.5d | 2019-11-21 | 2020-06-02 | 129d | 2019-11-21 | 2020-06-02 | 666d | 0d | 0% |  |  |  |  | ok | 0% | 0% | São Vítor (distrito Governador Valadares/MG) |  |  |  |
| 1176 | 6.6.2.5.1.2 | Assinatura de Termo de Entrega das Obras de Melhoria do Sistema de Abastecimento de Água - São Vítor/MG | milestone | 0d | 2020-03-19 | 2020-03-19 | 1175, 1172 |  |  | 2020-08-12 | 2020-08-12 | 0d | 2020-08-12 | 2020-08-12 | 914d | 666d | 0% |  |  |  |  | ok | 0% | 0% | São Vítor (distrito Governador Valadares/MG) |  |  |  |
| 1177 | 6.6.2.5.2 | **Operação** |  | 248d | 2020-03-19 | 2021-03-19 |  |  |  | 2020-08-13 | 2021-08-27 | 260d | 2020-08-13 | 2021-08-27 | 666d |  | 0% |  |  |  |  | ok | 0% | 0% | São Vítor (distrito Governador Valadares/MG) |  |  |  |
| 1178 | 6.6.2.5.2.1 | Realizar Treinamento Operacional do Sistema - São Vítor/MG |  | 5d | 2020-03-20 | 2020-03-26 | 1175 |  |  | 2020-08-13 | 2020-08-19 | 5d | 2020-08-13 | 2020-08-19 | 895d | 0d | 0% |  |  |  |  | ok | 0% | 0% | São Vítor (distrito Governador Valadares/MG) |  |  |  |
| 1179 | 6.6.2.5.2.2 | Realizar Testes e Pré-operação - São Vítor/MG |  | 14d | 2020-03-27 | 2020-04-16 | 1178 |  |  | 2020-08-20 | 2020-09-09 | 14d | 2020-08-20 | 2020-09-09 | 895d |  | 0% |  |  |  |  | ok | 0% | 0% | São Vítor (distrito Governador Valadares/MG) |  |  |  |
| 1180 | 6.6.2.5.2.3 | Realizar Acompanhamento da Funcionalidade do Sistema - Captação Alternativa - São Vítor (distrito Governador Valadares/MG) |  | 365ed | 2020-03-19 | 2021-03-19 | 1182SS |  |  | 2020-03-12 | 2021-03-12 | 365ed |  |  | 2934d |  |  |  |  |  |  |  |  |  |  |  |  |  |
| 1181 | 6.6.2.5.2.4 | **Operação Assistida** |  | 60d | 2020-03-19 | 2020-06-17 |  |  |  | 2020-08-13 | 2020-11-13 | 64d | 2020-08-13 | 2020-11-13 | 666d |  | 0% |  |  |  |  | ok | 0% | 0% | São Vítor (distrito Governador Valadares/MG) |  |  |  |
| 1182 | 6.6.2.5.2.4.1 | Realizar Operação Assistida - São Vítor/MG |  | 90ed | 2020-03-19 | 2020-06-17 | 1175 |  |  | 2020-08-13 | 2020-11-13 | 3.2mo | 2020-08-13 | 2020-11-13 | 2934d | 0d | 0% |  |  |  |  | ok | 0% | 0% | São Vítor (distrito Governador Valadares/MG) |  |  |  |
| 1183 | 6.6.3 | **UTR** |  | 665d | 2019-12-03 A | 2022-08-05 |  | 2% | 654.22d | 2020-03-12 | 2021-03-12 | 249d |  |  | 320d |  |  |  |  |  |  |  |  |  |  |  |  |  |
| 1184 | 6.6.3.1 | **Engenharia Básica e Detalhada** |  | 186d | 2019-12-03 A | 2020-09-02 |  | 17% | 155.15d | 2016-03-23 | 2019-06-21 | 840d | 2016-03-23 | 2019-06-21 | 351d |  | 100% | 66 | 100 | 66 | 100 | ok | 0% | 0% | São Vítor (distrito Governador Valadares/MG) | Socioambiental |  |  |
| 1185 | 6.6.3.1.1 | **Engenharia UTR** |  | 186d | 2019-12-03 A | 2020-09-02 |  | 17% | 155.15d | 2019-01-03 | 2019-05-23 | 95d | 2019-01-03 | 2019-05-23 | 351d |  | 100% | 25 | 100 | 25 | 100 | ok | 0% | 0% | São Vítor (distrito Governador Valadares/MG) | Socioambiental |  |  |
| 1186 | 6.6.3.1.1.1 | Aprovar Plano de Trabalho e Abrir SE - UTR - São Vítor/MG |  | 19d | 2019-12-03 A | 2020-01-02 | 1147FS+432d | 95% | 1d | 2019-01-04 | 2019-01-29 | 18d | 2019-01-04 | 2019-01-29 | 322d | 0d | 100% | 100 | 100 | 100 | 100 | Não OK | 0% | 0% | São Vítor (distrito Governador Valadares/MG) | Socioambiental | Não OK | 8888888 |
| 1187 | 6.6.3.1.1.2 | Realizar Levantamento de Campo - UTR - São Vítor/MG |  | 10d | 2019-12-18 A | 2020-01-03 | 1186FF+1d | 80% | 2d | 2019-01-31 | 2019-01-31 | 1d | 2019-01-31 | 2019-01-31 | 332d | 10d | 100% | 100 | 100 | 100 | 100 | ok | 0% | 0% | São Vítor (distrito Governador Valadares/MG) |  |  | 8888888 |
| 1188 | 6.6.3.1.1.3 | Realizar Sondagem - UTR - São Vítor/MG |  | 10d | 2019-12-18 A | 2020-01-03 | 1186FF+1d | 80% | 2d | 2019-01-30 | 2019-03-15 | 30d | 2019-01-30 | 2019-03-15 | 322d | 0d | 100% | 100 | 100 | 100 | 100 |  |  |  |  |  |  | 8888888 |
| 1189 | 6.6.3.1.1.4 | Elaborar Projeto Básico - UTR - São Vítor/MG |  | 65d | 2020-01-20 | 2020-04-24 | 1188FS+10d, 1187 |  |  | 2018-02-08 | 2018-03-21 | 30d | 2018-02-08 | 2018-03-21 | 322d | 0d | 100% |  | 100 |  | 100 | ok | 0% | 0% | São Vítor (distrito Governador Valadares/MG) |  |  |  |
| 1190 | 6.6.3.1.1.5 | Aprovar Projeto Básico - UTR - São Vítor/MG |  | 22d | 2020-04-27 | 2020-05-27 | 1189 |  |  | 2018-03-01 | 2018-03-30 | 22d |  |  | 351d | 0d |  |  |  |  |  |  |  |  |  |  |  |  |
| 1191 | 6.6.3.1.1.6 | Emitir RT/PQ para Suprimentos - UTR - São Vítor/MG |  | 10d | 2020-04-27 | 2020-05-11 | 1189 |  |  | 2019-02-27 | 2019-03-15 | 10d | 2019-02-27 | 2019-03-15 | 322d | 0d | 100% |  | 100 |  | 100 | ok | 0% | 0% | São Vítor (distrito Governador Valadares/MG) |  |  |  |
| 1192 | 6.6.3.1.1.7 | Elaborar Projeto Executivo - UTR - São Vítor/MG |  | 69d | 2020-05-28 | 2020-09-02 | 1188, 1189, 1190, 1191FF |  |  | 2019-01-31 | 2019-05-23 | 75d | 2019-01-31 | 2019-05-23 | 351d | 0d | 100% |  | 100 |  | 100 | ok | 0% | 0% | São Vítor (distrito Governador Valadares/MG) |  |  |  |
| 1193 | 6.6.3.1.1.8 | Elaboração do Projeto Executivo - UTR - São Vítor/MG | milestone | 0d | 2020-09-02 | 2020-09-02 | 1192 |  |  | 2019-05-23 | 2019-05-23 | 0d | 2019-05-23 | 2019-05-23 | 351d | 29d | 100% |  | 100 |  | 100 |  |  |  |  |  |  |  |

Notes:
- 1168: 20/Dez: / - Refere-se a Captação Alternativa - Poço São Vítor - Termo de Autorização de Superficiário.
- 1171: 26/Nov: / - Segundo Licenciamento, o Poço São Vitor deverá ser licenciado (outorga para captação/DAIA).
- 1187: 25/Jan19: / - Levantamento de campo previsto para iniciar em 05/02 e finalizar em 06/02/19; Sondagem prevista para iniciar em 07/02 e finalizar em 13/03/19.

| ID | WBS | Task | Type | Duration | Start | Finish | Predecessors | Complete | Remaining | Baseline start | Baseline finish | Baseline duration | Baseline 1 start | Baseline 1 finish | Total slack | Free slack | Text3 | Text4 | Text5 | Text7 | Text15 | Text25 | Text26 | Text27 | Text29 | Text1 | Text23 |
| --- | --- | --- | --- | --- | --- | --- | --- | --- | --- | --- | --- | --- | --- | --- | --- | --- | --- | --- | --- | --- | --- | --- | --- | --- | --- | --- | --- |
| 1194 | 6.6.3.2 | **Licenciamento** |  | 199d | 2020-04-27 | 2021-02-09 |  |  |  | 2019-02-21 | 2019-11-05 | 176d | 2019-02-21 | 2019-11-05 | 563d |  | 48% | 25 | 48 | 52 | 48 | 0% | ok | 0% | São Vítor (distrito Governador Valadares/MG) |  |  |
| 1195 | 6.6.3.2.1 | Obter DAIA para UTR - São Vítor/MG |  | 199d | 2020-04-27 | 2021-02-09 | 1189 |  |  | 2020-01-03 | 2020-10-20 | 199d |  |  | 563d | 0d |  |  |  |  |  |  |  |  |  | 8888 |  |
| 1196 | 6.6.3.2.2 | Conclusão do Licenciamento Ambiental da Localidade - São Vítor/MG | milestone | 0d | 2021-02-09 | 2021-02-09 | 1195 |  |  | 2019-11-05 | 2019-11-05 | 0d | 2019-11-05 | 2019-11-05 | 691d | 121d | 0% |  |  |  |  |  |  |  |  |  |  |
| 1197 | 6.6.3.3 | **Suprimentos** |  | 110d | 2020-05-12 | 2020-10-15 |  |  |  | 2019-03-18 | 2019-09-18 | 128d | 2019-03-18 | 2019-09-18 | 322d |  | 55% |  | 55 |  | 72 | 0% | ok | 0% | São Vítor (distrito Governador Valadares/MG) |  |  |
| 1198 | 6.6.3.3.1 | **Contratação MAS 2 (UTR's)** |  | 110d | 2020-05-12 | 2020-10-15 |  |  |  | 2019-03-18 | 2019-07-23 | 88d | 2019-03-18 | 2019-07-23 | 322d |  | 80% |  | 80 |  | 81 | 0% | ok | 0% | São Vítor (distrito Governador Valadares/MG) |  |  |
| 1199 | 6.6.3.3.1.1 | Analisar a RT/PQ emitida pela Engenharia (Infra) - UTR - São Vítor/MG |  | 22d | 2020-05-12 | 2020-06-10 | 1191 |  |  | 2020-04-16 | 2020-05-19 | 22d |  |  | 322d | 0d |  |  |  |  |  |  |  |  |  | 8888 |  |
| 1200 | 6.6.3.3.1.2 | Abrir a RC - São Vítor/MG |  | 8d | 2020-06-12 | 2020-06-23 | 1199 |  |  | 2019-03-18 | 2019-03-27 | 8d | 2019-03-18 | 2019-03-27 | 322d | 0d | 100% |  | 100 |  | 100 |  |  |  |  |  |  |
| 1201 | 6.6.3.3.1.3 | Aprovar a RC (liberação) - São Vítor/MG |  | 8d | 2020-06-24 | 2020-07-03 | 1200 |  |  | 2019-03-28 | 2019-04-08 | 8d | 2019-03-28 | 2019-04-08 | 322d | 0d | 100% |  | 100 |  | 100 |  |  |  |  |  |  |
| 1202 | 6.6.3.3.1.4 | Prospectar fornecedores e receber proposta técnicas - São Vítor/MG |  | 30d | 2020-07-06 | 2020-08-14 | 1201 |  |  | 2019-04-09 | 2019-05-23 | 30d | 2019-04-09 | 2019-05-23 | 322d | 0d | 100% |  | 100 |  | 100 |  |  |  |  |  |  |
| 1203 | 6.6.3.3.1.5 | Aprovar proposta técnica - São Vítor/MG |  | 12d | 2020-08-17 | 2020-09-01 | 1202 |  |  | 2019-05-24 | 2019-06-10 | 12d | 2019-05-24 | 2019-06-10 | 322d | 0d | 100% |  | 100 |  | 100 |  |  |  |  |  |  |
| 1204 | 6.6.3.3.1.6 | Realizar negociação e aprovar o pedido - São Vítor/MG |  | 30d | 2020-09-02 | 2020-10-15 | 1203 |  |  | 2019-06-11 | 2019-07-23 | 30d | 2019-06-11 | 2019-07-23 | 322d | 0d | 43% |  | 43 |  | 43 |  |  |  |  |  |  |
| 1205 | 6.6.3.3.1.7 | Conclusão da Contratação de Suprimentos - São Vítor/MG | milestone | 0d | 2020-10-15 | 2020-10-15 | 1204 |  |  | 2019-07-23 | 2019-07-23 | 0d | 2019-07-23 | 2019-07-23 | 770d | 0d | 0% |  |  |  |  |  |  |  |  |  |  |
| 1206 | 6.6.3.3.2 | Conclusão da Contratação de Suprimentos das obras de Melhoria do Sistema de Abastecimento de Água - São Vítor/MG | milestone | 0d | 2020-10-15 | 2020-10-15 | 1205 |  |  | 2019-09-18 | 2019-09-18 | 0d | 2019-09-18 | 2019-09-18 | 770d | 200d | 0% |  |  |  |  |  |  |  |  |  |  |
| 1207 | 6.6.3.4 | **Infraestrutura** |  | 450d | 2020-10-16 | 2022-08-05 |  |  |  | 2016-10-03 | 2021-08-27 | 1247d | 2016-10-03 | 2021-08-27 | 320d |  | 56% |  | 56 | 40 | 20 | 0% | ok | 0% | São Vítor (distrito Governador Valadares/MG) |  |  |
| 1208 | 6.6.3.4.1 | **Obras** |  | 200d | 2020-10-16 | 2021-08-05 |  |  |  | 2016-10-03 | 2020-08-12 | 987d | 2016-10-03 | 2020-08-12 | 322d |  | 71% | 24 | 71 | 120 | 20 |  |  |  |  |  |  |
| 1209 | 6.6.3.4.1.1 | Executar UTR - São Vítor/MG |  | 200d | 2020-10-16 | 2021-08-05 | 1192, 1204, 1195FF-120d, 1193 |  |  | 2019-09-19 | 2020-08-12 | 223d | 2019-09-19 | 2020-08-12 | 322d | 0d | 0% |  |  |  |  | 0% | ok | 0% | São Vítor (distrito Governador Valadares/MG) |  |  |
| 1210 | 6.6.3.4.1.2 | Assinatura de Termo de Entrega das Obras de Melhoria do Sistema de Abastecimento de Água - São Vítor/MG | milestone | 0d | 2021-08-05 | 2021-08-05 | 1209, 1196, 1206 |  |  | 2020-08-12 | 2020-08-12 | 0d | 2020-08-12 | 2020-08-12 | 570d | 322d | 0% |  |  |  |  | 0% | ok | 0% | São Vítor (distrito Governador Valadares/MG) |  |  |
| 1211 | 6.6.3.4.2 | **Operação** |  | 250d | 2021-08-05 | 2022-08-05 |  |  |  | 2020-08-13 | 2021-08-27 | 260d | 2020-08-13 | 2021-08-27 | 320d |  | 0% |  |  |  |  | 0% | ok | 0% | São Vítor (distrito Governador Valadares/MG) |  |  |
| 1212 | 6.6.3.4.2.1 | Realizar Treinamento Operacional do Sistema - São Vítor/MG |  | 5d | 2021-08-06 | 2021-08-12 | 1209 |  |  | 2020-08-13 | 2020-08-19 | 5d | 2020-08-13 | 2020-08-19 | 551d | 0d | 0% |  |  |  |  | 0% | ok | 0% | São Vítor (distrito Governador Valadares/MG) |  |  |
| 1213 | 6.6.3.4.2.2 | Realizar Testes e Pré-operação - São Vítor/MG |  | 14d | 2021-08-13 | 2021-09-01 | 1212 |  |  | 2020-08-20 | 2020-09-09 | 14d | 2020-08-20 | 2020-09-09 | 551d |  | 0% |  |  |  |  | 0% | ok | 0% | São Vítor (distrito Governador Valadares/MG) |  |  |
| 1214 | 6.6.3.4.2.3 | Realizar Acompanhamento da Funcionalidade do Sistema - UTR - São Vítor (distrito Governador Valadares/MG) |  | 365ed | 2021-08-05 | 2022-08-05 | 1216SS |  |  | 2020-08-13 | 2021-08-27 | 260d |  |  | 1422d |  |  |  |  |  |  |  |  |  |  |  |  |
| 1215 | 6.6.3.4.2.4 | **Operação Assistida** |  | 61d | 2021-08-05 | 2021-11-03 |  |  |  | 2020-08-13 | 2020-11-13 | 64d | 2020-08-13 | 2020-11-13 | 322d |  | 0% |  |  |  |  | 0% | ok | 0% | São Vítor (distrito Governador Valadares/MG) |  |  |
| 1216 | 6.6.3.4.2.4.1 | Realizar Operação Assistida - São Vítor/MG |  | 90ed | 2021-08-05 | 2021-11-03 | 1209 |  |  | 2020-08-13 | 2020-11-13 | 3.2mo | 2020-08-13 | 2020-11-13 | 1422d | 0d | 0% |  |  |  |  | 0% | ok | 0% | São Vítor (distrito Governador Valadares/MG) |  |  |
| 1217 | 6.7 | **Galileia/MG (sede)** |  | 888d | 2017-06-01 A | 2020-11-28 |  | 67% | 297.18d | 2016-10-03 | 2020-12-17 | 1075d | 2016-10-03 | 2020-12-17 | 740d |  | 65% | 56 | 65 | 73 | 77 | 0% | ok | 0% | Galileia/MG (sede) |  | Socioambiental |
| 1218 | 6.7.1 | **Captação Principal, Alternativa, Melhorias em ETA e UTR** |  | 888d | 2017-06-01 A | 2020-11-28 |  | 67% | 297.18d | 2017-06-01 | 2020-11-28 | 888d |  |  | 740d |  |  |  |  |  |  |  |  |  |  |  |  |
| 1219 | 6.7.1.1 | **Engenharia** |  | 534d | 2017-06-01 A | 2019-06-28 A |  | 100% |  | 2017-06-01 | 2019-05-29 | 513d | 2017-06-01 | 2019-05-29 |  |  | 100% | 100 | 100 | 100 | 100 |  | ok |  |  |  | Socioambiental |
| 1220 | 6.7.1.1.1 | **Estudos de Concepção do Sistema** |  | 366d | 2017-11-18 A | 2019-04-23 A |  | 100% |  | 2017-11-18 | 2019-04-23 | 366d | 2017-11-18 | 2019-04-23 |  |  | 100% | 100 | 100 | 100 | 100 | 0% | ok | 0% | Galileia/MG (sede) |  | Socioambiental |
| 1221 | 6.7.1.1.1.1 | Declaração de Escopo e Premissas de Projeto (DEPP) concluída - Galiléia/MG | milestone | 0d | 2017-11-18 A | 2017-11-18 A | 26 | 100% |  | 2017-11-18 | 2017-11-18 | 0d | 2017-11-18 | 2017-11-18 |  |  | 100% | 100 | 100 | 100 | 100 | 0% | ok | 0% | Galileia/MG (sede) |  |  |
| 1222 | 6.7.1.1.1.2 | Aprovação das DEPPs pela Operadora e Prefeitura - Galiléia/MG | milestone | 0d | 2018-03-02 A | 2018-03-02 A | 26SS | 100% |  | 2018-03-02 | 2018-03-02 | 0d | 2018-03-02 | 2018-03-02 |  |  | 100% | 100 | 100 | 100 | 100 | 0% | ok | 0% | Galileia/MG (sede) |  |  |

Notes:
- 1195: 18/09/19: Prazo da DAIA extraído do cronograma do Licenciamento de 18-09-19
- 1197: 14/Fev19: / - Em reunião de integração entre as áreas nesta data, foi informado pelo Alessandro (Infraestrutura Território II - Calha e Médio Rio Doce) o abaixo: / . RT para contratação de STA Poços Tubulares para: Pedra Corrida, Tumiritinga (sede), Senhora da Penha e São Vitor (GV); e para construções de novas ETA's/UTR's de Senhora da Penha e São Tomé do Rio Doce (Tumiritinga). / . Contrato guarda-chuva existente da Infraestrutura: execução de pequenas melhorias (ETA, Captação Principal). / - Deverá ser elaborada outra RT para a UTR.

| ID | WBS | Task | Type | Duration | Start | Finish | Predecessors | Complete | Baseline start | Baseline finish | Baseline duration | Baseline 1 start | Baseline 1 finish | Text3 | Text4 | Text5 | Text7 | Text15 | Text23 | Text25 | Text26 | Text27 | Text29 | Text28 | Text9 |
| --- | --- | --- | --- | --- | --- | --- | --- | --- | --- | --- | --- | --- | --- | --- | --- | --- | --- | --- | --- | --- | --- | --- | --- | --- | --- |
| 1223 | 6.7.1.1.1.3 | **Serviços em Poços Tubulares** |  | 228d | 2018-05-31 A | 2019-04-23 A |  | 100% | 2018-05-31 | 2019-04-23 | 228d | 2018-05-31 | 2019-04-23 | 100% | 100 | 100 | 100 | 100 | Socioambiental | 0% | ok | 0% | Galileia/MG (sede) |  |  |
| 1224 | 6.7.1.1.1.3.1 | Realizar Perfilagem (Poços 1, 2, 3 e 4) - Galiléia/MG |  | 11d | 2018-05-31 A | 2018-06-14 A | 1221FS+49d | 100% | 2018-05-31 | 2018-06-14 | 11d | 2018-05-31 | 2018-06-14 | 100% | 100 | 100 | 100 | 100 |  | 0% | ok | 0% | Galileia/MG (sede) |  |  |
| 1225 | 6.7.1.1.1.3.2 | Realizar Recuperação (Poços 1, 2, 3 e 4) - Galiléia/MG |  | 22d | 2018-08-01 A | 2018-08-30 A | 1224FS+34d | 100% | 2018-08-01 | 2018-08-30 | 22d | 2018-08-01 | 2018-08-30 | 100% | 100 | 100 | 100 | 100 |  | 0% | ok | 0% | Galileia/MG (sede) |  |  |
| 1226 | 6.7.1.1.1.3.3 | Realizar Instrumentação (Poços 1, 2, 3 e 4) - Galiléia/MG |  | 4d | 2018-12-17 A | 2018-12-20 A | 1225FS+76d | 100% | 2018-12-17 | 2018-12-20 | 4d | 2018-12-17 | 2018-12-20 | 100% | 100 | 100 | 100 | 100 |  | 0% | ok | 0% | Galileia/MG (sede) |  |  |
| 1227 | 6.7.1.1.1.3.4 | Elaborar Relatório Técnico (Poços 1, 2, 3 e 4) - Galiléia/MG |  | 10d | 2019-01-08 A | 2019-01-21 A | 1224, 1225FS+92d | 100% | 2019-01-08 | 2019-01-21 | 10d | 2019-01-08 | 2019-01-21 | 100% | 100 | 100 | 100 | 100 |  | 0% | ok | 0% | Galileia/MG (sede) | Não OK |  |
| 1228 | 6.7.1.1.1.3.5 | Realizar Laudo dos Serviços de Coleta e Análise de Água - Galiléia/MG |  | 15d | 2018-10-17 A | 2018-11-06 A | 1225FS+35d | 100% | 2018-10-17 | 2018-11-06 | 15d | 2018-10-17 | 2018-11-06 | 100% | 100 | 100 | 100 | 100 |  | 0% | ok | 0% | Galileia/MG (sede) |  |  |
| 1229 | 6.7.1.1.1.3.6 | Realizar Teste de Interferência entre poços - Galiléia/MG |  | 30d | 2019-03-11 A | 2019-04-23 A | 1225FS+190ed | 100% | 2019-03-11 | 2019-04-23 | 30d | 2019-03-11 | 2019-04-23 | 100% | 100 | 100 | 100 | 100 | Socioambiental | 0% | Não OK | 0% | Galileia/MG (sede) |  |  |
| 1230 | 6.7.1.1.1.3.7 | Conclusão dos Serviços em poço tubular - Galiléia/MG | milestone | 0d | 2019-04-23 A | 2019-04-23 A | 1229 | 100% | 2019-04-23 | 2019-04-23 | 0d | 2019-04-23 | 2019-04-23 | 100% | 100 | 100 | 100 | 100 |  |  |  |  |  |  |  |
| 1231 | 6.7.1.1.1.4 | Conclusão dos Estudos de Concepção das Melhorias do Sistema de Abastecimento de Água - Galileia/MG | milestone | 0d | 2019-04-23 A | 2019-04-23 A | 1222, 1230 | 100% | 2019-04-23 | 2019-04-23 | 0d | 2019-04-23 | 2019-04-23 | 100% | 100 | 100 | 100 | 100 |  |  |  |  |  |  |  |
| 1232 | 6.7.1.1.2 | **Engenharia Básica e Detalhada** |  | 534d | 2017-06-01 A | 2019-06-28 A |  | 100% | 2017-06-01 | 2019-05-29 | 513d | 2017-06-01 | 2019-05-29 | 100% | 100 | 100 | 100 | 100 | Socioambiental | 0% | ok | 0% | Galileia/MG (sede) |  |  |
| 1233 | 6.7.1.1.2.1 | **Engenharia Captação Principal (Captação, Adução e Elevatória)** |  | 284d | 2017-06-01 A | 2018-07-03 A |  | 100% | 2017-06-01 | 2018-07-03 | 284d | 2017-06-01 | 2018-07-03 | 100% | 100 | 100 | 100 | 100 |  | 0% | ok | 0% | Galileia/MG (sede) |  |  |
| 1234 | 6.7.1.1.2.1.1 | Levantar Dados de Entrada (levantamento de campo, topografia e sondagem) - Captação Principal - Galiléia/MG |  | 16d | 2017-06-01 A | 2017-06-22 A | 26 | 100% | 2017-06-01 | 2017-06-22 | 16d | 2017-06-01 | 2017-06-22 | 100% | 100 | 100 | 100 | 100 |  | 0% | ok | 0% | Galileia/MG (sede) |  |  |
| 1235 | 6.7.1.1.2.1.2 | Elaborar arranjo para obtenção de Dados de Entrada Licenciamento e Fundiário - Captação Principal - Galiléia/MG |  | 44d | 2017-07-03 A | 2017-08-31 A | 1234SS+22d | 100% | 2017-07-03 | 2017-08-31 | 44d | 2017-07-03 | 2017-08-31 | 100% | 100 | 100 | 100 | 100 |  | 0% | ok | 0% | Galileia/MG (sede) |  |  |
| 1236 | 6.7.1.1.2.1.3 | Emitir RT/PQ para Suprimentos - Captação Principal - Galiléia/MG |  | 22d | 2017-08-09 A | 2017-09-07 A | 1235SS+27d | 100% | 2017-08-09 | 2017-09-07 | 22d | 2017-08-09 | 2017-09-07 | 100% | 100 | 100 | 100 | 100 |  | 0% | ok | 0% | Galileia/MG (sede) |  |  |
| 1237 | 6.7.1.1.2.1.4 | Elaborar Projeto Executivo - Captação Principal - Galiléia/MG |  | 218d | 2017-09-01 A | 2018-07-03 A | 1235 | 100% | 2017-09-01 | 2018-07-03 | 218d | 2017-09-01 | 2018-07-03 | 100% | 100 | 100 | 100 | 100 |  | 0% | ok | 0% | Galileia/MG (sede) |  |  |
| 1238 | 6.7.1.1.2.1.5 | Elaboração do Projeto Executivo - Captação Principal - Galiléia/MG | milestone | 0d | 2018-07-03 A | 2018-07-03 A | 1237 | 100% | 2018-07-03 | 2018-07-03 | 0d | 2018-07-03 | 2018-07-03 | 100% | 100 | 100 | 100 | 100 |  |  |  |  |  |  |  |
| 1239 | 6.7.1.1.2.2 | **Engenharia Captação Alternativa (Poços 1, 2, 3 e 4)** |  | 240d | 2018-01-10 A | 2018-12-11 A |  | 100% | 2018-01-10 | 2018-12-11 | 240d | 2018-01-10 | 2018-12-11 | 100% | 100 | 100 | 100 | 100 |  | 0% | ok | 0% | Galileia/MG (sede) |  |  |
| 1240 | 6.7.1.1.2.2.1 | Aprovar Plano de Trabalho e abrir OSE - Captação Alternativa - Poços 1, 2, 3 e 4 - Galiléia/MG |  | 16d | 2018-01-10 A | 2018-01-31 A | 26 | 100% | 2018-01-10 | 2018-01-31 | 16d | 2018-01-10 | 2018-01-31 | 100% | 100 | 100 | 100 | 100 |  | 0% | ok | 0% | Galileia/MG (sede) |  |  |
| 1241 | 6.7.1.1.2.2.2 | Levantar Dados de Entrada (levantamento de campo, topografia e sondagem) - Captação Alternativa - Poços 1, 2, 3 e 4 - Galiléia/MG |  | 16d | 2018-01-10 A | 2018-01-31 A | 26, 1240SS | 100% | 2018-01-10 | 2018-01-31 | 16d | 2018-01-10 | 2018-01-31 | 100% | 100 | 100 | 100 | 100 |  | 0% | ok | 0% | Galileia/MG (sede) |  |  |
| 1242 | 6.7.1.1.2.2.3 | Elaborar Projeto Executivo - Captação Alternativa - Poços 1, 2, 3 e 4 - Galiléia/MG |  | 224d | 2018-02-01 A | 2018-12-11 A | 1227, 1230, 1241 | 100% | 2018-02-01 | 2018-12-11 | 224d | 2018-02-01 | 2018-12-11 | 100% | 100 | 100 | 100 | 100 |  | 0% | ok | 0% | Galileia/MG (sede) |  |  |
| 1243 | 6.7.1.1.2.2.4 | Elaboração do Projeto Executivo - Captação Alternativa - Poços 1, 2, 3 e 4 - Galiléia/MG | milestone | 0d | 2018-12-11 A | 2018-12-11 A | 1242 | 100% | 2018-12-11 | 2018-12-11 | 0d | 2018-12-11 | 2018-12-11 | 100% | 100 | 100 | 100 | 100 |  |  |  |  |  |  |  |
| 1244 | 6.7.1.1.2.3 | **Engenharia Melhorias ETA** |  | 132d | 2018-11-19 A | 2019-05-30 A |  | 100% | 2018-11-19 | 2019-04-30 | 111d | 2018-11-19 | 2019-04-30 | 100% | 100 | 100 | 100 | 100 | Socioambiental | 0% | ok | 0% | Galileia/MG (sede) |  |  |
| 1245 | 6.7.1.1.2.3.1 | Aprovar Plano de Trabalho e abrir OSE - Melhorias na ETA - Galiléia/MG |  | 22d | 2018-11-19 A | 2018-12-18 A | 1221 | 100% | 2018-11-19 | 2018-12-18 | 22d | 2018-11-19 | 2018-12-18 | 100% | 100 | 100 | 100 | 100 |  | 0% | ok | 0% | Galileia/MG (sede) |  |  |
| 1246 | 6.7.1.1.2.3.2 | Dados de Entrada (levantamento de campo, topografia e informações da Caixa de Coleta) - Melhorias na ETA - Galiléia/MG |  | 57d | 2018-11-26 A | 2019-02-13 A | 1245SS+5d | 100% | 2018-11-26 | 2019-02-13 | 57d | 2018-11-26 | 2019-02-13 | 100% | 100 | 100 | 100 | 100 | Socioambiental | 0% | Não OK | 0% | Galileia/MG (sede) |  | Não OK |
| 1247 | 6.7.1.1.2.3.3 | Elaborar Projeto Executivo - Melhorias na ETA - Galiléia/MG |  | 70d | 2019-02-14 A | 2019-05-30 A | 1228, 1246 | 100% | 2019-02-14 | 2019-04-30 | 49d | 2019-02-14 | 2019-04-30 | 100% | 100 | 100 | 100 | 100 |  | 0% | ok | 0% | Galileia/MG (sede) |  |  |
| 1248 | 6.7.1.1.2.3.4 | Elaboração do Projeto Executivo - Melhorias na ETA - Galiléia/MG | milestone | 0d | 2019-05-30 A | 2019-05-30 A | 1247 | 100% | 2019-04-30 | 2019-04-30 | 0d | 2019-04-30 | 2019-04-30 | 100% | 100 | 100 | 100 | 100 |  |  |  |  |  |  |  |

Notes:
- 1227: 18/Fev19: / - Essa atividade está sem Sucessora (deveria ser o Projeto Executivo da Captação Alternativa), em função da Engenharia não ter respeitado o sequenciamento de atividades definido. (Ver e-mail enviado em 03/02/19 "Considerações Relevantes: Cronograma Engenharia X Cronograma Master PG 32" e Relato Gerências").
- 1229: 18/Fev19: / - Teste de intereferência necessário para atender informação complementar (Licenciamento). / - Na duração da atividade estão sendo considerados o prazo para execução do teste e o resultado do mesmo.
- 1233: 25/Jan19: / - Projeto de "Solução para Manutenção Bombas Elevatória" realizado de 10/09 a 04/12/18. / 06/Dez: / - Consta no CR ENG (03/12/18) projeto de "Captação, Adução, Nova ETA, Elevatória". Estamos considerando que tal projeto se refere à captação principal. Ratificar esse entendimento junto a Engenharia. / - Projeto concluído em 03/07/18. Verificar com o PG se foi entregue.
- 1234: 06/Dez: / - Consta no CR ENG (03/12/18) projeto para Manutenção das Bombas Elevatória. Verificar com a área se esse projeto refere-se a Captação Principal. (PG entende que sim e por isso não deu o projeto como concluído). Verificar com o PG/ENG. / - Considerando para a data de conclusão o projeto supracitado.
- 1235: 06/Dez: / - Segundo CR ENG, não fo desenvolvido projeto conceital para o de Manutenção de Bombas Elevatória. Essa tarefa refere-se ao projeto de captação principal.
- 1236: 06/Dez: / - Segundo CR ENG, não foi previsto emissão de PQ/RT preliminar para o projeto de Manutenção de Bombas Elevatória. Essa tarefa refere-se ao projeto de captação principal.
- 1239: 25/Jan19: / - CR ENG considerando Projeto de ADEQUAÇÃO E AS BULT DOS 4 POÇOS para a captação alternativa. / - Não foi considerado como input para desenvolvimento do projeto de Captação Alternativa, o Relatório Técnico dos serviços realizados nos poços (previsto para 06/02/19). Verificando com a Engenharia se o Laudo de Serviços de Coleta e Análise de Água foi considerado quando do desenvolvimento do Projeto Executivo, uma vez que foi emitido em 06/11/18. / 23/Nov: / - Segunda planilha de detalhamento da Engenharia/DEPP, deverá ser feita a urbanização e as built de todos os poços implementados em Galiléia. Não retratado no CR ENG. / 01/Dez:/ / - Não previsto no cronograma da Engenharia e nem há DEPP correspondente. Colhi a informação do poço do cronograma da Hidropoços. / 06/Dez - Verificar com a Engenharia: / - Se não há projeto previsto para captação alternativa dos 2 poços fora da área da ETA (não serão interligados na ETA nova e nem estão interligados na ETA existente). Possuem sistema de tratamento próprio e estão interligados na rede de distribuição. Onde está sendo considerado o projeto relacionado a esses poços uma vez que consta na Tarefa-Resumo dessa captação apenas os poços na área da ETA.
- 1244: 01/Dez: / - Ao invés do DEPP foi apresentado para aprovação ao SAAE de Galileia Projeto Executivo da nova ETA que considera melhorias na ETA existente. / - Melhorias na ETA existente (será desativada após a conclusão do comissionamento da nova ETA) prevista na Declaração de Escopo da ETA Galileia.
- 1246: 25/Jan19: / - Levantamento de campo iniciado em 26/11 e concluído em 07/12/18; Topografia iniciada em 19/12/18 e concluída em 17/01/19; Informações da Caixa de Coleta prevista pra 01/02/19.

| ID | WBS | Task | Type | Duration | Start | Finish | Predecessors | Complete | Remaining | Baseline start | Baseline finish | Baseline duration | Baseline 1 start | Baseline 1 finish | Total slack | Text3 | Text4 | Text5 | Text7 | Text15 | Text25 | Text26 | Text27 | Text29 | Text23 | Text9 | Indicadores MIR |
| --- | --- | --- | --- | --- | --- | --- | --- | --- | --- | --- | --- | --- | --- | --- | --- | --- | --- | --- | --- | --- | --- | --- | --- | --- | --- | --- | --- |
| 1249 | 6.7.1.1.2.4 | **Engenharia nova ETA e UTR** |  | 287d | 2017-11-03 A | 2018-12-10 A |  | 100% |  | 2017-11-03 | 2018-12-10 | 287d | 2017-11-03 | 2018-12-10 |  | 100% | 100 | 100 | 100 | 100 | 0% | ok | 0% | Galileia/MG (sede) |  |  |  |
| 1250 | 6.7.1.1.2.4.1 | Elaborar arranjo para obtenção de Dados de Entrada Licenciamento e Fundiário - Nova ETA/UTR - Galiléia/MG |  | 44d | 2017-11-03 A | 2018-01-03 A | 26 | 100% |  | 2017-11-03 | 2018-01-03 | 44d | 2017-11-03 | 2018-01-03 |  | 100% | 100 | 100 | 100 | 100 | 0% | ok | 0% | Galileia/MG (sede) |  |  |  |
| 1251 | 6.7.1.1.2.4.2 | Elaborar Projeto Executivo - Nova ETA/UTR - Galiléia/MG |  | 277d | 2017-11-17 A | 2018-12-10 A | 1250SS+10d | 100% |  | 2017-11-17 | 2018-12-10 | 277d | 2017-11-17 | 2018-12-10 |  | 100% | 100 | 100 | 100 | 100 | 0% | ok | 0% | Galileia/MG (sede) |  |  |  |
| 1252 | 6.7.1.1.2.4.3 | Elaboração do Projeto Executivo - Nova ETA/UTR - Galiléia/MG | milestone | 0d | 2018-12-10 A | 2018-12-10 A | 1251 | 100% |  | 2018-12-10 | 2018-12-10 | 0d | 2018-12-10 | 2018-12-10 |  | 100% | 100 | 100 | 100 | 100 |  |  |  |  |  |  |  |
| 1253 | 6.7.1.1.2.5 | **Validação dos Projetos** |  | 20d | 2019-05-31 A | 2019-06-28 A |  | 100% |  | 2019-05-02 | 2019-05-29 | 20d | 2019-05-02 | 2019-05-29 |  | 100% | 100 | 100 | 100 | 100 | 0% | ok | 0% | Galileia/MG (sede) |  |  |  |
| 1254 | 6.7.1.1.2.5.1 | Validar Projetos com Prefeitura e Operadora - Galiléia/MG |  | 20d | 2019-05-31 A | 2019-06-28 A | 1237, 1242, 1247, 1251 | 100% |  | 2019-05-02 | 2019-05-29 | 20d | 2019-05-02 | 2019-05-29 |  | 100% | 100 | 100 | 100 | 100 | 0% | ok | 0% | Galileia/MG (sede) |  |  |  |
| 1255 | 6.7.1.1.2.5.2 | Validação com Prefeitura e Operadora dos Projetos de Melhoria do Sistema de Abastecimento de Água - Galiléia/MG | milestone | 0d | 2019-06-28 A | 2019-06-28 A | 1238, 1243, 1248, 1252, 1254 | 100% |  | 2019-05-29 | 2019-05-29 | 0d | 2019-05-29 | 2019-05-29 |  | 100% | 100 | 100 | 100 | 100 |  |  |  |  |  |  |  |
| 1256 | 6.7.1.1.3 | Conclusão e Validação da Engenharia - Galileia/MG | milestone | 0d | 2019-06-28 A | 2019-06-28 A | 1231, 1255 | 100% |  | 2019-05-29 | 2019-05-29 | 0d | 2019-05-29 | 2019-05-29 |  | 100% | 100 | 100 | 100 | 100 |  |  |  |  |  |  |  |
| 1257 | 6.7.1.2 | **Licenciamento** |  | 519d | 2017-09-18 A | 2019-09-25 A |  | 100% |  | 2017-09-18 | 2018-12-13 | 324d | 2017-09-18 | 2018-12-13 |  | 100% | 100 | 100 | 100 | 100 | 0% | ok | 0% | Galileia/MG (sede) | Socioambiental |  |  |
| 1258 | 6.7.1.2.1 | Nova ETA Galiléia (DAIA / LAS Cadastro) - Captação Principal - Galiléia/MG | milestone | 0d | 2018-07-13 A | 2018-07-13 A | 1221FS+82d | 100% |  | 2018-07-13 | 2018-07-13 | 0d | 2018-07-13 | 2018-07-13 |  | 100% | 100 | 100 | 100 | 100 | 0% | ok | 0% | Galileia/MG (sede) |  |  |  |
| 1259 | 6.7.1.2.2 | Obter Outorga para Captação Alternativa (Poços 3 e 4) - Galiléia/MG |  | 224d | 2017-09-18 A | 2018-07-26 A | 26FS-45d | 100% |  | 2017-09-18 | 2018-07-26 | 224d | 2017-09-18 | 2018-07-26 |  | 100% | 100 | 100 | 100 | 100 | 0% | ok | 0% | Galileia/MG (sede) |  |  |  |
| 1260 | 6.7.1.2.3 | Obter Outorga para Captação Alternativa (Poços 1 e 2) - Galiléia/MG |  | 279d | 2017-11-20 A | 2018-12-13 A | 26, 1229FF | 100% |  | 2017-11-20 | 2018-12-13 | 279d | 2017-11-20 | 2018-12-13 |  | 100% | 100 | 100 | 100 | 100 | 0% | Não OK | 0% | Galileia/MG (sede) | Socioambiental | Não OK |  |
| 1261 | 6.7.1.2.4 | Obtenção de Outorgas para Captação Alternativa - Galiléia/MG | milestone | 0d | 2018-12-13 A | 2018-12-13 A | 1258, 1259, 1260 | 100% |  | 2018-12-13 | 2018-12-13 | 0d | 2018-12-13 | 2018-12-13 |  | 100% | 100 | 100 | 100 | 100 |  |  |  |  |  |  |  |
| 1262 | 6.7.1.2.5 | Indeferimento das Outorgas para Captação Alternativa (Poço 1 e 2) - Galiléia/MG | milestone | 0d | 2019-07-23 A | 2019-07-23 A | 1261FS+150d | 100% |  | 2019-07-23 | 2019-07-23 | 0d |  |  |  |  |  |  |  |  |  |  |  |  |  |  |  |
| 1263 | 6.7.1.2.6 | Reabrir processo de Outorga para Captação Alternativa (Poços 1 e 2) - Galiléia/MG |  | 30d | 2019-08-14 A | 2019-09-25 A | 1262FS+15d | 100% |  | 2019-08-14 | 2020-04-13 | 164d |  |  |  |  |  |  |  |  |  |  |  |  |  |  |  |
| 1264 | 6.7.1.2.7 | Conclusão do Licenciamento Ambiental para as Melhorias no Sistema de Abastecimento - Galiléia/MG | milestone | 0d | 2019-09-25 A | 2019-09-25 A | 1263 | 100% |  | 2019-09-30 | 2019-09-30 | 0d |  |  |  |  |  |  |  |  |  |  |  |  |  |  |  |
| 1265 | 6.7.1.3 | **Suprimentos** |  | 195d | 2018-09-04 A | 2019-06-12 A |  | 100% |  | 2018-09-04 | 2019-09-04 | 253d | 2018-09-04 | 2019-09-04 |  | 81% | 66 | 81 | 75 | 88 | 0% | ok | 0% | Galileia/MG (sede) | Socioambiental |  |  |
| 1266 | 6.7.1.3.1 | **Melhorias na ETA (contrato guarda-chuva existente - Infraestrutura)** |  | 8d | 2019-06-03 A | 2019-06-12 A |  | 100% |  | 2019-05-02 | 2019-09-04 | 88d | 2019-05-02 | 2019-09-04 |  | 46% | 100 | 46 | 100 | 100 | 0% | ok | 0% | Galileia/MG (sede) |  |  |  |
| 1267 | 6.7.1.3.1.1 | Incluir PQ no CGC existente - Galiléia/MG |  | 8d | 2019-06-03 A | 2019-06-12 A | 1247FS+1d, 1254SS+1d | 100% |  | 2019-05-02 | 2019-05-13 | 8d | 2019-05-02 | 2019-05-13 |  | 100% | 100 | 100 | 100 | 100 |  |  |  |  |  |  |  |
| 1268 | 6.7.1.3.1.2 | Conclusão da Contratação de Suprimentos - Galileia/MG | milestone | 0d | 2019-06-12 A | 2019-06-12 A | 1267 | 100% |  | 2019-05-13 | 2019-05-13 | 0d | 2019-09-04 | 2019-09-04 |  | 100% | 100 | 100 | 100 | 100 |  |  |  |  |  |  |  |
| 1269 | 6.7.1.3.2 | Processo contratação MAS 1 (Contratação Eletromecânica) - Galiléia/MG |  | 165d | 2018-09-04 A | 2019-04-30 A | 1236FS+257d | 100% |  | 2018-09-04 | 2019-04-30 | 165d | 2018-09-04 | 2019-04-30 |  | 100% | 100 | 100 | 100 | 100 | 0% | Não OK | 0% | Galileia/MG (sede) | Socioambiental | Não OK |  |
| 1270 | 6.7.1.3.3 | Conclusão da Contratação de Suprimentos das obras de Melhoria do Sistema de Abastecimento de Água - Galileia/MG | milestone | 0d | 2019-06-12 A | 2019-06-12 A | 1268, 1269 | 100% |  | 2019-09-04 | 2019-09-04 | 0d | 2019-09-04 | 2019-09-04 |  | 0% |  |  |  |  |  |  |  |  |  |  |  |
| 1271 | 6.7.1.4 | **Infraestrutura** |  | 681d | 2018-03-19 A | 2020-11-28 |  | 29% | 480.92d | 2016-10-03 | 2020-12-17 | 1075d | 2016-10-03 | 2020-12-17 | 740d | 65% | 13 | 65 | 25 | 51 | 0% | ok | 0% | Galileia/MG (sede) |  |  |  |
| 1272 | 6.7.1.4.1 | **Obras** |  | 475d | 2018-03-19 A | 2020-01-30 |  | 99% | 0d | 2016-10-03 | 2019-11-30 | 815d | 2016-10-03 | 2019-11-30 | 946d | 86% | 61 | 86 | 120 | 51 |  |  |  |  |  |  |  |
| 1273 | 6.7.1.4.1.1 | **Nova ETA/UTR/Melhorias na ETA e na Captação Principal** |  | 392d | 2018-03-19 A | 2019-09-30 A |  | 100% |  | 2018-03-19 | 2019-08-08 | 356d |  |  |  |  |  |  |  |  |  |  |  |  |  |  |  |
| 1274 | 6.7.1.4.1.1.1 | Executar Melhorias de ETA - Adutora e Reservatório - Galiléia/MG |  | 158d | 2018-03-19 A | 2018-10-24 A | 1247, 1268 | 100% |  | 2018-03-19 | 2018-10-24 | 158d | 2018-03-19 | 2018-10-24 |  | 45% | 100 | 45 | 222 | 45 | 0% | ok | 0% | Galileia/MG (sede) |  |  |  |
| 1275 | 6.7.1.4.1.1.2 | Executar Captação Principal, Adução, Nova ETA / UTR, Elevatória - Galiléia/MG |  | 61d | 2019-07-05 A | 2019-09-30 A | 1237, 1251, 1258, 1268FS+15d, 1269 | 100% |  | 2019-05-02 | 2019-08-08 | 70d | 2019-05-02 | 2019-08-08 |  | 58% |  | 58 |  | 58 | 0% | ok | 0% | Galileia/MG (sede) |  |  |  |
| 1276 | 6.7.1.4.1.1.3 | Conclusão das Obras de Melhorias de ETA - Captação Principal, Adução, Nova ETA / UTR, Elevatória - Galiléia/MG | milestone | 0d | 2019-09-30 A | 2019-09-30 A | 1275 | 100% |  | 2019-08-08 | 2019-08-08 | 0d |  |  |  |  |  |  |  |  |  |  |  |  |  |  | ETA |

Notes:
- 1249: 25/Jan19: / - Projeto de ETA e URT concluído em 10/12/18. Consta no Cronograma da Engenharia como "Contratação Pacote: Engenharia, Fornecimento e Obras". / 18/Dez / - Cronograma da Engenharia considerando o projeto de "ETA e UTR - (CONTRATAÇÃO PACOTE: ENGENHARIA, FORNECIMENTO E OBRAS)" para essas datas apontadas aqui.
- 1260: 18/Fev19: / - Teste de intereferência necessário para atender informação complementar. / 26/Nov: / - Processo protocolado no órgão (SEMAD) dia 09/04/18.
- 1269: 15/Fev19: / - Só está em aberto a contratação da Eletromecânica, todo o restante já está contratado.

| ID | WBS | Task | Type | Duration | Start | Finish | Predecessors | Complete | Remaining | Baseline start | Baseline finish | Baseline duration | Baseline 1 start | Baseline 1 finish | Total slack | Free slack | Text3 | Text25 | Text26 | Text27 | Text29 | Indicadores MIR | Text13 | Text4 | Text5 | Text7 | Text15 | Text23 | Text9 |
| --- | --- | --- | --- | --- | --- | --- | --- | --- | --- | --- | --- | --- | --- | --- | --- | --- | --- | --- | --- | --- | --- | --- | --- | --- | --- | --- | --- | --- | --- |
| 1277 | 6.7.1.4.1.2 | **Captação Alternativa** |  | 15d | 2019-09-10 A | 2019-09-30 A |  | 100% |  | 2019-09-10 | 2019-09-30 | 15d |  |  |  |  |  |  |  |  |  |  |  |  |  |  |  |  |  |
| 1278 | 6.7.1.4.1.2.1 | Executar Captação Alternativa (Interligação dos poços 1, 2, 3 e 4) - Galiléia/MG |  | 15d | 2019-09-10 A | 2019-09-30 A | 1226, 1242, 1259, 1260, 1275FF | 100% |  | 2019-08-23 | 2019-09-30 | 70d | 2019-08-23 | 2019-11-30 |  |  | 0% | 0% | ok | 0% | Galileia/MG (sede) |  |  |  |  |  |  |  |  |
| 1279 | 6.7.1.4.1.2.2 | Conclusão das obras de Captação Alternativa - Poços 01, 02, 03 e 04 - Galiléia/MG | milestone | 0d | 2019-09-30 A | 2019-09-30 A | 1278 | 100% |  | 2019-09-30 | 2019-09-30 | 0d |  |  |  |  |  |  |  |  |  | CA |  |  |  |  |  |  |  |
| 1280 | 6.7.1.4.1.3 | Realizar ajustes no escopo do projeto para atender solicitações do MP - Galiléia/MG |  | 43d | 2019-10-01 A | 2019-11-29 A | 1276, 1279 | 100% |  | 2019-10-01 | 2019-10-18 | 14d |  |  |  |  |  |  |  |  |  |  |  |  |  |  |  |  |  |
| 1281 | 6.7.1.4.1.4 | Assinatura de Termo de Entrega das Obras de Melhoria do Sistema de Abastecimento de Água - Galiléia/MG | milestone | 0d | 2020-01-30 | 2020-01-30 | 1275, 1278, 1274, 1264, 1280FS+40d |  |  | 2019-11-30 | 2019-11-30 | 0d | 2019-11-30 | 2019-11-30 | 946d | 698d | 0% | 0% | ok | 0% | Galileia/MG (sede) |  |  |  |  |  |  |  |  |
| 1282 | 6.7.1.4.2 | **Operação** |  | 246d | 2019-11-29 A | 2020-11-28 |  | 15% | 208.5d | 2019-12-02 | 2020-12-17 | 260d | 2019-12-02 | 2020-12-17 | 740d |  | 0% | 0% | ok | 0% | Galileia/MG (sede) |  |  |  |  |  |  |  |  |
| 1283 | 6.7.1.4.2.1 | Realizar Treinamento Operacional do Sistema - Galiléia/MG |  | 5d | 2019-12-02 A | 2019-12-06 A | 1275, 1278, 1274, 1280 | 100% |  | 2019-12-02 | 2019-12-06 | 5d | 2019-12-02 | 2019-12-06 |  |  | 0% | 0% | ok | 0% | Galileia/MG (sede) |  | 8888888 |  |  |  |  |  |  |
| 1284 | 6.7.1.4.2.2 | Realizar Testes e Pré-operação - Galiléia/MG |  | 14d | 2019-12-09 A | 2019-12-31 A | 1283 | 100% |  | 2019-12-09 | 2019-12-31 | 14d | 2019-12-09 | 2019-12-31 |  |  | 0% | 0% | ok | 0% | Galileia/MG (sede) |  | 8888888 |  |  |  |  |  |  |
| 1285 | 6.7.1.4.2.3 | Realizar Acompanhamento da Funcionalidade do Sistema - Captação Principal, Alternativa, Melhorias em ETA e UTR - Galileia/MG (sede) |  | 365ed | 2019-11-29 A | 2020-11-28 | 1287SS | 9% | 333ed | 2019-11-29 | 2020-11-28 | 365ed |  |  | 3267d |  |  |  |  |  |  |  | 8888888 |  |  |  |  |  |  |
| 1286 | 6.7.1.4.2.4 | **Operação Assistida** |  | 57d | 2019-11-29 A | 2020-02-27 |  | 36% | 36.73d | 2019-12-02 | 2020-03-09 | 64d | 2019-12-02 | 2020-03-09 | 929d |  | 0% | 0% | ok | 0% | Galileia/MG (sede) |  |  |  |  |  |  |  |  |
| 1287 | 6.7.1.4.2.4.1 | Realizar Operação Assistida - Galiléia/MG |  | 90ed | 2019-11-29 A | 2020-02-27 | 1275, 1278, 1274, 1280 | 36% | 58ed | 2019-12-02 | 2020-03-09 | 3.2mo | 2019-12-02 | 2020-03-09 | 4092d | 0d | 0% | 0% | ok | 0% | Galileia/MG (sede) |  | 8888888 |  |  |  |  |  |  |
| 1288 | 6.8 | **Tumiritinga/MG (sede)** |  | 1243d | 2018-01-31 A | 2023-01-14 |  | 8% | 1145.2d | 2018-01-31 | 2022-02-02 | 1008d | 2018-01-31 | 2022-02-02 | 211d |  | 35% | 0% | ok | 0% | Tumiritinga/MG (sede) |  |  | 13 | 35 | 42 | 31 | Socioambiental |  |
| 1289 | 6.8.1 | **Captação Principal e Melhorias em ETA** |  | 1127d | 2018-03-23 A | 2022-09-20 |  | 18% | 926.24d | 2018-03-14 | 2022-02-02 | 978d |  |  | 290d |  |  |  |  |  |  |  |  |  |  |  |  |  |  |
| 1290 | 6.8.1.1 | **Estudos de Concepção do Sistema** |  | 0d | 2018-03-23 A | 2018-03-23 A |  | 100% |  | 2018-03-14 | 2019-05-13 | 297d | 2018-03-14 | 2019-05-13 |  |  | 100% | 0% | ok | 0% | Tumiritinga/MG (sede) |  |  | 100 | 100 | 100 | 100 | Socioambiental |  |
| 1291 | 6.8.1.1.1 | Declaração de Escopo e Premissas de Projeto (DEPP) concluída - Tumiritinga/MG | milestone | 0d | 2018-03-23 A | 2018-03-23 A | 25, 26 | 100% |  | 2018-03-23 | 2018-03-23 | 0d | 2018-03-23 | 2018-03-23 |  |  | 100% | 0% | ok | 0% | Tumiritinga/MG (sede) |  |  | 100 | 100 | 100 | 100 |  |  |
| 1292 | 6.8.1.1.2 | Aprovação das DEPPs pela Operadora e Prefeitura - Tumiritinga/MG | milestone | 0d | 2018-03-23 A | 2018-03-23 A | 1291 | 100% |  | 2018-03-14 | 2018-03-14 | 0d | 2018-03-14 | 2018-03-14 |  |  | 100% | 0% | ok | 0% | Tumiritinga/MG (sede) |  |  | 100 | 100 | 100 | 100 |  |  |
| 1293 | 6.8.1.2 | **Engenharia Básica e Detalhada** |  | 175d | 2018-10-29 A | 2019-07-10 A |  | 100% |  | 2018-10-29 | 2019-11-14 | 265d | 2018-10-29 | 2019-11-14 |  |  | 63% | 0% | ok | 0% | Tumiritinga/MG (sede) |  |  | 48 | 63 | 59 | 81 | Socioambiental |  |
| 1294 | 6.8.1.2.1 | **Engenharia Captação Principal - SE 32248** |  | 175d | 2018-10-29 A | 2019-07-10 A |  | 100% |  | 2018-10-29 | 2019-07-22 | 183d | 2018-10-29 | 2019-07-22 |  |  | 91% | 0% | ok | 0% | Tumiritinga/MG (sede) |  |  | 75 | 91 | 82 | 92 | Socioambiental |  |
| 1295 | 6.8.1.2.1.1 | Aprovação Plano de Trabalho /abertura OSE - Captação Principal - Tumiritinga/MG |  | 23d | 2018-10-29 A | 2018-11-28 A | 1291 | 100% |  | 2018-10-29 | 2018-11-28 | 23d | 2018-10-29 | 2018-11-28 |  |  | 100% | 0% | ok | 0% | Tumiritinga/MG (sede) |  |  | 100 | 100 | 100 | 100 |  |  |
| 1296 | 6.8.1.2.1.2 | Realizar Levantamento de Campo - Captação Principal - Tumiritinga/MG |  | 1d | 2019-01-22 A | 2019-01-22 A | 1295SS | 100% |  | 2019-01-22 | 2019-01-22 | 1d | 2019-01-22 | 2019-01-22 |  |  | 100% | 0% | Não OK | 0% | Tumiritinga/MG (sede) |  |  | 100 | 100 | 100 | 100 | Socioambiental | Não OK |
| 1297 | 6.8.1.2.1.3 | Executar Topografia - Captação Principal - Tumiritinga/MG |  | 55d | 2018-10-29 A | 2019-01-14 A | 1295 | 100% |  | 2018-10-29 | 2019-01-14 | 55d | 2018-10-29 | 2019-01-14 |  |  | 100% |  |  |  |  |  |  | 100 | 100 | 100 | 100 |  |  |
| 1298 | 6.8.1.2.1.4 | Emitir RT/PQ para Suprimentos - Captação Principal - Tumiritinga/MG |  | 10d | 2019-06-27 A | 2019-07-10 A | 1299FF | 100% |  | 2019-05-27 | 2019-06-07 | 10d | 2019-05-27 | 2019-06-07 |  |  | 100% |  |  |  |  |  |  | 100 | 100 | 100 | 100 |  |  |
| 1299 | 6.8.1.2.1.5 | Elaborar Projeto Executivo - Captação Principal - Tumiritinga/MG |  | 87d | 2019-03-01 A | 2019-07-10 A | 1296, 1297 | 100% |  | 2019-03-01 | 2019-06-07 | 65d | 2019-03-01 | 2019-06-07 |  |  | 100% | 0% | ok | 0% | Tumiritinga/MG (sede) |  |  | 100 | 100 | 100 | 100 |  |  |
| 1300 | 6.8.1.2.1.6 | Elaboração do Projeto Executivo - Captação Principal - Tumiritinga/MG | milestone | 0d | 2019-07-10 A | 2019-07-10 A | 1299 | 100% |  | 2019-06-07 | 2019-06-07 | 0d | 2019-06-07 | 2019-06-07 |  |  | 100% |  |  |  |  |  |  | 100 | 100 | 100 | 100 |  |  |

Notes:
- 1293: 25/Jan19: / - Projeto da Captação Principal e ETA sendo considerados juntos no CR ENG.
- 1294: 25/Jan19: / - Projeto considerado no CR ENG como "Pequenas Melhorias na Captação Principal". / 06/Dez: / - Projeto não considerado no CR ENG (03/12/18).
- 1296: 25/Jan19: / - Levantamento de campo realizado/concluído em 22/01/19; Topografia iniciada em 29/10/18 e concluída 14/01/19.

| ID | WBS | Task | Type | Duration | Start | Finish | Predecessors | Complete | Remaining | Baseline start | Baseline finish | Baseline duration | Baseline 1 start | Baseline 1 finish | Total slack | Free slack | Constraint | Text3 | Text4 | Text5 | Text7 | Text15 | Text23 | Text25 | Text26 | Text27 | Text29 | Text9 | Indicadores MIR |
| --- | --- | --- | --- | --- | --- | --- | --- | --- | --- | --- | --- | --- | --- | --- | --- | --- | --- | --- | --- | --- | --- | --- | --- | --- | --- | --- | --- | --- | --- |
| 1301 | 6.8.1.2.2 | **Engenharia Melhorias na ETA - SE 32248** |  | 175d | 2018-10-29 A | 2019-07-10 A |  | 100% |  | 2018-10-29 | 2019-06-07 | 153d | 2018-10-29 | 2019-06-07 |  |  |  | 100% | 75 | 100 | 75 | 100 | Socioambiental | 0% | ok | 0% | Tumiritinga/MG (sede) |  |  |
| 1302 | 6.8.1.2.2.1 | Aprovar Plano de Trabalho e abrir OSE - Melhorias na ETA - Tumiritinga/MG |  | 23d | 2018-10-29 A | 2018-11-28 A | 1291 | 100% |  | 2018-10-29 | 2018-11-28 | 23d | 2018-10-29 | 2018-11-28 |  |  |  | 100% | 100 | 100 | 100 | 100 |  | 0% | ok | 0% | Tumiritinga/MG (sede) |  |  |
| 1303 | 6.8.1.2.2.2 | Realizar Levantamento de Campo - Melhorias na ETA - Tumiritinga/MG |  | 1d | 2019-01-22 A | 2019-01-22 A | 1302 | 100% |  | 2019-01-22 | 2019-01-22 | 1d | 2019-01-22 | 2019-01-22 |  |  |  | 100% | 100 | 100 | 100 | 100 | Socioambiental | 0% | Não OK | 0% | Tumiritinga/MG (sede) | Não OK |  |
| 1304 | 6.8.1.2.2.3 | Executar Topografia - Melhorias na ETA - Tumiritinga/MG |  | 55d | 2018-10-29 A | 2019-01-14 A | 1302 | 100% |  | 2018-10-29 | 2019-01-14 | 55d | 2018-10-29 | 2019-01-14 |  |  |  | 100% | 100 | 100 | 100 | 100 |  |  |  |  |  |  |  |
| 1305 | 6.8.1.2.2.4 | Emitir RT/PQ para Suprimentos - Melhorias na ETA - Tumiritinga/MG |  | 10d | 2019-06-26 A | 2019-07-10 A | 1306FF | 100% |  | 2019-05-27 | 2019-06-07 | 10d | 2019-05-27 | 2019-06-07 |  |  |  | 100% | 100 | 100 | 100 | 100 |  |  |  |  |  |  |  |
| 1306 | 6.8.1.2.2.5 | Elaborar Projeto Executivo - Melhorias na ETA - Tumiritinga/MG |  | 87d | 2019-03-01 A | 2019-07-10 A | 1303, 1304 | 100% |  | 2019-03-01 | 2019-06-07 | 65d | 2019-03-01 | 2019-06-07 |  |  |  | 100% | 100 | 100 | 100 | 100 |  | 0% | ok | 0% | Tumiritinga/MG (sede) |  |  |
| 1307 | 6.8.1.2.2.6 | Elaboração do Projeto Executivo - Melhorias na ETA - Tumiritinga/MG | milestone | 0d | 2019-07-10 A | 2019-07-10 A | 1306 | 100% |  | 2019-06-07 | 2019-06-07 | 0d | 2019-06-07 | 2019-06-07 |  |  |  | 100% | 100 | 100 | 100 | 100 |  |  |  |  |  |  |  |
| 1308 | 6.8.1.3 | **Infraestrutura** |  | 369d | 2021-03-31 | 2022-09-20 |  |  |  | 2019-11-20 | 2022-02-02 | 548d | 2019-11-20 | 2022-02-02 | 290d |  |  | 0% |  |  |  |  |  | 0% | ok | 0% | Tumiritinga/MG (sede) |  |  |
| 1309 | 6.8.1.3.1 | **Obras** |  | 120d | 2021-03-31 | 2021-09-20 |  |  |  | 2019-11-20 | 2021-01-19 | 288d | 2019-11-20 | 2021-01-19 | 291d |  |  | 0% |  |  |  |  |  |  |  |  |  |  |  |
| 1310 | 6.8.1.3.1.1 | Captação Principal e Melhorias na ETA (contrato guarda-chuva existente - Infraestrutura) - Tumiritinga/MG | milestone | 0d | 2021-03-31 | 2021-03-31 | 1298, 1299, 1305, 1306 |  |  | 2019-10-04 | 2019-11-20 | 0d | 2019-10-04 | 2019-11-20 | 291d | 0d | start no earlier than 2021-03-31 | 0% |  |  |  |  |  | 0% | ok | 0% | Tumiritinga/MG (sede) |  |  |
| 1311 | 6.8.1.3.1.2 | Executar obras de Melhorias na Captação Principal - Tumiritinga/MG |  | 120d | 2021-03-31 | 2021-09-20 | 1299, 1310, 1312SS |  |  | 2019-11-20 | 2021-01-19 | 288d | 2019-11-20 | 2021-01-19 | 291d | 0d |  | 0% |  |  |  |  |  | 0% | ok | 0% | Tumiritinga/MG (sede) |  |  |
| 1312 | 6.8.1.3.1.3 | Executar Melhorias na ETA - Tumiritinga/MG |  | 120d | 2021-03-31 | 2021-09-20 | 1306, 1310 |  |  | 2019-11-21 | 2020-06-02 | 129d | 2019-11-21 | 2020-06-02 | 291d | 0d |  | 0% |  |  |  |  |  | 0% | ok | 0% | Tumiritinga/MG (sede) |  | ETA |
| 1313 | 6.8.1.3.1.4 | Assinatura de Termo de Entrega das Obras de Melhoria do Sistema de Abastecimento de Água - Tumiritinga - Tumiritinga/MG | milestone | 0d | 2021-09-20 | 2021-09-20 | 1311, 1312 |  |  | 2021-01-19 | 2021-01-19 | 0d | 2021-01-19 | 2021-01-19 | 539d | 291d |  | 0% |  |  |  |  |  | 0% | ok | 0% | Tumiritinga/MG (sede) |  |  |
| 1314 | 6.8.1.3.2 | **Operação** |  | 249d | 2021-09-20 | 2022-09-20 |  |  |  | 2021-01-20 | 2022-02-02 | 260d | 2021-01-20 | 2022-02-02 | 290d |  |  | 0% |  |  |  |  |  | 0% | ok | 0% | Tumiritinga/MG (sede) |  |  |
| 1315 | 6.8.1.3.2.1 | Realizar Treinamento Operacional do Sistema - Tumiritinga/MG |  | 5d | 2021-09-21 | 2021-09-27 | 1311, 1312 |  |  | 2021-01-20 | 2021-01-26 | 5d | 2021-01-20 | 2021-01-26 | 520d | 0d |  | 0% |  |  |  |  |  | 0% | ok | 0% | Tumiritinga/MG (sede) |  |  |
| 1316 | 6.8.1.3.2.2 | Realizar Testes e Pré-operação - Tumiritinga/MG |  | 14d | 2021-09-28 | 2021-10-18 | 1315 |  |  | 2021-01-27 | 2021-02-18 | 14d | 2021-01-27 | 2021-02-18 | 520d |  |  | 0% |  |  |  |  |  | 0% | ok | 0% | Tumiritinga/MG (sede) |  |  |
| 1317 | 6.8.1.3.2.3 | Realizar Acompanhamento da Funcionalidade do Sistema - Captação Principal e Melhorias em ETA - Tumiritinga/MG (sede) |  | 365ed | 2021-09-20 | 2022-09-20 | 1319SS |  |  | 2021-01-20 | 2022-02-02 | 260d |  |  | 1284d |  |  |  |  |  |  |  |  |  |  |  |  |  |  |
| 1318 | 6.8.1.3.2.4 | **Operação Assistida** |  | 61d | 2021-09-20 | 2021-12-19 |  |  |  | 2021-01-20 | 2021-04-26 | 64d | 2021-01-20 | 2021-04-26 | 291d |  |  | 0% |  |  |  |  |  | 0% | ok | 0% | Tumiritinga/MG (sede) |  |  |
| 1319 | 6.8.1.3.2.4.1 | Realizar Operação Assistida - Tumiritinga/MG |  | 90ed | 2021-09-20 | 2021-12-19 | 1311, 1312 |  |  | 2021-01-20 | 2021-04-26 | 3.2mo | 2021-01-20 | 2021-04-26 | 1284d | 0d |  | 0% |  |  |  |  |  | 0% | ok | 0% | Tumiritinga/MG (sede) |  |  |
| 1320 | 6.8.2 | **Captação Alternativa** |  | 1109d | 2018-01-31 A | 2022-07-01 |  | 6% | 1047.82d | 2018-03-14 | 2022-02-02 | 978d |  |  | 345d |  |  |  |  |  |  |  |  |  |  |  |  |  |  |
| 1321 | 6.8.2.1 | **Estudos de Concepção do Sistema** |  | 317d | 2018-03-14 A | 2019-06-10 A |  | 100% |  | 2018-03-14 | 2019-05-13 | 297d | 2018-03-14 | 2019-05-13 |  |  |  | 100% | 100 | 100 | 100 | 100 | Socioambiental | 0% | ok | 0% | Tumiritinga/MG (sede) |  |  |
| 1322 | 6.8.2.1.1 | Declaração de Escopo e Premissas de Projeto (DEPP) concluída - Tumiritinga/MG | milestone | 0d | 2018-03-23 A | 2018-03-23 A | 25, 26 | 100% |  | 2018-03-23 | 2018-03-23 | 0d | 2018-03-23 | 2018-03-23 |  |  |  | 100% | 100 | 100 | 100 | 100 |  | 0% | ok | 0% | Tumiritinga/MG (sede) |  |  |
| 1323 | 6.8.2.1.2 | Aprovação das DEPPs pela Operadora e Prefeitura - Tumiritinga/MG | milestone | 0d | 2018-03-14 A | 2018-03-14 A | 25, 26 | 100% |  | 2018-03-14 | 2018-03-14 | 0d | 2018-03-14 | 2018-03-14 |  |  |  | 100% | 100 | 100 | 100 | 100 |  | 0% | ok | 0% | Tumiritinga/MG (sede) |  |  |
| 1324 | 6.8.2.1.3 | **Captações Subterrâneas - Serviços em Poços Tubulares (Poço 4)** |  | 228d | 2018-07-17 A | 2019-06-10 A |  | 100% |  | 2018-07-17 | 2019-05-03 | 202d | 2018-07-17 | 2019-05-03 |  |  |  | 100% | 100 | 100 | 100 | 100 | Socioambiental | 0% | ok | 0% | Tumiritinga/MG (sede) |  |  |
| 1325 | 6.8.2.1.3.1 | Realizar Perfilagem - Captação Alternativa - Poço 4 - Tumiritinga/MG |  | 2d | 2018-07-17 A | 2018-07-18 A | 1322 | 100% |  | 2018-07-17 | 2018-07-18 | 2d | 2018-07-17 | 2018-07-18 |  |  |  | 100% | 100 | 100 | 100 | 100 |  | 0% | ok | 0% | Tumiritinga/MG (sede) |  |  |
| 1326 | 6.8.2.1.3.2 | Realizar Recuperação - Captação Alternativa - Poço 4 - Tumiritinga/MG |  | 3d | 2018-09-28 A | 2018-10-02 A | 1325FS+51d | 100% |  | 2018-09-28 | 2018-10-02 | 3d | 2018-09-28 | 2018-10-02 |  |  |  | 100% | 100 | 100 | 100 | 100 |  | 0% | ok | 0% | Tumiritinga/MG (sede) |  |  |
| 1327 | 6.8.2.1.3.3 | Elaborar Relatório Técnico - Captação Alternativa - Poço 4 - Tumiritinga/MG |  | 47d | 2018-10-03 A | 2018-12-06 A | 1325, 1326 | 100% |  | 2018-10-03 | 2018-12-06 | 47d | 2018-10-03 | 2018-12-06 |  |  |  | 100% | 100 | 100 | 100 | 100 |  | 0% | ok | 0% | Tumiritinga/MG (sede) |  |  |
| 1328 | 6.8.2.1.3.4 | Realizar Instrumentação - Captação Alternativa - Poço 4 - Tumiritinga/MG |  | 3d | 2019-04-26 A | 2019-04-30 A | 1327FS+94d | 100% |  | 2019-04-26 | 2019-04-30 | 3d | 2019-04-26 | 2019-04-30 |  |  |  | 100% | 100 | 100 | 100 | 100 | Socioambiental | 0% | Não OK | 0% | Tumiritinga/MG (sede) |  |  |
| 1329 | 6.8.2.1.3.5 | Realizar Laudo de Serviços de Coleta e Análise de Água - Captação Alternativa - Poço 4 - Tumiritinga/MG |  | 26d | 2019-05-06 A | 2019-06-10 A | 1326FS+215ed | 100% |  | 2019-04-01 | 2019-05-03 | 22d | 2019-04-01 | 2019-05-03 |  |  |  | 100% | 100 | 100 | 100 | 100 |  | 0% | ok | 0% | Tumiritinga/MG (sede) |  |  |
| 1330 | 6.8.2.1.3.6 | Conclusão dos Serviços em poço tubular - Captação Alternativa - Poço 4 - Tumiritinga/MG | milestone | 0d | 2019-06-10 A | 2019-06-10 A | 1329 | 100% |  | 2019-05-03 | 2019-05-03 | 0d | 2019-05-03 | 2019-05-03 |  |  |  | 100% | 100 | 100 | 100 | 100 |  |  |  |  |  |  |  |
| 1331 | 6.8.2.1.4 | Conclusão dos Estudos de Concepção das Melhorias do Sistema de Abastecimento de Água - Tumiritinga/MG | milestone | 0d | 2019-06-10 A | 2019-06-10 A | 1330 | 100% |  | 2019-05-13 | 2019-05-13 | 0d | 2019-05-13 | 2019-05-13 |  |  |  | 100% | 100 | 100 | 100 | 100 |  |  |  |  |  |  |  |

Notes:
- 1303: 25/Jan19: / - Levantamento de campo realizado/concluído em 22/01/19; Topografia iniciada em 29/10/18 e concluída 14/01/19.
- 1328: 21/Jan19: / - O resultado do Laudo da água do Poço C4 apresentou-se ruim. Foi proposto à Copasa a investigação do Poço C3. Aguardando retorno da Copasa para programar as atividades.
- 1329: 22/04: Foram realizado dos testes, que tiveram resultados diferentes. Será realizado um terceiro teste.

| ID | WBS | Task | Type | Duration | Start | Finish | Predecessors | Complete | Remaining | Baseline start | Baseline finish | Baseline duration | Baseline 1 start | Baseline 1 finish | Total slack | Free slack | Text3 | Text4 | Text5 | Text7 | Text15 | Text23 | Text25 | Text26 | Text27 | Text29 | Text9 | Indicadores MIR |
| --- | --- | --- | --- | --- | --- | --- | --- | --- | --- | --- | --- | --- | --- | --- | --- | --- | --- | --- | --- | --- | --- | --- | --- | --- | --- | --- | --- | --- |
| 1332 | 6.8.2.2 | **Engenharia Básica e Detalhada** |  | 372d | 2019-02-27 A | 2020-08-27 |  | 16% | 313.35d | 2018-10-29 | 2019-11-14 | 265d | 2018-10-29 | 2019-11-14 | 803d |  | 63% | 48 | 63 | 59 | 81 | Socioambiental | 0% | ok | 0% | Tumiritinga/MG (sede) |  |  |
| 1333 | 6.8.2.2.1 | **Engenharia Captação Alternativa (Poço 4) - SE 32154** |  | 372d | 2019-02-27 A | 2020-08-27 |  | 16% | 313.35d | 2019-01-24 | 2019-07-18 | 119d | 2019-01-24 | 2019-07-18 | 803d |  | 88% |  | 88 |  | 85 | Socioambiental | 0% | ok | 0% | Tumiritinga/MG (sede) |  |  |
| 1334 | 6.8.2.2.1.1 | Aprovar Plano de Trabalho - Captação Alternativa - Poço 4 - Tumiritinga/MG |  | 10d | 2019-02-27 A | 2019-03-15 A | 1322, 1329FS-63d | 100% |  | 2019-01-24 | 2019-02-06 | 10d | 2019-01-24 | 2019-02-06 |  |  | 100% | 100 | 100 | 100 | 100 | Socioambiental | 0% | Não OK | 0% | Tumiritinga/MG (sede) | Não OK |  |
| 1335 | 6.8.2.2.1.2 | Realizar Levantamento de Campo - Captação Alternativa - Poço 4 - Tumiritinga/MG |  | 1d | 2019-07-23 A | 2019-07-23 A | 1329FS+29d, 1334FS+52d | 100% |  | 2019-02-07 | 2019-02-13 | 5d | 2019-02-07 | 2019-02-13 |  |  | 100% |  | 100 |  | 100 | Socioambiental | 0% | Não OK | 0% | Tumiritinga/MG (sede) |  |  |
| 1336 | 6.8.2.2.1.3 | Realizar Sondagem - Captação Alternativa - Poço 4 - Tumiritinga/MG |  | 12d | 2019-10-25 A | 2019-11-11 A | 1335FS+66d | 100% |  | 2019-02-06 | 2019-03-12 | 22d | 2019-02-06 | 2019-03-12 |  |  | 100% |  | 100 |  | 100 |  |  |  |  |  |  |  |
| 1337 | 6.8.2.2.1.4 | Realizar levantamento topográfico complementar (interferência de PVs e undergrounds) - Captação Alternativa - Poço 4 - Tumiritinga/MG |  | 12d | 2019-07-24 A | 2019-08-08 A | 1335 | 100% |  | 2019-07-24 | 2019-08-08 | 12d |  |  |  |  | 0% |  |  |  |  |  |  |  |  |  |  |  |
| 1338 | 6.8.2.2.1.5 | Elaborar arranjo conceitual para obtenção de Dados de Entrada Licenciamento e Fundiário - Captação Alternativa - Poço 4 - Tumiritinga/MG |  | 38d | 2020-02-06 | 2020-04-02 | 1336FS+57d |  |  | 2019-03-12 | 2019-04-15 | 25d | 2019-03-12 | 2019-04-15 | 347d | 0d | 100% |  | 100 |  | 100 | Socioambiental | 0% | Não OK | 0% | Tumiritinga/MG (sede) |  |  |
| 1339 | 6.8.2.2.1.6 | Elaborar Projeto Básico - Captação Alternativa - Poço 4 - Tumiritinga/MG |  | 50d | 2020-02-06 | 2020-04-22 | 1338SS |  |  | 2018-02-08 | 2018-03-21 | 30d | 2018-02-08 | 2018-03-21 | 347d | 0d | 100% |  | 100 |  | 100 |  |  |  |  |  |  |  |
| 1340 | 6.8.2.2.1.7 | Aprovar Projeto Básico - Captação Alternativa - Poço 4 - Tumiritinga/MG |  | 22d | 2020-04-23 | 2020-05-25 | 1339 |  |  | 2018-03-01 | 2018-03-30 | 22d |  |  | 347d | 0d |  |  |  |  |  |  |  |  |  |  |  |  |
| 1341 | 6.8.2.2.1.8 | Emitir RT/PQ para Suprimentos - Captação Alternativa - Poço 4 - Tumiritinga/MG |  | 10d | 2020-08-14 | 2020-08-27 | 1342FF |  |  | 2019-07-05 | 2019-07-18 | 10d | 2019-07-05 | 2019-07-18 | 347d | 0d | 0% |  |  |  |  | Socioambiental | 0% | Não OK | 0% | Tumiritinga/MG (sede) |  |  |
| 1342 | 6.8.2.2.1.9 | Elaborar Projeto Executivo - Captação Alternativa - Poço 4 - Tumiritinga/MG |  | 67d | 2020-05-26 | 2020-08-27 | 1327, 1336FF, 1337, 1338, 1339, 1340 |  |  | 2019-04-15 | 2019-07-18 | 65d | 2019-04-15 | 2019-07-18 | 347d | 0d | 78% |  | 78 |  | 78 | Socioambiental | 0% | Não OK | 0% | Tumiritinga/MG (sede) |  |  |
| 1343 | 6.8.2.2.1.10 | Elaboração do Projeto Executivo - Captação Alternativa - Poço 4 - Tumiritinga/MG | milestone | 0d | 2020-08-27 | 2020-08-27 | 1342 |  |  | 2019-07-18 | 2019-07-18 | 0d | 2019-07-18 | 2019-07-18 | 803d | 208d | 0% |  |  |  |  |  |  |  |  |  |  |  |
| 1344 | 6.8.2.3 | **Fundiária** |  | 616d | 2018-01-31 A | 2020-07-09 |  | 2% | 603.68d | 2018-01-31 | 2019-08-09 | 390d | 2018-01-31 | 2019-08-09 | 838d |  | 92% |  | 92 |  | 39 | Socioambiental | 0% | ok | 0% | Tumiritinga/MG (sede) |  |  |
| 1345 | 6.8.2.3.1 | Obter Termos de Autorização de Superficiário - Captação Alternativa - Poço 4 - Tumiritinga/MG |  | 1d | 2018-01-31 A | 2018-01-31 A | 26FS+52d | 100% |  | 2018-01-31 | 2018-01-31 | 1d | 2018-01-31 | 2018-01-31 |  |  | 100% | 100 | 100 | 100 | 100 |  | 0% | ok | 0% | Tumiritinga/MG (sede) |  |  |
| 1346 | 6.8.2.3.2 | Obter Termos de Autorização de Superficiário - Captação Alternativa - Adutora (ligando água do Poço 4 à ETA) - Tumiritinga/MG |  | 5d | 2020-04-03 | 2020-04-09 | 1338 |  |  | 2019-06-10 | 2019-06-14 | 5d | 2019-06-10 | 2019-06-14 | 470d | 0d | 100% |  | 100 |  | 100 | Socioambiental | 0% | Não OK | 0% | Tumiritinga/MG (sede) |  |  |
| 1347 | 6.8.2.3.3 | Captação Alternativa - Adutora (ligando água do Poço 4 à ETA) - Desimpedimento da Área e Negociação de Servidão - Tumiritinga/MG |  | 44d | 2020-05-08 | 2020-07-09 | 1346SS+22d |  |  | 2019-06-10 | 2019-08-09 | 44d | 2019-06-10 | 2019-08-09 | 470d | 0d | 31% |  | 31 |  | 31 | Socioambiental | 0% | Não OK | 0% | Tumiritinga/MG (sede) |  |  |
| 1348 | 6.8.2.3.4 | Conclusão da Regularização Fundiária para as obras de Melhoria do Sistema de Abastecimento da Localidade - Tumiritinga/MG | milestone | 0d | 2020-07-09 | 2020-07-09 | 1345, 1346, 1347 |  |  | 2019-08-09 | 2019-08-09 | 0d | 2019-08-09 | 2019-08-09 | 838d | 243d | 0% |  |  |  |  |  |  |  |  |  |  |  |
| 1349 | 6.8.2.4 | **Licenciamento** |  | 176d | 2020-04-13 | 2020-12-22 |  |  |  | 2019-03-12 | 2019-11-20 | 176d | 2019-03-12 | 2019-11-20 | 475d |  | 42% |  | 42 |  | 42 | Socioambiental | 0% | ok | 0% | Tumiritinga/MG (sede) |  |  |
| 1350 | 6.8.2.4.1 | Obter Outorga para Captação Alternativa (Poço 4) - Tumiritinga/MG |  | 176d | 2020-04-13 | 2020-12-22 | 1327, 1338, 1345, 1346 |  |  | 2019-03-12 | 2019-11-20 | 176d | 2019-03-12 | 2019-11-20 | 475d | 0d | 42% |  | 42 |  | 42 | Socioambiental | 0% | Não OK | 0% | Tumiritinga/MG (sede) |  |  |
| 1351 | 6.8.2.4.2 | Conclusão do Licenciamento Ambiental da Localidade - Tumiritinga/MG | milestone | 0d | 2020-12-22 | 2020-12-22 | 1350 |  |  | 2019-11-20 | 2019-11-20 | 0d | 2019-11-20 | 2019-11-20 | 723d | 128d | 0% |  |  |  |  |  |  |  |  |  |  |  |
| 1352 | 6.8.2.5 | **Suprimentos** |  | 88d | 2020-08-28 | 2021-01-06 |  |  |  | 2019-07-18 | 2020-02-28 | 153d | 2019-07-18 | 2020-02-28 | 347d |  | 0% |  |  |  |  |  | 0% | ok | 0% | Tumiritinga/MG (sede) |  |  |
| 1353 | 6.8.2.5.1 | Contratação MAS 1 (STA Poços Tubulares) - Tumiritinga/MG |  | 88d | 2020-08-28 | 2021-01-06 | 1341 |  |  | 2019-07-18 | 2019-11-20 | 88d | 2019-07-18 | 2019-11-20 | 347d | 0d | 0% |  |  |  |  |  | 0% | ok | 0% | Tumiritinga/MG (sede) |  |  |
| 1354 | 6.8.2.5.2 | Conclusão da Contratação de Suprimentos das obras de Melhoria do Sistema de Abastecimento de Água - Tumiritinga/MG | milestone | 0d | 2021-01-06 | 2021-01-06 | 1353 |  |  | 2020-02-28 | 2020-02-28 | 0d | 2020-02-28 | 2020-02-28 | 715d | 120d | 0% |  |  |  |  |  |  |  |  |  |  |  |
| 1355 | 6.8.2.6 | **Infraestrutura** |  | 370d | 2021-01-07 | 2022-07-01 |  |  |  | 2019-11-20 | 2022-02-02 | 548d | 2019-11-20 | 2022-02-02 | 345d |  | 0% |  |  |  |  |  | 0% | ok | 0% | Tumiritinga/MG (sede) |  |  |
| 1356 | 6.8.2.6.1 | **Obras** |  | 120d | 2021-01-07 | 2021-07-01 |  |  |  | 2019-11-20 | 2021-01-19 | 288d | 2019-11-20 | 2021-01-19 | 347d |  | 0% |  |  |  |  |  |  |  |  |  |  |  |
| 1357 | 6.8.2.6.1.1 | Executar Captação Alternativa (Interligação do Poço 4) - Tumiritinga/MG |  | 120d | 2021-01-07 | 2021-07-01 | 1328, 1342, 1345, 1346, 1347, 1350FF, 1353 |  |  | 2019-11-20 | 2021-01-19 | 288d | 2019-11-20 | 2021-01-19 | 347d | 0d | 0% |  |  |  |  |  | 0% | ok | 0% | Tumiritinga/MG (sede) |  | CA |
| 1358 | 6.8.2.6.1.2 | Assinatura de Termo de Entrega das Obras de Melhoria do Sistema de Abastecimento de Água - Tumiritinga - Tumiritinga/MG | milestone | 0d | 2021-07-01 | 2021-07-01 | 1357, 1343, 1348, 1351, 1354 |  |  | 2021-01-19 | 2021-01-19 | 0d | 2021-01-19 | 2021-01-19 | 595d | 347d | 0% |  |  |  |  |  | 0% | ok | 0% | Tumiritinga/MG (sede) |  |  |

Notes:
- 1332: 25/Jan19: / - Projeto da Captação Principal e ETA sendo considerados juntos no CR ENG.
- 1333: 25/Jan19 / - Projeto considerado no CR ENG como "Captação Alternativa, Adução e Tratamento".
- 1335: 25/Jan19: / - Levantamento de campo previsto para iniciar em 01/02 e finalizar em 07/02/19; Sondagem prevista para ser realizada/concluída em 01/02/19.
- 1345: 22/Nov: / - Negociação das áreas concluída. Pendente a emissão de documento comprobatório. / 06/Dez: Segundo CR Gestão Fundiária, "existe um poço dentro de uma área tombada pelo Município, conhecida como Praia do Jaó. Já foi definida a operação, mas a engenharia precisa definir o traçado de ligação do poço até a ETA". Pergunta: esse poço é o que está sendo utilizado para a captação alternativa? Verificar com o PG. / - Confirmar com a área se esse processo já foi 100% concluído (consta esta observação na planilha do Fundiário).
- 1346: 11/Fev19: / - Aguardando input da Engenharia, que por sua vez está aguardando confirmação do PG da utilização do Poço C4 como captação alternativa. / 06/Dez: / - Segundo planilha da Gestão Fundiária, "traçado em fase de definição - por vias públicas". Aguardando projeto Engenharia.
- 1350: 26/Nov: / - Necessário o projeto georreferenciado da adutora, bem como autorização do proprietário e documentos do imóvel. Prazo: 8 meses a contar da data de recebimento do projeto e do fundiário (pode ser 1 mês depois da entrega do projeto da Engenharia). / 22/Nov / - Processo não iniciado, data prevista para 01/04/19 cf planilha do licenciamento.
- 1352: 14/Fev19: / - Em reunião de integração entre as áreas nesta data, foi informado pelo Alessandro (Infraestrutura Território II - Calha e Médio Rio Doce) o abaixo: / . RT para contratação de STA Poços Tubulares para: Pedra Corrida, Tumiritinga (sede), Senhora da Penha e São Vitor (GV); e para construções de novas ETA's/UTR's de Senhora da Penha e São Tomé do Rio Doce (Tumiritinga). / . Contrato guarda-chuva existente da Infraestrutura: execução de pequenas melhorias (ETA, Captação Principal). / - Deverá ser elaborada outra RT para a UTR.

| ID | WBS | Task | Type | Duration | Start | Finish | Predecessors | Baseline start | Baseline finish | Baseline duration | Baseline 1 start | Baseline 1 finish | Total slack | Free slack | Text3 | Text25 | Text26 | Text27 | Text29 | Text4 | Text5 | Text7 | Text15 | Text23 |
| --- | --- | --- | --- | --- | --- | --- | --- | --- | --- | --- | --- | --- | --- | --- | --- | --- | --- | --- | --- | --- | --- | --- | --- | --- |
| 1359 | 6.8.2.6.2 | **Operação** |  | 250d | 2021-07-01 | 2022-07-01 |  | 2021-01-20 | 2022-02-02 | 260d | 2021-01-20 | 2022-02-02 | 345d |  | 0% | 0% | ok | 0% | Tumiritinga/MG (sede) |  |  |  |  |  |
| 1360 | 6.8.2.6.2.1 | Realizar Treinamento Operacional do Sistema - Tumiritinga/MG |  | 5d | 2021-07-02 | 2021-07-08 | 1357 | 2021-01-20 | 2021-01-26 | 5d | 2021-01-20 | 2021-01-26 | 576d | 0d | 0% | 0% | ok | 0% | Tumiritinga/MG (sede) |  |  |  |  |  |
| 1361 | 6.8.2.6.2.2 | Realizar Testes e Pré-operação - Tumiritinga/MG |  | 14d | 2021-07-09 | 2021-07-28 | 1360 | 2021-01-27 | 2021-02-18 | 14d | 2021-01-27 | 2021-02-18 | 576d |  | 0% | 0% | ok | 0% | Tumiritinga/MG (sede) |  |  |  |  |  |
| 1362 | 6.8.2.6.2.3 | Realizar Acompanhamento da Funcionalidade do Sistema - Captação Alternativa - Tumiritinga/MG (sede) |  | 365ed | 2021-07-01 | 2022-07-01 | 1364SS | 2021-01-20 | 2022-02-02 | 260d |  |  | 1527d |  |  |  |  |  |  |  |  |  |  |  |
| 1363 | 6.8.2.6.2.4 | **Operação Assistida** |  | 63d | 2021-07-01 | 2021-09-29 |  | 2021-01-20 | 2021-04-26 | 64d | 2021-01-20 | 2021-04-26 | 346d |  | 0% | 0% | ok | 0% | Tumiritinga/MG (sede) |  |  |  |  |  |
| 1364 | 6.8.2.6.2.4.1 | Realizar Operação Assistida - Tumiritinga/MG |  | 90ed | 2021-07-01 | 2021-09-29 | 1357 | 2021-01-20 | 2021-04-26 | 3.2mo | 2021-01-20 | 2021-04-26 | 1527d | 0d | 0% | 0% | ok | 0% | Tumiritinga/MG (sede) |  |  |  |  |  |
| 1365 | 6.8.3 | **UTR** |  | 679d | 2020-04-27 | 2023-01-14 |  | 2018-10-29 | 2022-02-02 | 815d |  |  | 211d |  |  |  |  |  |  |  |  |  |  |  |
| 1366 | 6.8.3.1 | **Engenharia Básica e Detalhada** |  | 212d | 2020-04-27 | 2021-03-03 |  | 2018-10-29 | 2019-11-14 | 265d | 2018-10-29 | 2019-11-14 | 211d |  | 63% | 0% | ok | 0% | Tumiritinga/MG (sede) | 48 | 63 | 59 | 81 | Socioambiental |
| 1367 | 6.8.3.1.1 | **Engenharia UTR** |  | 212d | 2020-04-27 | 2021-03-03 |  | 2018-11-29 | 2019-10-17 | 222d | 2018-11-29 | 2019-10-17 | 211d |  | 64% | 0% | ok | 0% | Tumiritinga/MG (sede) | 17 | 64 | 33 | 52 |  |
| 1368 | 6.8.3.1.1.1 | Elaborar arranjo para obtenção de Dados de Entrada Licenciamento e Fundiário - UTR - Tumiritinga/MG |  | 38d | 2020-04-27 | 2020-06-19 | 1322FS+527d | 2019-06-05 | 2019-07-17 | 30d | 2019-06-05 | 2019-07-17 | 211d | 0d | 56% |  |  |  |  |  | 56 |  | 56 |  |
| 1369 | 6.8.3.1.1.2 | Elaborar Projeto Básico - UTR - Tumiritinga/MG |  | 65d | 2020-08-03 | 2020-11-04 | 1368FS+30d | 2018-02-08 | 2018-03-21 | 30d | 2018-02-08 | 2018-03-21 | 211d | 0d | 100% | 0% | ok | 0% | Tumiritinga/MG (sede) |  | 100 |  | 100 |  |
| 1370 | 6.8.3.1.1.3 | Aprovar Projeto Básico - UTR - Tumiritinga/MG |  | 22d | 2020-11-05 | 2020-12-04 | 1369 | 2018-03-01 | 2018-03-30 | 22d |  |  | 230d | 0d |  |  |  |  |  |  |  |  |  |  |
| 1371 | 6.8.3.1.1.4 | Emitir RT/PQ para Suprimentos - UTR - Tumiritinga/MG |  | 10d | 2020-11-05 | 2020-11-18 | 1369 | 2019-07-11 | 2019-07-24 | 10d | 2019-07-11 | 2019-07-24 | 211d | 0d | 0% | 0% | ok | 0% | Tumiritinga/MG (sede) |  |  |  |  |  |
| 1372 | 6.8.3.1.1.5 | Elaborar Projeto Executivo - UTR - Tumiritinga/MG |  | 57d | 2020-12-07 | 2021-03-03 | 1368, 1369, 1370 | 2019-07-18 | 2019-10-17 | 65d | 2019-07-18 | 2019-10-17 | 230d | 0d | 0% | 0% | ok | 0% | Tumiritinga/MG (sede) |  |  |  |  |  |
| 1373 | 6.8.3.1.1.6 | Elaboração do Projeto Executivo - UTR - Tumiritinga/MG | milestone | 0d | 2021-03-03 | 2021-03-03 | 1372 | 2019-10-17 | 2019-10-17 | 0d | 2019-10-17 | 2019-10-17 | 230d | 19d | 0% |  |  |  |  |  |  |  |  |  |
| 1374 | 6.8.3.2 | **Suprimentos** |  | 88d | 2020-11-19 | 2021-03-30 |  | 2019-07-18 | 2020-02-28 | 153d | 2019-07-18 | 2020-02-28 | 211d |  | 0% | 0% | ok | 0% | Tumiritinga/MG (sede) |  |  |  |  |  |
| 1375 | 6.8.3.2.1 | Contratação MAS 2 (UTR's) - Tumiritinga/MG |  | 88d | 2020-11-19 | 2021-03-30 | 1371 | 2019-10-18 | 2020-02-28 | 88d | 2019-10-18 | 2020-02-28 | 211d | 0d | 0% | 0% | ok | 0% | Tumiritinga/MG (sede) |  |  |  |  |  |
| 1376 | 6.8.3.2.2 | Conclusão da Contratação de Suprimentos das obras de Melhoria do Sistema de Abastecimento de Água - Tumiritinga/MG | milestone | 0d | 2021-03-30 | 2021-03-30 | 1375 | 2020-02-28 | 2020-02-28 | 0d | 2020-02-28 | 2020-02-28 | 659d | 200d | 0% |  |  |  |  |  |  |  |  |  |
| 1377 | 6.8.3.3 | **Infraestrutura** |  | 448d | 2021-03-31 | 2023-01-14 |  | 2019-11-20 | 2022-02-02 | 548d | 2019-11-20 | 2022-02-02 | 211d |  | 0% | 0% | ok | 0% | Tumiritinga/MG (sede) |  |  |  |  |  |
| 1378 | 6.8.3.3.1 | **Obras** |  | 200d | 2021-03-31 | 2022-01-14 |  | 2019-11-20 | 2021-01-19 | 288d | 2019-11-20 | 2021-01-19 | 211d |  | 0% |  |  |  |  |  |  |  |  |  |
| 1379 | 6.8.3.3.1.1 | Executar UTR - Tumiritinga/MG |  | 200d | 2021-03-31 | 2022-01-14 | 1372, 1375, 1373 | 2020-03-02 | 2020-11-05 | 172d | 2020-03-02 | 2020-11-05 | 211d | 0d | 0% | 0% | ok | 0% | Tumiritinga/MG (sede) |  |  |  |  |  |
| 1380 | 6.8.3.3.1.2 | Assinatura de Termo de Entrega das Obras de Melhoria do Sistema de Abastecimento de Água - Tumiritinga - Tumiritinga/MG | milestone | 0d | 2022-01-14 | 2022-01-14 | 1379, 1376 | 2021-01-19 | 2021-01-19 | 0d | 2021-01-19 | 2021-01-19 | 459d | 211d | 0% | 0% | ok | 0% | Tumiritinga/MG (sede) |  |  |  |  |  |
| 1381 | 6.8.3.3.2 | **Operação** |  | 248d | 2022-01-14 | 2023-01-14 |  | 2021-01-20 | 2022-02-02 | 260d | 2021-01-20 | 2022-02-02 | 211d |  | 0% | 0% | ok | 0% | Tumiritinga/MG (sede) |  |  |  |  |  |
| 1382 | 6.8.3.3.2.1 | Realizar Treinamento Operacional do Sistema - Tumiritinga/MG |  | 5d | 2022-01-17 | 2022-01-21 | 1379 | 2021-01-20 | 2021-01-26 | 5d | 2021-01-20 | 2021-01-26 | 440d | 0d | 0% | 0% | ok | 0% | Tumiritinga/MG (sede) |  |  |  |  |  |
| 1383 | 6.8.3.3.2.2 | Realizar Testes e Pré-operação - Tumiritinga/MG |  | 14d | 2022-01-24 | 2022-02-10 | 1382 | 2021-01-27 | 2021-02-18 | 14d | 2021-01-27 | 2021-02-18 | 440d |  | 0% | 0% | ok | 0% | Tumiritinga/MG (sede) |  |  |  |  |  |
| 1384 | 6.8.3.3.2.3 | Realizar Acompanhamento da Funcionalidade do Sistema - UTR - Tumiritinga/MG (sede) |  | 365ed | 2022-01-14 | 2023-01-14 | 1386SS | 2021-01-20 | 2022-02-02 | 260d |  |  | 936d |  |  |  |  |  |  |  |  |  |  |  |

Notes:
- 1366: 25/Jan19: / - Projeto da Captação Principal e ETA sendo considerados juntos no CR ENG.
- 1374: 14/Fev19: / - Em reunião de integração entre as áreas nesta data, foi informado pelo Alessandro (Infraestrutura Território II - Calha e Médio Rio Doce) o abaixo: / . RT para contratação de STA Poços Tubulares para: Pedra Corrida, Tumiritinga (sede), Senhora da Penha e São Vitor (GV); e para construções de novas ETA's/UTR's de Senhora da Penha e São Tomé do Rio Doce (Tumiritinga). / . Contrato guarda-chuva existente da Infraestrutura: execução de pequenas melhorias (ETA, Captação Principal). / - Deverá ser elaborada outra RT para a UTR.

| ID | WBS | Task | Type | Duration | Start | Finish | Predecessors | Complete | Remaining | Baseline start | Baseline finish | Baseline duration | Baseline 1 start | Baseline 1 finish | Total slack | Free slack | Text3 | Text25 | Text26 | Text27 | Text29 | Text4 | Text5 | Text7 | Text15 | Text23 | Text9 | Text13 |
| --- | --- | --- | --- | --- | --- | --- | --- | --- | --- | --- | --- | --- | --- | --- | --- | --- | --- | --- | --- | --- | --- | --- | --- | --- | --- | --- | --- | --- |
| 1385 | 6.8.3.3.2.4 | **Operação Assistida** |  | 61d | 2022-01-14 | 2022-04-14 |  |  |  | 2021-01-20 | 2021-04-26 | 64d | 2021-01-20 | 2021-04-26 | 211d |  | 0% | 0% | ok | 0% | Tumiritinga/MG (sede) |  |  |  |  |  |  |  |
| 1386 | 6.8.3.3.2.4.1 | Realizar Operação Assistida - Tumiritinga/MG |  | 90ed | 2022-01-14 | 2022-04-14 | 1379 |  |  | 2021-01-20 | 2021-04-26 | 3.2mo | 2021-01-20 | 2021-04-26 | 936d | 0d | 0% | 0% | ok | 0% | Tumiritinga/MG (sede) |  |  |  |  |  |  |  |
| 1387 | 6.9 | **São Tomé do Rio Doce (distrito Tumiritinga/MG)** |  | 1156d | 2017-12-12 A | 2022-07-19 |  | 41% | 687.35d | 2016-10-03 | 2021-11-03 | 1292d | 2016-10-03 | 2021-11-03 | 333d |  | 54% | 0% | ok | 0% | São Tomé do Rio Doce (distrito Tumiritinga/MG) | 31 | 54 | 55 | 56 | Socioambiental |  |  |
| 1388 | 6.9.1 | **Captação Principal / Nova ETA / UTR** |  | 1156d | 2017-12-12 A | 2022-07-19 |  | 25% | 868.62d | 2017-12-12 | 2021-11-03 | 981d |  |  | 333d |  |  |  |  |  |  |  |  |  |  |  |  |  |
| 1389 | 6.9.1.1 | **Estudos de Concepção do Sistema** |  | 72d | 2017-12-12 A | 2018-03-23 A |  | 100% |  | 2017-12-12 | 2019-06-12 | 385d | 2017-12-12 | 2019-06-12 |  |  | 100% | 0% | ok | 0% | São Tomé do Rio Doce (distrito Tumiritinga/MG) | 100 | 100 | 100 | 100 | Socioambiental |  |  |
| 1390 | 6.9.1.1.1 | Declaração de Escopo e Premissas de Projeto (DEPP) concluída - São Tomé do Rio Doce/MG | milestone | 0d | 2018-03-23 A | 2018-03-23 A | 25, 26 | 100% |  | 2018-03-23 | 2018-03-23 | 0d | 2018-03-23 | 2018-03-23 |  |  | 100% | 0% | ok | 0% | São Tomé do Rio Doce (distrito Tumiritinga/MG) | 100 | 100 | 100 | 100 |  |  |  |
| 1391 | 6.9.1.1.2 | Aprovação das DEPPs pela Operadora e Prefeitura - São Tomé do Rio Doce/MG | milestone | 0d | 2017-12-12 A | 2017-12-12 A | 25, 26FS+17d | 100% |  | 2017-12-12 | 2017-12-12 | 0d | 2017-12-12 | 2017-12-12 |  |  | 100% | 0% | ok | 0% | São Tomé do Rio Doce (distrito Tumiritinga/MG) | 100 | 100 | 100 | 100 |  |  |  |
| 1392 | 6.9.1.2 | **Engenharia Básica e Detalhada** |  | 376d | 2018-10-29 A | 2020-05-04 |  | 66% | 129.34d | 2018-01-30 | 2019-05-31 | 342d | 2018-01-30 | 2019-05-31 | 885d |  | 100% | 0% | ok | 0% | São Tomé do Rio Doce (distrito Tumiritinga/MG) | 79 | 100 | 79 | 100 | Socioambiental |  |  |
| 1393 | 6.9.1.2.1 | **Engenharia Captação Principal / Nova ETA / UTR - SE 32156** |  | 376d | 2018-10-29 A | 2020-05-04 |  | 66% | 129.34d | 2018-10-29 | 2019-05-31 | 148d | 2018-10-29 | 2019-05-31 | 885d |  | 100% | 0% | ok | 0% | São Tomé do Rio Doce (distrito Tumiritinga/MG) | 40 | 100 | 40 | 100 | Socioambiental |  |  |
| 1394 | 6.9.1.2.1.1 | Aprovar plano de Trabalho - Captação Principal / Nova ETA / UTR - São Tomé do Rio Doce/MG |  | 8d | 2019-03-11 A | 2019-03-20 A | 1390FS+353ed | 100% |  | 2018-11-30 | 2018-12-13 | 10d | 2018-11-30 | 2018-12-13 |  |  | 100% | 0% | Não OK | 0% | São Tomé do Rio Doce (distrito Tumiritinga/MG) | 100 | 100 | 100 | 100 | Socioambiental | Não OK |  |
| 1395 | 6.9.1.2.1.2 | Realizar Levantamento de Campo - Captação Principal / Nova ETA / UTR - São Tomé do Rio Doce/MG |  | 4d | 2019-05-24 A | 2019-05-31 A | 1390, 1394FF+52d | 100% |  | 2018-12-06 | 2018-12-13 | 6d | 2018-12-06 | 2018-12-13 |  |  | 100% | 0% | Não OK | 0% | São Tomé do Rio Doce (distrito Tumiritinga/MG) | 100 | 100 | 100 | 100 | Socioambiental | Não OK |  |
| 1396 | 6.9.1.2.1.3 | Realizar Sondagem - Captação Principal / Nova ETA / UTR - São Tomé do Rio Doce/MG |  | 21d | 2019-11-26 A | 2019-12-27 A | 1394, 1407FS-30d | 100% |  | 2018-12-13 | 2019-01-14 | 22d | 2018-12-13 | 2019-01-14 |  |  | 100% |  |  |  |  |  | 100 |  | 100 |  |  | 8888888 |
| 1397 | 6.9.1.2.1.4 | Executar Topografia - Captação Principal / Nova ETA / UTR - São Tomé do Rio Doce/MG |  | 55d | 2018-10-29 A | 2019-01-14 A | 1390 | 100% |  | 2018-10-29 | 2019-01-14 | 55d | 2018-10-29 | 2019-01-14 |  |  | 100% |  |  |  |  | 100 | 100 | 100 | 100 |  |  |  |
| 1398 | 6.9.1.2.1.5 | Elaborar arranjo para obtenção de Dados de Entrada Licenciamento e Fundiário - Captação Principal / Nova ETA / UTR - São Tomé do Rio Doce/MG |  | 21d | 2019-07-12 A | 2019-08-09 A | 1395, 1397 | 100% |  | 2019-01-14 | 2019-02-22 | 30d | 2019-01-14 | 2019-02-22 |  |  | 100% | 0% | Não OK | 0% | São Tomé do Rio Doce (distrito Tumiritinga/MG) | 25 | 100 | 25 | 100 | Socioambiental |  |  |
| 1399 | 6.9.1.2.1.6 | Elaborar Projeto Básico - Captação Principal / Nova ETA / UTR - São Tomé do Rio Doce/MG |  | 55d | 2019-10-22 A | 2020-01-13 A | 1396FF, 1398 | 100% |  | 2018-02-08 | 2018-03-21 | 30d | 2018-02-08 | 2018-03-21 |  |  | 100% |  |  |  |  |  | 100 |  | 100 |  |  | 8888888 |
| 1400 | 6.9.1.2.1.7 | Aprovar Projeto Básico - Captação Principal / Nova ETA / UTR - São Tomé do Rio Doce/MG |  | 22d | 2020-01-14 | 2020-02-12 | 1399 |  |  | 2018-03-01 | 2018-03-30 | 22d |  |  | 349d | 0d |  |  |  |  |  |  |  |  |  |  |  |  |
| 1401 | 6.9.1.2.1.8 | Emitir RT/PQ para Suprimentos - Captação Principal / Nova ETA / UTR - São Tomé do Rio Doce/MG |  | 12d | 2020-04-15 | 2020-05-04 | 1399, 1402FF |  |  | 2019-02-26 | 2019-03-14 | 10d | 2019-02-26 | 2019-03-14 | 349d | 0d | 100% | 0% | Não OK | 0% | São Tomé do Rio Doce (distrito Tumiritinga/MG) |  | 100 |  | 100 | Socioambiental |  |  |
| 1402 | 6.9.1.2.1.9 | Elaborar Projeto Executivo - Captação Principal / Nova ETA / UTR - São Tomé do Rio Doce/MG |  | 52d | 2020-02-13 | 2020-05-04 | 1396FF, 1398, 1399, 1400 |  |  | 2019-02-22 | 2019-05-31 | 65d | 2019-02-22 | 2019-05-31 | 349d | 0d | 100% | 0% | Não OK | 0% | São Tomé do Rio Doce (distrito Tumiritinga/MG) |  | 100 |  | 100 | Socioambiental |  |  |
| 1403 | 6.9.1.2.1.10 | Elaboração do Projeto Executivo - Captação Principal / Nova ETA / UTR - São Tomé do Rio Doce/MG | milestone | 0d | 2020-05-04 | 2020-05-04 | 1402 |  |  | 2019-05-31 | 2019-05-31 | 0d | 2019-05-31 | 2019-05-31 | 885d | 102d | 100% |  |  |  |  |  | 100 |  | 100 |  |  |  |
| 1404 | 6.9.1.3 | **Fundiária** |  | 291d | 2018-11-12 A | 2020-01-10 |  | 61% | 113.49d | 2018-11-12 | 2019-07-15 | 168d | 2018-11-12 | 2019-07-15 | 960d |  | 93% | 0% | ok | 0% | São Tomé do Rio Doce (distrito Tumiritinga/MG) | 63 | 93 | 68 | 93 | Socioambiental |  |  |
| 1405 | 6.9.1.3.1 | Captação Principal - Adutora rio Doce - Desimpedimento de área - São Tomé do Rio Doce/MG |  | 291d | 2018-11-12 A | 2020-01-10 | 1390FS+166d | 61% | 113.49d | 2018-11-12 | 2019-07-15 | 168d | 2018-11-12 | 2019-07-15 | 512d | 0d | 93% | 0% | Não OK | 0% | São Tomé do Rio Doce (distrito Tumiritinga/MG) | 63 | 93 | 68 | 93 | Socioambiental |  |  |
| 1406 | 6.9.1.3.2 | Nova ETA / UTR - Desimpedimento de área - São Tomé do Rio Doce/MG |  | 291d | 2018-11-12 A | 2020-01-10 | 1390FS+166d | 61% | 113.49d | 2018-11-12 | 2019-07-15 | 168d | 2018-11-12 | 2019-07-15 | 512d | 0d | 93% | 0% | Não OK | 0% | São Tomé do Rio Doce (distrito Tumiritinga/MG) | 63 | 93 | 68 | 93 | Socioambiental |  |  |
| 1407 | 6.9.1.3.3 | Conclusão da Regularização Fundiária para as obras de Melhoria do Sistema de Abastecimento da Localidade - São Tomé do Rio Doce/MG | milestone | 0d | 2020-01-10 | 2020-01-10 | 1405, 1406 |  |  | 2019-07-15 | 2019-07-15 | 0d | 2019-07-15 | 2019-07-15 | 433d | 0d | 0% |  |  |  |  |  |  |  |  |  |  |  |
| 1408 | 6.9.1.4 | **Licenciamento** |  | 444d | 2018-12-14 A | 2020-09-25 |  | 48% | 229.92d | 2018-10-22 | 2020-01-17 | 311d | 2018-10-22 | 2020-01-17 | 783d |  | 55% | 0% | ok | 0% | São Tomé do Rio Doce (distrito Tumiritinga/MG) |  | 55 | 14 | 43 | Socioambiental |  |  |
| 1409 | 6.9.1.4.1 | Outorga/DAIA para Captação Principal (rio Doce) - São Tomé do Rio Doce/MG |  | 176d | 2020-01-14 | 2020-09-25 | 1398, 1399 |  |  | 2019-02-25 | 2019-11-07 | 176d | 2019-02-25 | 2019-11-07 | 335d | 0d | 47% | 0% | Não OK | 0% | São Tomé do Rio Doce (distrito Tumiritinga/MG) |  | 47 |  | 47 | Socioambiental |  |  |
| 1410 | 6.9.1.4.2 | Obter DAIA Nova ETA - São Tomé do Rio Doce/MG |  | 267d | 2018-12-14 A | 2020-01-10 |  | 80% | 53.4d | 2019-06-13 | 2019-12-16 | 129d | 2019-06-13 | 2019-12-16 | 512d | 177d | 8% | 0% | Não OK | 0% | São Tomé do Rio Doce (distrito Tumiritinga/MG) | 25 |  | 312 |  | Socioambiental | Não OK | 8888888 |
| 1411 | 6.9.1.4.3 | Conclusão do Licenciamento Ambiental da Localidade - São Tomé do Rio Doce/MG | milestone | 0d | 2020-09-25 | 2020-09-25 | 1409, 1410 |  |  | 2020-01-17 | 2020-01-17 | 0d | 2020-01-17 | 2020-01-17 | 783d | 0d | 0% |  |  |  |  |  |  |  |  |  |  |  |

Notes:
- 1391: 06/Dez: / - Validação do diagnóstico/propostas para o abastecimento de São Tomé do Rio Doce através de Ata de Reunião datada de 12/12/17.
- 1395: 25/Jan19: / - Topografia iniciada em 29/10/18 e concluída em 14/01/19; Levantamento de campo previsto pra iniciar em 06/02 e finalizar em 12/02/19; Sondagem prevista pra iniciar em 06/02 e finalizar em 12/03/19.
- 1404: 01/Fev19: / - Imóvel sem registro imobiliário localizado. Aguardando orientações do Jurídico. / - Termos de Autorização desnecessários pois o imóvel já abriga outras estruturas da FR. / - Indenizações necessárias e urgentes! / - Engenharia já disponibilizou projeto para o Fundiário realizar a avaliação imobiliária. / 03/Dez: / - Segundo planilha da Gestão Fundiária, pesquisas cartoriais em andamento. Possivel terra devoluta. Poço + ETA já implantados, mas falta indenizar possuidor. Projetados mais uma ETA + UTR + adutora + captação para o mesmo imóvel. / - Obtenção de Autorização de Acesso p/ estudos e Verificação Documentação das Áreas concluídaS em 18/05 e 27/07/18, respectivamente. Aguardando Laudo de Avaliação. (Enviada RT de compra para Wisney em 31/10 para laudo de avaliação. Poço, áreas para ETAs e Adutora).
- 1410: 13/06/19: Pedido de informação complementar recebido 05/06/19

| ID | WBS | Task | Type | Duration | Start | Finish | Predecessors | Complete | Remaining | Baseline start | Baseline finish | Baseline duration | Baseline 1 start | Baseline 1 finish | Total slack | Free slack | Text3 | Text4 | Text5 | Text7 | Text15 | Text23 | Text25 | Text26 | Text27 | Text29 | Indicadores MIR |
| --- | --- | --- | --- | --- | --- | --- | --- | --- | --- | --- | --- | --- | --- | --- | --- | --- | --- | --- | --- | --- | --- | --- | --- | --- | --- | --- | --- |
| 1412 | 6.9.1.5 | **Suprimentos** |  | 88d | 2020-05-05 | 2020-09-04 |  |  |  | 2018-11-08 | 2019-07-22 | 175d | 2018-11-08 | 2019-07-22 | 349d |  | 90% | 27 | 90 | 31 | 86 | Socioambiental | 0% | ok | 0% | São Tomé do Rio Doce (distrito Tumiritinga/MG) |  |
| 1413 | 6.9.1.5.1 | Contratação MAS 1 (Captação Principal e Construções novas ETA's/UTR's) - São Tomé do Rio Doce/MG |  | 88d | 2020-05-05 | 2020-09-04 | 1401 |  |  | 2019-03-15 | 2019-07-22 | 88d | 2019-03-15 | 2019-07-22 | 349d | 0d | 81% |  | 81 |  | 81 | Socioambiental | 0% | Não OK | 0% | São Tomé do Rio Doce (distrito Tumiritinga/MG) |  |
| 1414 | 6.9.1.5.2 | Conclusão da Contratação de Suprimentos das obras de Melhoria do Sistema de Abastecimento de Água - São Tomé do Rio Doce/MG | milestone | 0d | 2020-09-04 | 2020-09-04 | 1413 |  |  | 2019-07-22 | 2019-07-22 | 0d | 2019-07-22 | 2019-07-22 | 797d | 14d | 0% |  |  |  |  |  |  |  |  |  |  |
| 1415 | 6.9.1.6 | **Infraestrutura** |  | 450d | 2020-09-28 | 2022-07-19 |  |  |  | 2016-10-03 | 2021-11-03 | 1292d | 2016-10-03 | 2021-11-03 | 333d |  | 54% |  | 54 | 100 |  |  | 0% | ok | 0% | São Tomé do Rio Doce (distrito Tumiritinga/MG) |  |
| 1416 | 6.9.1.6.1 | **Obras** |  | 200d | 2020-09-28 | 2021-07-19 |  |  |  | 2016-10-03 | 2020-10-16 | 1032d | 2016-10-03 | 2020-10-16 | 335d |  | 68% | 32 | 68 | 100 | 32 |  |  |  |  |  |  |
| 1417 | 6.9.1.6.1.1 | Executar Captação Principal / Nova ETA / UTR - São Tomé do Rio Doce/MG |  | 200d | 2020-09-28 | 2021-07-19 | 1402, 1405, 1406, 1409, 1410, 1413 |  |  | 2019-10-03 | 2020-10-16 | 258d | 2019-10-03 | 2020-10-16 | 335d | 0d | 0% |  |  |  |  |  | 0% | ok | 0% | São Tomé do Rio Doce (distrito Tumiritinga/MG) | ETA |
| 1418 | 6.9.1.6.2 | **Operação** |  | 250d | 2021-07-19 | 2022-07-19 |  |  |  | 2020-10-19 | 2021-11-03 | 260d | 2020-10-19 | 2021-11-03 | 333d |  | 0% |  |  |  |  |  | 0% | ok | 0% | São Tomé do Rio Doce (distrito Tumiritinga/MG) |  |
| 1419 | 6.9.1.6.2.1 | Realizar Treinamento Operacional do Sistema - São Tomé do Rio Doce/MG |  | 5d | 2021-07-20 | 2021-07-26 | 1417 |  |  | 2020-10-19 | 2020-10-23 | 5d | 2020-10-19 | 2020-10-23 | 564d | 0d | 0% |  |  |  |  |  | 0% | ok | 0% | São Tomé do Rio Doce (distrito Tumiritinga/MG) |  |
| 1420 | 6.9.1.6.2.2 | Realizar Testes e Pré-operação - São Tomé do Rio Doce/MG |  | 14d | 2021-07-27 | 2021-08-13 | 1419 |  |  | 2020-10-26 | 2020-11-13 | 14d | 2020-10-26 | 2020-11-13 | 564d |  | 0% |  |  |  |  |  | 0% | ok | 0% | São Tomé do Rio Doce (distrito Tumiritinga/MG) |  |
| 1421 | 6.9.1.6.2.3 | Realizar Acompanhamento da Funcionalidade do Sistema - Captação Principal / Nova ETA / UTR - São Tomé do Rio Doce (distrito Tumiritinga/MG) |  | 365ed | 2021-07-19 | 2022-07-19 | 1423SS |  |  | 2020-10-19 | 2021-11-03 | 260d |  |  | 1473d |  |  |  |  |  |  |  |  |  |  |  |  |
| 1422 | 6.9.1.6.2.4 | **Operação Assistida** |  | 62d | 2021-07-19 | 2021-10-17 |  |  |  | 2020-10-19 | 2021-01-20 | 64d | 2020-10-19 | 2021-01-20 | 335d |  | 0% |  |  |  |  |  | 0% | ok | 0% | São Tomé do Rio Doce (distrito Tumiritinga/MG) |  |
| 1423 | 6.9.1.6.2.4.1 | Realizar Operação Assistida - São Tomé do Rio Doce/MG |  | 90ed | 2021-07-19 | 2021-10-17 | 1417 |  |  | 2020-10-19 | 2021-01-20 | 3.2mo | 2020-10-19 | 2021-01-20 | 1473d | 0d | 0% |  |  |  |  |  | 0% | ok | 0% | São Tomé do Rio Doce (distrito Tumiritinga/MG) |  |
| 1424 | 6.9.2 | **Captação Alternativa** |  | 706d | 2017-12-12 A | 2020-09-25 |  | 80% | 144.47d | 2017-12-12 | 2020-09-25 | 707d |  |  | 783d |  |  |  |  |  |  |  |  |  |  |  |  |
| 1425 | 6.9.2.1 | **Estudos de Concepção do Sistema - Etapa 1** |  | 404d | 2017-12-12 A | 2019-07-11 A |  | 100% |  | 2017-12-12 | 2019-06-12 | 385d | 2017-12-12 | 2019-06-12 |  |  | 100% | 100 | 100 | 100 | 100 | Socioambiental | 0% | ok | 0% | São Tomé do Rio Doce (distrito Tumiritinga/MG) |  |
| 1426 | 6.9.2.1.1 | Declaração de Escopo e Premissas de Projeto (DEPP) concluída - São Tomé do Rio Doce/MG | milestone | 0d | 2018-03-23 A | 2018-03-23 A | 25, 26 | 100% |  | 2018-03-23 | 2018-03-23 | 0d | 2018-03-23 | 2018-03-23 |  |  | 100% | 100 | 100 | 100 | 100 |  | 0% | ok | 0% | São Tomé do Rio Doce (distrito Tumiritinga/MG) |  |
| 1427 | 6.9.2.1.2 | Aprovação das DEPPs pela Operadora e Prefeitura - São Tomé do Rio Doce/MG | milestone | 0d | 2017-12-12 A | 2017-12-12 A | 25, 26FS+17d | 100% |  | 2017-12-12 | 2017-12-12 | 0d | 2017-12-12 | 2017-12-12 |  |  | 100% | 100 | 100 | 100 | 100 |  | 0% | ok | 0% | São Tomé do Rio Doce (distrito Tumiritinga/MG) |  |
| 1428 | 6.9.2.1.3 | **Estudos de Concepção do Sistema - Etapa 2** |  | 52d | 2019-04-29 A | 2019-07-11 A |  | 100% |  | 2019-04-29 | 2019-07-11 | 52d |  |  |  |  |  |  |  |  |  |  |  |  |  |  |  |
| 1429 | 6.9.2.1.3.1 | **Captações Subterrâneas - Serviços em Poços Tubulares** |  | 52d | 2019-04-29 A | 2019-07-11 A |  | 100% |  | 2019-04-29 | 2019-06-12 | 32d | 2019-04-29 | 2019-06-12 |  |  | 100% | 100 | 100 | 100 | 100 | Socioambiental | 0% | ok | 0% | São Tomé do Rio Doce (distrito Tumiritinga/MG) |  |
| 1430 | 6.9.2.1.3.1.1 | Realizar Perfilagem - São Tomé do Rio Doce/MG |  | 2d | 2019-04-29 A | 2019-04-30 A | 1426FS+400ed | 100% |  | 2019-04-29 | 2019-04-30 | 2d | 2019-04-29 | 2019-04-30 |  |  | 100% | 100 | 100 | 100 | 100 | Socioambiental | 0% | Não OK | 0% | São Tomé do Rio Doce (distrito Tumiritinga/MG) |  |
| 1431 | 6.9.2.1.3.1.2 | Realizar Recuperação - São Tomé do Rio Doce/MG |  | 7d | 2019-05-02 A | 2019-05-10 A | 1430 | 100% |  | 2019-05-02 | 2019-05-10 | 7d | 2019-05-02 | 2019-05-10 |  |  | 100% | 100 | 100 | 100 | 100 | Socioambiental | 0% | Não OK | 0% | São Tomé do Rio Doce (distrito Tumiritinga/MG) |  |
| 1432 | 6.9.2.1.3.1.3 | Elaborar Relatório Técnico - São Tomé do Rio Doce/MG |  | 43d | 2019-05-13 A | 2019-07-11 A | 1431 | 100% |  | 2019-05-13 | 2019-06-12 | 23d | 2019-05-13 | 2019-06-12 |  |  | 100% | 100 | 100 | 100 | 100 | Socioambiental | 0% | Não OK | 0% | São Tomé do Rio Doce (distrito Tumiritinga/MG) |  |
| 1433 | 6.9.2.1.3.1.4 | Conclusão dos Serviços em poço tubular - São Tomé do Rio Doce/MG | milestone | 0d | 2019-07-11 A | 2019-07-11 A | 1432 | 100% |  | 2019-06-12 | 2019-06-12 | 0d | 2019-06-12 | 2019-06-12 |  |  | 100% | 100 | 100 | 100 | 100 |  |  |  |  |  |  |
| 1434 | 6.9.2.1.3.2 | Conclusão dos Estudos de Concepção das Melhorias do Sistema de Abastecimento de Água - São Tomé do Rio Doce/MG | milestone | 0d | 2019-07-11 A | 2019-07-11 A | 1433 | 100% |  | 2019-06-12 | 2019-06-12 | 0d | 2019-06-12 | 2019-06-12 |  |  | 100% | 100 | 100 | 100 | 100 |  |  |  |  |  |  |
| 1435 | 6.9.2.2 | **Engenharia Básica e Detalhada** |  | 189d | 2018-01-30 A | 2018-10-19 A |  | 100% |  | 2018-01-30 | 2019-05-31 | 342d | 2018-01-30 | 2019-05-31 |  |  | 100% | 79 | 100 | 79 | 100 | Socioambiental | 0% | ok | 0% | São Tomé do Rio Doce (distrito Tumiritinga/MG) |  |
| 1436 | 6.9.2.2.1 | **Engenharia Captação Alternativa (Poço 1)** |  | 189d | 2018-01-30 A | 2018-10-19 A |  | 100% |  | 2018-01-30 | 2018-10-19 | 189d | 2018-01-30 | 2018-10-19 |  |  | 100% | 100 | 100 | 100 | 100 |  | 0% | ok | 0% | São Tomé do Rio Doce (distrito Tumiritinga/MG) |  |
| 1437 | 6.9.2.2.1.1 | Aprovação Plano de Trabalho /abertura OSE - Captação Alternativa - Poço 1 - São Tomé do Rio Doce/MG |  | 152d | 2018-01-30 A | 2018-08-29 A | 26 | 100% |  | 2018-01-30 | 2018-08-29 | 152d | 2018-01-30 | 2018-08-29 |  |  | 100% | 100 | 100 | 100 | 100 |  | 0% | ok | 0% | São Tomé do Rio Doce (distrito Tumiritinga/MG) |  |
| 1438 | 6.9.2.2.1.2 | Dados de Entrada (levantamento de campo, topografia e sondagem) - Captação Alternativa - Poço 1 - São Tomé do Rio Doce/MG |  | 152d | 2018-01-30 A | 2018-08-29 A | 26, 1437FF | 100% |  | 2018-01-30 | 2018-08-29 | 152d | 2018-01-30 | 2018-08-29 |  |  | 100% | 100 | 100 | 100 | 100 |  | 0% | ok | 0% | São Tomé do Rio Doce (distrito Tumiritinga/MG) |  |
| 1439 | 6.9.2.2.1.3 | Elaborar Projeto Executivo - Captação Alternativa - Poço 1 - São Tomé do Rio Doce/MG |  | 103d | 2018-05-30 A | 2018-10-19 A | 1438SS+86d | 100% |  | 2018-05-30 | 2018-10-19 | 103d | 2018-05-30 | 2018-10-19 |  |  | 100% | 100 | 100 | 100 | 100 |  | 0% | ok | 0% | São Tomé do Rio Doce (distrito Tumiritinga/MG) |  |
| 1440 | 6.9.2.2.1.4 | Elaboração do Projeto Executivo - Captação Alternativa - Poço 1 - São Tomé do Rio Doce/MG | milestone | 0d | 2018-10-19 A | 2018-10-19 A | 1439 | 100% |  | 2018-10-19 | 2018-10-19 | 0d | 2018-10-19 | 2018-10-19 |  |  | 100% | 100 | 100 | 100 | 100 |  |  |  |  |  |  |

Notes:
- 1412: 14/Fev19: / - Em reunião de integração entre as áreas nesta data, foi informado pelo Alessandro (Infraestrutura Território II - Calha e Médio Rio Doce) o abaixo: / . RT para contratação de STA Poços Tubulares para: Pedra Corrida, Tumiritinga (sede), Senhora da Penha e São Vitor (GV); e para construções de novas ETA's/UTR's de Senhora da Penha e São Tomé do Rio Doce (Tumiritinga). / . Contrato guarda-chuva existente da Infraestrutura: execução de pequenas melhorias Captação Alternativa).
- 1415: 18/Fev19: / - A construção do poço e o seu STA foi realizada e entregue no período emergencial, por isso, não há previsão de obra/execução no Cronograma Master do PG. / - O projeto referente a captação alternativa constante nesse cronograma visa subsidiar o pedido de outorga de uso de água subterrânea.
- 1427: 06/Dez: / - Validação do diagnóstico/propostas para o abastecimento de São Tomé do Rio Doce através de Ata de Reunião datada de 12/12/17.
- 1429: 22/Nov: / - atividades não realizadas, dependem da construção da captação no Rio Doce conforme cronograma poços atualizado em 5/Nov
- 1430: 23/Nov / - atividade vinculada com o fornecimento de pipa pois o poço é a única fonte de água no distrito / - o poço existente é atualmente a captação principal e vai se tornar a captação alternativa quando a nova ETA estiver operando.
- 1436: 25/Jan19: / - Engenharia considerando no Cronograma para Captação Alternativa, projeto de Melhorias Poço e As Built, concluído em 19/10/18. / 07/Dez: / - No CR ENG (03/12/18) consta "Captação, Melhorias Poço e As built". Estamos entendendo que trata-se da Captação Alternativa. / - Verificar com a ENG se nesse projeto de "Captação, Melhorias Poço e As built" estão previstas melhorias e/ou adequações no sistema de tratamento do poço existente ou se estas melhorias estão no projeto "Nova ETA/URT".
- 1439: 25/Jan19: / - Não foi considerado como input para desenvolvimento do projeto de Captação Alternativa, o Relatório Técnico dos serviços a serem realizados no poço (previsto para 26/04/19). / - Relatório Técnico também não considerado no Cronograma Master do PG.

| ID | WBS | Task | Type | Duration | Start | Finish | Predecessors | Complete | Remaining | Baseline start | Baseline finish | Baseline duration | Baseline 1 start | Baseline 1 finish | Total slack | Free slack | Text3 | Text4 | Text5 | Text7 | Text15 | Text23 | Text25 | Text26 | Text27 | Text29 | Text1 | Indicadores MIR |
| --- | --- | --- | --- | --- | --- | --- | --- | --- | --- | --- | --- | --- | --- | --- | --- | --- | --- | --- | --- | --- | --- | --- | --- | --- | --- | --- | --- | --- |
| 1441 | 6.9.2.3 | **Fundiária** |  | 291d | 2018-11-12 A | 2020-01-10 |  | 61% | 113.49d | 2018-11-12 | 2019-07-15 | 168d | 2018-11-12 | 2019-07-15 | 960d |  | 93% | 63 | 93 | 68 | 93 | Socioambiental | 0% | ok | 0% | São Tomé do Rio Doce (distrito Tumiritinga/MG) |  |  |
| 1442 | 6.9.2.3.1 | Captação Alternativa - Poço 1 - Desimpedimento de área - São Tomé do Rio Doce/MG |  | 291d | 2018-11-12 A | 2020-01-10 | 1426FS+166d | 61% | 113.49d | 2018-11-12 | 2019-07-15 | 168d | 2018-11-12 | 2019-07-15 | 900d | 0d | 93% | 63 | 93 | 68 | 93 | Socioambiental | 0% | Não OK | 0% | São Tomé do Rio Doce (distrito Tumiritinga/MG) |  |  |
| 1443 | 6.9.2.3.2 | Conclusão da Regularização Fundiária para as obras de Melhoria do Sistema de Abastecimento da Localidade - São Tomé do Rio Doce/MG | milestone | 0d | 2020-01-10 | 2020-01-10 | 1442 |  |  | 2019-07-15 | 2019-07-15 | 0d | 2019-07-15 | 2019-07-15 | 960d | 177d | 0% |  |  |  |  |  |  |  |  |  |  |  |
| 1444 | 6.9.2.4 | **Licenciamento** |  | 286d | 2018-11-19 A | 2020-01-10 |  | 76% | 69d | 2018-10-22 | 2020-01-17 | 311d | 2018-10-22 | 2020-01-17 | 960d |  | 55% |  | 55 | 14 | 43 | Socioambiental | 0% | ok | 0% | São Tomé do Rio Doce (distrito Tumiritinga/MG) |  |  |
| 1445 | 6.9.2.4.1 | **Outorga/DAIA para Captação Alternativa (Poço 1) - São Tomé do Rio Doce/MG** |  | 286d | 2018-11-19 A | 2020-01-10 |  | 76% | 69d | 2018-11-19 | 2019-12-16 | 270d |  |  | 960d |  | 0% |  |  |  |  |  |  |  |  |  |  |  |
| 1446 | 6.9.2.4.1.1 | Acompanhar processo junto ao orgão - Outorga/DAIA para Captação Alternativa (Poço 1) - São Tomé do Rio Doce/MG |  | 163d | 2018-11-19 A | 2019-07-15 A | 1433FS-161d | 100% |  | 2018-10-22 | 2020-01-17 | 311d | 2018-10-22 | 2020-01-17 |  |  | 55% |  | 55 |  | 55 |  | 0% | ok | 0% | São Tomé do Rio Doce (distrito Tumiritinga/MG) |  |  |
| 1447 | 6.9.2.4.1.2 | Indeferimento da Outorga para Captação Alternativa - São Tomé do Rio Doce | milestone | 0d | 2019-07-15 A | 2019-07-15 A | 1446 | 100% |  | 2019-07-15 | 2019-07-15 | 0d |  |  |  |  | 0% |  |  |  |  |  |  |  |  |  |  |  |
| 1448 | 6.9.2.4.1.3 | Protocolar defesa junto ao orgão - São Tomé do Rio Doce |  | 1d | 2019-07-16 A | 2019-07-16 A | 1447 | 100% |  | 2019-07-16 | 2019-07-16 | 1d |  |  |  |  | 0% |  |  |  |  |  |  |  |  |  |  |  |
| 1449 | 6.9.2.4.1.4 | Protocolar estudo complementar no orgão ambiental - São Tomé do Rio Doce/MG |  | 32d | 2019-07-17 A | 2019-08-30 A | 1448 | 100% |  | 2019-07-17 | 2019-08-30 | 32d |  |  |  |  | 0% |  |  |  |  |  |  |  |  |  |  |  |
| 1450 | 6.9.2.4.1.5 | Acompanhar processo junto ao orgão - São Tomé do Rio Doce/MG |  | 90d | 2019-09-02 A | 2020-01-10 | 1449 | 23% | 69d | 2019-09-02 | 2019-09-30 | 21d |  |  | 960d | 0d | 0% |  |  |  |  |  |  |  |  |  |  |  |
| 1451 | 6.9.2.4.1.6 | Obtenção da Outorga para captação - Poço 1 - São Tomé do Rio Doce/MG | milestone | 0d | 2020-01-10 | 2020-01-10 | 1450 |  |  | 2019-09-30 | 2019-09-30 | 0d |  |  | 960d | 60d | 0% |  |  |  |  |  |  |  |  |  |  |  |
| 1452 | 6.9.2.5 | **Suprimentos** |  | 33d | 2018-11-08 A | 2018-12-24 A |  | 100% |  | 2018-11-08 | 2019-07-22 | 175d | 2018-11-08 | 2019-07-22 |  |  | 90% | 27 | 90 | 31 | 86 | Socioambiental | 0% | ok | 0% | São Tomé do Rio Doce (distrito Tumiritinga/MG) |  |  |
| 1453 | 6.9.2.5.1 | Captação Alternativa (contrato guarda-chuva existente - Infraestrutura) - São Tomé do Rio Doce/MG |  | 33d | 2018-11-08 A | 2018-12-24 A | 1439 | 100% |  | 2018-11-08 | 2018-12-24 | 33d | 2018-11-08 | 2018-12-24 |  |  | 100% | 100 | 100 | 100 | 100 | Socioambiental | 0% | Não OK | 0% | São Tomé do Rio Doce (distrito Tumiritinga/MG) |  |  |
| 1454 | 6.9.2.5.2 | Conclusão da Contratação de Suprimentos das obras de Melhoria do Sistema de Abastecimento de Água - São Tomé do Rio Doce/MG | milestone | 0d | 2018-12-24 A | 2018-12-24 A | 1453 | 100% |  | 2019-07-22 | 2019-07-22 | 0d | 2019-07-22 | 2019-07-22 |  |  | 0% |  |  |  |  |  |  |  |  |  |  |  |
| 1455 | 6.9.2.6 | **Infraestrutura** |  | 683d | 2018-01-15 A | 2020-09-25 |  | 48% | 353.28d | 2016-10-03 | 2021-11-03 | 1292d | 2016-10-03 | 2021-11-03 | 783d |  | 54% |  | 54 | 100 |  |  | 0% | ok | 0% | São Tomé do Rio Doce (distrito Tumiritinga/MG) |  |  |
| 1456 | 6.9.2.6.1 | **Obras** |  | 683d | 2018-01-15 A | 2020-09-25 |  | 48% | 353.28d | 2016-10-03 | 2020-10-16 | 1032d | 2016-10-03 | 2020-10-16 | 783d |  | 68% | 32 | 68 | 100 | 32 |  |  |  |  |  |  |  |
| 1457 | 6.9.2.6.1.1 | **Captação Alternativa** |  | 566d | 2018-01-15 A | 2020-04-08 |  | 48% | 292.76d | 2018-01-15 | 2020-04-08 | 566d |  |  | 900d |  |  |  |  |  |  |  |  |  |  |  | 8888 |  |
| 1458 | 6.9.2.6.1.1.1 | Executar da Captação Alternativa - Poço 1 - São Tomé do Rio Doce/MG |  | 56d | 2018-01-15 A | 2018-04-02 A | 1440FS-200d | 100% |  | 2018-01-15 | 2018-04-02 | 56d | 2018-01-15 | 2018-04-02 |  |  | 100% | 100 | 100 | 100 | 100 |  |  |  |  |  |  |  |
| 1459 | 6.9.2.6.1.1.2 | Executar obras de urbanização do Poço - Poço 1 - Captação Alternativa - São Tomé do Rio Doce/MG |  | 60d | 2020-01-13 | 2020-04-08 | 1451FF, 1442 |  |  | 2020-01-13 | 2020-04-08 | 60d |  |  | 900d | 117d |  |  |  |  |  |  |  |  |  |  | 8888 |  |
| 1460 | 6.9.2.6.1.2 | Assinatura de Termo de Entrega das Obras de Melhoria do Sistema de Abastecimento de Água - São Tomé do Rio Doce/MG | milestone | 0d | 2020-09-25 | 2020-09-25 | 1458, 1459, 1403, 1411, 1414, 1443, 1454 |  |  | 2020-10-16 | 2020-10-16 | 0d | 2020-10-16 | 2020-10-16 | 783d | 535d | 0% |  |  |  |  |  | 0% | ok | 0% | São Tomé do Rio Doce (distrito Tumiritinga/MG) |  | CA |
| 1461 | 7 | **Território Baixo Rio Doce (MG/ES)** |  | 1620d | 2017-01-26 A | 2023-07-01 |  | 17% | 1342.99d | 2016-03-23 | 2022-02-14 | 1501d | 2016-03-23 | 2022-02-14 | 98d |  | 56% | 23 | 56 | 53 | 43 | Socioambiental | 0% | ok | 0% | São Tomé do Rio Doce (distrito Tumiritinga/MG) |  |  |
| 1462 | 7.1 | **Resplendor/MG (sede)** |  | 1470d | 2017-01-26 A | 2022-11-22 |  | 26% | 1081.84d | 2017-01-26 | 2021-05-03 | 1081d | 2017-01-26 | 2021-05-03 | 248d |  | 57% | 37 | 57 | 65 | 57 | Socioambiental | 0% | ok | 0% | Resplendor/MG (sede) |  |  |
| 1463 | 7.1.1 | **Captação Alternativa** |  | 1032d | 2017-01-26 A | 2021-02-20 |  | 50% | 515.12d | 2017-01-26 | 2020-12-19 | 993d |  |  | 686d |  |  |  |  |  |  |  |  |  |  |  |  |  |
| 1464 | 7.1.1.1 | **Estudos de Concepção do Sistema** |  | 301d | 2017-01-26 A | 2018-03-23 A |  | 100% |  | 2017-01-26 | 2018-03-23 | 302d | 2017-01-26 | 2018-03-23 |  |  | 100% | 99 | 100 | 99 | 100 |  | 0% | ok | 0% | Resplendor/MG (sede) |  |  |
| 1465 | 7.1.1.1.1 | Declaração de Escopo e Premissas de Projeto (DEPP) concluída - Resplendor/MG | milestone | 0d | 2018-03-23 A | 2018-03-23 A | 25, 26 | 100% |  | 2018-03-23 | 2018-03-23 | 0d | 2018-03-23 | 2018-03-23 |  |  | 100% | 100 | 100 | 100 | 100 |  | 0% | ok | 0% | Resplendor/MG (sede) |  |  |
| 1466 | 7.1.1.1.2 | Aprovação das DEPPs pela Operadora e Prefeitura - Resplendor/MG | milestone | 0d | 2018-03-14 A | 2018-03-14 A | 25, 26 | 100% |  | 2018-03-14 | 2018-03-14 | 0d | 2018-03-14 | 2018-03-14 |  |  | 100% | 100 | 100 | 100 | 100 |  | 0% | ok | 0% | Resplendor/MG (sede) |  |  |

Notes:
- 1441: 01/Fev19: / - Imóvel sem registro imobiliário localizado. Aguardando orientações do Jurídico. / - Termos de Autorização desnecessários pois o imóvel já abriga outras estruturas da FR. / - Indenizações necessárias e urgentes! / - Engenharia já disponibilizou projeto para o Fundiário realizar a avaliação imobiliária. / 03/Dez: / - Segundo planilha da Gestão Fundiária, pesquisas cartoriais em andamento. Possivel terra devoluta. Poço + ETA já implantados, mas falta indenizar possuidor. Projetados mais uma ETA + UTR + adutora + captação para o mesmo imóvel. / - Obtenção de Autorização de Acesso p/ estudos e Verificação Documentação das Áreas concluídaS em 18/05 e 27/07/18, respectivamente. Aguardando Laudo de Avaliação. (Enviada RT de compra para Wisney em 31/10 para laudo de avaliação. Poço, áreas para ETAs e Adutora).
- 1452: 14/Fev19: / - Em reunião de integração entre as áreas nesta data, foi informado pelo Alessandro (Infraestrutura Território II - Calha e Médio Rio Doce) o abaixo: / . RT para contratação de STA Poços Tubulares para: Pedra Corrida, Tumiritinga (sede), Senhora da Penha e São Vitor (GV); e para construções de novas ETA's/UTR's de Senhora da Penha e São Tomé do Rio Doce (Tumiritinga). / . Contrato guarda-chuva existente da Infraestrutura: execução de pequenas melhorias Captação Alternativa).
- 1455: 18/Fev19: / - A construção do poço e o seu STA foi realizada e entregue no período emergencial, por isso, não há previsão de obra/execução no Cronograma Master do PG. / - O projeto referente a captação alternativa constante nesse cronograma visa subsidiar o pedido de outorga de uso de água subterrânea.
- 1466: 10/Dez / - Aprovação por parte da COPASA. Pendente Prefeitura (a população não aceita a retomada do Doce).

| ID | WBS | Task | Type | Duration | Start | Finish | Predecessors | Complete | Baseline start | Baseline finish | Baseline duration | Baseline 1 start | Baseline 1 finish | Text3 | Text4 | Text5 | Text7 | Text15 | Text25 | Text26 | Text27 | Text29 | Text23 | Text9 |
| --- | --- | --- | --- | --- | --- | --- | --- | --- | --- | --- | --- | --- | --- | --- | --- | --- | --- | --- | --- | --- | --- | --- | --- | --- |
| 1467 | 7.1.1.1.3 | **Captações Subterrâneas - Serviços em Poço Tubular Existente** |  | 82d | 2017-01-26 A | 2017-05-19 A |  | 100% | 2017-01-26 | 2017-05-19 | 82d | 2017-01-26 | 2017-05-19 | 100% | 100 | 100 | 100 | 100 | 0% | ok | 0% | Resplendor/MG (sede) |  |  |
| 1468 | 7.1.1.1.3.1 | Realizar Perfilagem e Recuperação - Poço C1 - Resplendor/MG |  | 7d | 2017-01-26 A | 2017-02-03 A | 24 | 100% | 2017-01-26 | 2017-02-03 | 7d | 2017-01-26 | 2017-02-03 | 100% | 100 | 100 | 100 | 100 | 0% | ok | 0% | Resplendor/MG (sede) |  |  |
| 1469 | 7.1.1.1.3.2 | Elaborar Relatório Técnico - Poço C1 - Resplendor/MG |  | 21d | 2017-02-06 A | 2017-03-06 A | 1468 | 100% | 2017-02-06 | 2017-03-06 | 21d | 2017-02-06 | 2017-03-06 | 100% | 100 | 100 | 100 | 100 | 0% | ok | 0% | Resplendor/MG (sede) |  |  |
| 1470 | 7.1.1.1.3.3 | Realizar Laudo dos Serviços de Coleta e Análise de Água - Poço C1 - Resplendor/MG |  | 79d | 2017-01-31 A | 2017-05-19 A | 1468SS+3d | 100% | 2017-01-31 | 2017-05-19 | 79d | 2017-01-31 | 2017-05-19 | 100% | 100 | 100 | 100 | 100 | 0% | ok | 0% | Resplendor/MG (sede) |  |  |
| 1471 | 7.1.1.1.3.4 | Conclusão dos Serviços em poço tubular - Poço C1 - Resplendor/MG | milestone | 0d | 2017-05-19 A | 2017-05-19 A | 1470 | 100% | 2017-05-19 | 2017-05-19 | 0d | 2017-05-19 | 2017-05-19 | 100% | 100 | 100 | 100 | 100 |  |  |  |  |  |  |
| 1472 | 7.1.1.2 | **Engenharia Básica e Detalhada** |  | 357d | 2017-10-23 A | 2019-03-11 A |  | 100% | 2017-10-23 | 2019-06-19 | 426d | 2017-10-23 | 2019-06-19 | 100% | 71 | 100 | 72 | 99 | 0% | ok | 0% | Resplendor/MG (sede) | Socioambiental |  |
| 1473 | 7.1.1.2.1 | **Engenharia Captação Alternativa (Poço C2)** |  | 202d | 2017-10-23 A | 2018-07-31 A |  | 100% | 2017-10-23 | 2018-07-31 | 202d | 2017-10-23 | 2018-07-31 | 100% | 100 | 100 | 100 | 100 | 0% | ok | 0% | Resplendor/MG (sede) | Socioambiental |  |
| 1474 | 7.1.1.2.1.1 | Aprovar Plano de Trabalho e abrir OSE - Captação Alternativa - Poço C2 - Resplendor/MG |  | 11d | 2018-03-23 A | 2018-04-06 A | 1465 | 100% | 2018-03-23 | 2018-04-06 | 11d | 2018-03-23 | 2018-04-06 | 100% | 100 | 100 | 100 | 100 |  |  |  |  |  |  |
| 1475 | 7.1.1.2.1.2 | Realizar Levantamento de Campo - Captação Alternativa - Poço C2 - Resplendor/MG |  | 6d | 2018-04-09 A | 2018-04-16 A | 1474 | 100% | 2018-04-09 | 2018-04-16 | 6d | 2018-04-09 | 2018-04-16 | 100% | 100 | 100 | 100 | 100 |  |  |  |  |  |  |
| 1476 | 7.1.1.2.1.3 | Elaborar arranjo para obtenção de Dados de Entrada Licenciamento e Fundiário - Captação Alternativa - Poço C2 - Resplendor/MG |  | 30d | 2018-04-17 A | 2018-05-28 A | 1475 | 100% | 2018-04-17 | 2018-05-28 | 30d | 2018-04-17 | 2018-05-28 | 100% | 100 | 100 | 100 | 100 |  |  |  |  |  |  |
| 1477 | 7.1.1.2.1.4 | Emitir RT/PQ para Suprimentos - Captação Alternativa - Poço C2 - Resplendor/MG |  | 10d | 2018-06-26 A | 2018-07-09 A | 1478FF | 100% | 2018-06-26 | 2018-07-09 | 10d | 2018-06-26 | 2018-07-09 | 100% | 100 | 100 | 100 | 100 |  |  |  |  |  |  |
| 1478 | 7.1.1.2.1.5 | Elaborar Projeto Executivo As Built do Poço Existente - Captação Alternativa - Poço C2 - Resplendor/MG |  | 202d | 2017-10-23 A | 2018-07-31 A | 1475, 1476FF | 100% | 2017-10-23 | 2018-07-31 | 202d | 2017-10-23 | 2018-07-31 | 100% | 100 | 100 | 100 | 100 | 0% | Não OK | 0% | Resplendor/MG (sede) | Socioambiental |  |
| 1479 | 7.1.1.2.1.6 | Elaboração do Projeto Executivo - Captação Alternativa - Poço C2 - Resplendor/MG | milestone | 0d | 2018-07-31 A | 2018-07-31 A | 1478, 1477 | 100% | 2018-07-31 | 2018-07-31 | 0d | 2018-07-31 | 2018-07-31 | 100% | 100 | 100 | 100 | 100 |  |  |  |  |  |  |
| 1480 | 7.1.1.2.2 | **Engenharia Captação Alternativa (Poço C1)** |  | 260d | 2018-03-07 A | 2019-03-11 A |  | 100% | 2018-03-07 | 2019-06-19 | 329d | 2018-03-07 | 2019-06-19 | 100% | 93 | 100 | 93 | 100 | 0% | ok | 0% | Resplendor/MG (sede) | Socioambiental |  |
| 1481 | 7.1.1.2.2.1 | Aprovar Plano de Trabalho e abrir OSE (Poço C1) - Captação Alternativa - Poço C1 - Resplendor/MG |  | 22d | 2018-03-07 A | 2018-04-05 A | 26 | 100% | 2018-03-07 | 2018-04-05 | 22d | 2018-03-07 | 2018-04-05 | 100% | 100 | 100 | 100 | 100 | 0% | ok | 0% | Resplendor/MG (sede) |  |  |
| 1482 | 7.1.1.2.2.2 | Realizar Levantamento de Campo - Captação Alternativa - Poço C1 - Resplendor/MG |  | 5d | 2018-04-13 A | 2018-04-19 A | 1481 | 100% | 2018-04-13 | 2018-04-19 | 5d | 2018-04-13 | 2018-04-19 | 100% | 100 | 100 | 100 | 100 | 0% | Não OK | 0% | Resplendor/MG (sede) | Socioambiental | Não OK |
| 1483 | 7.1.1.2.2.3 | Realizar Sondagem - Captação Alternativa - Poço C1 - Resplendor/MG |  | 40d | 2018-05-18 A | 2018-07-12 A | 1481 | 100% | 2018-05-18 | 2018-07-12 | 40d | 2018-05-18 | 2018-07-12 | 100% | 100 | 100 | 100 | 100 |  |  |  |  |  |  |
| 1484 | 7.1.1.2.2.4 | Executar Topografia - Captação Alternativa - Poço C1 - Resplendor/MG |  | 40d | 2018-05-18 A | 2018-07-12 A | 1481 | 100% | 2018-05-18 | 2018-07-12 | 40d | 2018-05-18 | 2018-07-12 | 100% | 100 | 100 | 100 | 100 |  |  |  |  |  |  |
| 1485 | 7.1.1.2.2.5 | Elaborar arranjo para obtenção de Dados de Entrada Licenciamento e Fundiário (Poço C1) - Captação Alternativa - Poço C1 - Resplendor/MG |  | 10d | 2018-05-07 A | 2018-05-18 A | 1482, 1483, 1484 | 100% | 2018-05-07 | 2018-05-18 | 10d | 2018-05-07 | 2018-05-18 | 100% | 100 | 100 | 100 | 100 | 0% | ok | 0% | Resplendor/MG (sede) |  |  |
| 1486 | 7.1.1.2.2.6 | Emitir RT/PQ para Suprimentos - Captação Alternativa - Poço C1 - Resplendor/MG |  | 71d | 2018-11-27 A | 2019-03-11 A | 1487FF | 100% | 2018-11-27 | 2019-03-11 | 71d | 2018-11-27 | 2019-03-11 | 100% | 100 | 100 | 100 | 100 |  |  |  |  |  |  |
| 1487 | 7.1.1.2.2.7 | Elaborar Projeto Executivo (Poço C1) - Captação Alternativa - Poço C1 - Resplendor/MG |  | 215d | 2018-05-09 A | 2019-03-11 A | 1469, 1485 | 100% | 2018-05-09 | 2019-03-11 | 215d | 2018-05-09 | 2019-03-11 | 100% | 100 | 100 | 100 | 100 | 0% | Não OK | 0% | Resplendor/MG (sede) | Socioambiental | Não OK |
| 1488 | 7.1.1.2.2.8 | Elaboração do Projeto Executivo - Captação Alternativa - Poço C1 - Resplendor/MG | milestone | 0d | 2019-03-11 A | 2019-03-11 A | 1487, 1486 | 100% | 2019-03-11 | 2019-03-11 | 0d | 2019-03-11 | 2019-03-11 | 100% | 100 | 100 | 100 | 100 |  |  |  |  |  |  |
| 1489 | 7.1.1.3 | **Licenciamento** |  | 386d | 2017-12-12 A | 2019-06-13 A |  | 100% | 2017-12-12 | 2019-09-24 | 457d | 2017-12-12 | 2019-09-24 | 86% | 51 | 86 | 61 | 83 | 0% | ok | 0% | Resplendor/MG (sede) | Socioambiental |  |
| 1490 | 7.1.1.3.1 | Captação Alternativa - Dispensa de Licença - Poços C01, C02 e C03 (Aut. Municipal para obras) - Resplendor/MG |  | 1d | 2017-12-12 A | 2017-12-12 A | 26FS+16d | 100% | 2017-12-12 | 2017-12-12 | 1d | 2017-12-12 | 2017-12-12 | 100% | 100 | 100 | 100 | 100 | 0% | ok | 0% | Resplendor/MG (sede) |  |  |
| 1491 | 7.1.1.3.2 | Outorga para Captação Alternativa (Poço C01) - Resplendor/MG |  | 185d | 2018-09-19 A | 2019-06-13 A | 1469, 1485 | 100% | 2018-09-19 | 2019-04-24 | 150d | 2018-09-19 | 2019-04-24 | 100% | 100 | 100 | 100 | 100 | 0% | ok | 0% | Resplendor/MG (sede) |  |  |
| 1492 | 7.1.1.3.3 | Conclusão do Licenciamento Ambiental da Localidade - Resplendor/MG | milestone | 0d | 2019-06-13 A | 2019-06-13 A | 1490, 1491 | 100% | 2019-09-24 | 2019-09-24 | 0d | 2019-09-24 | 2019-09-24 | 0% |  |  |  |  |  |  |  |  |  |  |

Notes:
- 1470: 10/Dez / - Foi realizada mais de uma coleta. As datas de início e fim constantes nesse CR referem a dois laudos emitidos.
- 1472: 10/Dez / - Projetos de Captação Principal, Alternativa e Melhorias de ETA estão sendo desenvolvidos por uma empresa sob a gestão da Infra, em regime EPC (farão a obra também). / - Há um projeto de Estudo de Demanda (captação alternativa) e outro de Melhorias de ETA que estão sendo desenvolvidos pela ENG matricial da FR em complementação.
- 1473: 25/04/19: No cronograma da engenharia: / CAPTAÇÃO ALTERNATIVA - INTERLIGAÇÃO POÇOS (PROJETO, FORNECIMENTO E OBRAS) / 25/Jan19: / - Não há projeto sendo desenvolvido pela Engenharia Matricial referente a esta Captação. / - As datas constantes aqui referem-se ao projeto em regime EPC. / 10/Dez / - Contrato em regime EPC para as melhorias no SAA de Resplendor, sob gestão da Infra. Solicitar à Infra o status do projeto de captação principal / ver no CR Infra atualizado. / 08/Dez / - Projeto não previsto no CR ENG (03/12/18) por ser de responsabilidade da Infra. / - Considerado no CR ENG projeto de "Estudo de Demanda Elétrica".
- 1480: 25/Jan19: / - Projeto de Interligação Poços (Projeto, Fornecimento e Obras) concluído em 31/07/18. / - Outros 2 projetos referentes a Captação Alternativa estão em desenvolvimento pela Engenharia e suas datas estão sendo consideradas no Cronograma Master do PG: o de Sistema de Tratamento Poços e o de Estudo de Demanda Elétrica. / 10/Dez / - Contrato em regime EPC para as melhorias no SAA de Resplendor, sob gestão da Infra. Solicitar à Infra o status do projeto de captação alternativa / ver no CR Infra atualizado. / 27/Nov: / - Segundo José Alaércio, projeto de captação e interligação dos poços com a nova elevatória (poço C1) concluído (contrato não pertencente a Engenharia). Mateus irá solicitar o projeto à Infra.
- 1481: 30/Jan19: / - Plano de Trabalho do projeto de Sistema de Tratamento Poços iniciado em 07/03 e concluído em 05/04/18; do de Estudo Demanda Elétrica iniciado em 23/11/18 e concluído em 09/01/19.
- 1482: 30/Jan19: / - Projeto de Sistema de Tratamento Poços: Levantamento de campo inciado em 13/04 e concluído em 19/04/18; Topografia e Sondagem iniciados em 18/05 e concluídos em 12/07/18. / - Estudo Demanda Elétrica: Levantamento de campo previsto pra iniciar em 04/02 e finalizar em 08/02/19.
- 1485: 30/Jan19: / - Projeto Conceitual referente ao projeto de Sistema de Tratamento Poços. Não foi considerado no Cronograma da Engenharia para o de Estudo Demanda Elétrica.
- 1487: 30/Jan19: / - Projeto Executivo do Sistema de Tratamento Poços iniciado em 09/05/18 com previsão de conclusão em 31/01/19; do de Estudo Demanda Elétrica (elaboração do projeto e As Built) previsto pra iniciar em 11/02 e concluir em 15/03/19.
- 1489: 13/Dez / - Licenciamento irá confirmar com a COPASA se já possuem outorga para captação no rio Doce.
- 1491: 13/Dez / - Não linkar na obra por se tratar de emergencial. Linkar na operação. / - Fundiário ok para essa licença.

| ID | WBS | Task | Type | Duration | Start | Finish | Predecessors | Complete | Remaining | Baseline start | Baseline finish | Baseline duration | Baseline 1 start | Baseline 1 finish | Total slack | Free slack | Text3 | Text4 | Text5 | Text7 | Text15 | Text25 | Text26 | Text27 | Text29 | Text1 | Indicadores MIR | Text23 | Text9 |
| --- | --- | --- | --- | --- | --- | --- | --- | --- | --- | --- | --- | --- | --- | --- | --- | --- | --- | --- | --- | --- | --- | --- | --- | --- | --- | --- | --- | --- | --- |
| 1493 | 7.1.1.4 | **Infraestrutura** |  | 726d | 2018-03-30 A | 2021-02-20 |  | 25% | 547.85d | 2018-03-30 | 2021-05-03 | 775d | 2018-03-30 | 2021-05-03 | 686d |  | 41% | 17 | 41 | 59 | 29 | 0% | ok | 0% | Resplendor/MG (sede) |  |  |  |  |
| 1494 | 7.1.1.4.1 | **Obras** |  | 482d | 2018-03-30 A | 2020-02-21 |  | 95% | 24.1d | 2018-03-30 | 2020-04-14 | 515d | 2018-03-30 | 2020-04-14 | 930d |  | 61% | 42 | 61 | 145 | 29 |  |  |  |  |  |  |  |  |
| 1495 | 7.1.1.4.1.1 | **Captação Alternativa** |  | 482d | 2018-03-30 A | 2020-02-21 |  | 95% | 24.1d | 2018-03-30 | 2019-11-08 | 412d |  |  | 930d |  |  |  |  |  |  |  |  |  |  | 8888 |  |  |  |
| 1496 | 7.1.1.4.1.1.1 | Executar Captação Alternativa (Poço C1 e C2) - Resplendor/MG |  | 482d | 2018-03-30 A | 2020-02-21 | 1487, 1490 | 95% | 24.1d | 2018-03-30 | 2019-08-30 | 362d | 2018-03-30 | 2019-11-12 | 682d | 0d | 76% | 96 | 76 | 126 | 76 | 0% | ok | 0% | Resplendor/MG (sede) |  |  |  |  |
| 1497 | 7.1.1.4.1.1.2 | Conclusão das Obras de Captação Alternativa (Poço C1 e C2) - Resplendor/MG | milestone | 0d | 2020-02-21 | 2020-02-21 | 1496 |  |  | 2019-08-30 | 2019-08-30 | 0d |  |  | 930d | 0d |  |  |  |  |  |  |  |  |  |  | CA |  |  |
| 1498 | 7.1.1.4.1.2 | Assinatura de Termo de Entrega das Obras de Melhoria do Sistema de Abastecimento de Água - Resplendor/MG | milestone | 0d | 2020-02-21 | 2020-02-21 | 1496, 1497, 1492, 1488, 1479, 1471 |  |  | 2020-04-14 | 2020-04-14 | 0d | 2020-04-14 | 2020-04-14 | 930d | 682d | 0% |  |  |  |  | 0% | ok | 0% | Resplendor/MG (sede) |  |  |  |  |
| 1499 | 7.1.1.4.2 | **Operação** |  | 244d | 2020-02-21 | 2021-02-20 |  |  |  | 2020-04-15 | 2021-05-03 | 260d | 2020-04-15 | 2021-05-03 | 682d |  | 0% |  |  |  |  | 0% | ok | 0% | Resplendor/MG (sede) |  |  |  |  |
| 1500 | 7.1.1.4.2.1 | Realizar Treinamento Operacional do Sistema - Resplendor/MG |  | 5d | 2020-02-27 | 2020-03-04 | 1496 |  |  | 2020-04-15 | 2020-04-22 | 5d | 2020-04-15 | 2020-04-22 | 911d | 0d | 0% |  |  |  |  | 0% | ok | 0% | Resplendor/MG (sede) |  |  |  |  |
| 1501 | 7.1.1.4.2.2 | Realizar Testes e Pré-operação - Resplendor/MG |  | 14d | 2020-03-05 | 2020-03-24 | 1500 |  |  | 2020-04-23 | 2020-05-13 | 14d | 2020-04-23 | 2020-05-13 | 911d |  | 0% |  |  |  |  | 0% | ok | 0% | Resplendor/MG (sede) |  |  |  |  |
| 1502 | 7.1.1.4.2.3 | Realizar Acompanhamento da Funcionalidade do Sistema - Captação Alternativa - Resplendor/MG (sede) |  | 365ed | 2020-02-21 | 2021-02-20 | 1504SS |  |  | 2019-12-20 | 2020-12-19 | 365ed |  |  | 3015d |  |  |  |  |  |  |  |  |  |  |  |  |  |  |
| 1503 | 7.1.1.4.2.4 | **Operação Assistida** |  | 58d | 2020-02-21 | 2020-05-21 |  |  |  | 2020-04-15 | 2020-07-16 | 64d | 2020-04-15 | 2020-07-16 | 682d |  | 0% |  |  |  |  | 0% | ok | 0% | Resplendor/MG (sede) |  |  |  |  |
| 1504 | 7.1.1.4.2.4.1 | Realizar Operação Assistida - Resplendor/MG |  | 90ed | 2020-02-21 | 2020-05-21 | 1496 |  |  | 2020-04-15 | 2020-07-16 | 3.2mo | 2020-04-15 | 2020-07-16 | 3015d | 0d | 0% |  |  |  |  | 0% | ok | 0% | Resplendor/MG (sede) |  |  |  |  |
| 1505 | 7.1.2 | **Melhorias de ETA e na Captação Principal** |  | 828d | 2018-03-14 A | 2021-06-30 |  | 20% | 660.16d | 2017-01-26 | 2021-05-03 | 1081d |  |  | 596d |  |  |  |  |  |  |  |  |  |  |  |  |  |  |
| 1506 | 7.1.2.1 | **Engenharia** |  | 438d | 2018-03-14 A | 2019-11-29 A |  | 100% |  | 2017-01-26 | 2019-06-19 | 618d | 2017-01-26 | 2019-06-19 |  |  | 100% | 73 | 100 | 73 | 100 |  | ok |  |  |  |  | Socioambiental |  |
| 1507 | 7.1.2.1.1 | **Estudos de Concepção do Sistema** |  | 7d | 2018-03-14 A | 2018-03-23 A |  | 100% |  | 2017-01-26 | 2018-03-23 | 302d | 2017-01-26 | 2018-03-23 |  |  | 100% | 99 | 100 | 99 | 100 | 0% | ok | 0% | Resplendor/MG (sede) |  |  |  |  |
| 1508 | 7.1.2.1.1.1 | Declaração de Escopo e Premissas de Projeto (DEPP) concluída - Resplendor/MG | milestone | 0d | 2018-03-23 A | 2018-03-23 A | 25, 26 | 100% |  | 2018-03-23 | 2018-03-23 | 0d | 2018-03-23 | 2018-03-23 |  |  | 100% | 100 | 100 | 100 | 100 | 0% | ok | 0% | Resplendor/MG (sede) |  |  |  |  |
| 1509 | 7.1.2.1.1.2 | Aprovação das DEPPs pela Operadora e Prefeitura - Resplendor/MG | milestone | 0d | 2018-03-14 A | 2018-03-14 A | 25, 26 | 100% |  | 2018-03-14 | 2018-03-14 | 0d | 2018-03-14 | 2018-03-14 |  |  | 100% | 100 | 100 | 100 | 100 | 0% | ok | 0% | Resplendor/MG (sede) |  |  |  |  |
| 1510 | 7.1.2.1.2 | **Engenharia Básica e Detalhada** |  | 391d | 2018-05-18 A | 2019-11-29 A |  | 100% |  | 2017-10-23 | 2019-06-19 | 426d | 2017-10-23 | 2019-06-19 |  |  | 100% | 71 | 100 | 72 | 99 | 0% | ok | 0% | Resplendor/MG (sede) |  |  | Socioambiental |  |
| 1511 | 7.1.2.1.2.1 | **Engenharia Melhorias ETA - SE 32247** |  | 391d | 2018-05-18 A | 2019-11-29 A |  | 100% |  | 2018-05-18 | 2019-05-22 | 257d | 2018-05-18 | 2019-05-22 |  |  | 100% | 32 | 100 | 32 | 100 | 0% | ok | 0% | Resplendor/MG (sede) |  |  | Socioambiental |  |
| 1512 | 7.1.2.1.2.1.1 | Aprovar Plano de Trabalho e abrir OSE - Melhorias na ETA - Resplendor/MG |  | 10d | 2018-10-29 A | 2018-11-09 A | 1508 | 100% |  | 2018-10-29 | 2018-11-09 | 10d | 2018-10-29 | 2018-11-09 |  |  | 100% | 100 | 100 | 100 | 100 | 0% | Não OK | 0% | Resplendor/MG (sede) |  |  | Socioambiental | Não OK |
| 1513 | 7.1.2.1.2.1.2 | Realizar Levantamento de Campo - Melhorias na ETA - Resplendor/MG |  | 2d | 2019-01-22 A | 2019-01-23 A | 1512FS+51d | 100% |  | 2019-01-22 | 2019-01-23 | 2d | 2019-01-22 | 2019-01-23 |  |  | 100% | 100 | 100 | 100 | 100 | 0% | Não OK | 0% | Resplendor/MG (sede) |  |  | Socioambiental |  |
| 1514 | 7.1.2.1.2.1.3 | Realizar Sondagem - Melhorias na ETA - Resplendor/MG |  | 40d | 2018-05-18 A | 2018-07-12 A | 1512 | 100% |  | 2018-05-18 | 2018-07-12 | 40d | 2018-05-18 | 2018-07-12 |  |  | 100% | 100 | 100 | 100 | 100 |  |  |  |  |  |  |  |  |
| 1515 | 7.1.2.1.2.1.4 | Emitir RT/PQ para Suprimentos - Melhorias na ETA - Resplendor/MG |  | 10d | 2019-11-18 A | 2019-11-29 A | 1516FF | 100% |  | 2019-04-26 | 2019-05-10 | 10d | 2019-04-26 | 2019-05-10 |  |  | 100% |  | 100 |  | 100 |  |  |  |  |  |  |  |  |
| 1516 | 7.1.2.1.2.1.5 | Elaborar Projeto Executivo - Melhorias na ETA - Resplendor/MG |  | 207d | 2019-02-01 A | 2019-11-29 A | 1513, 1514 | 100% |  | 2019-02-01 | 2019-05-10 | 65d | 2019-02-01 | 2019-05-10 |  |  | 100% | 25 | 100 | 25 | 100 | 0% | Não OK | 0% | Resplendor/MG (sede) |  |  | Socioambiental |  |
| 1517 | 7.1.2.1.2.1.6 | Elaboração do Projeto Executivo - Melhorias na ETA - Resplendor/MG | milestone | 0d | 2019-11-29 A | 2019-11-29 A | 1516 | 100% |  | 2019-05-22 | 2019-05-22 | 0d | 2019-05-22 | 2019-05-22 |  |  | 100% |  | 100 |  | 100 |  |  |  |  |  |  |  |  |

Notes:
- 1496: 04/Dez: / - Considerando aqui, execução de "Obras Interligação Dos Pçs E Adutora", bem como "Obras - Captação Poços E ETA / UTR", constantes no cronograma de Infra. Verificar se esse entendimento está correto.
- 1509: 10/Dez / - Aprovação por parte da COPASA. Pendente Prefeitura (a população não aceita a retomada do Doce).
- 1510: 10/Dez / - Projetos de Captação Principal, Alternativa e Melhorias de ETA estão sendo desenvolvidos por uma empresa sob a gestão da Infra, em regime EPC (farão a obra também). / - Há um projeto de Estudo de Demanda (captação alternativa) e outro de Melhorias de ETA que estão sendo desenvolvidos pela ENG matricial da FR em complementação.
- 1511: 10/Dez / - Contrato em regime EPC para as melhorias no SAA de Resplendor, sob gestão da Infra. Solicitar à Infra o status do projeto de Melhorias de ETA / ver no CR Infra atualizado. / - Considerado no CR ENG projeto de "Melhorias na ETA".
- 1513: 25/Jan19: / - Levantamento de campo iniciado em 22/01 e concluído em 23/01/19; Sondagem prevista para iniciar em 01/03 e finalizar em 04/04/19.

| ID | WBS | Task | Type | Duration | Start | Finish | Predecessors | Complete | Remaining | Baseline start | Baseline finish | Baseline duration | Baseline 1 start | Baseline 1 finish | Total slack | Free slack | Text3 | Text5 | Text15 | Text25 | Text26 | Text27 | Text29 | Text4 | Text7 | Text1 | Indicadores MIR |
| --- | --- | --- | --- | --- | --- | --- | --- | --- | --- | --- | --- | --- | --- | --- | --- | --- | --- | --- | --- | --- | --- | --- | --- | --- | --- | --- | --- |
| 1518 | 7.1.2.2 | **Suprimentos** |  | 86d | 2019-12-02 A | 2020-04-08 |  | 8% | 79.5d | 2019-05-22 | 2019-09-24 | 88d | 2019-05-22 | 2019-09-24 | 900d |  | 30% | 30 | 30 | 0% | ok | 0% | Resplendor/MG (sede) |  |  |  |  |
| 1519 | 7.1.2.2.1 | Verificar se obra está incluída no CGC existente - Processo contratação Captações e ETA - Resplendor/MG |  | 26d | 2019-12-02 A | 2020-01-10 | 1515, 1516 | 25% | 19.5d | 2019-05-22 | 2019-09-24 | 88d | 2019-05-22 | 2019-09-24 | 597d | 0d | 30% | 30 | 30 | 0% | ok | 0% | Resplendor/MG (sede) |  |  |  |  |
| 1520 | 7.1.2.2.2 | Processo de contratação - Melhorias na ETA - Resplendor/MG |  | 60d | 2020-01-13 | 2020-04-08 | 1519 |  |  | 2019-11-19 | 2020-03-30 | 88d |  |  | 564d | 0d |  |  |  |  |  |  |  |  |  |  |  |
| 1521 | 7.1.2.2.3 | Conclusão da Contratação de Suprimentos das obras de Melhoria do Sistema de Abastecimento de Água - Resplendor/MG | milestone | 0d | 2020-04-08 | 2020-04-08 | 1520 |  |  | 2019-09-24 | 2019-09-24 | 0d | 2019-09-24 | 2019-09-24 | 900d | 88d | 0% |  |  |  |  |  |  |  |  |  |  |
| 1522 | 7.1.2.3 | **Infraestrutura** |  | 632d | 2018-12-13 A | 2021-06-30 |  | 7% | 586.73d | 2018-03-30 | 2021-05-03 | 775d | 2018-03-30 | 2021-05-03 | 596d |  | 41% | 41 | 29 | 0% | ok | 0% | Resplendor/MG (sede) | 17 | 59 |  |  |
| 1523 | 7.1.2.3.1 | **Obras** |  | 383d | 2018-12-13 A | 2020-06-30 |  | 66% | 130.88d | 2018-03-30 | 2020-04-14 | 515d | 2018-03-30 | 2020-04-14 | 845d |  | 61% | 61 | 29 |  |  |  |  | 42 | 145 |  |  |
| 1524 | 7.1.2.3.1.1 | Executar Captação Principal - Balsa de Captação do Rio Doce - Resplendor/MG |  | 55d | 2019-10-28 A | 2020-01-17 | 1508 | 95% | 2.75d | 2019-10-28 | 2020-01-24 | 60d |  |  | 955d | 110d |  |  |  |  |  |  |  |  |  |  |  |
| 1525 | 7.1.2.3.1.2 | **Melhorias na ETA** |  | 383d | 2018-12-13 A | 2020-06-30 |  | 52% | 184.78d | 2018-12-13 | 2020-06-16 | 373d |  |  | 597d |  |  |  |  |  |  |  |  |  |  | 8888 |  |
| 1526 | 7.1.2.3.1.2.1 | Executar Melhorias na ETA (Serviço de adequação da elevatória) - Resplendor/MG |  | 59d | 2018-12-13 A | 2019-03-11 A | 1508FS+189d | 100% |  | 2018-05-03 | 2019-09-27 | 358d | 2018-05-03 | 2019-09-27 |  |  | 82% | 82 | 82 | 0% | ok | 0% | Resplendor/MG (sede) | 100 | 122 |  |  |
| 1527 | 7.1.2.3.1.2.2 | Executar Melhorias de ETA - Resplendor/MG |  | 55d | 2020-04-09 | 2020-06-30 | 1515, 1517, 1519, 1520 |  |  | 2019-07-25 | 2020-01-31 | 131d |  |  | 597d | 0d | 0% |  |  |  |  |  |  |  |  |  | ETA |
| 1528 | 7.1.2.3.1.2.3 | Conclusão das Obras de Melhorias em ETA - Resplendor/MG | milestone | 0d | 2020-06-30 | 2020-06-30 | 1526, 1527 |  |  | 2020-01-31 | 2020-01-31 | 0d |  |  | 597d | 0d |  |  |  |  |  |  |  |  |  |  |  |
| 1529 | 7.1.2.3.1.3 | Assinatura de Termo de Entrega das Obras de Melhoria do Sistema de Abastecimento de Água - Resplendor/MG | milestone | 0d | 2020-06-30 | 2020-06-30 | 1524, 1526, 1527, 1528, 1521 |  |  | 2020-04-14 | 2020-04-14 | 0d | 2020-04-14 | 2020-04-14 | 845d | 597d | 0% |  |  | 0% | ok | 0% | Resplendor/MG (sede) |  |  |  |  |
| 1530 | 7.1.2.3.2 | **Operação** |  | 249d | 2020-06-30 | 2021-06-30 |  |  |  | 2020-04-15 | 2021-05-03 | 260d | 2020-04-15 | 2021-05-03 | 596d |  | 0% |  |  | 0% | ok | 0% | Resplendor/MG (sede) |  |  |  |  |
| 1531 | 7.1.2.3.2.1 | Realizar Treinamento Operacional do Sistema - Resplendor/MG |  | 5d | 2020-07-01 | 2020-07-07 | 1526, 1527, 1528 |  |  | 2020-04-15 | 2020-04-22 | 5d | 2020-04-15 | 2020-04-22 | 826d | 0d | 0% |  |  | 0% | ok | 0% | Resplendor/MG (sede) |  |  |  |  |
| 1532 | 7.1.2.3.2.2 | Realizar Testes e Pré-operação - Resplendor/MG |  | 14d | 2020-07-08 | 2020-07-27 | 1531 |  |  | 2020-04-23 | 2020-05-13 | 14d | 2020-04-23 | 2020-05-13 | 826d |  | 0% |  |  | 0% | ok | 0% | Resplendor/MG (sede) |  |  |  |  |
| 1533 | 7.1.2.3.2.3 | Realizar Acompanhamento da Funcionalidade do Sistema - Melhorias de ETA e na Captação Principal - Resplendor/MG (sede) |  | 365ed | 2020-06-30 | 2021-06-30 | 1535SS |  |  | 2020-04-15 | 2021-05-03 | 260d |  |  | 2625d |  |  |  |  |  |  |  |  |  |  |  |  |
| 1534 | 7.1.2.3.2.4 | **Operação Assistida** |  | 63d | 2020-06-30 | 2020-09-28 |  |  |  | 2020-04-15 | 2020-07-16 | 64d | 2020-04-15 | 2020-07-16 | 596d |  | 0% |  |  | 0% | ok | 0% | Resplendor/MG (sede) |  |  |  |  |
| 1535 | 7.1.2.3.2.4.1 | Realizar Operação Assistida - Resplendor/MG |  | 90ed | 2020-06-30 | 2020-09-28 | 1526, 1528 |  |  | 2020-04-15 | 2020-07-16 | 3.2mo | 2020-04-15 | 2020-07-16 | 2625d | 0d | 0% |  |  | 0% | ok | 0% | Resplendor/MG (sede) |  |  |  |  |
| 1536 | 7.1.3 | **UTR** |  | 1388d | 2017-05-19 A | 2022-11-22 |  |  | 1383.4d | 2017-01-26 | 2021-05-03 | 1081d |  |  | 248d |  |  |  |  |  |  |  |  |  |  |  |  |
| 1537 | 7.1.3.1 | **Estudos de Concepção do Sistema** |  | 523d | 2017-05-19 A | 2019-05-31 A |  | 100% |  | 2017-01-26 | 2018-03-23 | 302d | 2017-01-26 | 2018-03-23 |  |  | 100% | 100 | 100 | 0% | ok | 0% | Resplendor/MG (sede) | 99 | 99 |  |  |
| 1538 | 7.1.3.1.1 | Declaração de Escopo e Premissas de Projeto (DEPP) concluída - Resplendor/MG | milestone | 0d | 2018-03-23 A | 2018-03-23 A | 25, 26 | 100% |  | 2018-03-23 | 2018-03-23 | 0d | 2018-03-23 | 2018-03-23 |  |  | 100% | 100 | 100 | 0% | ok | 0% | Resplendor/MG (sede) | 100 | 100 |  |  |
| 1539 | 7.1.3.1.2 | Aprovação das DEPPs pela Operadora e Prefeitura - Resplendor/MG | milestone | 0d | 2018-03-14 A | 2018-03-14 A | 25, 26 | 100% |  | 2018-03-14 | 2018-03-14 | 0d | 2018-03-14 | 2018-03-14 |  |  | 100% | 100 | 100 | 0% | ok | 0% | Resplendor/MG (sede) | 100 | 100 |  |  |
| 1540 | 7.1.3.1.3 | **Coleta e Análise do Lodo de ETA** |  | 7d | 2019-05-23 A | 2019-05-31 A |  | 100% |  | 2019-05-22 | 2019-06-04 | 10d | 2019-05-22 | 2019-06-04 |  |  | 100% | 100 | 100 |  |  |  |  | 100 | 100 |  |  |
| 1541 | 7.1.3.1.3.1 | Executar Coleta e Análise do Lodo de ETA - Resplendor/MG |  | 7d | 2019-05-23 A | 2019-05-31 A | 1539FS+304d | 100% |  | 2019-05-22 | 2019-06-04 | 10d | 2019-05-22 | 2019-06-04 |  |  | 100% | 100 | 100 |  |  |  |  | 100 | 100 |  |  |
| 1542 | 7.1.3.1.3.2 | Conclusão das Coletas e Análises de Lodo de ETA - Resplendor/MG | milestone | 0d | 2019-05-31 A | 2019-05-31 A | 1541 | 100% |  | 2019-06-04 | 2019-06-04 | 0d | 2019-06-04 | 2019-06-04 |  |  | 100% | 100 | 100 |  |  |  |  | 100 | 100 |  |  |
| 1543 | 7.1.3.1.4 | Conclusão dos Estudos de Concepção das Melhorias do Sistema de Abastecimento de Água - Resplendor/MG | milestone | 0d | 2017-05-19 A | 2017-05-19 A |  | 100% |  | 2017-05-19 | 2017-05-19 | 0d | 2017-05-19 | 2017-05-19 |  |  | 100% | 100 | 100 |  |  |  |  | 100 | 100 |  |  |

Notes:
- 1518: 2/Jan / - Verificar o escopo e empacotamento de atividades de engenharia e suprimentos em função do contrato EPC. / - O contrato EPC não contempla UTR
- 1526: 28/06/19: / Cronograma Infra: Consideradas a tarefa Serviço de adequação da elevatória. / 08/Dez: / - Considerando aqui, execução de "Sistema De Tratamento De Água (Abrandador)", bem como "Obras - Captação Poços E ETA / UTR", constantes no cronograma de Infra. Verificar se esse entendimento está correto.
- 1539: 10/Dez / - Aprovação por parte da COPASA. Pendente Prefeitura (a população não aceita a retomada do Doce).

| ID | WBS | Task | Type | Duration | Start | Finish | Predecessors | Baseline start | Baseline finish | Baseline duration | Baseline 1 start | Baseline 1 finish | Total slack | Free slack | Text3 | Text4 | Text5 | Text7 | Text15 | Text23 | Text25 | Text26 | Text27 | Text29 | Text9 | Text1 |
| --- | --- | --- | --- | --- | --- | --- | --- | --- | --- | --- | --- | --- | --- | --- | --- | --- | --- | --- | --- | --- | --- | --- | --- | --- | --- | --- |
| 1544 | 7.1.3.2 | **Engenharia Básica e Detalhada** |  | 229d | 2020-01-02 | 2020-12-01 |  | 2017-10-23 | 2019-06-19 | 426d | 2017-10-23 | 2019-06-19 | 258d |  | 100% | 71 | 100 | 72 | 99 | Socioambiental | 0% | ok | 0% | Resplendor/MG (sede) |  |  |
| 1545 | 7.1.3.2.1 | **Engenharia UTR** |  | 229d | 2020-01-02 | 2020-12-01 |  | 2018-05-18 | 2019-05-22 | 257d | 2018-05-18 | 2019-05-22 | 258d |  | 100% | 51 | 100 | 53 | 97 | Socioambiental | 0% | ok | 0% | Resplendor/MG (sede) |  |  |
| 1546 | 7.1.3.2.1.1 | Aprovar Plano de Trabalho e abrir OSE - UTR - Resplendor/MG |  | 7d | 2020-01-02 | 2020-01-10 | 1538FS+450d, 1542 | 2018-11-05 | 2019-01-23 | 57d | 2018-11-05 | 2019-01-23 | 294d | 0d | 100% | 100 | 100 | 100 | 100 | Socioambiental | 0% | Não OK | 0% | Resplendor/MG (sede) | Não OK |  |
| 1547 | 7.1.3.2.1.2 | Realizar Levantamento de Campo - UTR - Resplendor/MG |  | 14d | 2020-01-16 | 2020-02-04 | 1546FS+3d | 2019-01-22 | 2019-01-23 | 2d | 2019-01-22 | 2019-01-23 | 294d | 0d | 100% | 100 | 100 | 100 | 100 | Socioambiental | 0% | Não OK | 0% | Resplendor/MG (sede) |  |  |
| 1548 | 7.1.3.2.1.3 | Realizar Sondagem - UTR - Resplendor/MG |  | 14d | 2020-01-16 | 2020-02-04 | 1547SS | 2018-05-18 | 2018-07-12 | 40d | 2018-05-18 | 2018-07-12 | 294d | 0d | 100% | 100 | 100 | 100 | 100 |  |  |  |  |  |  |  |
| 1549 | 7.1.3.2.1.4 | Elaborar Projeto Conceitual - UTR - Resplendor/MG |  | 60d | 2020-01-15 | 2020-04-13 | 1547SS-1d, 1548SS-1d | 2020-01-02 | 2020-01-31 | 22d |  |  | 249d | 0d |  |  |  |  |  |  |  |  |  |  |  | 8888 |
| 1550 | 7.1.3.2.1.5 | Elaborar Projeto Básico - UTR - Resplendor/MG |  | 60d | 2020-04-14 | 2020-07-09 | 1549 | 2018-02-08 | 2018-03-21 | 30d | 2018-02-08 | 2018-03-21 | 249d | 0d | 100% |  | 100 |  | 100 |  |  |  |  |  |  |  |
| 1551 | 7.1.3.2.1.6 | Aprovar Projeto Básico - UTR - Resplendor/MG |  | 32d | 2020-07-10 | 2020-08-24 | 1550 | 2018-03-01 | 2018-03-30 | 22d |  |  | 249d | 0d |  |  |  |  |  |  |  |  |  |  |  |  |
| 1552 | 7.1.3.2.1.7 | Emitir RT/PQ para Suprimentos - UTR - Resplendor/MG |  | 3d | 2020-09-21 | 2020-09-23 | 1553FF-47d | 2019-05-09 | 2019-05-22 | 10d | 2019-05-09 | 2019-05-22 | 249d | 0d | 100% |  | 100 |  | 100 | Socioambiental | 0% | Não OK | 0% | Resplendor/MG (sede) |  |  |
| 1553 | 7.1.3.2.1.8 | Elaborar Projeto Executivo - UTR - Resplendor/MG |  | 68d | 2020-08-25 | 2020-12-01 | 1550, 1551 | 2019-03-08 | 2019-05-22 | 51d | 2019-03-08 | 2019-05-22 | 249d | 0d | 100% |  | 100 |  | 100 | Socioambiental | 0% | Não OK | 0% | Resplendor/MG (sede) |  |  |
| 1554 | 7.1.3.2.1.9 | Elaboração do Projeto Executivo - UTR - Resplendor/MG | milestone | 0d | 2020-12-01 | 2020-12-01 | 1553 | 2019-05-22 | 2019-05-22 | 0d | 2019-05-22 | 2019-05-22 | 738d | 241d | 100% |  | 100 |  | 100 |  |  |  |  |  |  |  |
| 1555 | 7.1.3.3 | **Licenciamento** |  | 176d | 2020-04-14 | 2020-12-23 |  | 2017-12-12 | 2019-09-24 | 457d | 2017-12-12 | 2019-09-24 | 274d |  | 86% | 51 | 86 | 61 | 83 | Socioambiental | 0% | ok | 0% | Resplendor/MG (sede) |  |  |
| 1556 | 7.1.3.3.1 | DAIA para execução da obra - UTR - Resplendor/MG |  | 176d | 2020-04-14 | 2020-12-23 | 1549 | 2019-01-10 | 2019-09-24 | 176d | 2019-01-10 | 2019-09-24 | 274d | 0d | 65% |  | 65 |  | 65 | Socioambiental | 0% | Não OK | 0% | Resplendor/MG (sede) |  |  |
| 1557 | 7.1.3.3.2 | Conclusão do Licenciamento Ambiental da Localidade - Resplendor/MG | milestone | 0d | 2020-12-23 | 2020-12-23 | 1556 | 2019-09-24 | 2019-09-24 | 0d | 2019-09-24 | 2019-09-24 | 722d | 225d | 0% |  |  |  |  |  |  |  |  |  |  |  |
| 1558 | 7.1.3.4 | **Suprimentos** |  | 88d | 2020-09-24 | 2021-02-01 |  | 2019-05-22 | 2019-09-24 | 88d | 2019-05-22 | 2019-09-24 | 249d |  | 30% |  | 30 |  | 30 |  | 0% | ok | 0% | Resplendor/MG (sede) |  |  |
| 1559 | 7.1.3.4.1 | Processo contratação (UTR) - Resplendor/MG |  | 88d | 2020-09-24 | 2021-02-01 | 1552 | 2019-05-22 | 2019-09-24 | 88d | 2019-05-22 | 2019-09-24 | 249d | 0d | 30% |  | 30 |  | 30 |  | 0% | ok | 0% | Resplendor/MG (sede) |  |  |
| 1560 | 7.1.3.4.2 | Conclusão da Contratação de Suprimentos das obras de Melhoria do Sistema de Abastecimento de Água - Resplendor/MG | milestone | 0d | 2021-02-01 | 2021-02-01 | 1559 | 2019-09-24 | 2019-09-24 | 0d | 2019-09-24 | 2019-09-24 | 697d | 200d | 0% |  |  |  |  |  |  |  |  |  |  |  |
| 1561 | 7.1.3.5 | **Infraestrutura** |  | 449d | 2021-02-02 | 2022-11-22 |  | 2018-03-30 | 2021-05-03 | 775d | 2018-03-30 | 2021-05-03 | 248d |  | 41% | 17 | 41 | 59 | 29 |  | 0% | ok | 0% | Resplendor/MG (sede) |  |  |
| 1562 | 7.1.3.5.1 | **Obras** |  | 200d | 2021-02-02 | 2021-11-22 |  | 2018-03-30 | 2020-04-14 | 515d | 2018-03-30 | 2020-04-14 | 249d |  | 61% | 42 | 61 | 145 | 29 |  |  |  |  |  |  |  |
| 1563 | 7.1.3.5.1.1 | Executar UTR - Resplendor/MG |  | 200d | 2021-02-02 | 2021-11-22 | 1556, 1559, 1552 | 2019-09-24 | 2020-04-14 | 137d | 2019-09-24 | 2020-04-14 | 249d | 0d | 0% |  |  |  |  |  | 0% | ok | 0% | Resplendor/MG (sede) |  |  |
| 1564 | 7.1.3.5.1.2 | Assinatura de Termo de Entrega das Obras de Melhoria do Sistema de Abastecimento de Água - Resplendor/MG | milestone | 0d | 2021-11-22 | 2021-11-22 | 1563, 1554, 1557, 1560 | 2020-04-14 | 2020-04-14 | 0d | 2020-04-14 | 2020-04-14 | 497d | 249d | 0% |  |  |  |  |  | 0% | ok | 0% | Resplendor/MG (sede) |  |  |
| 1565 | 7.1.3.5.2 | **Operação** |  | 249d | 2021-11-22 | 2022-11-22 |  | 2020-04-15 | 2021-05-03 | 260d | 2020-04-15 | 2021-05-03 | 248d |  | 0% |  |  |  |  |  | 0% | ok | 0% | Resplendor/MG (sede) |  |  |
| 1566 | 7.1.3.5.2.1 | Realizar Treinamento Operacional do Sistema - Resplendor/MG |  | 5d | 2021-11-23 | 2021-11-29 | 1563 | 2020-04-15 | 2020-04-22 | 5d | 2020-04-15 | 2020-04-22 | 478d | 0d | 0% |  |  |  |  |  | 0% | ok | 0% | Resplendor/MG (sede) |  |  |
| 1567 | 7.1.3.5.2.2 | Realizar Testes e Pré-operação - Resplendor/MG |  | 14d | 2021-11-30 | 2021-12-17 | 1566 | 2020-04-23 | 2020-05-13 | 14d | 2020-04-23 | 2020-05-13 | 478d |  | 0% |  |  |  |  |  | 0% | ok | 0% | Resplendor/MG (sede) |  |  |
| 1568 | 7.1.3.5.2.3 | Realizar Acompanhamento da Funcionalidade do Sistema - UTR - Resplendor/MG (sede) |  | 365ed | 2021-11-22 | 2022-11-22 | 1570SS | 2020-04-15 | 2021-05-03 | 260d |  |  | 1095d |  |  |  |  |  |  |  |  |  |  |  |  |  |

Notes:
- 1544: 10/Dez / - Projetos de Captação Principal, Alternativa e Melhorias de ETA estão sendo desenvolvidos por uma empresa sob a gestão da Infra, em regime EPC (farão a obra também). / - Há um projeto de Estudo de Demanda (captação alternativa) e outro de Melhorias de ETA que estão sendo desenvolvidos pela ENG matricial da FR em complementação.
- 1545: 10/Dez / - Projeto desenvolvido pela Engenharia Matricial da FR.
- 1547: 25/Jan19: / - Levantamento de campo previsto para iniciar em 01/02 e finalizar em 07/02/19; Sondagem prevista para iniciar em 01/03 e finalizar em 04/04/19.
- 1555: 13/Dez / - Licenciamento irá confirmar com a COPASA se já possuem outorga para captação no rio Doce.
- 1556: 13/Dez / - Licenciamento entende que essa atividade será desenvolvida pós regime EPC. / - Fundiário ok para essa licença.
- 1558: 2/Jan / - Verificar o escopo e empacotamento de atividades de engenharia e suprimentos em função do contrato EPC. / - O contrato EPC não contempla UTR

| ID | WBS | Task | Type | Duration | Start | Finish | Predecessors | Complete | Remaining | Baseline start | Baseline finish | Baseline duration | Baseline 1 start | Baseline 1 finish | Total slack | Free slack | Text3 | Text25 | Text26 | Text27 | Text29 | Text4 | Text5 | Text7 | Text15 | Text23 | Text1 | Text9 |
| --- | --- | --- | --- | --- | --- | --- | --- | --- | --- | --- | --- | --- | --- | --- | --- | --- | --- | --- | --- | --- | --- | --- | --- | --- | --- | --- | --- | --- |
| 1569 | 7.1.3.5.2.4 | **Operação Assistida** |  | 63d | 2021-11-22 | 2022-02-20 |  |  |  | 2020-04-15 | 2020-07-16 | 64d | 2020-04-15 | 2020-07-16 | 248d |  | 0% | 0% | ok | 0% | Resplendor/MG (sede) |  |  |  |  |  |  |  |
| 1570 | 7.1.3.5.2.4.1 | Realizar Operação Assistida - Resplendor/MG |  | 90ed | 2021-11-22 | 2022-02-20 | 1563 |  |  | 2020-04-15 | 2020-07-16 | 3.2mo | 2020-04-15 | 2020-07-16 | 1095d | 0d | 0% | 0% | ok | 0% | Resplendor/MG (sede) |  |  |  |  |  |  |  |
| 1571 | 7.2 | **Itueta/MG (sede)** |  | 1273d | 2018-03-23 A | 2023-04-25 |  | 4% | 1220.81d | 2018-03-14 | 2022-02-14 | 986d | 2018-03-14 | 2022-02-14 | 144d |  | 33% | 0% | ok | 0% | Itueta/MG (sede) | 24 | 33 | 89 | 27 | Socioambiental |  |  |
| 1572 | 7.2.1 | **Captação Alternativa (Rio Manhuaçu) / Nova ETA e UTR** |  | 1273d | 2018-03-23 A | 2023-04-25 |  | 4% | 1220.81d | 2018-03-14 | 2022-02-14 | 986d |  |  | 144d |  |  |  |  |  |  |  |  |  |  |  |  |  |
| 1573 | 7.2.1.1 | **Estudos de Concepção do Sistema - Etapa 1** |  | 0d | 2018-03-23 A | 2018-03-23 A |  | 100% |  | 2018-03-14 | 2019-04-04 | 273d | 2018-03-14 | 2019-04-04 |  |  | 100% | 0% | ok | 0% | Itueta/MG (sede) | 100 | 100 | 100 | 100 | Socioambiental |  |  |
| 1574 | 7.2.1.1.1 | Declaração de Escopo e Premissas de Projeto (DEPP) concluída - Itueta/MG | milestone | 0d | 2018-03-23 A | 2018-03-23 A | 25, 26 | 100% |  | 2018-03-23 | 2018-03-23 | 0d | 2018-03-23 | 2018-03-23 |  |  | 100% | 0% | ok | 0% | Itueta/MG (sede) | 100 | 100 | 100 | 100 |  |  |  |
| 1575 | 7.2.1.1.2 | Aprovação das DEPPs pela Operadora e Prefeitura - Itueta/MG | milestone | 0d | 2018-03-23 A | 2018-03-23 A | 1574 | 100% |  | 2018-03-14 | 2018-03-14 | 0d | 2018-03-14 | 2018-03-14 |  |  | 100% | 0% | ok | 0% | Itueta/MG (sede) | 100 | 100 | 100 | 100 |  |  |  |
| 1576 | 7.2.1.2 | **Estudos de Concepção do Sistema - Etapa 2** |  | 157d | 2019-03-08 A | 2019-10-21 A |  | 100% |  | 2019-03-08 | 2019-10-21 | 157d |  |  |  |  |  |  |  |  |  |  |  |  |  |  |  |  |
| 1577 | 7.2.1.2.1 | Início das atividades da nova definição para a captação principal - Itueta/MG | milestone | 0d | 2019-10-21 A | 2019-10-21 A | 1575FS+410d | 100% |  | 2019-10-10 | 2019-10-10 | 0d |  |  |  |  |  |  |  |  |  |  |  |  |  |  | 8888 |  |
| 1578 | 7.2.1.2.2 | **Captações Superficiais - Rio Manhuaçu** |  | 20d | 2019-03-08 A | 2019-04-04 A |  | 100% |  | 2019-03-08 | 2019-04-04 | 20d | 2019-03-08 | 2019-04-04 |  |  | 100% | 0% | ok | 0% | Itueta/MG (sede) | 100 | 100 | 100 | 100 | Socioambiental |  |  |
| 1579 | 7.2.1.2.2.1 | Realizar Laudo dos Serviços de Coleta e Análise de Água (Dados do PMQQS) - Itueta/MG |  | 20d | 2019-03-08 A | 2019-04-04 A | 1574FS+350ed | 100% |  | 2019-03-08 | 2019-04-04 | 20d | 2019-03-08 | 2019-04-04 |  |  | 100% | 0% | Não OK | 0% | Itueta/MG (sede) | 100 | 100 | 100 | 100 | Socioambiental |  |  |
| 1580 | 7.2.1.2.2.2 | Conclusão do Estudo da Captação Superficial - Itueta/MG | milestone | 0d | 2019-04-04 A | 2019-04-04 A | 1579 | 100% |  | 2019-04-04 | 2019-04-04 | 0d | 2019-04-04 | 2019-04-04 |  |  | 100% |  |  |  |  | 100 | 100 | 100 | 100 |  |  |  |
| 1581 | 7.2.1.2.3 | Conclusão dos Estudos de Concepção das Melhorias do Sistema de Abastecimento de Água - Itueta/MG | milestone | 0d | 2019-04-04 A | 2019-04-04 A | 1580 | 100% |  | 2019-04-04 | 2019-04-04 | 0d | 2019-04-04 | 2019-04-04 |  |  | 100% |  |  |  |  | 100 | 100 | 100 | 100 |  |  |  |
| 1582 | 7.2.1.3 | **Engenharia Básica e Detalhada** |  | 317d | 2019-08-23 A | 2020-11-30 |  | 24% | 240.07d | 2018-03-23 | 2019-11-11 | 418d | 2018-03-23 | 2019-11-11 | 739d |  | 77% | 0% | ok | 0% | Itueta/MG (sede) | 62 | 77 | 74 | 84 | Socioambiental |  |  |
| 1583 | 7.2.1.3.1 | **Engenharia Captação Alternativa (Rio Manhuaçu) / Nova ETA e UTR** |  | 297d | 2019-08-23 A | 2020-10-30 |  | 26% | 220.44d | 2018-03-23 | 2019-09-19 | 381d | 2018-03-23 | 2019-09-19 | 739d |  | 84% | 0% | ok | 0% | Itueta/MG (sede) | 57 | 84 | 68 | 84 | Socioambiental |  |  |
| 1584 | 7.2.1.3.1.1 | Aprovar Plano de Trabalho e abrir OSE - Captação Alternativa, ETA e UTR, Nova ETA e UTR - Itueta/MG |  | 36d | 2019-10-22 A | 2019-12-11 A | 1577 | 100% |  | 2018-03-23 | 2018-12-21 | 196d | 2018-03-23 | 2018-12-21 |  |  | 100% | 0% | Não OK | 0% | Itueta/MG (sede) | 100 | 100 | 100 | 100 | Socioambiental |  | Não OK |
| 1585 | 7.2.1.3.1.2 | Realizar Sondagem - Captação Alternativa, ETA e UTR -Itueta/MG |  | 30d | 2020-02-04 | 2020-03-19 | 1584FS+34d |  |  | 2019-05-08 | 2019-06-06 | 22d | 2019-05-08 | 2019-06-06 | 213d | 68d | 100% |  |  |  |  |  | 100 |  | 100 |  |  |  |
| 1586 | 7.2.1.3.1.3 | Executar Topografia - Captação Alternativa, ETA e UTR - Itueta/MG |  | 47d | 2019-08-23 A | 2019-10-28 A | 1584FS-40d | 100% |  | 2019-05-08 | 2019-06-18 | 30d | 2019-05-08 | 2019-06-18 |  |  | 100% |  |  |  |  | 100 | 100 | 100 | 100 |  |  |  |
| 1587 | 7.2.1.3.1.4 | Elaborar arranjo para obtenção de Dados de Entrada Licenciamento e Fundiário - Captação Alternativa, ETA e UTR -Itueta/MG |  | 30d | 2020-01-10 | 2020-02-20 | 1584FS+17d |  |  | 2019-05-08 | 2019-06-21 | 32d | 2019-05-08 | 2019-06-21 | 145d | 0d | 100% | 0% | Não OK | 0% | Itueta/MG (sede) | 31 | 100 | 31 | 100 | Socioambiental |  |  |
| 1588 | 7.2.1.3.1.5 | Elaborar Projeto Básico - Captação Alternativa, ETA e UTR - Itueta/MG |  | 85d | 2020-02-21 | 2020-06-29 | 1585FF, 1586FF, 1587 |  |  | 2018-02-08 | 2018-03-21 | 30d | 2018-02-08 | 2018-03-21 | 145d | 0d | 100% |  |  |  |  |  | 100 |  | 100 |  |  |  |
| 1589 | 7.2.1.3.1.6 | Aprovar Projeto Básico - Captação Alternativa, ETA e UTR - Itueta/MG |  | 17d | 2020-06-30 | 2020-07-22 | 1588 |  |  | 2018-03-01 | 2018-03-30 | 22d |  |  | 145d | 0d |  |  |  |  |  |  |  |  |  |  |  |  |
| 1590 | 7.2.1.3.1.7 | Emitir RT/PQ para Suprimentos - Captação Alternativa, ETA e UTR - Itueta/MG |  | 7d | 2020-09-16 | 2020-09-24 | 1591FF-25d |  |  | 2019-08-27 | 2019-09-19 | 18d | 2019-08-27 | 2019-09-19 | 145d | 0d | 0% | 0% | ok | 0% | Itueta/MG (sede) |  |  |  |  |  |  |  |
| 1591 | 7.2.1.3.1.8 | Elaborar Projeto Executivo - Captação Alternativa, ETA e UTR - Itueta/MG |  | 70d | 2020-07-23 | 2020-10-30 | 1588, 1589 |  |  | 2019-06-19 | 2019-09-19 | 65d | 2019-06-19 | 2019-09-19 | 145d | 0d | 10% | 0% | ok | 0% | Itueta/MG (sede) |  | 10 |  | 10 |  |  |  |
| 1592 | 7.2.1.3.1.9 | Elaboração do Projeto Executivo- Captação Alternativa, ETA e UTR -Itueta/MG | milestone | 0d | 2020-10-30 | 2020-10-30 | 1591 |  |  | 2019-09-19 | 2019-09-19 | 0d | 2019-09-19 | 2019-09-19 | 739d | 0d | 0% |  |  |  |  |  |  |  |  |  |  |  |

Notes:
- 1579: 04/Fev19: / - O resultado da análise da água será obtido a partir da estação automática e dos pontos de monitoramento do PMQQS. Thales irá me informar nova data. / 08/Dez / - Verificar com Thales a necessidade dessa atividade.
- 1583: 25/Jan19: / - Engenharia considerando 2 projetos para esta Captação: "Captação / Adução Rio Manhuaçu" e "Alimentação Elétrica Captação Rio Manhuaçu".
- 1584: 25/Jan19: / - Plano de Trabalho referente ao projeto de Captação / Adudão Rio Manhuaçu iniciado em 12/06 e concluído em 09/11/18; do de Alimentação Elétrica Captação Rio Manhuaçu previsto pra iniciar em 15/02 e concluir em 12/03/19.
- 1587: 04/Dez: / - Projeto previsto apenas para o de Captação / Adução do Rio Manhuaçu e não para o de Alimentação Elétrica Captação Rio Manhuaçu.
- 1590: 04/Dez: / - Emissão Preliminar para Suprimentos de RT/PQ prevista apenas para projeto de Captação / Adução do Rio Manhuaçu. Para o de Alimentação Elétrica Captação Rio Manhuaçu a previsão é a emissão final desses documentos.
- 1591: 25/Jan19: / - Projeto Executivo da Captação / Adução Rio Manhuaçu previsto para iniciar em 25/03 e finalizar em 18/06/19; e da Alimentação Elétrica Captaçaõ Rio Manhuaçu previsto para iniciar em 13/03 e finalizar em 22/05/19. / - Laudo de análise da água previsto para 29/03/19 (dentro do prazo pra desenvolvimento do projeto executivo pela Engenharia). / 04/Dez: / - Considerando aqui os projetos executivos de CAPTAÇÃO / ADUÇÃO RIO MANHUAÇU (início em 15/02 com previsão de término para 16/05/19), bem como de ALIMENTAÇÃO ELÉTRICA CAPTAÇÃO RIO MANHUAÇU (início previsto para 13/03 e término 22/05/19).

| ID | WBS | Task | Type | Duration | Start | Finish | Predecessors | Complete | Remaining | Baseline start | Baseline finish | Baseline duration | Baseline 1 start | Baseline 1 finish | Total slack | Free slack | Text3 | Text25 | Text26 | Text27 | Text29 | Text4 | Text5 | Text7 | Text15 | Text23 | Text1 | Indicadores MIR |
| --- | --- | --- | --- | --- | --- | --- | --- | --- | --- | --- | --- | --- | --- | --- | --- | --- | --- | --- | --- | --- | --- | --- | --- | --- | --- | --- | --- | --- |
| 1593 | 7.2.1.3.2 | **Validação dos Projetos** |  | 20d | 2020-11-03 | 2020-11-30 |  |  |  | 2019-10-15 | 2019-11-11 | 20d | 2019-10-15 | 2019-11-11 | 739d |  | 0% | 0% | ok | 0% | Itueta/MG (sede) |  |  |  |  |  |  |  |
| 1594 | 7.2.1.3.2.1 | Validar Projetos com Prefeitura e Operadora - Itueta/MG |  | 20d | 2020-11-03 | 2020-11-30 | 1592 |  |  | 2019-10-15 | 2019-11-11 | 20d | 2019-10-15 | 2019-11-11 | 739d | 0d | 0% | 0% | ok | 0% | Itueta/MG (sede) |  |  |  |  |  |  |  |
| 1595 | 7.2.1.3.2.2 | Validação com Prefeitura e Operadora dos Projetos de Melhoria do Sistema de Abastecimento de Água - Itueta/MG | milestone | 0d | 2020-11-30 | 2020-11-30 | 1594 |  |  | 2019-11-11 | 2019-11-11 | 0d | 2019-11-11 | 2019-11-11 | 739d | 346d | 0% |  |  |  |  |  |  |  |  |  |  |  |
| 1596 | 7.2.1.4 | **Fundiária** |  | 367d | 2019-05-16 A | 2020-11-03 |  | 11% | 327.27d | 2019-03-07 | 2019-11-28 | 185d | 2019-03-07 | 2019-11-28 | 758d |  | 42% | 0% | ok | 0% | Itueta/MG (sede) | 20 | 42 | 87 | 23 | Socioambiental |  |  |
| 1597 | 7.2.1.4.1 | **Captação Alternativa - Rio Manhuaçu - Desimpedimento da Área e Negociação de Servidão** |  | 367d | 2019-05-16 A | 2020-11-03 |  | 20% | 295.31d | 2019-05-16 | 2019-09-24 | 92d | 2019-05-16 | 2019-09-24 | 223d |  | 33% |  |  |  |  | 29 | 33 | 85 | 34 |  |  |  |
| 1598 | 7.2.1.4.1.1 | [Traçado antigo] Realizar Levantamento da documentação da propriedade - Termo de Autorização e Cadastro de superficiários - Itueta/MG |  | 22d | 2019-05-16 A | 2019-06-14 A | 1574 | 100% |  | 2019-05-16 | 2019-06-14 | 22d | 2019-05-16 | 2019-06-14 |  |  | 100% |  |  |  |  | 100 | 100 | 100 | 100 |  |  |  |
| 1599 | 7.2.1.4.1.2 | [Traçado antigo] Obter assinatura do Contrato de servidão pelo proprietário - Itueta/MG |  | 20d | 2019-06-17 A | 2019-07-15 A | 1598 | 100% |  | 2019-06-17 | 2019-07-15 | 20d | 2019-06-17 | 2019-07-15 |  |  | 45% |  |  |  |  | 25 | 45 | 56 | 45 |  |  |  |
| 1600 | 7.2.1.4.1.3 | Definição de novo traçado para Adutora do rio Manhuaçu - Itueta/MG | milestone | 0d | 2019-10-21 A | 2019-10-21 A | 1599, 1577 | 100% |  | 2019-10-10 | 2019-10-10 | 0d |  |  |  |  |  |  |  |  |  |  |  |  |  |  | 8888 |  |
| 1601 | 7.2.1.4.1.4 | Realizar Negociação da Servidão - Adutora Rio Manhuaçu - Captação Alternativa - Itueta/MG |  | 173d | 2020-02-21 | 2020-11-03 | 1600, 1587 |  |  | 2019-11-27 | 2020-08-03 | 168d |  |  | 223d | 0d |  |  |  |  |  |  |  |  |  |  | 8888 |  |
| 1602 | 7.2.1.4.1.5 | Regularização da Servidão - Captação Alternativa - Itueta/MG | milestone | 0d | 2020-11-03 | 2020-11-03 | 1601 |  |  | 2019-09-24 | 2019-09-24 | 0d | 2019-09-24 | 2019-09-24 | 223d | 0d | 0% |  |  |  |  |  |  |  |  |  |  |  |
| 1603 | 7.2.1.4.2 | Nova ETA / UTR - Desimpedimento de áreas - Itueta/MG |  | 173d | 2020-02-21 | 2020-11-03 | 1587 |  |  | 2019-07-15 | 2019-09-13 | 44d | 2019-07-15 | 2019-09-13 | 310d | 0d | 0% | 0% | ok | 0% | Itueta/MG (sede) |  |  |  |  |  |  |  |
| 1604 | 7.2.1.4.3 | Conclusão da Regularização Fundiária para as obras de Melhoria do Sistema de Abastecimento da Localidade - Itueta/MG | milestone | 0d | 2020-11-03 | 2020-11-03 | 1602, 1603 |  |  | 2019-09-24 | 2019-09-24 | 0d | 2019-09-24 | 2019-09-24 | 758d | 365d | 0% |  |  |  |  |  |  |  |  |  |  |  |
| 1605 | 7.2.1.5 | **Licenciamento** |  | 203d | 2020-02-21 | 2020-12-15 |  |  |  | 2019-03-20 | 2020-03-24 | 252d | 2019-03-20 | 2020-03-24 | 227d |  | 27% | 0% | ok | 0% | Itueta/MG (sede) |  | 27 |  | 26 |  |  |  |
| 1606 | 7.2.1.5.1 | Captação Alternativa - Outorga para Captação no rio Manhuaçu - Itueta/MG |  | 203d | 2020-02-21 | 2020-12-15 | 1587 |  |  | 2019-03-20 | 2019-11-28 | 176d | 2019-03-20 | 2019-11-28 | 480d | 0d | 39% | 0% | ok | 0% | Itueta/MG (sede) |  | 39 |  | 39 |  |  |  |
| 1607 | 7.2.1.5.2 | Captação Alternativa - DAIA para Construção de Adutora rio Manhuaçu - Itueta/MG |  | 203d | 2020-02-21 | 2020-12-15 | 1587 |  |  | 2019-11-27 | 2020-09-22 | 203d |  |  | 227d | 82d |  |  |  |  |  |  |  |  |  |  | 8888 |  |
| 1608 | 7.2.1.5.3 | Verificar necessidade de Licença/Autorização - Nova ETA / UTR - Itueta/MG |  | 203d | 2020-02-21 | 2020-12-15 | 1587 |  |  | 2019-07-10 | 2020-03-24 | 176d | 2019-07-10 | 2020-03-24 | 280d | 0d | 0% | 0% | ok | 0% | Itueta/MG (sede) |  |  |  |  |  |  |  |
| 1609 | 7.2.1.5.4 | Conclusão do Licenciamento Ambiental da Localidade - Itueta/MG | milestone | 0d | 2020-12-15 | 2020-12-15 | 1606, 1608 |  |  | 2020-03-24 | 2020-03-24 | 0d | 2020-03-24 | 2020-03-24 | 728d | 335d | 0% |  |  |  |  |  |  |  |  |  |  |  |
| 1610 | 7.2.1.6 | **Suprimentos** |  | 101d | 2020-09-25 | 2021-02-24 |  |  |  | 2019-07-26 | 2020-02-20 | 144d | 2019-07-26 | 2020-02-20 | 145d |  | 0% | 0% | ok | 0% | Itueta/MG (sede) |  |  |  |  |  |  |  |
| 1611 | 7.2.1.6.1 | Realizar análise da RT/PQ pela Infra - Adutora, Nova ETA e UTR - Itueta/MG |  | 10d | 2020-09-25 | 2020-10-08 | 1590 |  |  | 2020-03-11 | 2020-03-24 | 10d |  |  | 145d | 0d |  |  |  |  |  |  |  |  |  |  | 8888 |  |
| 1612 | 7.2.1.6.2 | Realizar Processo contratação - Adutora, Nova ETA e UTR - Itueta/MG |  | 91d | 2020-10-09 | 2021-02-24 | 1611 |  |  | 2019-07-26 | 2019-11-28 | 88d | 2019-07-26 | 2019-11-28 | 145d | 0d | 0% | 0% | ok | 0% | Itueta/MG (sede) |  |  |  |  |  |  |  |
| 1613 | 7.2.1.6.3 | Conclusão da Contratação de Suprimentos - Adutora, Nova ETA e UTR - Itueta/MG | milestone | 0d | 2021-02-24 | 2021-02-24 | 1612 |  |  | 2020-02-20 | 2020-02-20 | 0d | 2020-02-20 | 2020-02-20 | 145d | 0d | 0% |  |  |  |  |  |  |  |  |  |  |  |
| 1614 | 7.2.1.7 | **Infraestrutura** |  | 539d | 2021-02-25 | 2023-04-25 |  |  |  | 2019-11-28 | 2022-02-14 | 550d | 2019-11-28 | 2022-02-14 | 144d |  | 0% | 0% | ok | 0% | Itueta/MG (sede) |  |  |  |  |  |  |  |
| 1615 | 7.2.1.7.1 | **Obras** |  | 539d | 2021-02-25 | 2023-04-25 |  |  |  | 2019-11-28 | 2021-01-31 | 290d | 2019-11-28 | 2021-01-31 | 144d |  | 0% |  |  |  |  |  |  |  |  |  |  |  |
| 1616 | 7.2.1.7.1.1 | Executar Captação Principal (Pequenas Melhorias Captação rio Doce) - Itueta/MG |  | 66d | 2021-02-25 | 2021-05-31 | 1602, 1613 |  |  | 2019-11-28 | 2021-01-31 | 290d | 2019-11-28 | 2021-01-31 | 369d | 224d | 0% | 0% | ok | 0% | Itueta/MG (sede) |  |  |  |  |  |  |  |
| 1617 | 7.2.1.7.1.2 | Executar Captação Alternativa (Rio Manhuaçu) - Itueta/MG |  | 290d | 2021-02-25 | 2022-04-25 | 1602FS-3d, 1606FF, 1613, 1607FS-37d |  |  | 2019-11-28 | 2021-01-31 | 290d | 2019-11-28 | 2021-01-31 | 145d | 0d | 0% | 0% | ok | 0% | Itueta/MG (sede) |  |  |  |  |  |  | CA |
| 1618 | 7.2.1.7.1.3 | Executar Nova ETA - Itueta/MG |  | 137d | 2021-02-25 | 2021-09-09 | 1603, 1608, 1613 |  |  | 2020-03-25 | 2020-10-08 | 137d | 2020-03-25 | 2020-10-08 | 298d | 153d | 0% | 0% | ok | 0% | Itueta/MG (sede) |  |  |  |  |  |  | ETA |
| 1619 | 7.2.1.7.1.4 | Executar UTR - Itueta/MG |  | 200d | 2021-03-15 | 2021-12-29 | 1603, 1608, 1613FS+12d |  |  | 2020-03-25 | 2020-10-08 | 137d | 2020-03-25 | 2020-10-08 | 223d | 78d | 0% | 0% | ok | 0% | Itueta/MG (sede) |  |  |  |  |  |  |  |
| 1620 | 7.2.1.7.1.5 | Assinatura de Termo de Entrega das Obras de Melhoria do Sistema de Abastecimento de Água - Itueta/MG | milestone | 0d | 2022-04-25 | 2022-04-25 | 1616, 1617, 1618, 1619, 1595, 1604, 1609 |  |  | 2021-01-31 | 2021-01-31 | 0d | 2021-01-31 | 2021-01-31 | 393d | 145d | 0% | 0% | ok | 0% | Itueta/MG (sede) |  |  |  |  |  |  |  |
| 1621 | 7.2.1.7.1.6 | Realizar Acompanhamento da Funcionalidade do Sistema - Captação Alternativa (Rio Manhuaçu) / Nova ETA e UTR - Itueta/MG (sede) |  | 365ed | 2022-04-25 | 2023-04-25 | 1626SS |  |  | 2020-01-31 | 2021-01-31 | 250d |  |  | 633d |  |  |  |  |  |  |  |  |  |  |  |  |  |

Notes:
- 1597: 23Nov: / - Obtenção de autorização de acesso para estudos concluída em 10/11/18. / 04/Dez: / - Segundo CR Gestão Fundiária em 12/11/2018 "existe apenas uma proposta de traçado indicando uma frente de cadastro, pendentes todas as outras atividades e ações dos demais setores envolvidos. Identificação preliminar realizada. Falta definição do ponto da captação para evolução".
- 1598: 23/Nov: / - Obtenção de autorização de acesso para estudos concluída em 10/11/18. / 04/Dez: / - Vários imóveis envolvidos no traçado da adutora (60 imóveis pela planilha/CR do Fundiário). Pergunta: Esses imóveis estão mesmo no traçado desta adutora ou pode ser na da captação alternativa?
- 1603: 01/Fev19: / - Termos de Autorização do Superficiário(s) já obtido(s).
- 1606: 22/Nov / - Processo não iniciado, data prevista para 22/08/19 cf planilha do licenciamento. / - O processo de licenciamento será iniciado após a elaboração do projeto georreferenciado.
- 1614: 04/Dez: / - Consta no CR de Infra a "Execução da Extensão Rede Elétrica". Verificar se é para acompanhar separado ou junto a obra das adutoras e/ou nova ETA, etc.
- 1618: 04/Dez: / - Não consta no CR de Infra (atualizado em 14/11/18).

| ID | WBS | Task | Type | Duration | Start | Finish | Predecessors | Complete | Remaining | Baseline start | Baseline finish | Baseline duration | Baseline 1 start | Baseline 1 finish | Total slack | Free slack | Text3 | Text25 | Text26 | Text27 | Text29 | Text5 | Text7 | Text15 | Text23 | Text4 |
| --- | --- | --- | --- | --- | --- | --- | --- | --- | --- | --- | --- | --- | --- | --- | --- | --- | --- | --- | --- | --- | --- | --- | --- | --- | --- | --- |
| 1622 | 7.2.1.7.2 | **Operação** |  | 63d | 2022-04-25 | 2022-07-24 |  |  |  | 2021-02-01 | 2022-02-14 | 260d | 2021-02-01 | 2022-02-14 | 145d |  | 0% | 0% | ok | 0% | Itueta/MG (sede) |  |  |  |  |  |
| 1623 | 7.2.1.7.2.1 | Realizar Treinamento Operacional do Sistema - Itueta/MG |  | 5d | 2022-04-26 | 2022-05-02 | 1616, 1617, 1618, 1619 |  |  | 2021-02-01 | 2021-02-05 | 5d | 2021-02-01 | 2021-02-05 | 374d | 0d | 0% | 0% | ok | 0% | Itueta/MG (sede) |  |  |  |  |  |
| 1624 | 7.2.1.7.2.2 | Realizar Testes e Pré-operação - Itueta/MG |  | 14d | 2022-05-03 | 2022-05-20 | 1623 |  |  | 2021-02-08 | 2021-03-02 | 14d | 2021-02-08 | 2021-03-02 | 374d |  | 0% | 0% | ok | 0% | Itueta/MG (sede) |  |  |  |  |  |
| 1625 | 7.2.1.7.2.3 | **Operação Assistida** |  | 63d | 2022-04-25 | 2022-07-24 |  |  |  | 2021-02-01 | 2021-05-06 | 64d | 2021-02-01 | 2021-05-06 | 144d |  | 0% | 0% | ok | 0% | Itueta/MG (sede) |  |  |  |  |  |
| 1626 | 7.2.1.7.2.3.1 | Realizar Operação Assistida - Itueta/MG |  | 90ed | 2022-04-25 | 2022-07-24 | 1616, 1617, 1618, 1619 |  |  | 2021-02-01 | 2021-05-06 | 3.2mo | 2021-02-01 | 2021-05-06 | 633d | 0d | 0% | 0% | ok | 0% | Itueta/MG (sede) |  |  |  |  |  |
| 1627 | 7.3 | **Santo Antônio do Rio Doce (distrito Aimorés/MG)** |  | 1319d | 2018-03-23 A | 2023-07-01 |  | 7% | 1227.72d | 2018-03-16 | 2021-12-14 | 941d | 2018-03-16 | 2021-12-14 | 98d |  | 34% | 0% | ok | 0% | Santo Antônio do Rio Doce (distrito Aimorés/MG) | 34 | 27 | 22 | Socioambiental |  |
| 1628 | 7.3.1 | **Captação Principal, UTR na ETA de Aimorés** |  | 1319d | 2018-03-23 A | 2023-07-01 |  | 7% | 1227.72d | 2018-03-23 | 2021-12-14 | 936d |  |  | 98d |  |  |  |  |  |  |  |  |  |  |  |
| 1629 | 7.3.1.1 | **Estudos de Concepção do Sistema** |  | 384d | 2018-03-23 A | 2019-09-24 A |  | 100% |  | 2018-03-23 | 2019-06-26 | 321d | 2018-03-23 | 2019-06-26 |  |  | 100% | 0% | ok | 0% | Santo Antônio do Rio Doce (distrito Aimorés/MG) | 100 | 96 | 100 | Socioambiental | 96 |
| 1630 | 7.3.1.1.1 | Declaração de Escopo e Premissas de Projeto (DEPP) concluída - Santo Antônio do Rio Doce/MG | milestone | 0d | 2018-03-23 A | 2018-03-23 A | 25, 26 | 100% |  | 2018-03-23 | 2018-03-23 | 0d | 2018-03-23 | 2018-03-23 |  |  | 100% | 0% | ok | 0% | Santo Antônio do Rio Doce (distrito Aimorés/MG) | 100 | 100 | 100 |  | 100 |
| 1631 | 7.3.1.1.2 | Revisar Definições - Santo Antônio do Rio Doce/MG |  | 55d | 2019-01-28 A | 2019-04-17 A | 1630FS+220d | 100% |  | 2019-01-28 | 2019-04-17 | 55d | 2019-01-28 | 2019-04-17 |  |  | 100% | 0% | ok | 0% | Santo Antônio do Rio Doce (distrito Aimorés/MG) | 100 | 100 | 100 |  | 100 |
| 1632 | 7.3.1.1.3 | Aprovação da Revisão da Definição pela Operadora e Prefeitura - Santo Antônio do Rio Doce/MG |  | 7d | 2019-04-22 A | 2019-04-30 A | 1631 | 100% |  | 2019-04-22 | 2019-05-13 | 15d | 2019-04-22 | 2019-05-13 |  |  | 100% | 0% | ok | 0% | Santo Antônio do Rio Doce (distrito Aimorés/MG) | 100 | 100 | 100 |  | 100 |
| 1633 | 7.3.1.1.4 | Aprovação pelo CIF da solução da Prefeitura de Aimorés/MG - Deliberação nº 325/2019 - Santo Antônio do Rio Doce/MG | milestone | 0d | 2019-09-24 A | 2019-09-24 A | 1632FS+102d | 100% |  | 2019-09-06 | 2019-09-06 | 0d |  |  |  |  | 0% |  |  |  |  |  |  |  |  |  |
| 1634 | 7.3.1.2 | **Engenharia Básica e Detalhada** |  | 417d | 2019-05-02 A | 2020-12-31 |  | 30% | 293.18d | 2018-03-16 | 2019-12-10 | 443d | 2018-03-16 | 2019-12-10 | 718d |  | 74% | 0% | ok | 0% | Santo Antônio do Rio Doce (distrito Aimorés/MG) | 74 |  | 57 | Socioambiental |  |
| 1635 | 7.3.1.2.1 | **Engenharia Projeto Município Aimorés (Captação principal)** |  | 329d | 2019-05-02 A | 2020-08-24 |  | 48% | 171.5d | 2019-05-02 | 2019-09-30 | 106d | 2019-05-02 | 2019-09-30 | 786d |  | 38% |  |  |  |  | 38 | 26 | 35 |  |  |
| 1636 | 7.3.1.2.1.1 | Analisar o Projeto Básico da Prefeitura - Captação Principal - Santo Antônio do Rio Doce/MG |  | 126d | 2019-05-02 A | 2019-10-28 A | 1632 | 100% |  | 2019-05-02 | 2019-06-21 | 36d | 2019-05-02 | 2019-06-21 |  |  | 100% |  |  |  |  | 100 | 25 | 100 |  | 25 |
| 1637 | 7.3.1.2.1.2 | Aprovar Plano de Trabalho e abrir OSE - Captação Principal - Santo Antônio do Rio Doce/MG |  | 24d | 2019-10-29 A | 2019-12-02 A | 1636 | 100% |  | 2019-06-24 | 2019-06-28 | 5d | 2019-06-24 | 2019-06-28 |  |  | 100% |  |  |  |  | 100 |  | 100 |  |  |
| 1638 | 7.3.1.2.1.3 | Realizar Levantamento de Campo/Sondagem - Captação Principal - Santo Antônio do Rio Doce/MG |  | 30d | 2019-12-03 A | 2020-01-17 | 1637 | 25% | 22.5d | 2019-11-26 | 2020-01-10 | 30d |  |  | 97d | 0d |  |  |  |  |  |  |  |  |  |  |
| 1639 | 7.3.1.2.1.4 | Elaborar Projeto Básico - Captação Principal - Santo Antônio do Rio Doce/MG |  | 60d | 2020-01-27 | 2020-04-24 | 1638FS+5d |  |  | 2019-05-02 | 2019-06-21 | 36d | 2019-05-02 | 2019-06-21 | 97d | 0d | 100% |  |  |  |  | 100 | 25 | 100 |  | 25 |
| 1640 | 7.3.1.2.1.5 | Aprovar Projeto Básico - Captação Principal - Santo Antônio do Rio Doce/MG |  | 32d | 2020-04-27 | 2020-06-10 | 1639 |  |  | 2018-03-01 | 2018-03-30 | 22d |  |  | 195d | 0d |  |  |  |  |  |  |  |  |  |  |
| 1641 | 7.3.1.2.1.6 | Emitir RT/PQ para Suprimentos - Captação Principal - Santo Antônio do Rio Doce/MG |  | 5d | 2020-07-14 | 2020-07-20 | 1642FF-25d |  |  | 2019-09-17 | 2019-09-30 | 10d | 2019-09-17 | 2019-09-30 | 195d | 0d | 0% |  |  |  |  |  |  |  |  |  |
| 1642 | 7.3.1.2.1.7 | Elaborar Projeto Executivo - Captação Principal - Santo Antônio do Rio Doce/MG |  | 52d | 2020-06-12 | 2020-08-24 | 1636, 1637, 1639, 1640 |  |  | 2019-07-01 | 2019-09-30 | 65d | 2019-07-01 | 2019-09-30 | 195d | 0d | 0% |  |  |  |  |  |  |  |  |  |
| 1643 | 7.3.1.2.1.8 | Elaboração do Projeto Executivo - Captação Principal - Santo Antônio do Rio Doce/MG | milestone | 0d | 2020-08-24 | 2020-08-24 | 1642 |  |  | 2019-09-30 | 2019-09-30 | 0d | 2019-09-30 | 2019-09-30 | 786d | 68d | 0% |  |  |  |  |  |  |  |  |  |
| 1644 | 7.3.1.2.2 | **Engenharia UTR na ETA de Aimorés/MG** |  | 248d | 2019-12-02 A | 2020-12-01 |  | 3% | 239.53d | 2019-05-02 | 2019-10-30 | 128d | 2019-05-02 | 2019-10-30 | 738d |  | 32% | 0% | ok | 0% | Santo Antônio do Rio Doce (distrito Aimorés/MG) | 32 |  | 49 |  |  |
| 1645 | 7.3.1.2.2.1 | Aprovar Plano de Trabalho e abrir OSE - UTR - Santo Antônio do Rio Doce/MG |  | 7d | 2019-12-02 A | 2019-12-10 A | 1636FS+23d | 100% |  | 2019-05-02 | 2019-05-15 | 10d | 2019-05-02 | 2019-05-15 |  |  | 100% | 0% | ok | 0% | Santo Antônio do Rio Doce (distrito Aimorés/MG) | 100 |  | 100 |  |  |
| 1646 | 7.3.1.2.2.2 | Elaborar arranjo para obtenção de Dados de Entrada Licenciamento e Fundiário - UTR - Santo Antônio do Rio Doce/MG |  | 35d | 2020-02-19 | 2020-04-13 | 1645FS+46d |  |  | 2019-06-28 | 2019-07-29 | 22d | 2019-06-28 | 2019-07-29 | 227d | 0d | 4% | 0% | ok | 0% | Santo Antônio do Rio Doce (distrito Aimorés/MG) |  |  |  |  |  |
| 1647 | 7.3.1.2.2.3 | Elaborar Projeto Básico - UTR - Santo Antônio do Rio Doce/MG |  | 70d | 2020-04-14 | 2020-07-23 | 1646 |  |  | 2018-02-08 | 2018-03-21 | 30d | 2018-02-08 | 2018-03-21 | 227d | 0d | 100% |  |  |  |  | 100 |  | 100 |  |  |
| 1648 | 7.3.1.2.2.4 | Aprovar Projeto Básico - UTR - Santo Antônio do Rio Doce/MG |  | 22d | 2020-07-24 | 2020-08-24 | 1647 |  |  | 2018-03-01 | 2018-03-30 | 22d |  |  | 227d | 0d |  |  |  |  |  |  |  |  |  |  |
| 1649 | 7.3.1.2.2.5 | Emitir RT/PQ para Suprimentos - UTR - Santo Antônio do Rio Doce/MG |  | 3d | 2020-10-22 | 2020-10-26 | 1650FF-25d |  |  | 2019-07-30 | 2019-08-20 | 15d | 2019-07-30 | 2019-08-20 | 227d | 0d | 0% | 0% | ok | 0% | Santo Antônio do Rio Doce (distrito Aimorés/MG) |  |  |  |  |  |
| 1650 | 7.3.1.2.2.6 | Elaborar Projeto Executivo - UTR - Santo Antônio do Rio Doce/MG |  | 68d | 2020-08-25 | 2020-12-01 | 1646, 1648 |  |  | 2019-07-30 | 2019-10-30 | 66d | 2019-07-30 | 2019-10-30 | 227d | 0d | 0% | 0% | ok | 0% | Santo Antônio do Rio Doce (distrito Aimorés/MG) |  |  |  |  |  |
| 1651 | 7.3.1.2.2.7 | Elaboração do Projeto Executivo - UTR - Santo Antônio do Rio Doce/MG | milestone | 0d | 2020-12-01 | 2020-12-01 | 1650 |  |  | 2019-10-30 | 2019-10-30 | 0d | 2019-10-30 | 2019-10-30 | 738d | 20d | 0% |  |  |  |  |  |  |  |  |  |

Notes:
- 1627: 28/Jan19: / - Aguardando resposta CIF para continuar com os trabalhos nessa localidade.
- 1631: 27/Nov: / - Aguardando manifestação do CIF quanto ao pleito do SAAE de Aimorés.
- 1632: 27/Nov: / - A população de Santo Antônio do Rio Doce rejeita a água do Rio Doce, ainda que tratada e tem resistência ao consumo de água de manancial subterrâneo. Em função disso, o SAAE Aimorés não aprovou as melhorias de ETA propostas e nem o sistema de captação alternativa (poço). Solicitou ao CIF substituição do ponto de captação principal no rio Doce para o rio Manhuaçu, com a construção de uma adutora de água tratada proveniente da ETA de Aimorés. / - CIF ainda não se manifestou a respeito.
- 1634: 25/Jan19: / - Para essa localidade, o Cronograma da Engenharia contém apenas o desenvolvendo das PQ's e RT, emissão preliminar e final, do projeto "Poço Captação Alternativa". / 27/Nov: / - Mesmo sem o retorno do CIF em relação ao pleito do SAAE Aimorés, a ENG está desenvolvendo o projeto "Poço Captação Alternativa" e o de "Validação do Projeto Básico de Interligação (SAAE)". Verificar com o PG.
- 1644: 18/Fev19: / - Não há projeto previsto no CR ENG. / 10/Dez: / - Aguardando posicionamento do CIF quanto ao pleito feito pelo município/SAAE Aimorés.

| ID | WBS | Task | Type | Duration | Start | Finish | Predecessors | Baseline start | Baseline finish | Baseline duration | Baseline 1 start | Baseline 1 finish | Total slack | Free slack | Text3 | Text25 | Text26 | Text27 | Text29 | Text5 | Text15 | Text4 | Text7 |
| --- | --- | --- | --- | --- | --- | --- | --- | --- | --- | --- | --- | --- | --- | --- | --- | --- | --- | --- | --- | --- | --- | --- | --- |
| 1652 | 7.3.1.2.3 | **Validação dos Projetos** |  | 20d | 2020-12-02 | 2020-12-31 |  | 2019-10-31 | 2019-11-28 | 20d | 2019-10-31 | 2019-11-28 | 718d |  | 0% | 0% | ok | 0% | Santo Antônio do Rio Doce (distrito Aimorés/MG) |  |  |  |  |
| 1653 | 7.3.1.2.3.1 | Validar Projetos com Prefeitura e Operadora - Santo Antônio do Rio Doce/MG |  | 20d | 2020-12-02 | 2020-12-31 | 1643, 1650 | 2019-10-31 | 2019-11-28 | 20d | 2019-10-31 | 2019-11-28 | 718d | 0d | 0% | 0% | ok | 0% | Santo Antônio do Rio Doce (distrito Aimorés/MG) |  |  |  |  |
| 1654 | 7.3.1.2.3.2 | Validação com Prefeitura e Operadora dos Projetos de Melhoria do Sistema de Abastecimento de Água - Santo Antônio do Rio Doce/MG | milestone | 0d | 2020-12-31 | 2020-12-31 | 1647, 1651, 1653 | 2019-11-28 | 2019-11-28 | 0d | 2019-11-28 | 2019-11-28 | 718d | 0d | 0% |  |  |  |  |  |  |  |  |
| 1655 | 7.3.1.3 | Conclusão e Validação da Engenharia - Santo Antônio do Rio Doce/MG | milestone | 0d | 2020-12-31 | 2020-12-31 | 1654 | 2019-11-28 | 2019-11-28 | 0d | 2019-11-28 | 2019-11-28 | 718d | 373d | 0% |  |  |  |  |  |  |  |  |
| 1656 | 7.3.1.4 | **Fundiária** |  | 245d | 2020-04-27 | 2021-04-20 |  | 2019-06-13 | 2019-10-10 | 84d | 2019-06-13 | 2019-10-10 | 97d |  | 13% | 0% | ok | 0% | Santo Antônio do Rio Doce (distrito Aimorés/MG) | 13 | 16 |  |  |
| 1657 | 7.3.1.4.1 | Obter Termo de Autorização de Superficiário - Captação Principal - Santo Antônio do Rio Doce/MG |  | 5d | 2020-04-27 | 2020-05-04 | 1639 | 2019-06-13 | 2019-06-19 | 5d | 2019-06-13 | 2019-06-19 | 97d | 0d | 100% | 0% | ok | 0% | Santo Antônio do Rio Doce (distrito Aimorés/MG) | 100 | 100 |  |  |
| 1658 | 7.3.1.4.2 | Captação Principal - Desimpedimento de área - Santo Antônio do Rio Doce/MG |  | 240d | 2020-05-05 | 2021-04-20 | 1657 | 2019-08-09 | 2019-10-10 | 44d | 2019-08-09 | 2019-10-10 | 97d | 0d | 0% | 0% | ok | 0% | Santo Antônio do Rio Doce (distrito Aimorés/MG) |  |  |  |  |
| 1659 | 7.3.1.4.3 | Conclusão da Regularização Fundiária para as obras de Melhoria do Sistema de Abastecimento da Localidade - Santo Antônio do Rio Doce/MG | milestone | 0d | 2021-04-20 | 2021-04-20 | 1657, 1658 | 2019-10-10 | 2019-10-10 | 0d | 2019-10-10 | 2019-10-10 | 645d | 300d | 0% |  |  |  |  |  |  |  |  |
| 1660 | 7.3.1.5 | **Licenciamento** |  | 184d | 2020-04-14 | 2021-01-07 |  | 2018-10-16 | 2020-04-27 | 381d | 2018-10-16 | 2020-04-27 | 174d |  | 46% | 0% | ok | 0% | Santo Antônio do Rio Doce (distrito Aimorés/MG) | 46 | 41 | 24 | 59 |
| 1661 | 7.3.1.5.1 | Obter Outorga/DAIA para Captação Principal - Santo Antônio do Rio Doce/MG |  | 176d | 2020-04-27 | 2021-01-07 | 1639 | 2019-08-09 | 2020-04-27 | 176d | 2019-08-09 | 2020-04-27 | 166d | 0d | 0% | 0% | ok | 0% | Santo Antônio do Rio Doce (distrito Aimorés/MG) |  |  |  |  |
| 1662 | 7.3.1.5.2 | Licença/Autorização ETA / UTR - Santo Antônio do Rio Doce/MG |  | 176d | 2020-04-14 | 2020-12-23 | 1646 | 2019-04-25 | 2020-01-07 | 176d | 2019-04-25 | 2020-01-07 | 274d | 8d | 25% | 0% | ok | 0% | Santo Antônio do Rio Doce (distrito Aimorés/MG) | 25 | 25 |  |  |
| 1663 | 7.3.1.5.3 | Conclusão do Licenciamento Ambiental da Localidade - Santo Antônio do Rio Doce/MG | milestone | 0d | 2021-01-07 | 2021-01-07 | 1661, 1662 | 2020-04-27 | 2020-04-27 | 0d | 2020-04-27 | 2020-04-27 | 714d | 369d | 0% |  |  |  |  |  |  |  |  |
| 1664 | 7.3.1.6 | **Suprimentos** |  | 156d | 2020-07-21 | 2021-03-08 |  | 2019-08-30 | 2020-03-24 | 140d | 2019-08-30 | 2020-03-24 | 195d |  | 0% | 0% | ok | 0% | Santo Antônio do Rio Doce (distrito Aimorés/MG) |  |  |  |  |
| 1665 | 7.3.1.6.1 | Processo de Contrataçao (Projeto da Prefeitura) - Santo Antônio do Rio Doce/MG |  | 88d | 2020-07-21 | 2020-11-24 | 1641 | 2019-08-30 | 2020-01-07 | 88d | 2019-08-30 | 2020-01-07 | 195d | 68d | 0% | 0% | ok | 0% | Santo Antônio do Rio Doce (distrito Aimorés/MG) |  |  |  |  |
| 1666 | 7.3.1.6.2 | Processo contratação MAS 2 (UTR) - Santo Antônio do Rio Doce/MG |  | 88d | 2020-10-27 | 2021-03-08 | 1649 | 2019-11-12 | 2020-03-24 | 88d | 2019-11-12 | 2020-03-24 | 227d | 0d | 0% | 0% | ok | 0% | Santo Antônio do Rio Doce (distrito Aimorés/MG) |  |  |  |  |
| 1667 | 7.3.1.6.3 | Conclusão da Contratação de Suprimentos das obras de Melhoria do Sistema de Abastecimento de Água - Santo Antônio do Rio Doce/MG | milestone | 0d | 2021-03-08 | 2021-03-08 | 1665, 1666 | 2020-03-24 | 2020-03-24 | 0d | 2020-03-24 | 2020-03-24 | 675d | 330d | 0% |  |  |  |  |  |  |  |  |
| 1668 | 7.3.1.7 | **Infraestrutura** |  | 577d | 2021-03-09 | 2023-07-01 |  | 2020-01-07 | 2021-12-14 | 483d | 2020-01-07 | 2021-12-14 | 98d |  | 0% | 0% | ok | 0% | Santo Antônio do Rio Doce (distrito Aimorés/MG) |  |  |  |  |
| 1669 | 7.3.1.7.1 | **Obras** |  | 577d | 2021-03-09 | 2023-07-01 |  | 2020-01-07 | 2020-11-26 | 223d | 2020-01-07 | 2020-11-26 | 98d |  | 0% |  |  |  |  |  |  |  |  |
| 1670 | 7.3.1.7.1.1 | Executar Captação Principal (Adutora de Aimorés e expansão do Reservatório) - Santo Antônio do Rio Doce/MG |  | 300d | 2021-04-22 | 2022-07-01 | 1642, 1658, 1661, 1665 | 2020-04-28 | 2020-11-11 | 137d | 2020-04-28 | 2020-11-11 | 97d | 0d | 0% | 0% | ok | 0% | Santo Antônio do Rio Doce (distrito Aimorés/MG) |  |  |  |  |
| 1671 | 7.3.1.7.1.2 | Executar UTR na ETA de Aimorés/MG - Santo Antônio do Rio Doce/MG |  | 200d | 2021-03-09 | 2021-12-22 | 1650, 1662, 1666 | 2020-03-25 | 2020-10-08 | 137d | 2020-03-25 | 2020-10-08 | 227d | 130d | 0% | 0% | ok | 0% | Santo Antônio do Rio Doce (distrito Aimorés/MG) |  |  |  |  |
| 1672 | 7.3.1.7.1.3 | Assinatura de Termo de Entrega das Obras de Melhoria do Sistema de Abastecimento de Água - Santo Antônio do Rio Doce | milestone | 0d | 2022-07-01 | 2022-07-01 | 1670, 1671, 1655, 1659, 1663, 1667 | 2020-11-26 | 2020-11-26 | 0d | 2020-11-26 | 2020-11-26 | 345d | 97d | 0% | 0% | ok | 0% | Santo Antônio do Rio Doce (distrito Aimorés/MG) |  |  |  |  |
| 1673 | 7.3.1.7.1.4 | Realizar Acompanhamento da Funcionalidade do Sistema - Captação Principal, UTR na ETA de Aimorés - Santo Antônio do Rio Doce (distrito Aimorés/MG) |  | 365ed | 2022-07-01 | 2023-07-01 | 1678SS | 2020-12-14 | 2021-12-14 | 250d |  |  | 432d |  |  |  |  |  |  |  |  |  |  |
| 1674 | 7.3.1.7.2 | **Operação** |  | 62d | 2022-07-01 | 2022-09-29 |  | 2020-11-27 | 2021-12-14 | 260d | 2020-11-27 | 2021-12-14 | 97d |  | 0% | 0% | ok | 0% | Santo Antônio do Rio Doce (distrito Aimorés/MG) |  |  |  |  |
| 1675 | 7.3.1.7.2.1 | Realizar Treinamento Operacional do Sistema - Santo Antônio do Rio Doce/MG |  | 5d | 2022-07-04 | 2022-07-08 | 1670, 1671 | 2020-11-27 | 2020-12-03 | 5d | 2020-11-27 | 2020-12-03 | 326d | 0d | 0% | 0% | ok | 0% | Santo Antônio do Rio Doce (distrito Aimorés/MG) |  |  |  |  |
| 1676 | 7.3.1.7.2.2 | Realizar Testes e Pré-operação - Santo Antônio do Rio Doce/MG |  | 14d | 2022-07-11 | 2022-07-28 | 1675 | 2020-12-04 | 2020-12-23 | 14d | 2020-12-04 | 2020-12-23 | 326d |  | 0% | 0% | ok | 0% | Santo Antônio do Rio Doce (distrito Aimorés/MG) |  |  |  |  |

Notes:
- 1656: 27/Nov: / - Aguardando decisão do CIF quanto ao pleito do município/SAAE Aimorés. / - Datas previstas com base na data de decisão do CIF considerado no CR.
- 1657: 27/Nov: / - Caso o CIF dê o seu de acordo ao pleito realizado pelo município/SAAE Aimorés, a adutora ficará próxima a ferrovia, passará em trecho urbano dentro de Baixo Guandu/ES (município vizinho) e fará travessia na ponte sobre o rio Doce.
- 1658: 27/Nov: / - Aguardando decisão do CIF quanto ao pleito do município/SAAE Aimorés.
- 1660: 13/Fev19: / - Em hold, aguardando retorno do CIF. / 27/Nov: / - Aguardando decisão do CIF quanto ao pleito do município/SAAE Aimorés.

| ID | WBS | Task | Type | Duration | Start | Finish | Predecessors | Complete | Remaining | Baseline start | Baseline finish | Baseline duration | Baseline 1 start | Baseline 1 finish | Total slack | Free slack | Text3 | Text25 | Text26 | Text27 | Text29 | Text4 | Text5 | Text7 | Text15 | Text23 | Text9 |
| --- | --- | --- | --- | --- | --- | --- | --- | --- | --- | --- | --- | --- | --- | --- | --- | --- | --- | --- | --- | --- | --- | --- | --- | --- | --- | --- | --- |
| 1677 | 7.3.1.7.2.3 | **Operação Assistida** |  | 62d | 2022-07-01 | 2022-09-29 |  |  |  | 2020-11-27 | 2021-03-04 | 64d | 2020-11-27 | 2021-03-04 | 97d |  | 0% | 0% | ok | 0% | Santo Antônio do Rio Doce (distrito Aimorés/MG) |  |  |  |  |  |  |
| 1678 | 7.3.1.7.2.3.1 | Realizar Operação Assistida - Santo Antônio do Rio Doce/MG |  | 90ed | 2022-07-01 | 2022-09-29 | 1670, 1671 |  |  | 2020-11-27 | 2021-03-04 | 3.2mo | 2020-11-27 | 2021-03-04 | 432d | 0d | 0% | 0% | ok | 0% | Santo Antônio do Rio Doce (distrito Aimorés/MG) |  |  |  |  |  |  |
| 1679 | 7.4 | **Baixo Guandu/ES (sede)** |  | 1123d | 2017-09-25 A | 2022-03-10 |  | 22% | 877.53d | 2017-09-25 | 2021-12-30 | 1076d | 2017-09-25 | 2021-12-30 | 423d |  | 42% | 0% | ok | 0% | Baixo Guandu/ES (sede) | 29 | 42 | 60 | 48 | Socioambiental |  |
| 1680 | 7.4.1 | **Captação Alternativa** |  | 915d | 2018-03-23 A | 2021-11-13 |  | 37% | 577.96d | 2017-09-25 | 2021-12-30 | 1076d |  |  | 502d |  |  |  |  |  |  |  |  |  |  |  |  |
| 1681 | 7.4.1.1 | **Estudos de Concepção do Sistema** |  | 183d | 2018-03-23 A | 2018-12-04 A |  | 100% |  | 2017-09-25 | 2018-12-04 | 312d | 2017-09-25 | 2018-12-04 |  |  | 100% | 0% | ok | 0% | Baixo Guandu/ES (sede) | 100 | 100 | 100 | 100 |  |  |
| 1682 | 7.4.1.1.1 | Declaração de Escopo e Premissas de Projeto (DEPP) concluída - Baixo Guandu/ES | milestone | 0d | 2018-03-23 A | 2018-03-23 A | 25, 26 | 100% |  | 2018-03-23 | 2018-03-23 | 0d | 2018-03-23 | 2018-03-23 |  |  | 100% | 0% | ok | 0% | Baixo Guandu/ES (sede) | 100 | 100 | 100 | 100 |  |  |
| 1683 | 7.4.1.1.2 | Aprovação das DEPPs pela Operadora e Prefeitura - Baixo Guandu/ES | milestone | 0d | 2018-03-23 A | 2018-03-23 A | 1682 | 100% |  | 2017-09-25 | 2017-09-25 | 0d | 2017-09-25 | 2017-09-25 |  |  | 100% | 0% | ok | 0% | Baixo Guandu/ES (sede) | 100 | 100 | 100 | 100 |  |  |
| 1684 | 7.4.1.1.3 | **Captação Superficial - rio Guandu** |  | 1d | 2018-12-04 A | 2018-12-04 A |  | 100% |  | 2018-12-04 | 2018-12-04 | 1d | 2018-12-04 | 2018-12-04 |  |  | 100% | 0% | ok | 0% | Baixo Guandu/ES (sede) | 100 | 100 | 100 | 100 |  |  |
| 1685 | 7.4.1.1.3.1 | Realizar Laudo dos Serviços de Coleta e Análise de Água - Baixo Guandu/ES |  | 1d | 2018-12-04 A | 2018-12-04 A | 1682 | 100% |  | 2018-12-04 | 2018-12-04 | 1d | 2018-12-04 | 2018-12-04 |  |  | 100% | 0% | ok | 0% | Baixo Guandu/ES (sede) | 100 | 100 | 100 | 100 |  |  |
| 1686 | 7.4.1.1.3.2 | Conclusão do Estudo de Concepção da Captação Superficial - Baixo Guandu/ES | milestone | 0d | 2018-12-04 A | 2018-12-04 A | 1685 | 100% |  | 2018-12-04 | 2018-12-04 | 0d | 2018-12-04 | 2018-12-04 |  |  | 100% |  |  |  |  | 100 | 100 | 100 | 100 |  |  |
| 1687 | 7.4.1.2 | **Engenharia Básica e Detalhada** |  | 489d | 2018-04-30 A | 2020-04-06 |  | 88% | 59.1d | 2018-04-30 | 2019-08-30 | 341d | 2018-04-30 | 2019-08-30 | 534d |  | 87% | 0% | ok | 0% | Baixo Guandu/ES (sede) | 76 | 87 | 79 | 96 | Socioambiental |  |
| 1688 | 7.4.1.2.1 | **Engenharia Captação Alternativa (Rio Guandu)** |  | 489d | 2018-04-30 A | 2020-04-06 |  | 88% | 59.1d | 2018-04-30 | 2019-06-03 | 279d | 2018-04-30 | 2019-06-03 | 534d |  | 100% | 0% | ok | 0% | Baixo Guandu/ES (sede) | 82 | 100 | 82 | 100 | Socioambiental |  |
| 1689 | 7.4.1.2.1.1 | Aprovação Plano de Trabalho /abertura OSE - Captação Alternativa - Rio Guandu - Baixo Guandu/ES |  | 29d | 2018-11-05 A | 2018-12-13 A | 1682 | 100% |  | 2018-11-05 | 2018-12-13 | 29d | 2018-11-05 | 2018-12-13 |  |  | 100% | 0% | ok | 0% | Baixo Guandu/ES (sede) | 100 | 100 | 100 | 100 |  |  |
| 1690 | 7.4.1.2.1.2 | Levantar Dados de Entrada (levantamento de campo, topografia) - Captação Alternativa - Rio Guandu - Baixo Guandu/ES |  | 142d | 2018-04-30 A | 2018-11-13 A | 1682, 1689 | 100% |  | 2018-04-30 | 2018-11-13 | 142d | 2018-04-30 | 2018-11-13 |  |  | 100% | 0% | Não OK | 0% | Baixo Guandu/ES (sede) | 100 | 100 | 100 | 100 | Socioambiental | Não OK |
| 1691 | 7.4.1.2.1.3 | Realizar sondagem - Captação Alternativa - Rio Guandu - Baixo Guandu/ES |  | 56d | 2019-03-13 A | 2019-06-03 A | 1690FS+81d | 100% |  | 2019-01-25 | 2019-02-25 | 22d | 2019-01-25 | 2019-02-25 |  |  | 100% |  |  |  |  | 100 | 100 | 100 | 100 |  |  |
| 1692 | 7.4.1.2.1.4 | Elaborar arranjo para obtenção de Dados de Entrada Licenciamento e Fundiário - Adequação Adutora - Captação Alternativa - Rio Guandu - Baixo Guandu/ES |  | 267d | 2018-05-01 A | 2019-05-17 A | 1682 | 100% |  | 2018-05-01 | 2018-06-01 | 22d | 2018-05-01 | 2018-06-01 |  |  | 100% | 0% | Não OK | 0% | Baixo Guandu/ES (sede) | 100 | 100 | 100 | 100 | Socioambiental | Não OK |
| 1693 | 7.4.1.2.1.5 | Emitir RT/PQ para Suprimentos - Adequação Adutora - Captação Alternativa - Rio Guandu - Baixo Guandu/ES |  | 10d | 2019-09-17 A | 2019-09-30 A | 1694FF | 100% |  | 2019-05-21 | 2019-06-03 | 10d | 2019-05-21 | 2019-06-03 |  |  | 100% | 0% | Não OK | 0% | Baixo Guandu/ES (sede) |  | 100 |  | 100 | Socioambiental | Não OK |
| 1694 | 7.4.1.2.1.6 | Elaborar Projeto Executivo - Adequação Adutora (SE 32101) - Captação Alternativa - Rio Guandu - Baixo Guandu/ES |  | 351d | 2018-05-15 A | 2019-09-30 A | 1691FF, 1692SS+10d | 100% |  | 2019-02-25 | 2019-06-03 | 65d | 2019-02-25 | 2019-06-03 |  |  | 100% | 0% | Não OK | 0% | Baixo Guandu/ES (sede) | 85 | 100 | 85 | 100 | Socioambiental | Não OK |
| 1695 | 7.4.1.2.1.7 | Elaborar arranjo para obtenção de Dados de Entrada Licenciamento e Fundiário - Repotenciamento da Elevatória - Captação Alternativa - Rio Guandu - Baixo Guandu/ES |  | 55d | 2019-05-16 A | 2019-08-01 A | 1690FS+124d | 100% |  | 2018-05-01 | 2018-06-01 | 22d | 2018-05-01 | 2018-06-01 |  |  | 100% |  |  |  |  | 25 | 100 | 25 | 100 |  |  |
| 1696 | 7.4.1.2.1.8 | Emitir RT/PQ para Suprimentos - Repotenciamento da Elevatória - Captação Alternativa - Rio Guandu - Baixo Guandu/ES |  | 10d | 2019-09-17 A | 2019-09-30 A | 1694FF | 100% |  | 2019-05-21 | 2019-06-03 | 10d | 2019-05-21 | 2019-06-03 |  |  | 100% |  |  |  |  |  | 100 |  | 100 |  |  |
| 1697 | 7.4.1.2.1.9 | Elaborar Projeto Executivo - Repotenciamento da Elevatória (SE 32252) - Captação Alternativa - Rio Guandu - Baixo Guandu/ES |  | 146d | 2019-08-02 A | 2020-03-05 | 1695 | 25% | 109.5d | 2019-02-25 | 2019-06-03 | 65d | 2019-02-25 | 2019-06-03 | 534d | 0d | 100% |  |  |  |  |  | 100 |  | 100 |  |  |
| 1698 | 7.4.1.2.1.10 | Obter aprovação da Operadora/Prefeitura |  | 22d | 2020-03-06 | 2020-04-06 | 1697 |  |  | 2020-03-06 | 2020-04-06 | 22d |  |  | 534d | 0d |  |  |  |  |  |  |  |  |  |  |  |
| 1699 | 7.4.1.2.1.11 | Elaboração do Projeto Executivo - Captação Alternativa - Rio Guandu - Baixo Guandu/ES | milestone | 0d | 2020-04-06 | 2020-04-06 | 1694, 1695, 1698 |  |  | 2019-06-03 | 2019-06-03 | 0d | 2019-06-03 | 2019-06-03 | 534d | 32d | 100% |  |  |  |  |  | 100 |  | 100 |  |  |
| 1700 | 7.4.1.3 | **Fundiária** |  | 191d | 2019-08-16 A | 2020-05-25 |  | 48% | 99.61d | 2018-11-12 | 2019-08-28 | 199d | 2018-11-12 | 2019-08-28 | 870d |  | 78% | 0% | ok | 0% | Baixo Guandu/ES (sede) |  | 78 |  | 100 | Socioambiental |  |
| 1701 | 7.4.1.3.1 | **Captação Alternativa - Adutora Rio Guandu - Desimpedimento da Área e Negociação de Servidão** |  | 191d | 2019-08-16 A | 2020-05-25 |  | 48% | 99.61d | 2018-11-12 | 2019-05-22 | 131d | 2018-11-12 | 2019-05-22 | 502d |  | 100% |  |  |  |  |  | 100 |  | 100 |  |  |
| 1702 | 7.4.1.3.1.1 | Realizar Levantamento da documentação da propriedade - Cadastro dos proprietários - Baixo Guandu/ES |  | 89d | 2019-08-16 A | 2019-12-20 A | 1692FS+62d | 100% |  | 2018-11-12 | 2018-12-11 | 22d | 2018-11-12 | 2018-12-11 |  |  | 100% |  |  |  |  |  | 100 |  | 100 |  |  |
| 1703 | 7.4.1.3.1.2 | Obter laudo de Avaliação - Baixo Guandu/ES |  | 16d | 2020-01-02 | 2020-01-23 | 1702FS+5d |  |  | 2018-12-12 | 2019-01-11 | 22d | 2018-12-12 | 2019-01-11 | 502d | 0d | 100% |  |  |  |  |  | 100 |  | 100 |  |  |
| 1704 | 7.4.1.3.1.3 | Obter assinatura do Contrato de servidão pelo proprietário - Baixo Guandu/ES |  | 31d | 2020-01-24 | 2020-03-11 | 1703 |  |  | 2019-01-12 | 2019-03-10 | 44d | 2019-01-12 | 2019-03-10 | 502d | 0d | 100% |  |  |  |  |  | 100 |  | 100 |  |  |
| 1705 | 7.4.1.3.1.4 | Lavrar Escritura Pública de Servidão no cartório de notas - Baixo Guandu/ES |  | 30d | 2020-03-12 | 2020-04-24 | 1704 |  |  | 2019-03-11 | 2019-04-23 | 30d | 2019-03-11 | 2019-04-23 | 502d | 0d | 100% |  |  |  |  |  | 100 |  | 100 |  |  |
| 1706 | 7.4.1.3.1.5 | Averbar a escritura pública na matrícula do imóvel - Baixo Guandu/ES |  | 20d | 2020-04-27 | 2020-05-25 | 1705 |  |  | 2019-04-24 | 2019-05-22 | 20d | 2019-04-24 | 2019-05-22 | 502d | 0d | 100% |  |  |  |  |  | 100 |  | 100 |  |  |
| 1707 | 7.4.1.3.1.6 | Regularização da Servidão do imóvel - Adutora rio Guandu - Baixo Guandu/ES | milestone | 0d | 2020-05-25 | 2020-05-25 | 1706 |  |  | 2019-05-22 | 2019-05-22 | 0d | 2019-05-22 | 2019-05-22 | 502d | 0d | 100% |  |  |  |  |  | 100 |  | 100 |  |  |
| 1708 | 7.4.1.3.2 | Conclusão da Regularização Fundiária para as obras de Melhoria do Sistema de Abastecimento - Baixo Gandu/ES | milestone | 0d | 2020-05-25 | 2020-05-25 | 1707 |  |  | 2019-05-22 | 2019-05-22 | 0d | 2019-05-22 | 2019-05-22 | 870d | 120d | 100% |  |  |  |  |  | 100 |  | 100 |  |  |

Notes:
- 1683: 23/Nov: / - Anuência dada por meio de Ata de Reunião datada de 25/09/18.
- 1685: 19/Dez / - Laudo já previsto no PMQACH e nos monitoramentos do SAAE. (Verificar com a Bárbara data correta).
- 1687: 28/Jan19: / - Segundo José Alaércio, não há previsão de projeto para a Captação Principal pela Engenharia, com exceção do projeto de REPOTENCIAMENTO DA ELEVATÓRIA que atende as duas captações: Principal e Alternativa. As datas referentes ao projeto desse Repotenciamento estão sendo consideradas junto ao da Captação Alternativa.
- 1688: 25/Jan19: / - Considerados para a Captação Alternativa as datas dos projetos de "ADEQUAÇÃO ADUTORA RIO GUANDÚ" e de "REPOTENCIAMENTO DA ELEVATÓRIA".
- 1689: 25/Jan19: / - Plano de Trabalho previsto apenas para o projeto de Repotenciamento da Elevatória e finalizado em 13/12/18. Não há previsão de emissão de Plano de Trabalho para o projeto de Adequação Adutora Rio Guandú.
- 1690: 25/Jan19: / - Adequação Adutora Rio Guandú: levantamento de campo e topografia iniciados em 30/04 e concluídos em 13/11/18; Sondagem prevista pra iniciar em 13/03 e finalizar em 11/04/19. / - Repotenciamento da Elevatória: levantamento de campo e topografia iniciados em 05/11 e concluídos em 09 e 26/11/18, respectivamente.
- 1692: 25/Jan19: / - Projeto Conceitual Adequação Adutora Rio Guandú iniciado em 01/05/18 e previsto pra finalizar em 31/01/19; para o de Repotenciamento da Elevatória previsto pra iniciar em 01/02 e finalizar em 07/03/19.
- 1693: 25/Jan19: / - Emissão Preliminar para Suprimentos de RT/PQ referente ao projeto de Adequação Adutora Rio Guandú iniciado em 26/12/18 e previsto pra finalizar em 07/02/19; ao de Repotenciamento da Elevatória previsto pra iniciar em 19/02 e finalizar em 14/03/19.
- 1694: 25/Jan19: / - Projeto Executivo Adequação Adutora Rio Guandú iniciado em 15/05/18 e previsto pra finalizar em 18/04/19; para o de Repotenciamento da Elevatória previsto pra iniciar em 08/03 e finalizar em 17/05/19.
- 1700: 01/Fev19 / - Fundiário não possui conhecimento de demandas para Captação Principal, Melhorias na ETA existente, Nova ETA e UTR.
- 1701: 04/Dez: / - Não consta no CR da Gestão Fundiária. Mas consta no CR da Infra atualizado pelo Fundiário. / 23/Nov / - Processo iniciado aguardando retorno da EDP Energias após contato feito (captação dentro do rio Guandu, da massa falida da Luxor Geradora e hoje administrada pela EDP) / - Não iniciado. Segundo planilha fundiário/CR Infra, aguardando projeto de engenharia. / - Na planilha do Fundiário consta adutora de 10km (Mascarenhas), mas na planilha de detalhamento da Engenharia de 900m (existente: rio Guandu à ETA). / - 5 imóveis envolvidos (captação, reservatório, EFVM, Faixa de Domínio BR-259, Povoado de Mascarenhas). (Refere-se a Mascarenhas)

| ID | WBS | Task | Type | Duration | Start | Finish | Predecessors | Complete | Remaining | Baseline start | Baseline finish | Baseline duration | Baseline 1 start | Baseline 1 finish | Total slack | Free slack | Text3 | Text5 | Text15 | Text25 | Text26 | Text27 | Text29 | Indicadores MIR | Text4 | Text7 | Text23 | Text9 |
| --- | --- | --- | --- | --- | --- | --- | --- | --- | --- | --- | --- | --- | --- | --- | --- | --- | --- | --- | --- | --- | --- | --- | --- | --- | --- | --- | --- | --- |
| 1709 | 7.4.1.4 | **Licenciamento** |  | 103d | 2019-12-18 A | 2020-05-21 |  | 25% | 77.25d | 2019-01-22 | 2020-01-13 | 242d | 2019-01-22 | 2020-01-13 | 872d |  | 44% | 44 | 60 | 0% | ok | 0% | Baixo Guandu/ES (sede) |  |  |  |  |  |
| 1710 | 7.4.1.4.1 | Captação Alternativa - Outorga para captação e Autorizações - Baixo Guandu/ES |  | 103d | 2019-12-18 A | 2020-05-21 | 1695FS+95d | 25% | 77.25d | 2019-01-22 | 2019-10-04 | 176d | 2019-01-22 | 2019-10-04 | 504d | 0d | 60% | 60 | 60 | 0% | ok | 0% | Baixo Guandu/ES (sede) |  |  |  |  |  |
| 1711 | 7.4.1.4.2 | Conclusão do Licenciamento Ambiental da Localidade - Baixo Gandu/ES | milestone | 0d | 2020-05-21 | 2020-05-21 | 1710 |  |  | 2020-01-13 | 2020-01-13 | 0d | 2020-01-13 | 2020-01-13 | 872d | 122d | 0% |  |  |  |  |  |  |  |  |  |  |  |
| 1712 | 7.4.1.5 | **Suprimentos** |  | 90d | 2019-10-01 A | 2020-02-10 |  | 25% | 67.5d | 2019-06-03 | 2019-10-04 | 88d | 2019-06-03 | 2019-10-04 | 939d |  | 21% | 21 | 21 | 0% | ok | 0% | Baixo Guandu/ES (sede) |  |  |  |  |  |
| 1713 | 7.4.1.5.1 | Realizar processo de contratação - Adequação Adutora Rio Guandu e Repotenciamento da Elevatória - Baixo Guandu/ES |  | 90d | 2019-10-01 A | 2020-02-10 | 1693, 1696 | 25% | 67.5d | 2019-10-01 | 2020-02-06 | 88d |  |  | 571d | 0d |  |  |  |  |  |  |  |  |  |  |  |  |
| 1714 | 7.4.1.5.2 | Conclusão da Contratação de Suprimentos das obras de Melhoria do Sistema de Abastecimento de Água - Baixo Gandu/ES | milestone | 0d | 2020-02-10 | 2020-02-10 | 1713 |  |  | 2019-10-04 | 2019-10-04 | 0d | 2019-10-04 | 2019-10-04 | 939d | 189d | 0% |  |  |  |  |  |  |  |  |  |  |  |
| 1715 | 7.4.1.6 | **Infraestrutura** |  | 368d | 2020-05-26 | 2021-11-13 |  |  |  | 2019-10-04 | 2021-12-30 | 556d | 2019-10-04 | 2021-12-30 | 502d |  | 0% |  |  | 0% | ok | 0% | Baixo Guandu/ES (sede) |  |  |  |  |  |
| 1716 | 7.4.1.6.1 | **Obras** |  | 120d | 2020-05-26 | 2020-11-13 |  |  |  | 2019-10-04 | 2020-12-12 | 296d | 2019-10-04 | 2020-12-12 | 502d |  | 0% |  |  |  |  |  |  |  |  |  |  |  |
| 1717 | 7.4.1.6.1.1 | Executar Captação Alternativa (rio Guandu) - Baixo Guandu/ES |  | 120d | 2020-05-26 | 2020-11-13 | 1694, 1697, 1699, 1707, 1710, 1713 |  |  | 2019-10-04 | 2020-12-12 | 296d | 2019-10-04 | 2020-12-12 | 502d | 0d | 0% |  |  | 0% | ok | 0% | Baixo Guandu/ES (sede) | CA |  |  |  |  |
| 1718 | 7.4.1.6.1.2 | Assinatura de Termo de Entrega das Obras de Melhoria do Sistema de Abastecimento de Água - Baixo Guandu/ES | milestone | 0d | 2020-11-13 | 2020-11-13 | 1717, 1708, 1711, 1714 |  |  | 2020-12-12 | 2020-12-12 | 0d | 2020-12-12 | 2020-12-12 | 750d | 502d | 0% |  |  | 0% | ok | 0% | Baixo Guandu/ES (sede) |  |  |  |  |  |
| 1719 | 7.4.1.6.2 | **Operação** |  | 248d | 2020-11-13 | 2021-11-13 |  |  |  | 2020-12-14 | 2021-12-30 | 260d | 2020-12-14 | 2021-12-30 | 502d |  | 0% |  |  | 0% | ok | 0% | Baixo Guandu/ES (sede) |  |  |  |  |  |
| 1720 | 7.4.1.6.2.1 | Realizar Treinamento Operacional do Sistema - Baixo Guandu/ES |  | 5d | 2020-11-16 | 2020-11-20 | 1717 |  |  | 2020-12-14 | 2020-12-18 | 5d | 2020-12-14 | 2020-12-18 | 731d | 0d | 0% |  |  | 0% | ok | 0% | Baixo Guandu/ES (sede) |  |  |  |  |  |
| 1721 | 7.4.1.6.2.2 | Realizar Testes e Pré-operação - Baixo Guandu/ES |  | 14d | 2020-11-23 | 2020-12-10 | 1720 |  |  | 2020-12-21 | 2021-01-12 | 14d | 2020-12-21 | 2021-01-12 | 731d |  | 0% |  |  | 0% | ok | 0% | Baixo Guandu/ES (sede) |  |  |  |  |  |
| 1722 | 7.4.1.6.2.3 | Realizar Acompanhamento da Funcionalidade do Sistema - Captação Alternativa - Baixo Guandu/ES (sede) |  | 365ed | 2020-11-13 | 2021-11-13 | 1724SS |  |  | 2020-12-14 | 2021-12-30 | 260d |  |  | 2217d |  |  |  |  |  |  |  |  |  |  |  |  |  |
| 1723 | 7.4.1.6.2.4 | **Operação Assistida** |  | 61d | 2020-11-13 | 2021-02-11 |  |  |  | 2020-12-14 | 2021-03-19 | 64d | 2020-12-14 | 2021-03-19 | 502d |  | 0% |  |  | 0% | ok | 0% | Baixo Guandu/ES (sede) |  |  |  |  |  |
| 1724 | 7.4.1.6.2.4.1 | Realizar Operação Assistida - Baixo Guandu/ES |  | 90ed | 2020-11-13 | 2021-02-11 | 1717 |  |  | 2020-12-14 | 2021-03-19 | 3.2mo | 2020-12-14 | 2021-03-19 | 2217d | 0d | 0% |  |  | 0% | ok | 0% | Baixo Guandu/ES (sede) |  |  |  |  |  |
| 1725 | 7.4.2 | **Melhorias na ETA** |  | 999d | 2017-09-25 A | 2021-09-08 |  | 9% | 905.11d | 2017-09-25 | 2021-12-30 | 1076d |  |  | 547d |  |  |  |  |  |  |  |  |  |  |  |  |  |
| 1726 | 7.4.2.1 | **Estudos de Concepção do Sistema** |  | 312d | 2017-09-25 A | 2018-12-04 A |  | 100% |  | 2017-09-25 | 2018-12-04 | 312d | 2017-09-25 | 2018-12-04 |  |  | 100% | 100 | 100 | 0% | ok | 0% | Baixo Guandu/ES (sede) |  | 100 | 100 |  |  |
| 1727 | 7.4.2.1.1 | Declaração de Escopo e Premissas de Projeto (DEPP) concluída - Baixo Guandu/ES | milestone | 0d | 2018-03-23 A | 2018-03-23 A | 25, 26 | 100% |  | 2018-03-23 | 2018-03-23 | 0d | 2018-03-23 | 2018-03-23 |  |  | 100% | 100 | 100 | 0% | ok | 0% | Baixo Guandu/ES (sede) |  | 100 | 100 |  |  |
| 1728 | 7.4.2.1.2 | Aprovação das DEPPs pela Operadora e Prefeitura - Baixo Guandu/ES | milestone | 0d | 2017-09-25 A | 2017-09-25 A | 25, 26 | 100% |  | 2017-09-25 | 2017-09-25 | 0d | 2017-09-25 | 2017-09-25 |  |  | 100% | 100 | 100 | 0% | ok | 0% | Baixo Guandu/ES (sede) |  | 100 | 100 |  |  |
| 1729 | 7.4.2.1.3 | Conclusão dos Estudos de Concepção das Melhorias do Sistema de Abastecimento de Água - Baixo Gandu/ES | milestone | 0d | 2018-12-04 A | 2018-12-04 A | 1728 | 100% |  | 2018-12-04 | 2018-12-04 | 0d | 2018-12-04 | 2018-12-04 |  |  | 100% | 100 | 100 |  |  |  |  |  | 100 | 100 |  |  |
| 1730 | 7.4.2.2 | **Engenharia Básica e Detalhada** |  | 204d | 2018-09-06 A | 2019-06-28 A |  | 100% |  | 2018-04-30 | 2019-08-30 | 341d | 2018-04-30 | 2019-08-30 |  |  | 87% | 87 | 96 | 0% | ok | 0% | Baixo Guandu/ES (sede) |  | 76 | 79 | Socioambiental |  |
| 1731 | 7.4.2.2.1 | **Engenharia Pequenas Melhorias na ETA existente** |  | 204d | 2018-09-06 A | 2019-06-28 A |  | 100% |  | 2018-09-06 | 2019-06-09 | 190d | 2018-09-06 | 2019-06-09 |  |  | 100% | 100 | 100 | 0% | ok | 0% | Baixo Guandu/ES (sede) |  | 84 | 84 | Socioambiental |  |
| 1732 | 7.4.2.2.1.1 | Aprovação Plano de Trabalho /abertura OSE - Melhorias na ETA - Baixo Guandu/ES |  | 8d | 2018-09-06 A | 2018-09-17 A | 1727 | 100% |  | 2018-09-06 | 2018-09-17 | 8d | 2018-09-06 | 2018-09-17 |  |  | 100% | 100 | 100 | 0% | ok | 0% | Baixo Guandu/ES (sede) |  | 100 | 100 |  |  |
| 1733 | 7.4.2.2.1.2 | Dados de Entrada (levantamento de campo, topografia, sondagem e DR equipamento) - Melhorias na ETA - Baixo Guandu/ES |  | 12d | 2018-10-11 A | 2018-10-26 A | 1732 | 100% |  | 2018-10-11 | 2018-10-26 | 12d | 2018-10-11 | 2018-10-26 |  |  | 100% | 100 | 100 | 0% | Não OK | 0% | Baixo Guandu/ES (sede) |  | 100 | 100 | Socioambiental | Não OK |
| 1734 | 7.4.2.2.1.3 | Elaborar arranjo para obtenção de Dados de Entrada Licenciamento e Fundiário - Melhorias na ETA - Baixo Guandu/ES |  | 33d | 2018-10-31 A | 2018-12-14 A | 1733SS+65d | 100% |  | 2018-10-31 | 2018-12-14 | 33d | 2018-10-31 | 2018-12-14 |  |  | 100% | 100 | 100 | 0% | Não OK | 0% | Baixo Guandu/ES (sede) |  | 100 | 100 | Socioambiental | Não OK |
| 1735 | 7.4.2.2.1.4 | Emitir RT/PQ para Suprimentos - Melhorias na ETA - Baixo Guandu/ES |  | 10d | 2019-06-14 A | 2019-06-28 A | 1736FF | 100% |  | 2019-04-26 | 2019-05-10 | 10d | 2019-04-26 | 2019-05-10 |  |  | 100% | 100 | 100 | 0% | ok | 0% | Baixo Guandu/ES (sede) |  | 100 | 100 |  |  |
| 1736 | 7.4.2.2.1.5 | Elaborar Projeto Executivo - Melhorias na ETA - Baixo Guandu/ES |  | 98d | 2019-02-04 A | 2019-06-28 A | 1734 | 100% |  | 2019-02-04 | 2019-05-10 | 64d | 2019-02-04 | 2019-05-10 |  |  | 100% | 100 | 100 | 0% | ok | 0% | Baixo Guandu/ES (sede) |  | 100 | 100 |  |  |
| 1737 | 7.4.2.2.1.6 | Elaboração do Projeto Executivo - Melhorias na ETA - Baixo Guandu/ES | milestone | 0d | 2019-06-28 A | 2019-06-28 A | 1736 | 100% |  | 2019-05-10 | 2019-05-10 | 0d | 2019-05-10 | 2019-05-10 |  |  | 100% | 100 | 100 |  |  |  |  |  | 100 | 100 |  |  |

Notes:
- 1710: 23/Nov: / - Segundo Licenciamento, aguardando projeto para definir se será necessário licenciar.
- 1728: 23/Nov: / - Anuência dada por meio de Ata de Reunião datada de 25/09/18.
- 1730: 28/Jan19: / - Segundo José Alaércio, não há previsão de projeto para a Captação Principal pela Engenharia, com exceção do projeto de REPOTENCIAMENTO DA ELEVATÓRIA que atende as duas captações: Principal e Alternativa. As datas referentes ao projeto desse Repotenciamento estão sendo consideradas junto ao da Captação Alternativa.
- 1731: 19/Dez / - Definiu-se por instalar uma ETA modular nova para compensar a redução da vazão da unidade antiga devido ao decantador possuir baixa profundidade.
- 1733: 25/Jan19: / - Levantamento de campo realizado/concluído em 18 a 24/09/18; Topografia realizado/concluído em 25/09 a 19/10/18; DR Equipamento concluído em 11 a 17/12/18; Sondagem prevista pra iniciar em 08/03 e finalizar em 28/03/19. / 19/Dez / - Considerando aqui nos dados de entrada os projetos de "Nova ETA / UTR" (início em 18/09/18 com previsão de término para 08/01/19) e "Melhorias na ETA" (início previsto para 11/10 e término 21/12/18), segundo CR ENG de 14/12/18.

| ID | WBS | Task | Type | Duration | Start | Finish | Predecessors | Complete | Remaining | Baseline start | Baseline finish | Baseline duration | Baseline 1 start | Baseline 1 finish | Total slack | Free slack | Text3 | Text5 | Text15 | Text25 | Text26 | Text27 | Text29 | Indicadores MIR | Text4 | Text7 | Text1 | Text23 | Text9 |
| --- | --- | --- | --- | --- | --- | --- | --- | --- | --- | --- | --- | --- | --- | --- | --- | --- | --- | --- | --- | --- | --- | --- | --- | --- | --- | --- | --- | --- | --- |
| 1738 | 7.4.2.3 | **Suprimentos** |  | 88d | 2020-01-07 | 2020-05-15 |  |  |  | 2019-06-03 | 2019-10-04 | 88d | 2019-06-03 | 2019-10-04 | 548d |  | 21% | 21 | 21 | 0% | ok | 0% | Baixo Guandu/ES (sede) |  |  |  |  |  |  |
| 1739 | 7.4.2.3.1 | Realizar processo de contratação - Melhorias de ETA - Baixo Guandu/ES |  | 88d | 2020-01-07 | 2020-05-15 | 1737FS+130d |  |  | 2019-10-01 | 2020-02-06 | 88d |  |  | 548d | 0d |  |  |  |  |  |  |  |  |  |  |  |  |  |
| 1740 | 7.4.2.3.2 | Conclusão da Contratação de Suprimentos das obras de Melhoria do Sistema de Abastecimento de Água - Baixo Gandu/ES | milestone | 0d | 2020-05-15 | 2020-05-15 | 1739 |  |  | 2019-10-04 | 2019-10-04 | 0d | 2019-10-04 | 2019-10-04 | 876d | 80d | 0% |  |  |  |  |  |  |  |  |  |  |  |  |
| 1741 | 7.4.2.4 | **Infraestrutura** |  | 329d | 2020-05-18 | 2021-09-08 |  |  |  | 2019-10-04 | 2021-12-30 | 556d | 2019-10-04 | 2021-12-30 | 547d |  | 0% |  |  | 0% | ok | 0% | Baixo Guandu/ES (sede) |  |  |  |  |  |  |
| 1742 | 7.4.2.4.1 | **Obras** |  | 80d | 2020-05-18 | 2020-09-08 |  |  |  | 2019-10-04 | 2020-12-12 | 296d | 2019-10-04 | 2020-12-12 | 548d |  | 0% |  |  |  |  |  |  |  |  |  |  |  |  |
| 1743 | 7.4.2.4.1.1 | Executar Melhorias de ETA e Melhorias na Captação Principal - Baixo Guandu/ES |  | 80d | 2020-05-18 | 2020-09-08 | 1736, 1739 |  |  | 2020-01-14 | 2020-08-20 | 151d | 2020-01-14 | 2020-08-20 | 548d | 0d | 0% |  |  | 0% | ok | 0% | Baixo Guandu/ES (sede) | ETA |  |  |  |  |  |
| 1744 | 7.4.2.4.1.2 | Assinatura de Termo de Entrega das Obras de Melhoria do Sistema de Abastecimento de Água - Baixo Guandu/ES | milestone | 0d | 2020-09-08 | 2020-09-08 | 1743, 1740 |  |  | 2020-12-12 | 2020-12-12 | 0d | 2020-12-12 | 2020-12-12 | 796d | 548d | 0% |  |  | 0% | ok | 0% | Baixo Guandu/ES (sede) |  |  |  |  |  |  |
| 1745 | 7.4.2.4.2 | **Operação** |  | 249d | 2020-09-08 | 2021-09-08 |  |  |  | 2020-12-14 | 2021-12-30 | 260d | 2020-12-14 | 2021-12-30 | 547d |  | 0% |  |  | 0% | ok | 0% | Baixo Guandu/ES (sede) |  |  |  |  |  |  |
| 1746 | 7.4.2.4.2.1 | Realizar Treinamento Operacional do Sistema - Baixo Guandu/ES |  | 5d | 2020-09-09 | 2020-09-15 | 1743 |  |  | 2020-12-14 | 2020-12-18 | 5d | 2020-12-14 | 2020-12-18 | 777d | 0d | 0% |  |  | 0% | ok | 0% | Baixo Guandu/ES (sede) |  |  |  |  |  |  |
| 1747 | 7.4.2.4.2.2 | Realizar Testes e Pré-operação - Baixo Guandu/ES |  | 14d | 2020-09-16 | 2020-10-05 | 1746 |  |  | 2020-12-21 | 2021-01-12 | 14d | 2020-12-21 | 2021-01-12 | 777d |  | 0% |  |  | 0% | ok | 0% | Baixo Guandu/ES (sede) |  |  |  |  |  |  |
| 1748 | 7.4.2.4.2.3 | Realizar Acompanhamento da Funcionalidade do Sistema - Melhorias na ETA - Baixo Guandu/ES (sede) |  | 365ed | 2020-09-08 | 2021-09-08 | 1750SS |  |  | 2020-12-14 | 2021-12-30 | 260d |  |  | 2415d |  |  |  |  |  |  |  |  |  |  |  |  |  |  |
| 1749 | 7.4.2.4.2.4 | **Operação Assistida** |  | 62d | 2020-09-08 | 2020-12-07 |  |  |  | 2020-12-14 | 2021-03-19 | 64d | 2020-12-14 | 2021-03-19 | 548d |  | 0% |  |  | 0% | ok | 0% | Baixo Guandu/ES (sede) |  |  |  |  |  |  |
| 1750 | 7.4.2.4.2.4.1 | Realizar Operação Assistida - Baixo Guandu/ES |  | 90ed | 2020-09-08 | 2020-12-07 | 1743 |  |  | 2020-12-14 | 2021-03-19 | 3.2mo | 2020-12-14 | 2021-03-19 | 2415d | 0d | 0% |  |  | 0% | ok | 0% | Baixo Guandu/ES (sede) |  |  |  |  |  |  |
| 1751 | 7.4.3 | **Nova ETA e UTR** |  | 875d | 2018-09-06 A | 2022-03-10 |  | 12% | 771.5d | 2017-09-25 | 2021-12-30 | 1076d |  |  | 423d |  |  |  |  |  |  |  |  |  |  |  |  |  |  |
| 1752 | 7.4.3.1 | **Estudos de Concepção do Sistema** |  | 121d | 2018-12-04 A | 2019-05-31 A |  | 100% |  | 2017-09-25 | 2018-12-04 | 312d | 2017-09-25 | 2018-12-04 |  |  | 100% | 100 | 100 | 0% | ok | 0% | Baixo Guandu/ES (sede) |  | 100 | 100 |  |  |  |
| 1753 | 7.4.3.1.1 | **Coleta e Análise do Lodo de ETA** |  | 7d | 2019-05-23 A | 2019-05-31 A |  | 100% |  | 2019-05-23 | 2019-05-31 | 7d |  |  |  |  | 100% | 100 | 100 |  |  |  |  |  | 100 | 100 | 8888 |  |  |
| 1754 | 7.4.3.1.1.1 | Executar Coleta e Análise do Lodo de ETA - Baixo Guandu/ES |  | 7d | 2019-05-23 A | 2019-05-31 A |  | 100% |  | 2019-05-23 | 2019-05-31 | 7d |  |  |  |  | 100% | 100 | 100 |  |  |  |  |  | 100 | 100 | 8888 |  |  |
| 1755 | 7.4.3.1.1.2 | Conclusão das Coletas e Análises de Lodo de ETA - Baixo Guandu/ES | milestone | 0d | 2019-05-31 A | 2019-05-31 A | 1754 | 100% |  | 2019-05-31 | 2019-05-31 | 0d |  |  |  |  | 100% | 100 | 100 |  |  |  |  |  | 100 | 100 | 8888 |  |  |
| 1756 | 7.4.3.1.2 | Conclusão dos Estudos de Concepção das Melhorias do Sistema de Abastecimento de Água - Baixo Gandu/ES | milestone | 0d | 2018-12-04 A | 2018-12-04 A |  | 100% |  | 2018-12-04 | 2018-12-04 | 0d | 2018-12-04 | 2018-12-04 |  |  | 100% | 100 | 100 |  |  |  |  |  | 100 | 100 |  |  |  |
| 1757 | 7.4.3.2 | **Engenharia Básica e Detalhada** |  | 377d | 2018-09-06 A | 2020-03-10 |  | 46% | 205.22d | 2018-04-30 | 2019-08-30 | 341d | 2018-04-30 | 2019-08-30 | 513d |  | 87% | 87 | 96 | 0% | ok | 0% | Baixo Guandu/ES (sede) |  | 76 | 79 |  | Socioambiental |  |
| 1758 | 7.4.3.2.1 | **Engenharia Nova ETA e UTR** |  | 377d | 2018-09-06 A | 2020-03-10 |  | 46% | 205.22d | 2018-09-06 | 2019-08-01 | 228d | 2018-09-06 | 2019-08-01 | 513d |  | 89% | 89 | 89 | 0% | ok | 0% | Baixo Guandu/ES (sede) |  | 58 | 65 |  | Socioambiental |  |
| 1759 | 7.4.3.2.1.1 | Aprovação Plano de Trabalho /abertura OSE - Nova ETA/UTR - Baixo Guandu/ES |  | 8d | 2018-09-06 A | 2018-09-17 A |  | 100% |  | 2018-09-06 | 2018-09-17 | 8d | 2018-09-06 | 2018-09-17 |  |  | 100% | 100 | 100 | 0% | ok | 0% | Baixo Guandu/ES (sede) |  | 100 | 100 |  |  |  |
| 1760 | 7.4.3.2.1.2 | Dados de Entrada (levantamento de campo, topografia e DR equipamento) - Nova ETA/UTR - Baixo Guandu/ES |  | 65d | 2018-09-18 A | 2018-12-17 A | 1759 | 100% |  | 2018-09-18 | 2018-12-17 | 65d | 2018-09-18 | 2018-12-17 |  |  | 100% | 100 | 100 | 0% | Não OK | 0% | Baixo Guandu/ES (sede) |  | 100 | 100 |  | Socioambiental | Não OK |
| 1761 | 7.4.3.2.1.3 | Realizar sondagem - Nova ETA/UTR - Baixo Guandu/ES |  | 15d | 2019-03-08 A | 2019-03-28 A | 1759, 1762 | 100% |  | 2019-04-30 | 2019-05-30 | 22d | 2019-04-30 | 2019-05-30 |  |  | 100% | 100 | 100 |  |  |  |  |  | 100 | 100 |  |  |  |
| 1762 | 7.4.3.2.1.4 | Elaborar arranjo para obtenção de Dados de Entrada Licenciamento e Fundiário - Nova ETA/UTR - Baixo Guandu/ES |  | 54d | 2018-12-18 A | 2019-03-07 A | 1760SS+65d | 100% |  | 2018-12-18 | 2019-04-30 | 90d | 2018-12-18 | 2019-04-30 |  |  | 100% | 100 | 100 | 0% | Não OK | 0% | Baixo Guandu/ES (sede) |  | 100 | 100 |  | Socioambiental | Não OK |
| 1763 | 7.4.3.2.1.5 | Elaborar Projeto Básico - Nova ETA/UTR - Baixo Guandu/ES |  | 87d | 2019-09-12 A | 2020-01-17 | 1762FS+129d | 25% | 65.25d | 2018-02-08 | 2018-03-21 | 30d | 2018-02-08 | 2018-03-21 | 425d | 0d | 100% | 100 | 100 |  |  |  |  |  |  |  |  |  |  |
| 1764 | 7.4.3.2.1.6 | Emitir RT/PQ para Suprimentos - Nova ETA/UTR - Baixo Guandu/ES |  | 10d | 2020-02-21 | 2020-03-10 | 1763FF+34d |  |  | 2019-05-02 | 2019-05-15 | 10d | 2019-05-02 | 2019-05-15 | 299d | 0d | 100% | 100 | 100 | 0% | ok | 0% | Baixo Guandu/ES (sede) |  |  |  |  |  |  |
| 1765 | 7.4.3.2.1.7 | Elaborar Projeto Executivo - Nova ETA/UTR - Baixo Guandu/ES |  | 218d | 2019-03-08 A | 2020-01-21 | 1755FF, 1761FF, 1762 | 25% | 163.5d | 2019-05-02 | 2019-08-01 | 65d | 2019-05-02 | 2019-08-01 | 523d | 0d | 63% | 63 | 63 | 0% | ok | 0% | Baixo Guandu/ES (sede) |  | 25 | 40 |  |  |  |
| 1766 | 7.4.3.2.1.8 | Obter aprovação da Operadora/Prefeitura |  | 22d | 2020-01-22 | 2020-02-20 | 1765 |  |  | 2020-02-05 | 2020-03-10 | 22d |  |  | 397d | 0d |  |  |  |  |  |  |  |  |  |  |  |  |  |
| 1767 | 7.4.3.2.1.9 | Elaboração do Projeto Executivo - Nova ETA/UTR - Baixo Guandu/ES | milestone | 0d | 2020-02-20 | 2020-02-20 | 1766 |  |  | 2019-08-01 | 2019-08-01 | 0d | 2019-08-01 | 2019-08-01 | 397d | 98d | 0% |  |  |  |  |  |  |  |  |  |  |  |  |

Notes:
- 1739: 2020.01.02: Latência foi inserida na atividade pois está prevista a contratação também da nova linha de floculação, cujo projeto está em desenvolvimento pela Engenharia, com previsão de emissão da RT em 02/06/2020. A adoção dessa estratégia será validada em reunião com a liderança do PG32 em 07/01/2020.
- 1757: 28/Jan19: / - Segundo José Alaércio, não há previsão de projeto para a Captação Principal pela Engenharia, com exceção do projeto de REPOTENCIAMENTO DA ELEVATÓRIA que atende as duas captações: Principal e Alternativa. As datas referentes ao projeto desse Repotenciamento estão sendo consideradas junto ao da Captação Alternativa.
- 1760: 25/Jan19: / - Levantamento de campo realizado/concluído em 18 a 24/09/18; Topografia realizado/concluído em 25/09 a 19/10/18; DR Equipamento concluído em 11 a 17/12/18; Sondagem prevista pra iniciar em 08/03 e finalizar em 28/03/19.

| ID | WBS | Task | Type | Duration | Start | Finish | Predecessors | Complete | Remaining | Baseline start | Baseline finish | Baseline duration | Baseline 1 start | Baseline 1 finish | Total slack | Free slack | Text3 | Text5 | Text15 | Text25 | Text26 | Text27 | Text29 | Text4 | Text7 | Text23 |
| --- | --- | --- | --- | --- | --- | --- | --- | --- | --- | --- | --- | --- | --- | --- | --- | --- | --- | --- | --- | --- | --- | --- | --- | --- | --- | --- |
| 1768 | 7.4.3.3 | **Licenciamento** |  | 192d | 2019-09-05 A | 2020-06-16 |  | 25% | 144d | 2019-01-22 | 2020-01-13 | 242d | 2019-01-22 | 2020-01-13 | 855d |  | 44% | 44 | 60 | 0% | ok | 0% | Baixo Guandu/ES (sede) |  |  |  |
| 1769 | 7.4.3.3.1 | Nova ETA - Licenças e Autorizações - Baixo Guandu/ES |  | 192d | 2019-09-05 A | 2020-06-16 | 1762FS+124d | 25% | 144d | 2019-09-05 | 2020-06-16 | 192d |  |  | 447d | 0d |  |  |  |  |  |  |  |  |  |  |
| 1770 | 7.4.3.3.2 | Conclusão do Licenciamento Ambiental da Localidade - Baixo Gandu/ES | milestone | 0d | 2020-06-16 | 2020-06-16 | 1769 |  |  | 2020-01-13 | 2020-01-13 | 0d | 2020-01-13 | 2020-01-13 | 855d | 182d | 0% |  |  |  |  |  |  |  |  |  |
| 1771 | 7.4.3.4 | **Suprimentos** |  | 88d | 2020-03-11 | 2020-07-16 |  |  |  | 2019-06-03 | 2019-10-04 | 88d | 2019-06-03 | 2019-10-04 | 425d |  | 21% | 21 | 21 | 0% | ok | 0% | Baixo Guandu/ES (sede) |  |  |  |
| 1772 | 7.4.3.4.1 | Realizar processo contratação da obra - ETA e UTR - Baixo Guandu/ES |  | 88d | 2020-03-11 | 2020-07-16 | 1764 |  |  | 2019-06-03 | 2019-10-04 | 88d | 2019-06-03 | 2019-10-04 | 299d | 0d | 21% | 21 | 21 | 0% | ok | 0% | Baixo Guandu/ES (sede) |  |  |  |
| 1773 | 7.4.3.4.2 | Conclusão da Contratação de Suprimentos das obras de Melhoria do Sistema de Abastecimento de Água - Baixo Gandu/ES | milestone | 0d | 2020-07-16 | 2020-07-16 | 1772 |  |  | 2019-10-04 | 2019-10-04 | 0d | 2019-10-04 | 2019-10-04 | 833d | 160d | 0% |  |  |  |  |  |  |  |  |  |
| 1774 | 7.4.3.5 | **Infraestrutura** |  | 410d | 2020-07-17 | 2022-03-10 |  |  |  | 2019-10-04 | 2021-12-30 | 556d | 2019-10-04 | 2021-12-30 | 423d |  | 0% |  |  | 0% | ok | 0% | Baixo Guandu/ES (sede) |  |  |  |
| 1775 | 7.4.3.5.1 | **Obras** |  | 160d | 2020-07-17 | 2021-03-10 |  |  |  | 2019-10-04 | 2020-12-12 | 296d | 2019-10-04 | 2020-12-12 | 425d |  | 0% |  |  |  |  |  |  |  |  |  |
| 1776 | 7.4.3.5.1.1 | Executar Nova ETA e UTR - Baixo Guandu/ES |  | 160d | 2020-07-17 | 2021-03-10 | 1772, 1769, 1767 |  |  | 2019-10-07 | 2020-05-19 | 151d | 2019-10-07 | 2020-05-19 | 299d | 0d | 0% |  |  | 0% | ok | 0% | Baixo Guandu/ES (sede) |  |  |  |
| 1777 | 7.4.3.5.1.2 | Assinatura de Termo de Entrega das Obras de Melhoria do Sistema de Abastecimento de Água - Baixo Guandu/ES | milestone | 0d | 2021-03-10 | 2021-03-10 | 1776, 1770, 1773 |  |  | 2020-12-12 | 2020-12-12 | 0d | 2020-12-12 | 2020-12-12 | 673d | 425d | 0% |  |  | 0% | ok | 0% | Baixo Guandu/ES (sede) |  |  |  |
| 1778 | 7.4.3.5.2 | **Operação** |  | 250d | 2021-03-10 | 2022-03-10 |  |  |  | 2020-12-14 | 2021-12-30 | 260d | 2020-12-14 | 2021-12-30 | 423d |  | 0% |  |  | 0% | ok | 0% | Baixo Guandu/ES (sede) |  |  |  |
| 1779 | 7.4.3.5.2.1 | Realizar Treinamento Operacional do Sistema - Baixo Guandu/ES |  | 5d | 2021-03-11 | 2021-03-17 | 1776 |  |  | 2020-12-14 | 2020-12-18 | 5d | 2020-12-14 | 2020-12-18 | 654d | 0d | 0% |  |  | 0% | ok | 0% | Baixo Guandu/ES (sede) |  |  |  |
| 1780 | 7.4.3.5.2.2 | Realizar Testes e Pré-operação - Baixo Guandu/ES |  | 14d | 2021-03-18 | 2021-04-07 | 1779 |  |  | 2020-12-21 | 2021-01-12 | 14d | 2020-12-21 | 2021-01-12 | 654d |  | 0% |  |  | 0% | ok | 0% | Baixo Guandu/ES (sede) |  |  |  |
| 1781 | 7.4.3.5.2.3 | Realizar Acompanhamento da Funcionalidade do Sistema - Nova ETA e UTR - Baixo Guandu/ES (sede) |  | 365ed | 2021-03-10 | 2022-03-10 | 1783SS |  |  | 2020-12-14 | 2021-12-30 | 260d |  |  | 1866d |  |  |  |  |  |  |  |  |  |  |  |
| 1782 | 7.4.3.5.2.4 | **Operação Assistida** |  | 61d | 2021-03-10 | 2021-06-08 |  |  |  | 2020-12-14 | 2021-03-19 | 64d | 2020-12-14 | 2021-03-19 | 425d |  | 0% |  |  | 0% | ok | 0% | Baixo Guandu/ES (sede) |  |  |  |
| 1783 | 7.4.3.5.2.4.1 | Realizar Operação Assistida - Baixo Guandu/ES |  | 90ed | 2021-03-10 | 2021-06-08 | 1776 |  |  | 2020-12-14 | 2021-03-19 | 3.2mo | 2020-12-14 | 2021-03-19 | 1866d | 0d | 0% |  |  | 0% | ok | 0% | Baixo Guandu/ES (sede) |  |  |  |
| 1784 | 7.5 | **Mascarenhas (distrito Baixo Guandu/ES)** |  | 1099d | 2017-09-25 A | 2022-02-01 |  | 32% | 744.13d | 2017-09-25 | 2021-03-17 | 878d | 2017-09-25 | 2021-03-17 | 447d |  | 51% | 51 | 59 | 0% | ok | 0% | Mascarenhas (distrito Baixo Guandu/ES) | 23 | 39 | Socioambiental |
| 1785 | 7.5.1 | **Adutora de Água Tratada de Baixo Guandu** |  | 1099d | 2017-09-25 A | 2022-02-01 |  | 32% | 744.13d | 2017-09-25 | 2021-03-17 | 878d |  |  | 447d |  |  |  |  |  |  |  |  |  |  |  |
| 1786 | 7.5.1.1 | **Estudos de Concepção do Sistema** |  | 195d | 2017-09-25 A | 2018-06-22 A |  | 100% |  | 2017-09-25 | 2018-06-22 | 195d | 2017-09-25 | 2018-06-22 |  |  | 100% | 100 | 100 | 0% | ok | 0% | Mascarenhas (distrito Baixo Guandu/ES) | 100 | 100 |  |
| 1787 | 7.5.1.1.1 | Declaração de Escopo e Premissas de Projeto (DEPP) concluída - Mascarenhas/ES | milestone | 0d | 2018-03-23 A | 2018-03-23 A | 25, 26 | 100% |  | 2018-03-23 | 2018-03-23 | 0d | 2018-03-23 | 2018-03-23 |  |  | 100% | 100 | 100 | 0% | ok | 0% | Mascarenhas (distrito Baixo Guandu/ES) | 100 | 100 |  |
| 1788 | 7.5.1.1.2 | Aprovação das DEPPs pela Operadora e Prefeitura - Mascarenhas/ES | milestone | 0d | 2017-09-25 A | 2017-09-25 A | 25, 26 | 100% |  | 2017-09-25 | 2017-09-25 | 0d | 2017-09-25 | 2017-09-25 |  |  | 100% | 100 | 100 | 0% | ok | 0% | Mascarenhas (distrito Baixo Guandu/ES) | 100 | 100 |  |
| 1789 | 7.5.1.1.3 | **Serviços em Poços Tubulares** |  | 24d | 2018-05-22 A | 2018-06-22 A |  | 100% |  | 2018-05-22 | 2018-06-22 | 24d | 2018-05-22 | 2018-06-22 |  |  | 100% | 100 | 100 | 0% | ok | 0% | Mascarenhas (distrito Baixo Guandu/ES) | 100 | 100 |  |
| 1790 | 7.5.1.1.3.1 | Realizar Tamponamento - Mascarenhas/ES |  | 1d | 2018-05-22 A | 2018-05-22 A | 1787 | 100% |  | 2018-05-22 | 2018-05-22 | 1d | 2018-05-22 | 2018-05-22 |  |  | 100% | 100 | 100 | 0% | ok | 0% | Mascarenhas (distrito Baixo Guandu/ES) | 100 | 100 |  |
| 1791 | 7.5.1.1.3.2 | Elaborar Relatório Técnico - Mascarenhas/ES |  | 23d | 2018-05-23 A | 2018-06-22 A | 1790 | 100% |  | 2018-05-23 | 2018-06-22 | 23d | 2018-05-23 | 2018-06-22 |  |  | 100% | 100 | 100 | 0% | ok | 0% | Mascarenhas (distrito Baixo Guandu/ES) | 100 | 100 |  |
| 1792 | 7.5.1.1.3.3 | Conclusão dos Serviços em poço tubular - Mascarenhas/ES | milestone | 0d | 2018-06-22 A | 2018-06-22 A | 1791 | 100% |  | 2018-06-22 | 2018-06-22 | 0d | 2018-06-22 | 2018-06-22 |  |  | 100% | 100 | 100 |  |  |  |  | 100 | 100 |  |
| 1793 | 7.5.1.1.4 | Conclusão dos Estudos de Concepção das Melhorias do Sistema de Abastecimento de Água - Mascarenhas/ES | milestone | 0d | 2018-06-22 A | 2018-06-22 A | 1792 | 100% |  | 2018-06-22 | 2018-06-22 | 0d | 2018-06-22 | 2018-06-22 |  |  | 100% | 100 | 100 |  |  |  |  | 100 | 100 |  |

Notes:
- 1788: 27/Nov: / - Anuência dada por meio Ata de Reunião datada de 25/09/17.

| ID | WBS | Task | Type | Duration | Start | Finish | Predecessors | Complete | Remaining | Baseline start | Baseline finish | Baseline duration | Baseline 1 start | Baseline 1 finish | Total slack | Free slack | Text3 | Text4 | Text5 | Text7 | Text15 | Text23 | Text25 | Text26 | Text27 | Text29 | Text9 |
| --- | --- | --- | --- | --- | --- | --- | --- | --- | --- | --- | --- | --- | --- | --- | --- | --- | --- | --- | --- | --- | --- | --- | --- | --- | --- | --- | --- |
| 1794 | 7.5.1.2 | **Engenharia Básica e Detalhada** |  | 476d | 2018-03-22 A | 2020-02-05 |  | 95% | 25.03d | 2018-03-12 | 2019-04-22 | 285d | 2018-03-12 | 2019-04-22 | 942d |  | 100% | 85 | 100 | 85 | 100 | Socioambiental | 0% | ok | 0% | Mascarenhas (distrito Baixo Guandu/ES) |  |
| 1795 | 7.5.1.2.1 | **Engenharia Adutora Água Tratada (ETA Baixo Guandu até reservatório em Mascarenhas) - SE 32085** |  | 456d | 2018-03-22 A | 2020-01-08 |  | 97% | 11.99d | 2018-03-12 | 2019-03-21 | 265d | 2018-03-12 | 2019-03-21 | 33.75d |  | 100% | 88 | 100 | 88 | 100 | Socioambiental | 0% | ok | 0% | Mascarenhas (distrito Baixo Guandu/ES) |  |
| 1796 | 7.5.1.2.1.1 | Aprovação Plano de Trabalho /abertura OSE + Levantamento de campo - Adutora de Água Tratada - Mascarenhas/ES |  | 167d | 2018-03-22 A | 2018-11-09 A | 26 | 100% |  | 2018-03-12 | 2018-03-23 | 10d | 2018-03-12 | 2018-03-23 |  |  | 100% | 100 | 100 | 100 | 100 |  | 0% | ok | 0% | Mascarenhas (distrito Baixo Guandu/ES) |  |
| 1797 | 7.5.1.2.1.2 | Executar Topografia - Adutora de Água Tratada - Mascarenhas/ES |  | 11d | 2018-11-27 A | 2018-12-11 A | 1796FS+11d | 100% |  | 2018-04-10 | 2018-04-24 | 11d | 2018-04-10 | 2018-04-24 |  |  | 100% | 100 | 100 | 100 | 100 | Socioambiental | 0% | Não OK | 0% | Mascarenhas (distrito Baixo Guandu/ES) | Não OK |
| 1798 | 7.5.1.2.1.3 | Realizar sondagem - Adutora de Água Tratada - Mascarenhas/ES |  | 3d | 2020-01-06 | 2020-01-08 | 1796FS+286d |  |  | 2018-09-10 | 2018-10-09 | 22d | 2018-09-10 | 2018-10-09 | 33.75d | 0d | 100% | 25 | 100 | 25 | 100 |  |  |  |  |  |  |
| 1799 | 7.5.1.2.1.4 | Elaborar arranjo para obtenção de Dados de Entrada Licenciamento e Fundiário - Adutora de Água Tratada - Mascarenhas/ES |  | 264d | 2018-04-16 A | 2019-04-26 A | 1796SS | 100% |  | 2018-03-23 | 2018-06-14 | 60d | 2018-03-23 | 2018-06-14 |  |  | 100% | 100 | 100 | 100 | 100 |  | 0% | ok | 0% | Mascarenhas (distrito Baixo Guandu/ES) |  |
| 1800 | 7.5.1.2.1.5 | Emitir RT/PQ para Suprimentos - Adutora de Água Tratada - Mascarenhas/ES |  | 10d | 2019-08-28 A | 2019-09-10 A | 1802FF-60d | 100% |  | 2019-03-08 | 2019-03-21 | 10d | 2019-03-08 | 2019-03-21 |  |  | 100% | 25 | 100 | 25 | 100 |  | 0% | ok | 0% | Mascarenhas (distrito Baixo Guandu/ES) |  |
| 1801 | 7.5.1.2.1.6 | Elaborar Projeto Executivo - Adutora de Água Tratada - Mascarenhas/ES |  | 266d | 2018-12-03 A | 2020-01-08 | 1796, 1798FF | 94% | 15.96d | 2018-11-21 | 2019-03-21 | 119d | 2018-11-21 | 2019-03-21 | 33.75d | 0d | 100% | 85 | 100 | 85 | 100 | Socioambiental | 0% | Não OK | 0% | Mascarenhas (distrito Baixo Guandu/ES) | Não OK |
| 1802 | 7.5.1.2.1.7 | Elaboração do Projeto Executivo - Adutora de Água Tratada - Mascarenhas/ES | milestone | 0d | 2020-01-08 | 2020-01-08 | 1797, 1801 |  |  | 2019-03-21 | 2019-03-21 | 0d | 2019-03-21 | 2019-03-21 | 33.75d | 0d | 100% |  | 100 |  | 100 |  |  |  |  |  |  |
| 1803 | 7.5.1.2.2 | **Validação dos Projetos** |  | 20d | 2020-01-09 | 2020-02-05 |  |  |  | 2019-03-22 | 2019-04-22 | 20d | 2019-03-22 | 2019-04-22 | 942d |  | 100% |  | 100 |  | 100 |  | 0% | ok | 0% | Mascarenhas (distrito Baixo Guandu/ES) |  |
| 1804 | 7.5.1.2.2.1 | Validar Projetos com Prefeitura e Operadora - Mascarenhas/ES |  | 20d | 2020-01-09 | 2020-02-05 | 1802 |  |  | 2019-03-22 | 2019-04-22 | 20d | 2019-03-22 | 2019-04-22 | 942d | 0d | 100% |  | 100 |  | 100 |  | 0% | ok | 0% | Mascarenhas (distrito Baixo Guandu/ES) |  |
| 1805 | 7.5.1.2.2.2 | Validação com Prefeitura e Operadora dos Projetos de Melhoria do Sistema de Abastecimento de Água - Mascarenhas/ES | milestone | 0d | 2020-02-05 | 2020-02-05 | 1802, 1804 |  |  | 2019-04-22 | 2019-04-22 | 0d | 2019-04-22 | 2019-04-22 | 942d | 386d | 100% |  | 100 |  | 100 |  |  |  |  |  |  |
| 1806 | 7.5.1.3 | **Fundiária** |  | 214d | 2019-08-16 A | 2020-06-26 |  | 25% | 161.5d | 2018-12-24 | 2019-07-22 | 143d | 2018-12-24 | 2019-07-22 | 847d |  | 88% |  | 88 |  | 88 |  | 0% | ok | 0% | Mascarenhas (distrito Baixo Guandu/ES) |  |
| 1807 | 7.5.1.3.1 | Obter Termos de Autorização de Superficiário e Desimpedimento da Área - Adutora Água Tratada da ETA de Baixo Guandu ao reservatório em Mascarenhas/ES |  | 214d | 2019-08-16 A | 2020-06-26 | 1799FS+76d | 25% | 161.5d | 2018-12-24 | 2019-07-22 | 143d | 2018-12-24 | 2019-07-22 | 449d | 0d | 88% |  | 88 |  | 88 |  | 0% | ok | 0% | Mascarenhas (distrito Baixo Guandu/ES) |  |
| 1808 | 7.5.1.3.2 | Conclusão da Regularização Fundiária para as obras de Melhoria do Sistema de Abastecimento - Mascarenhas/ES | milestone | 0d | 2020-06-26 | 2020-06-26 | 1807 |  |  | 2019-07-22 | 2019-07-22 | 0d | 2019-07-22 | 2019-07-22 | 847d | 291d | 0% |  |  |  |  |  |  |  |  |  |  |
| 1809 | 7.5.1.4 | **Licenciamento** |  | 175d | 2019-09-05 A | 2020-05-21 |  | 25% | 131.25d | 2018-06-15 | 2019-02-18 | 176d | 2018-06-15 | 2019-02-18 | 872d |  | 100% |  | 100 |  | 100 |  | 0% | ok | 0% | Mascarenhas (distrito Baixo Guandu/ES) |  |
| 1810 | 7.5.1.4.1 | Licenciamento e autorização para construção - Adutora Água Tratada (da ETA de Baixo Guandu até reservatório em Mascarenhas) |  | 175d | 2019-09-05 A | 2020-05-21 | 1799, 1802FS-75d | 25% | 131.25d | 2018-06-15 | 2019-02-18 | 176d | 2018-06-15 | 2019-02-18 | 474d | 0d | 100% |  | 100 |  | 100 |  | 0% | ok | 0% | Mascarenhas (distrito Baixo Guandu/ES) |  |
| 1811 | 7.5.1.4.2 | Conclusão do Licenciamento Ambiental da Localidade - Mascarenhas/ES | milestone | 0d | 2020-05-21 | 2020-05-21 | 1810 |  |  | 2019-02-18 | 2019-02-18 | 0d | 2019-02-18 | 2019-02-18 | 872d | 316d | 100% |  | 100 |  | 100 |  |  |  |  |  |  |
| 1812 | 7.5.1.5 | **Suprimentos** |  | 104d | 2019-09-10 A | 2020-02-10 |  | 76% | 24.75d | 2019-03-21 | 2019-07-22 | 84d | 2019-03-21 | 2019-07-22 | 939d |  | 80% |  | 80 |  | 82 |  | 0% | ok | 0% | Mascarenhas (distrito Baixo Guandu/ES) |  |
| 1813 | 7.5.1.5.1 | **Processo contratação MAS 1 (Adutora)** |  | 104d | 2019-09-10 A | 2020-02-10 |  | 76% | 24.75d | 2019-03-21 | 2019-07-22 | 84d | 2019-03-21 | 2019-07-22 | 939d |  | 80% |  | 80 |  | 82 |  | 0% | ok | 0% | Mascarenhas (distrito Baixo Guandu/ES) |  |
| 1814 | 7.5.1.5.1.1 | Recebimento da RT/PQ pelo Suprimentos - Mascarenhas/ES | milestone | 0d | 2019-09-10 A | 2019-09-10 A | 1800 | 100% |  | 2019-03-07 | 2019-03-07 | 0d |  |  |  |  | 100% |  | 100 |  | 100 |  |  |  |  |  |  |
| 1815 | 7.5.1.5.1.2 | Realizar Entendimento da Demanda - Mascarenhas/ES |  | 10d | 2019-09-11 A | 2019-09-24 A | 1814 | 100% |  | 2019-03-07 | 2019-03-20 | 10d |  |  |  |  | 100% |  | 100 |  |  |  |  |  |  |  |  |
| 1816 | 7.5.1.5.1.3 | Abrir a RC - Mascarenhas/ES |  | 8d | 2019-09-25 A | 2019-10-04 A | 1815 | 100% |  | 2019-03-21 | 2019-04-01 | 8d | 2019-03-21 | 2019-04-01 |  |  | 100% |  | 100 |  | 100 |  |  |  |  |  |  |
| 1817 | 7.5.1.5.1.4 | Aprovar a RC (liberação) - Mascarenhas/ES |  | 8d | 2019-10-07 A | 2019-10-16 A | 1816 | 100% |  | 2019-04-01 | 2019-04-10 | 8d | 2019-04-01 | 2019-04-10 |  |  | 100% |  | 100 |  | 100 |  |  |  |  |  |  |
| 1818 | 7.5.1.5.1.5 | Prospectar fornecedores e receber proposta técnicas - Mascarenhas/ES |  | 31d | 2019-10-17 A | 2019-11-29 A | 1817 | 100% |  | 2019-04-10 | 2019-05-24 | 30d | 2019-04-10 | 2019-05-24 |  |  | 100% |  | 100 |  | 100 |  |  |  |  |  |  |
| 1819 | 7.5.1.5.1.6 | Aprovar proposta técnica - Mascarenhas/ES |  | 14d | 2019-12-02 A | 2019-12-20 A | 1818 | 100% |  | 2019-05-24 | 2019-06-10 | 12d | 2019-05-24 | 2019-06-10 |  |  | 100% |  | 100 |  | 100 |  |  |  |  |  |  |
| 1820 | 7.5.1.5.1.7 | Realizar negociação e aprovar o pedido - Mascarenhas/ES |  | 33d | 2019-12-23 A | 2020-02-10 | 1819 | 25% | 24.75d | 2019-06-10 | 2019-07-22 | 30d | 2019-06-10 | 2019-07-22 | 541d | 0d | 46% |  | 46 |  | 46 |  |  |  |  |  |  |
| 1821 | 7.5.1.5.1.8 | Conclusão da Contratação de Suprimentos - Adutora - Mascarenhas/ES | milestone | 0d | 2020-02-10 | 2020-02-10 | 1820 |  |  | 2019-07-22 | 2019-07-22 | 0d | 2019-07-22 | 2019-07-22 | 939d | 0d | 0% |  |  |  |  |  |  |  |  |  |  |
| 1822 | 7.5.1.5.2 | Conclusão da Contratação de Suprimentos das obras de Melhoria do Sistema de Abastecimento de Água - Mascarenhas/ES | milestone | 0d | 2020-02-10 | 2020-02-10 | 1821 |  |  | 2019-07-22 | 2019-07-22 | 0d | 2019-07-22 | 2019-07-22 | 939d | 383d | 0% |  |  |  |  |  |  |  |  |  |  |

Notes:
- 1795: 28/Nov: / - Segundo DEPP, além da construção da adutora (11km) a partir da ETA de Baixo Guandu até o reservatório de Mascarenhas, deverá ser construído novo reservatório em local que hoje se encontra um condomínio particular e nova adutora (1km) para interligar o reservatório à rede de distribuição existente em Mascarenhas.
- 1797: 25/Jan19: / - Topografia iniciada em 27/11 e concluída em 11/12/18; Sondagem prevista pra iniciar em 14/03 e finalizar em 12/04/19.
- 1807: 28/Nov: / - A etapa de obtenção e autorização de acesso para estudos para a adutora foi concluída em 22/10/18 (segundo CR Infra). E para o reservatório foi emitida liberação de acesso por Andreas Leo Holz em 18/10/18 através do seu advogado Dr. Mercinio (segundo CR GF). / 04/Dez: / - 5 imóveis envolvidos (1 EFVM e 4 Povoados de Mascarenhas).
- 1809: 2/Jan / - Verificar licenciamento específico da obra de interligação entre ETA Baixo Guandu e reservatório de Mascarenhas
- 1810: 04/Dez: / - Segundo planilha do Licenciamento, aguardando projeto para definir se será necessário licenciar. Processo não iniciado. Previsão para obtenção da autorização: 24/12/19.

| ID | WBS | Task | Type | Duration | Start | Finish | Predecessors | Complete | Remaining | Baseline start | Baseline finish | Baseline duration | Baseline 1 start | Baseline 1 finish | Total slack | Free slack | Text3 | Text25 | Text26 | Text27 | Text29 | Text4 | Text5 | Text7 | Text15 | Text23 | Text9 |
| --- | --- | --- | --- | --- | --- | --- | --- | --- | --- | --- | --- | --- | --- | --- | --- | --- | --- | --- | --- | --- | --- | --- | --- | --- | --- | --- | --- |
| 1823 | 7.5.1.6 | **Infraestrutura** |  | 400d | 2020-06-29 | 2022-02-01 |  |  |  | 2019-07-22 | 2021-03-17 | 411d | 2019-07-22 | 2021-03-17 | 447d |  | 0% | 0% | ok | 0% | Mascarenhas (distrito Baixo Guandu/ES) |  |  |  |  |  |  |
| 1824 | 7.5.1.6.1 | **Obras** |  | 150d | 2020-06-29 | 2021-02-01 |  |  |  | 2019-07-22 | 2020-03-01 | 151d | 2019-07-22 | 2020-03-01 | 449d |  | 0% |  |  |  |  |  |  |  |  |  |  |
| 1825 | 7.5.1.6.1.1 | Executar Captação Principal (adutora de água tratada de 11km da ETA de B-G até reservatório Mascarenhas) |  | 150d | 2020-06-29 | 2021-02-01 | 1807, 1810, 1820, 1802 |  |  | 2019-07-22 | 2020-03-01 | 151d | 2019-07-22 | 2020-03-01 | 449d | 0d | 0% | 0% | ok | 0% | Mascarenhas (distrito Baixo Guandu/ES) |  |  |  |  |  |  |
| 1826 | 7.5.1.6.1.2 | Assinatura de Termo de Entrega das Obras de Melhoria do Sistema de Abastecimento de Água - Mascarenhas/ES | milestone | 0d | 2021-02-01 | 2021-02-01 | 1825, 1805, 1808, 1811, 1822 |  |  | 2020-03-01 | 2020-03-01 | 0d | 2020-03-01 | 2020-03-01 | 697d | 449d | 0% | 0% | ok | 0% | Mascarenhas (distrito Baixo Guandu/ES) |  |  |  |  |  |  |
| 1827 | 7.5.1.6.2 | **Operação** |  | 250d | 2021-02-01 | 2022-02-01 |  |  |  | 2020-03-02 | 2021-03-17 | 260d | 2020-03-02 | 2021-03-17 | 447d |  | 0% | 0% | ok | 0% | Mascarenhas (distrito Baixo Guandu/ES) |  |  |  |  |  |  |
| 1828 | 7.5.1.6.2.1 | Realizar Treinamento Operacional do Sistema - Mascarenhas/ES |  | 5d | 2021-02-02 | 2021-02-08 | 1825 |  |  | 2020-03-02 | 2020-03-06 | 5d | 2020-03-02 | 2020-03-06 | 678d | 0d | 0% | 0% | ok | 0% | Mascarenhas (distrito Baixo Guandu/ES) |  |  |  |  |  |  |
| 1829 | 7.5.1.6.2.2 | Realizar Testes e Pré-operação - Mascarenhas/ES |  | 14d | 2021-02-09 | 2021-03-03 | 1828 |  |  | 2020-03-09 | 2020-03-26 | 14d | 2020-03-09 | 2020-03-26 | 678d |  | 0% | 0% | ok | 0% | Mascarenhas (distrito Baixo Guandu/ES) |  |  |  |  |  |  |
| 1830 | 7.5.1.6.2.3 | Realizar Acompanhamento da Funcionalidade do Sistema - Adutora de Água Tratada de Baixo Guandu - Mascarenhas (distrito Baixo Guandu/ES) |  | 365ed | 2021-02-01 | 2022-02-01 | 1832SS |  |  | 2020-03-02 | 2021-03-17 | 260d |  |  | 1977d |  |  |  |  |  |  |  |  |  |  |  |  |
| 1831 | 7.5.1.6.2.4 | **Operação Assistida** |  | 59d | 2021-02-01 | 2021-05-02 |  |  |  | 2020-03-02 | 2020-06-02 | 64d | 2020-03-02 | 2020-06-02 | 449d |  | 0% | 0% | ok | 0% | Mascarenhas (distrito Baixo Guandu/ES) |  |  |  |  |  |  |
| 1832 | 7.5.1.6.2.4.1 | Realizar Operação Assistida - Mascarenhas/ES |  | 90ed | 2021-02-01 | 2021-05-02 | 1825 |  |  | 2020-03-02 | 2020-06-02 | 3.2mo | 2020-03-02 | 2020-06-02 | 1977d | 0d | 0% | 0% | ok | 0% | Mascarenhas (distrito Baixo Guandu/ES) |  |  |  |  |  |  |
| 1833 | 7.6 | **Colatina/ES (sede)** |  | 854d | 2019-11-04 A | 2023-04-13 |  |  | 850.76d | 2016-03-23 | 2022-01-27 | 1489d | 2016-03-23 | 2022-01-27 | 151d |  | 56% | 0% | ok | 0% | Colatina/ES (sede) | 22 | 56 | 61 | 36 | Socioambiental |  |
| 1834 | 7.6.1 | **UTR - ETA Marista** |  | 835d | 2019-12-02 A | 2023-04-13 |  |  | 832.55d | 2018-11-01 | 2022-01-27 | 808d |  |  | 151d |  |  |  |  |  |  |  |  |  |  |  |  |
| 1835 | 7.6.1.1 | **Engenharia Básica e Detalhada** |  | 274d | 2019-12-02 A | 2021-01-11 |  | 2% | 268.16d | 2018-11-01 | 2019-10-18 | 243d | 2018-11-01 | 2019-10-18 | 214d |  | 67% | 0% | ok | 0% | Colatina/ES (sede) | 46 | 67 | 60 | 77 | Socioambiental |  |
| 1836 | 7.6.1.1.1 | **Engenharia UTR (ETA Marista) - SE 32257** |  | 274d | 2019-12-02 A | 2021-01-11 |  | 2% | 268.16d | 2018-11-01 | 2019-10-11 | 238d | 2018-11-01 | 2019-10-11 | 214d |  | 68% | 0% | ok | 0% | Colatina/ES (sede) | 48 | 68 | 53 | 91 | Socioambiental |  |
| 1837 | 7.6.1.1.1.1 | Aprovação Plano de Trabalho /abertura OSE - UTR - ETA Marista - Colatina/ES |  | 26d | 2019-12-02 A | 2020-01-10 | 24FS+968d | 25% | 19.5d | 2018-11-05 | 2019-01-03 | 43d | 2018-11-05 | 2019-01-03 | 151d | 0d | 100% | 0% | ok | 0% | Colatina/ES (sede) | 100 | 100 | 100 | 100 |  |  |
| 1838 | 7.6.1.1.1.2 | Realizar Levantamento de Campo (Sondagem, Topografia) - UTR - ETA Marista - Colatina/ES |  | 41d | 2020-01-13 | 2020-03-12 | 1837 |  |  | 2018-11-01 | 2019-01-21 | 57d | 2018-11-01 | 2019-01-21 | 167d | 16d | 100% | 0% | Não OK | 0% | Colatina/ES (sede) | 100 | 100 | 100 | 100 | Socioambiental | Não OK |
| 1839 | 7.6.1.1.1.3 | Elaborar projeto Conceitual (Dados de Entrada Licenciamento e Fundiário) - UTR - ETA Marista - Colatina/ES |  | 57d | 2020-01-13 | 2020-04-03 | 1837, 1838FF |  |  | 2019-04-26 | 2019-05-31 | 25d | 2019-04-26 | 2019-05-31 | 151d | 0d | 100% | 0% | Não OK | 0% | Colatina/ES (sede) |  | 100 |  | 100 | Socioambiental |  |
| 1840 | 7.6.1.1.1.4 | Elaborar Projeto Básico - UTR - ETA Marista - Colatina/ES |  | 75d | 2020-07-24 | 2020-11-10 | 1839FS+75d |  |  | 2018-02-08 | 2018-03-21 | 30d | 2018-02-08 | 2018-03-21 | 151d | 0d | 100% |  |  |  |  |  | 100 |  | 100 |  |  |
| 1841 | 7.6.1.1.1.5 | Obter Aprovação do projeto Básico com Prefeitura/Operadora- UTR - ETA Marista - Colatina/ES |  | 22d | 2020-11-11 | 2020-12-10 | 1840 |  |  | 2020-07-15 | 2020-08-13 | 22d |  |  | 233d | 19d |  |  |  |  |  |  |  |  |  |  |  |
| 1842 | 7.6.1.1.1.6 | Emitir RT/PQ para Suprimentos - UTR - ETA Marista - Colatina/ES |  | 18d | 2020-11-09 | 2020-12-02 | 1843FF-25d |  |  | 2019-05-22 | 2019-06-07 | 13d | 2019-05-22 | 2019-06-07 | 151d | 0d | 100% | 0% | Não OK | 0% | Colatina/ES (sede) |  | 100 |  | 100 | Socioambiental |  |
| 1843 | 7.6.1.1.1.7 | Elaborar Projeto Executivo - UTR - ETA Marista - Colatina/ES |  | 66d | 2020-10-05 | 2021-01-11 | 1840FS-25d |  |  | 2019-06-03 | 2019-07-31 | 42d | 2019-06-03 | 2019-07-31 | 151d | 0d | 45% | 0% | Não OK | 0% | Colatina/ES (sede) |  | 45 |  | 45 | Socioambiental |  |
| 1844 | 7.6.1.1.1.8 | Elaboração do Projeto Executivo - UTR - ETA Marista - Colatina/ES | milestone | 0d | 2021-01-11 | 2021-01-11 | 1843, 1841 |  |  | 2019-07-31 | 2019-07-31 | 0d | 2019-07-31 | 2019-07-31 | 214d | 63d | 0% |  |  |  |  |  |  |  |  |  |  |
| 1845 | 7.6.1.2 | **Fundiária** |  | 185d | 2020-04-06 | 2020-12-31 |  |  |  | 2018-08-07 | 2019-11-13 | 323d | 2018-08-07 | 2019-11-13 | 260d |  | 69% | 0% | ok | 0% | Colatina/ES (sede) | 40 | 69 | 60 | 67 |  |  |
| 1846 | 7.6.1.2.1 | Obter Termos de Autorização de Superficiário - UTRs - Imóveis 1, 2 e 4 (Marista, Aparecida e Columbia) - Colatina/ES |  | 5d | 2020-04-06 | 2020-04-13 | 24, 1839 |  |  | 2018-08-07 | 2019-11-13 | 323d | 2018-08-07 | 2019-11-13 | 260d | 0d | 69% | 0% | ok | 0% | Colatina/ES (sede) | 37 | 69 | 54 | 69 |  |  |
| 1847 | 7.6.1.2.2 | Realizar Negociação da Servidão do Imóvel - UTR Marista - Colatina/ES |  | 180d | 2020-04-14 | 2020-12-31 | 1846 |  |  | 2018-08-07 | 2019-11-13 | 323d |  |  | 260d | 0d |  |  |  |  |  |  |  |  |  |  |  |
| 1848 | 7.6.1.2.3 | Conclusão da Regularização Fundiária para as obras de Melhoria do Sistema de Abastecimento da Localidade - Colatina/ES | milestone | 0d | 2020-12-31 | 2020-12-31 | 1846, 1847 |  |  | 2019-11-13 | 2019-11-13 | 0d | 2019-11-13 | 2019-11-13 | 718d | 319d | 0% |  |  |  |  |  |  |  |  |  |  |

Notes:
- 1823: 28/Nov: / - Não está sendo considerada a construção do novo reservatório e a nova adutora (1km) ligando o reservatório à rede de distribuição de Mascarenhas. Apenas a adutora que ligará a ETA de Baixo Guandu até Mascarenhas. Verificar!
- 1835: 19/Dez / - As obras de captação principal, alternativa e melhorias na ETA foram executadas pela Samarco no período emergencial. Estão concluídas e formalmente entregues. Está pendente uma resolução fundiária da área onde foi construída a captação alternativa no rio Pancas. Necessária atuação do Jurídico.
- 1838: 25/Jan19: / - Levantamento de campo previsto para iniciar em 01/02 e finalizar em 04/02/19; Topografia iniciada em 01/11 e concluída em 21/01/19; Sondagem prevista para iniciar em 05/02 e finalizar em 11/03/19.
- 1840: 2020.01.02: de acordo com o cronograma da Engenharia, o início do projeto básico da ETA Marista está previsto para ser iniciado após a conclusão do projeto da ETA de São Vitor-MG.
- 1845: 01/Fev19: / - Está pendente uma resolução fundiária da área onde foi construída a captação alternativa no rio Pancas. Necessária atuação do Jurídico.
- 1846: 01/Fev19: / - Fundiário fez contato com o Diretor do SANEAR (Geraldo Avancini) solicitando documentação fundiária para produção de Termo de Autorização. / - Não haverá necessidade de Desimpedimento da área em função de já pertencer ao SANEAR. (Se efetivamente for do SANEAR). / 05/Dez: / - Segundo anotações no CR da Gestão Fundiária "Verificar existência de informações (DEPP) para subsidiar o desenvolvimento das atividades de campo". Ou seja, atividades não iniciadas.
- 1847: 2020.01.02: Foi alterada a latência para que processo de regularização fundiária inicie após obtenção do arranjo, disponibilizado pela engenharia.

| ID | WBS | Task | Type | Duration | Start | Finish | Predecessors | Complete | Remaining | Baseline start | Baseline finish | Baseline duration | Baseline 1 start | Baseline 1 finish | Total slack | Free slack | Text3 | Text25 | Text26 | Text27 | Text29 | Text5 | Text7 | Text4 | Text15 | Text23 |
| --- | --- | --- | --- | --- | --- | --- | --- | --- | --- | --- | --- | --- | --- | --- | --- | --- | --- | --- | --- | --- | --- | --- | --- | --- | --- | --- |
| 1849 | 7.6.1.3 | **Suprimentos** |  | 88d | 2020-12-03 | 2021-04-14 |  |  |  | 2019-09-23 | 2020-01-29 | 88d | 2019-09-23 | 2020-01-29 | 151d |  | 0% |  |  |  |  |  |  |  |  |  |
| 1850 | 7.6.1.3.1 | Suprimentos - Processo contratação UTRs - Colatina/ES |  | 88d | 2020-12-03 | 2021-04-14 | 1842 |  |  | 2019-09-23 | 2020-01-29 | 88d | 2019-09-23 | 2020-01-29 | 151d | 0d | 0% | 0% | ok | 0% | Colatina/ES (sede) |  |  |  |  |  |
| 1851 | 7.6.1.3.2 | Conclusão da Contratação de Suprimentos das obras de Melhoria do Sistema de Abastecimento de Água - Colatina/ES | milestone | 0d | 2021-04-14 | 2021-04-14 | 1850 |  |  | 2020-01-29 | 2020-01-29 | 0d | 2020-01-29 | 2020-01-29 | 649d | 250d | 0% |  |  |  |  |  |  |  |  |  |
| 1852 | 7.6.1.4 | **Infraestrutura** |  | 498d | 2021-04-15 | 2023-04-13 |  |  |  | 2016-03-23 | 2022-01-27 | 1489d | 2016-03-23 | 2022-01-27 | 151d |  | 56% | 0% | ok | 0% | Colatina/ES (sede) | 56 | 100 |  |  |  |
| 1853 | 7.6.1.4.1 | **Obras** |  | 250d | 2021-04-15 | 2022-04-13 |  |  |  | 2016-03-23 | 2021-01-13 | 1229d | 2016-03-23 | 2021-01-13 | 151d |  | 68% |  |  |  |  | 68 | 100 | 20 | 20 |  |
| 1854 | 7.6.1.4.1.1 | Executar UTR (ETA Marista 250L/s) - Colatina/ES |  | 250d | 2021-04-15 | 2022-04-13 | 1844, 1846, 1847FS-40d, 1850 |  |  | 2020-01-30 | 2021-01-13 | 237d | 2020-01-30 | 2021-01-13 | 151d | 0d | 0% | 0% | ok | 0% | Colatina/ES (sede) |  |  |  |  |  |
| 1855 | 7.6.1.4.1.2 | Assinatura de Termo de Entrega das Obras de Melhoria do Sistema de Abastecimento de Água - Colatina/ES | milestone | 0d | 2022-04-13 | 2022-04-13 | 1854, 1848, 1851 |  |  | 2021-01-13 | 2021-01-13 | 0d | 2021-01-13 | 2021-01-13 | 399d | 151d | 0% | 0% | ok | 0% | Colatina/ES (sede) |  |  |  |  |  |
| 1856 | 7.6.1.4.2 | **Operação** |  | 248d | 2022-04-13 | 2023-04-13 |  |  |  | 2021-01-14 | 2022-01-27 | 260d | 2021-01-14 | 2022-01-27 | 151d |  | 0% | 0% | ok | 0% | Colatina/ES (sede) |  |  |  |  |  |
| 1857 | 7.6.1.4.2.1 | Realizar Treinamento Operacional do Sistema - Colatina/ES |  | 5d | 2022-04-14 | 2022-04-22 | 1854 |  |  | 2021-01-14 | 2021-01-20 | 5d | 2021-01-14 | 2021-01-20 | 380d | 0d | 0% | 0% | ok | 0% | Colatina/ES (sede) |  |  |  |  |  |
| 1858 | 7.6.1.4.2.2 | Realizar Testes e Pré-operação - Colatina/ES |  | 14d | 2022-04-25 | 2022-05-12 | 1857 |  |  | 2021-01-21 | 2021-02-09 | 14d | 2021-01-21 | 2021-02-09 | 380d |  | 0% | 0% | ok | 0% | Colatina/ES (sede) |  |  |  |  |  |
| 1859 | 7.6.1.4.2.3 | Realizar Acompanhamento da Funcionalidade do Sistema - UTR - ETA Marista - Colatina/ES (sede) |  | 365ed | 2022-04-13 | 2023-04-13 | 1861SS |  |  | 2021-01-14 | 2022-01-27 | 260d |  |  | 669d |  |  |  |  |  |  |  |  |  |  |  |
| 1860 | 7.6.1.4.2.4 | **Operação Assistida** |  | 61d | 2022-04-13 | 2022-07-12 |  |  |  | 2021-01-14 | 2021-04-19 | 64d | 2021-01-14 | 2021-04-19 | 151d |  | 0% | 0% | ok | 0% | Colatina/ES (sede) |  |  |  |  |  |
| 1861 | 7.6.1.4.2.4.1 | Realizar Operação Assistida - Colatina/ES |  | 90ed | 2022-04-13 | 2022-07-12 | 1854 |  |  | 2021-01-14 | 2021-04-19 | 3.2mo | 2021-01-14 | 2021-04-19 | 669d | 0d | 0% | 0% | ok | 0% | Colatina/ES (sede) |  |  |  |  |  |
| 1862 | 7.6.2 | **UTR - ETA Aparecida** |  | 786d | 2019-11-04 A | 2023-01-03 |  | 1% | 782.01d | 2017-08-30 | 2022-01-27 | 1114d |  |  | 219d |  |  |  |  |  |  |  |  |  |  |  |
| 1863 | 7.6.2.1 | **Engenharia** |  | 210d | 2019-11-04 A | 2020-09-09 |  | 4% | 202.38d | 2017-08-30 | 2019-10-18 | 549d | 2017-08-30 | 2019-10-18 | 297d |  | 85% |  | ok |  |  | 85 | 60 | 46 | 77 | Socioambiental |
| 1864 | 7.6.2.1.1 | **Engenharia Básica e Detalhada** |  | 210d | 2019-11-04 A | 2020-09-09 |  | 4% | 202.38d | 2018-11-01 | 2019-10-18 | 243d | 2018-11-01 | 2019-10-18 | 297d |  | 67% | 0% | ok | 0% | Colatina/ES (sede) | 67 | 60 | 46 | 77 | Socioambiental |
| 1865 | 7.6.2.1.1.1 | **Engenharia UTR (ETA Aparecida) - SE 32256** |  | 210d | 2019-11-04 A | 2020-09-09 |  | 4% | 202.38d | 2018-11-01 | 2019-09-20 | 223d | 2018-11-01 | 2019-09-20 | 297d |  | 73% | 0% | ok | 0% | Colatina/ES (sede) | 73 | 66 | 48 | 73 | Socioambiental |
| 1866 | 7.6.2.1.1.1.1 | Aprovação Plano de Trabalho /abertura OSE - UTR - ETA Aparecida - Colatina/ES |  | 45d | 2019-11-04 A | 2020-01-10 | 24FS+949d | 25% | 33.75d | 2018-11-05 | 2019-01-03 | 43d | 2018-11-05 | 2019-01-03 | 220d | 0d | 100% | 0% | ok | 0% | Colatina/ES (sede) | 100 | 100 | 100 | 100 |  |
| 1867 | 7.6.2.1.1.1.2 | Realizar levantamento de Campo e Sondagem - UTR - ETA Aparecida - Colatina/ES |  | 41d | 2020-01-13 | 2020-03-12 | 1866 |  |  | 2019-05-06 | 2019-05-13 | 6d | 2019-05-06 | 2019-05-13 | 236d | 16d | 100% |  |  |  |  | 100 | 100 | 100 | 100 |  |
| 1868 | 7.6.2.1.1.1.3 | Elaborar projeto Conceitual (Dados de Entrada Licenciamento e Fundiário) - UTR - Aparecida - Colatina/ES |  | 57d | 2020-01-13 | 2020-04-03 | 1866, 1867FF |  |  | 2019-06-05 | 2019-07-10 | 25d | 2019-06-05 | 2019-07-10 | 220d | 0d | 68% | 0% | Não OK | 0% | Colatina/ES (sede) | 68 |  |  | 68 | Socioambiental |
| 1869 | 7.6.2.1.1.1.4 | Elaborar Projeto Básico - UTR - ETA Aparecida - Colatina/ES |  | 74d | 2020-04-06 | 2020-07-22 | 1868 |  |  | 2018-02-08 | 2018-03-21 | 30d | 2018-02-08 | 2018-03-21 | 234d | 0d | 100% |  |  |  |  | 100 |  |  | 100 |  |
| 1870 | 7.6.2.1.1.1.5 | Obter Aprovação do projeto Básico com Prefeitura/Operadora - UTR - ETA Aparecida - Colatina/ES |  | 22d | 2020-07-23 | 2020-08-21 | 1869 |  |  | 2020-07-10 | 2020-08-10 | 22d |  |  | 309d | 12d |  |  |  |  |  |  |  |  |  |  |
| 1871 | 7.6.2.1.1.1.6 | Emitir RT/PQ para Suprimentos - UTR - ETA Aparecida - Colatina/ES |  | 13d | 2020-07-17 | 2020-08-04 | 1872FF-25d |  |  | 2019-07-01 | 2019-07-17 | 13d | 2019-07-01 | 2019-07-17 | 234d | 0d | 0% | 0% | Não OK | 0% | Colatina/ES (sede) |  |  |  |  | Socioambiental |
| 1872 | 7.6.2.1.1.1.7 | Elaborar Projeto Executivo - UTR - ETA Aparecida - Colatina/ES |  | 58d | 2020-06-19 | 2020-09-09 | 1869FS-24d |  |  | 2019-07-11 | 2019-09-20 | 51d | 2019-07-11 | 2019-09-20 | 234d | 0d | 0% | 0% | Não OK | 0% | Colatina/ES (sede) |  |  |  |  | Socioambiental |
| 1873 | 7.6.2.1.1.1.8 | Elaboração do Projeto Executivo - UTR - ETA Aparecida - Colatina/ES | milestone | 0d | 2020-09-09 | 2020-09-09 | 1872, 1870 |  |  | 2019-09-20 | 2019-09-20 | 0d | 2019-09-20 | 2019-09-20 | 297d | 77d | 0% |  |  |  |  |  |  |  |  |  |

Notes:
- 1854: 05/Dez: / - Não considerando dadas previstas no CR da Infra. Não previsto nenhum tipo de licença. Idem para as UTRs Aparecida e Columbia.
- 1864: 19/Dez / - As obras de captação principal, alternativa e melhorias na ETA foram executadas pela Samarco no período emergencial. Estão concluídas e formalmente entregues. Está pendente uma resolução fundiária da área onde foi construída a captação alternativa no rio Pancas. Necessária atuação do Jurídico.

| ID | WBS | Task | Type | Duration | Start | Finish | Predecessors | Complete | Remaining | Baseline start | Baseline finish | Baseline duration | Baseline 1 start | Baseline 1 finish | Total slack | Free slack | Text3 | Text4 | Text5 | Text7 | Text15 | Text25 | Text26 | Text27 | Text29 | Text23 | Text9 |
| --- | --- | --- | --- | --- | --- | --- | --- | --- | --- | --- | --- | --- | --- | --- | --- | --- | --- | --- | --- | --- | --- | --- | --- | --- | --- | --- | --- |
| 1874 | 7.6.2.2 | **Fundiária** |  | 185d | 2020-04-06 | 2020-12-31 |  |  |  | 2018-08-07 | 2019-11-13 | 323d | 2018-08-07 | 2019-11-13 | 220d |  | 69% | 40 | 69 | 60 | 67 | 0% | ok | 0% | Colatina/ES (sede) |  |  |
| 1875 | 7.6.2.2.1 | Obter Termos de Autorização de Superficiário - UTRs - Imóveis 1, 2 e 4 (Marista, Aparecida e Columbia) - Colatina/ES |  | 5d | 2020-04-06 | 2020-04-13 | 1868 |  |  | 2018-08-07 | 2019-11-13 | 323d | 2018-08-07 | 2019-11-13 | 220d | 0d | 69% | 37 | 69 | 54 | 69 | 0% | ok | 0% | Colatina/ES (sede) |  |  |
| 1876 | 7.6.2.2.2 | Realizar Negociação da Servidão do Imóvel - UTR Aparecida - Colatina/ES |  | 180d | 2020-04-14 | 2020-12-31 | 1875 |  |  | 2020-03-26 | 2020-12-11 | 180d |  |  | 220d | 0d |  |  |  |  |  |  |  |  |  |  |  |
| 1877 | 7.6.2.2.3 | Conclusão da Regularização Fundiária para as obras de Melhoria do Sistema de Abastecimento da Localidade - Colatina/ES | milestone | 0d | 2020-12-31 | 2020-12-31 | 1875, 1876 |  |  | 2019-11-13 | 2019-11-13 | 0d | 2019-11-13 | 2019-11-13 | 718d | 250d | 0% |  |  |  |  |  |  |  |  |  |  |
| 1878 | 7.6.2.3 | **Suprimentos** |  | 88d | 2020-08-05 | 2020-12-09 |  |  |  | 2019-09-23 | 2020-01-29 | 88d | 2019-09-23 | 2020-01-29 | 234d |  | 0% |  |  |  |  |  |  |  |  |  |  |
| 1879 | 7.6.2.3.1 | Suprimentos - Processo contratação UTRs - Colatina/ES |  | 88d | 2020-08-05 | 2020-12-09 | 1871 |  |  | 2019-09-23 | 2020-01-29 | 88d | 2019-09-23 | 2020-01-29 | 234d | 0d | 0% |  |  |  |  | 0% | ok | 0% | Colatina/ES (sede) |  |  |
| 1880 | 7.6.2.3.2 | Conclusão da Contratação de Suprimentos das obras de Melhoria do Sistema de Abastecimento de Água - Colatina/ES | milestone | 0d | 2020-12-09 | 2020-12-09 | 1879 |  |  | 2020-01-29 | 2020-01-29 | 0d | 2020-01-29 | 2020-01-29 | 732d | 264d | 0% |  |  |  |  |  |  |  |  |  |  |
| 1881 | 7.6.2.4 | **Infraestrutura** |  | 499d | 2021-01-04 | 2023-01-03 |  |  |  | 2016-03-23 | 2022-01-27 | 1489d | 2016-03-23 | 2022-01-27 | 219d |  | 56% |  | 56 | 100 |  | 0% | ok | 0% | Colatina/ES (sede) |  |  |
| 1882 | 7.6.2.4.1 | **Obras** |  | 250d | 2021-01-04 | 2022-01-03 |  |  |  | 2016-03-23 | 2021-01-13 | 1229d | 2016-03-23 | 2021-01-13 | 220d |  | 68% | 20 | 68 | 100 | 20 |  |  |  |  |  |  |
| 1883 | 7.6.2.4.1.1 | Executar UTR (ETA Aparecida 250L/s) - Colatina/ES |  | 250d | 2021-01-04 | 2022-01-03 | 1873, 1875, 1876, 1879 |  |  | 2020-01-30 | 2021-01-13 | 237d | 2020-01-30 | 2021-01-13 | 220d | 0d | 0% |  |  |  |  | 0% | ok | 0% | Colatina/ES (sede) |  |  |
| 1884 | 7.6.2.4.1.2 | Assinatura de Termo de Entrega das Obras de Melhoria do Sistema de Abastecimento de Água - Colatina/ES | milestone | 0d | 2022-01-03 | 2022-01-03 | 1883, 1877, 1880 |  |  | 2021-01-13 | 2021-01-13 | 0d | 2021-01-13 | 2021-01-13 | 468d | 220d | 0% |  |  |  |  | 0% | ok | 0% | Colatina/ES (sede) |  |  |
| 1885 | 7.6.2.4.2 | **Operação** |  | 249d | 2022-01-03 | 2023-01-03 |  |  |  | 2021-01-14 | 2022-01-27 | 260d | 2021-01-14 | 2022-01-27 | 219d |  | 0% |  |  |  |  | 0% | ok | 0% | Colatina/ES (sede) |  |  |
| 1886 | 7.6.2.4.2.1 | Realizar Treinamento Operacional do Sistema - Colatina/ES |  | 5d | 2022-01-04 | 2022-01-10 | 1883 |  |  | 2021-01-14 | 2021-01-20 | 5d | 2021-01-14 | 2021-01-20 | 449d | 0d | 0% |  |  |  |  | 0% | ok | 0% | Colatina/ES (sede) |  |  |
| 1887 | 7.6.2.4.2.2 | Realizar Testes e Pré-operação - Colatina/ES |  | 14d | 2022-01-11 | 2022-01-28 | 1886 |  |  | 2021-01-21 | 2021-02-09 | 14d | 2021-01-21 | 2021-02-09 | 449d |  | 0% |  |  |  |  | 0% | ok | 0% | Colatina/ES (sede) |  |  |
| 1888 | 7.6.2.4.2.3 | Realizar Acompanhamento da Funcionalidade do Sistema - UTR - ETA Aparecida - Colatina/ES (sede) |  | 365ed | 2022-01-03 | 2023-01-03 | 1890SS |  |  | 2021-01-14 | 2022-01-27 | 260d |  |  | 969d |  |  |  |  |  |  |  |  |  |  |  |  |
| 1889 | 7.6.2.4.2.4 | **Operação Assistida** |  | 61d | 2022-01-03 | 2022-04-03 |  |  |  | 2021-01-14 | 2021-04-19 | 64d | 2021-01-14 | 2021-04-19 | 220d |  | 0% |  |  |  |  | 0% | ok | 0% | Colatina/ES (sede) |  |  |
| 1890 | 7.6.2.4.2.4.1 | Realizar Operação Assistida - Colatina/ES |  | 90ed | 2022-01-03 | 2022-04-03 | 1883 |  |  | 2021-01-14 | 2021-04-19 | 3.2mo | 2021-01-14 | 2021-04-19 | 969d | 0d | 0% |  |  |  |  | 0% | ok | 0% | Colatina/ES (sede) |  |  |
| 1891 | 7.6.3 | **UTR - ETA Columbia** |  | 669d | 2019-11-29 A | 2022-08-09 |  |  | 666.77d | 2018-11-01 | 2022-01-27 | 808d |  |  | 318d |  |  |  |  |  |  |  |  |  |  |  |  |
| 1892 | 7.6.3.1 | **Engenharia Básica e Detalhada** |  | 222d | 2019-11-29 A | 2020-10-22 |  | 2% | 216.49d | 2018-11-01 | 2019-10-18 | 243d | 2018-11-01 | 2019-10-18 | 407d |  | 67% | 46 | 67 | 60 | 77 | 0% | ok | 0% | Colatina/ES (sede) | Socioambiental |  |
| 1893 | 7.6.3.1.1 | **Engenharia UTR (ETA Columbia) - SE 32258** |  | 222d | 2019-11-29 A | 2020-10-22 |  | 2% | 216.49d | 2018-11-01 | 2019-09-20 | 223d | 2018-11-01 | 2019-09-20 | 407d |  | 73% | 43 | 73 | 60 | 72 | 0% | ok | 0% | Colatina/ES (sede) | Socioambiental |  |
| 1894 | 7.6.3.1.1.1 | Aprovação Plano de Trabalho /abertura OSE - UTR - ETA Columbia - Colatina/ES |  | 27d | 2019-11-29 A | 2020-01-10 | 24FS+967d | 25% | 20.25d | 2018-11-05 | 2019-01-03 | 43d | 2018-11-05 | 2019-01-03 | 320d | 0d | 100% | 100 | 100 | 100 | 100 | 0% | ok | 0% | Colatina/ES (sede) |  |  |
| 1895 | 7.6.3.1.1.2 | Realizar levantamento de Campo e Sondagem - UTR - ETA Columbia - Colatina/ES |  | 46d | 2020-01-13 | 2020-03-19 | 1894 |  |  | 2018-11-01 | 2019-01-21 | 57d | 2018-11-01 | 2019-01-21 | 320d | 0d | 100% | 100 | 100 | 100 | 100 | 0% | Não OK | 0% | Colatina/ES (sede) | Socioambiental | Não OK |
| 1896 | 7.6.3.1.1.3 | Elaborar Projeto Conceitual (Dados de Entrada Licenciamento e Fundiário) - UTR - ETA Columbia - Colatina/ES |  | 61d | 2020-03-20 | 2020-06-18 | 1895 |  |  | 2019-06-05 | 2019-07-10 | 25d | 2019-06-05 | 2019-07-10 | 320d | 0d | 68% |  | 68 |  | 68 | 0% | Não OK | 0% | Colatina/ES (sede) | Socioambiental |  |
| 1897 | 7.6.3.1.1.4 | Elaborar Projeto Básico - UTR - ETA Columbia - Colatina/ES |  | 55d | 2020-06-19 | 2020-09-03 | 1896 |  |  | 2018-02-08 | 2018-03-21 | 30d | 2018-02-08 | 2018-03-21 | 344d | 0d | 100% |  | 100 |  | 100 |  |  |  |  |  |  |
| 1898 | 7.6.3.1.1.5 | Obter Aprovação do projeto Básico com Prefeitura/Operadora - UTR - ETA Columbia - Colatina/ES |  | 22d | 2020-09-04 | 2020-10-06 | 1897 |  |  | 2020-09-04 | 2020-10-06 | 22d |  |  | 418d | 11d |  |  |  |  |  |  |  |  |  |  |  |
| 1899 | 7.6.3.1.1.6 | Emitir RT/PQ para Suprimentos - UTR - ETA Columbia - Colatina/ES |  | 3d | 2020-09-14 | 2020-09-16 | 1900FF-25d |  |  | 2019-09-09 | 2019-09-20 | 10d | 2019-09-09 | 2019-09-20 | 344d | 0d | 0% |  |  |  |  | 0% | Não OK | 0% | Colatina/ES (sede) | Socioambiental |  |
| 1900 | 7.6.3.1.1.7 | Elaborar Projeto Executivo - UTR - ETA Columbia - Colatina/ES |  | 58d | 2020-07-31 | 2020-10-22 | 1897FS-25d |  |  | 2019-07-11 | 2019-09-20 | 51d | 2019-07-11 | 2019-09-20 | 344d | 0d | 0% |  |  |  |  | 0% | Não OK | 0% | Colatina/ES (sede) | Socioambiental |  |
| 1901 | 7.6.3.1.1.8 | Elaboração do Projeto Executivo - UTR - ETA Columbia - Colatina/ES | milestone | 0d | 2020-10-22 | 2020-10-22 | 1900, 1898 |  |  | 2019-09-20 | 2019-09-20 | 0d | 2019-09-20 | 2019-09-20 | 407d | 87d | 0% |  |  |  |  |  |  |  |  |  |  |

Notes:
- 1874: 01/Fev19: / - Está pendente uma resolução fundiária da área onde foi construída a captação alternativa no rio Pancas. Necessária atuação do Jurídico.
- 1875: 01/Fev19: / - Fundiário fez contato com o Diretor do SANEAR (Geraldo Avancini) solicitando documentação fundiária para produção de Termo de Autorização. / - Não haverá necessidade de Desimpedimento da área em função de já pertencer ao SANEAR. (Se efetivamente for do SANEAR). / 05/Dez: / - Segundo anotações no CR da Gestão Fundiária "Verificar existência de informações (DEPP) para subsidiar o desenvolvimento das atividades de campo". Ou seja, atividades não iniciadas.
- 1892: 19/Dez / - As obras de captação principal, alternativa e melhorias na ETA foram executadas pela Samarco no período emergencial. Estão concluídas e formalmente entregues. Está pendente uma resolução fundiária da área onde foi construída a captação alternativa no rio Pancas. Necessária atuação do Jurídico.
- 1895: 25/Jan19: / - Levantamento de campo previsto para iniciar em 01/02 e finalizar em 04/02/19; Topografia iniciada em 01/11 e concluída em 21/01/19; Sondagem prevista para iniciar em 05/02 e finalizar em 11/03/19.

| ID | WBS | Task | Type | Duration | Start | Finish | Predecessors | Complete | Remaining | Baseline start | Baseline finish | Baseline duration | Baseline 1 start | Baseline 1 finish | Total slack | Free slack | Text3 | Text4 | Text5 | Text7 | Text15 | Text25 | Text26 | Text27 | Text29 | Text23 |
| --- | --- | --- | --- | --- | --- | --- | --- | --- | --- | --- | --- | --- | --- | --- | --- | --- | --- | --- | --- | --- | --- | --- | --- | --- | --- | --- |
| 1902 | 7.6.3.2 | **Fundiária** |  | 175d | 2020-06-19 | 2021-03-03 |  |  |  | 2018-08-07 | 2019-11-13 | 323d | 2018-08-07 | 2019-11-13 | 320d |  | 69% | 40 | 69 | 60 | 67 | 0% | ok | 0% | Colatina/ES (sede) |  |
| 1903 | 7.6.3.2.1 | Obter Termos de Autorização de Superficiário - UTRs - Imóveis 1, 2 e 4 (Marista, Aparecida e Columbia) - Colatina/ES |  | 5d | 2020-06-19 | 2020-06-25 | 1896 |  |  | 2018-08-07 | 2019-11-13 | 323d | 2018-08-07 | 2019-11-13 | 320d | 0d | 69% | 37 | 69 | 54 | 69 | 0% | ok | 0% | Colatina/ES (sede) |  |
| 1904 | 7.6.3.2.2 | Realizar Negociação da Servidão do Imóvel - UTR Columbia - Colatina/ES |  | 170d | 2020-06-26 | 2021-03-03 | 1903 |  |  | 2020-07-03 | 2021-03-24 | 180d |  |  | 320d | 0d |  |  |  |  |  |  |  |  |  |  |
| 1905 | 7.6.3.2.3 | Conclusão da Regularização Fundiária para as obras de Melhoria do Sistema de Abastecimento da Localidade - Colatina/ES | milestone | 0d | 2021-03-03 | 2021-03-03 | 1904 |  |  | 2019-11-13 | 2019-11-13 | 0d | 2019-11-13 | 2019-11-13 | 678d | 110d | 0% |  |  |  |  |  |  |  |  |  |
| 1906 | 7.6.3.3 | **Suprimentos** |  | 88d | 2020-09-17 | 2021-01-25 |  |  |  | 2019-09-23 | 2020-01-29 | 88d | 2019-09-23 | 2020-01-29 | 344d |  | 0% |  |  |  |  |  |  |  |  |  |
| 1907 | 7.6.3.3.1 | Suprimentos - Processo contratação UTRs - Colatina/ES |  | 88d | 2020-09-17 | 2021-01-25 | 1899 |  |  | 2019-09-23 | 2020-01-29 | 88d | 2019-09-23 | 2020-01-29 | 344d | 0d | 0% |  |  |  |  | 0% | ok | 0% | Colatina/ES (sede) |  |
| 1908 | 7.6.3.3.2 | Conclusão da Contratação de Suprimentos das obras de Melhoria do Sistema de Abastecimento de Água - Colatina/ES | milestone | 0d | 2021-01-25 | 2021-01-25 | 1907 |  |  | 2020-01-29 | 2020-01-29 | 0d | 2020-01-29 | 2020-01-29 | 702d | 134d | 0% |  |  |  |  |  |  |  |  |  |
| 1909 | 7.6.3.4 | **Infraestrutura** |  | 360d | 2021-03-04 | 2022-08-09 |  |  |  | 2016-03-23 | 2022-01-27 | 1489d | 2016-03-23 | 2022-01-27 | 318d |  | 56% |  | 56 | 100 |  | 0% | ok | 0% | Colatina/ES (sede) |  |
| 1910 | 7.6.3.4.1 | **Obras** |  | 110d | 2021-03-04 | 2021-08-09 |  |  |  | 2016-03-23 | 2021-01-13 | 1229d | 2016-03-23 | 2021-01-13 | 320d |  | 68% | 20 | 68 | 100 | 20 |  |  |  |  |  |
| 1911 | 7.6.3.4.1.1 | Executar UTR (ETA Columbia 19L/s) - Colatina/ES |  | 110d | 2021-03-04 | 2021-08-09 | 1907, 1901, 1904 |  |  | 2020-01-30 | 2021-01-13 | 237d | 2020-01-30 | 2021-01-13 | 320d | 0d | 0% |  |  |  |  | 0% | ok | 0% | Colatina/ES (sede) |  |
| 1912 | 7.6.3.4.1.2 | Assinatura de Termo de Entrega das Obras de Melhoria do Sistema de Abastecimento de Água - Colatina/ES | milestone | 0d | 2021-08-09 | 2021-08-09 | 1911, 1905, 1908 |  |  | 2021-01-13 | 2021-01-13 | 0d | 2021-01-13 | 2021-01-13 | 568d | 320d | 0% |  |  |  |  | 0% | ok | 0% | Colatina/ES (sede) |  |
| 1913 | 7.6.3.4.2 | **Operação** |  | 250d | 2021-08-09 | 2022-08-09 |  |  |  | 2021-01-14 | 2022-01-27 | 260d | 2021-01-14 | 2022-01-27 | 318d |  | 0% |  |  |  |  | 0% | ok | 0% | Colatina/ES (sede) |  |
| 1914 | 7.6.3.4.2.1 | Realizar Treinamento Operacional do Sistema - Colatina/ES |  | 5d | 2021-08-10 | 2021-08-16 | 1911 |  |  | 2021-01-14 | 2021-01-20 | 5d | 2021-01-14 | 2021-01-20 | 549d | 0d | 0% |  |  |  |  | 0% | ok | 0% | Colatina/ES (sede) |  |
| 1915 | 7.6.3.4.2.2 | Realizar Testes e Pré-operação - Colatina/ES |  | 14d | 2021-08-17 | 2021-09-03 | 1914 |  |  | 2021-01-21 | 2021-02-09 | 14d | 2021-01-21 | 2021-02-09 | 549d |  | 0% |  |  |  |  | 0% | ok | 0% | Colatina/ES (sede) |  |
| 1916 | 7.6.3.4.2.3 | Realizar Acompanhamento da Funcionalidade do Sistema - UTR - ETA Columbia - Colatina/ES (sede) |  | 365ed | 2021-08-09 | 2022-08-09 | 1918SS |  |  | 2021-01-14 | 2022-01-27 | 260d |  |  | 1410d |  |  |  |  |  |  |  |  |  |  |  |
| 1917 | 7.6.3.4.2.4 | **Operação Assistida** |  | 61d | 2021-08-09 | 2021-11-07 |  |  |  | 2021-01-14 | 2021-04-19 | 64d | 2021-01-14 | 2021-04-19 | 320d |  | 0% |  |  |  |  | 0% | ok | 0% | Colatina/ES (sede) |  |
| 1918 | 7.6.3.4.2.4.1 | Realizar Operação Assistida - Colatina/ES |  | 90ed | 2021-08-09 | 2021-11-07 | 1911 |  |  | 2021-01-14 | 2021-04-19 | 3.2mo | 2021-01-14 | 2021-04-19 | 1410d | 0d | 0% |  |  |  |  | 0% | ok | 0% | Colatina/ES (sede) |  |
| 1919 | 7.7 | **Boninsegna (distrito Marilândia/ES)** |  | 1026d | 2018-02-01 A | 2022-03-05 |  | 28% | 735.97d | 2018-02-01 | 2020-12-31 | 735d | 2018-02-01 | 2020-12-31 | 427d |  | 48% | 14 | 48 | 27 | 52 | 0% | ok | 0% | Boninsegna (distrito Marilândia/ES) | Socioambiental |
| 1920 | 7.7.1 | **Captação Principal, Alternativa, Nova ETA e UTR** |  | 1026d | 2018-02-01 A | 2022-03-05 |  | 28% | 735.97d | 2018-02-01 | 2020-12-31 | 735d |  |  | 427d |  |  |  |  |  |  |  |  |  |  |  |
| 1921 | 7.7.1.1 | **Estudos de Concepção do Sistema** |  | 155d | 2018-02-01 A | 2018-09-05 A |  | 100% |  | 2018-02-01 | 2018-11-22 | 211d | 2018-02-01 | 2018-11-22 |  |  | 100% |  | 100 |  | 100 | 0% | ok | 0% | Boninsegna (distrito Marilândia/ES) | Socioambiental |
| 1922 | 7.7.1.1.1 | Declaração de Escopo e Premissas de Projeto (DEPP) concluída - Boninsegna/ES | milestone | 0d | 2018-03-23 A | 2018-03-23 A | 25, 26 | 100% |  | 2018-03-23 | 2018-03-23 | 0d | 2018-03-23 | 2018-03-23 |  |  | 100% | 100 | 100 | 100 | 100 | 0% | ok | 0% | Boninsegna (distrito Marilândia/ES) |  |
| 1923 | 7.7.1.1.2 | Aprovação das DEPPs pela Operadora e Prefeitura - Boninsegna/ES | milestone | 0d | 2018-02-01 A | 2018-02-01 A | 25, 26 | 100% |  | 2018-02-01 | 2018-02-01 | 0d | 2018-02-01 | 2018-02-01 |  |  | 100% | 100 | 100 | 100 | 100 | 0% | ok | 0% | Boninsegna (distrito Marilândia/ES) |  |
| 1924 | 7.7.1.1.3 | Revisão de Definições - Boninsegna/ES | milestone | 0d | 2018-09-05 A | 2018-09-05 A | 1922FS+121d | 100% |  | 2018-09-05 | 2018-09-05 | 0d | 2018-09-05 | 2018-09-05 |  |  | 100% | 100 | 100 | 100 | 100 | 0% | ok | 0% | Boninsegna (distrito Marilândia/ES) |  |
| 1925 | 7.7.1.1.4 | Aprovação da Revisão da Definição pela Prefeitura de Marilândia - Boninsegna/ES | milestone | 0d | 2018-09-05 A | 2018-09-05 A | 1924 | 100% |  | 2018-09-05 | 2018-09-05 | 0d | 2018-09-05 | 2018-09-05 |  |  | 100% | 100 | 100 | 100 | 100 | 0% | ok | 0% | Boninsegna (distrito Marilândia/ES) |  |
| 1926 | 7.7.1.1.5 | Conclusão dos Estudos de Concepção das Melhorias do Sistema de Abastecimento de Água - Boninsegna/ES | milestone | 0d | 2018-09-05 A | 2018-09-05 A | 1925 | 100% |  | 2018-11-21 | 2018-11-21 | 0d | 2018-11-21 | 2018-11-21 |  |  | 100% |  | 100 |  | 100 |  |  |  |  |  |

Notes:
- 1902: 01/Fev19: / - Está pendente uma resolução fundiária da área onde foi construída a captação alternativa no rio Pancas. Necessária atuação do Jurídico.
- 1903: 01/Fev19: / - Fundiário fez contato com o Diretor do SANEAR (Geraldo Avancini) solicitando documentação fundiária para produção de Termo de Autorização. / - Não haverá necessidade de Desimpedimento da área em função de já pertencer ao SANEAR. (Se efetivamente for do SANEAR). / 05/Dez: / - Segundo anotações no CR da Gestão Fundiária "Verificar existência de informações (DEPP) para subsidiar o desenvolvimento das atividades de campo". Ou seja, atividades não iniciadas.
- 1919: 10/Dez / - Recebimento de um e-mail enviado pelo Mateus em 16/10/18 com a aprovação da nova definição.

| ID | WBS | Task | Type | Duration | Start | Finish | Predecessors | Complete | Remaining | Baseline start | Baseline finish | Baseline duration | Baseline 1 start | Baseline 1 finish | Total slack | Free slack | Text3 | Text4 | Text5 | Text7 | Text15 | Text23 | Text25 | Text26 | Text27 | Text29 | Text9 | Text13 |
| --- | --- | --- | --- | --- | --- | --- | --- | --- | --- | --- | --- | --- | --- | --- | --- | --- | --- | --- | --- | --- | --- | --- | --- | --- | --- | --- | --- | --- |
| 1927 | 7.7.1.2 | **Engenharia Básica e Detalhada** |  | 370d | 2018-09-06 A | 2020-02-28 |  | 82% | 68.31d | 2018-09-06 | 2019-10-22 | 285d | 2018-09-06 | 2019-10-22 | 928d |  | 71% | 55 | 71 | 61 | 90 | Socioambiental | 0% | ok | 0% | Boninsegna (distrito Marilândia/ES) |  |  |
| 1928 | 7.7.1.2.1 | **Engenharia Captação Principal (Rio Doce) - SE 32103** |  | 338d | 2018-10-22 A | 2020-02-28 |  | 84% | 55.56d | 2018-10-22 | 2019-02-19 | 86d | 2018-10-22 | 2019-02-19 | 928d |  | 100% | 59 | 100 | 59 | 100 | Socioambiental | 0% | ok | 0% | Boninsegna (distrito Marilândia/ES) |  |  |
| 1929 | 7.7.1.2.1.1 | Aprovação Plano de Trabalho /abertura OSE - Captação Principal - Rio Doce - Boninsegna/ES |  | 73d | 2018-12-03 A | 2019-03-19 A | 1925 | 100% |  | 2018-11-01 | 2018-11-14 | 10d | 2018-11-01 | 2018-11-14 |  |  | 100% | 100 | 100 | 100 | 100 | Socioambiental | 0% | Não OK | 0% | Boninsegna (distrito Marilândia/ES) | Não OK |  |
| 1930 | 7.7.1.2.1.2 | Realizar levantamento de Campo - Captação Principal - Rio Doce - Boninsegna/ES |  | 6d | 2019-06-05 A | 2019-06-12 A | 1929FS+52d | 100% |  | 2018-12-27 | 2019-01-04 | 6d | 2018-12-27 | 2019-01-04 |  |  | 100% | 100 | 100 | 100 | 100 |  |  |  |  |  |  |  |
| 1931 | 7.7.1.2.1.3 | Realizar sondagem - Captação Principal - Rio Doce - Boninsegna/ES |  | 1d | 2020-01-02 | 2020-01-02 | 1929FS+196d |  |  | 2018-12-27 | 2019-01-28 | 22d | 2018-12-27 | 2019-01-28 | 2.1d | 0d | 100% |  | 100 |  | 100 |  |  |  |  |  |  |  |
| 1932 | 7.7.1.2.1.4 | Executar Topografia - Captação Principal - Rio Doce - Boninsegna/ES |  | 30d | 2018-10-22 A | 2018-11-30 A | 1929SS-30d | 100% |  | 2018-10-22 | 2018-11-30 | 30d | 2018-10-22 | 2018-11-30 |  |  | 100% | 100 | 100 | 100 | 100 |  |  |  |  |  |  |  |
| 1933 | 7.7.1.2.1.5 | Realizar Batimetria - Captação Principal - Rio Doce - Boninsegna/ES |  | 19d | 2019-05-06 A | 2019-05-30 A | 1929FS+30d | 100% |  | 2018-11-14 | 2018-12-25 | 30d | 2018-11-14 | 2018-12-25 |  |  | 100% | 100 | 100 | 100 | 100 |  |  |  |  |  |  |  |
| 1934 | 7.7.1.2.1.6 | Elaborar arranjo para obtenção de Dados de Entrada Licenciamento e Fundiário - Captação Principal - Rio Doce - Boninsegna/ES |  | 31d | 2019-06-13 A | 2019-07-26 A | 1929FS+45d, 1930, 1932 | 100% |  | 2018-11-26 | 2018-12-25 | 22d | 2018-11-26 | 2018-12-25 |  |  | 100% | 80 | 100 | 80 | 100 | Socioambiental | 0% | Não OK | 0% | Boninsegna (distrito Marilândia/ES) |  |  |
| 1935 | 7.7.1.2.1.7 | Emitir RT/PQ para Suprimentos - Captação Principal - Rio Doce - Boninsegna/ES |  | 20d | 2019-12-02 A | 2020-01-02 A | 1934FS+88d | 100% |  | 2019-02-06 | 2019-02-19 | 10d | 2019-02-06 | 2019-02-19 |  |  | 100% |  | 100 |  | 100 | Socioambiental | 0% | Não OK | 0% | Boninsegna (distrito Marilândia/ES) |  | 8888888 |
| 1936 | 7.7.1.2.1.8 | Elaborar Projeto Executivo - Captação Principal - Rio Doce - Boninsegna/ES |  | 154d | 2019-07-17 A | 2020-02-28 | 1930, 1931FS-18d, 1933, 1934FS-8d | 65% | 53.9d | 2018-12-25 | 2019-02-19 | 40d | 2018-12-25 | 2019-02-19 | 533d | 0d | 100% |  | 100 |  | 100 | Socioambiental | 0% | Não OK | 0% | Boninsegna (distrito Marilândia/ES) |  |  |
| 1937 | 7.7.1.2.1.9 | Elaboração do Projeto Executivo - Captação Principal - Rio Doce - Boninsegna/ES | milestone | 0d | 2020-02-28 | 2020-02-28 | 1936 |  |  | 2019-02-19 | 2019-02-19 | 0d | 2019-02-19 | 2019-02-19 | 928d | 252d | 100% |  | 100 |  | 100 |  |  |  |  |  |  |  |
| 1938 | 7.7.1.2.2 | **Engenharia Captação Alternativa (Poço raso existente) - SE 32103** |  | 338d | 2018-10-22 A | 2020-02-28 |  | 82% | 59.28d | 2018-10-22 | 2019-09-24 | 233d | 2018-10-22 | 2019-09-24 | 928d |  | 73% | 58 | 73 | 81 | 72 | Socioambiental | 0% | ok | 0% | Boninsegna (distrito Marilândia/ES) |  |  |
| 1939 | 7.7.1.2.2.1 | Aprovação Plano de Trabalho /abertura OSE - Captação Alternativa - Cacimba - Boninsegna/ES |  | 73d | 2018-12-03 A | 2019-03-19 A | 1925 | 100% |  | 2018-12-03 | 2019-03-19 | 73d | 2018-12-03 | 2019-03-19 |  |  | 100% | 100 | 100 | 100 | 100 |  | 0% | ok | 0% | Boninsegna (distrito Marilândia/ES) |  |  |
| 1940 | 7.7.1.2.2.2 | Realizar levantamento de Campo - Captação Alternativa - Cacimba - Boninsegna/ES |  | 6d | 2019-06-05 A | 2019-06-12 A | 1939FS+52d | 100% |  | 2019-05-06 | 2019-05-10 | 5d | 2019-05-06 | 2019-05-10 |  |  | 100% | 100 | 100 | 100 | 100 | Socioambiental | 0% | Não OK | 0% | Boninsegna (distrito Marilândia/ES) | Não OK |  |
| 1941 | 7.7.1.2.2.3 | Realizar sondagem - Captação Alternativa - Cacimba - Boninsegna/ES |  | 1d | 2020-01-02 | 2020-01-02 | 1939FS+196d |  |  | 2019-05-06 | 2019-06-04 | 22d | 2019-05-06 | 2019-06-04 | 571d | 38d | 100% |  | 100 |  | 100 |  |  |  |  |  |  |  |
| 1942 | 7.7.1.2.2.4 | Executar Topografia - Captação Alternativa - Cacimba - Boninsegna/ES |  | 30d | 2018-10-22 A | 2018-11-30 A | 1939FS+30d | 100% |  | 2018-10-22 | 2018-11-30 | 30d | 2018-10-22 | 2018-11-30 |  |  | 100% | 100 | 100 | 100 | 100 |  |  |  |  |  |  |  |
| 1943 | 7.7.1.2.2.5 | Realizar Batimetria - Captação Alternativa - Cacimba - Boninsegna/ES |  | 19d | 2019-05-06 A | 2019-05-30 A | 1939FS+30d | 100% |  | 2019-05-06 | 2019-06-14 | 30d | 2019-05-06 | 2019-06-14 |  |  | 100% | 100 | 100 | 100 | 100 |  |  |  |  |  |  |  |
| 1944 | 7.7.1.2.2.6 | Elaborar arranjo para obtenção de Dados de Entrada Licenciamento e Fundiário - Captação Alternativa - Cacimba - Boninsegna/ES |  | 22d | 2019-06-13 A | 2019-07-15 A | 1940 | 100% |  | 2019-06-28 | 2019-07-29 | 22d | 2019-06-28 | 2019-07-29 |  |  | 4% | 80 |  | 2000 |  |  | 0% | ok | 0% | Boninsegna (distrito Marilândia/ES) |  |  |
| 1945 | 7.7.1.2.2.7 | Emitir RT/PQ para Suprimentos - Captação Alternativa - Cacimba - Boninsegna/ES |  | 20d | 2019-12-02 A | 2020-01-02 A | 1944FS+97d | 100% |  | 2019-09-11 | 2019-09-24 | 10d | 2019-09-11 | 2019-09-24 |  |  | 0% |  |  |  |  |  | 0% | ok | 0% | Boninsegna (distrito Marilândia/ES) |  | 8888888 |
| 1946 | 7.7.1.2.2.8 | Elaborar Projeto Executivo - Captação Alternativa - Cacimba - Boninsegna/ES |  | 166d | 2019-07-01 A | 2020-02-28 | 1941FF, 1942, 1943, 1944FS-11d | 65% | 58.1d | 2019-07-30 | 2019-09-24 | 40d | 2019-07-30 | 2019-09-24 | 533d | 0d | 0% |  |  |  |  |  | 0% | ok | 0% | Boninsegna (distrito Marilândia/ES) |  |  |
| 1947 | 7.7.1.2.2.9 | Elaboração do Projeto Executivo - Captação Alternativa - Cacimba - Boninsegna/ES | milestone | 0d | 2020-02-28 | 2020-02-28 | 1946 |  |  | 2019-09-24 | 2019-09-24 | 0d | 2019-09-24 | 2019-09-24 | 928d | 252d | 0% |  |  |  |  |  |  |  |  |  |  |  |
| 1948 | 7.7.1.2.3 | **Engenharia nova ETA - SE 32103** |  | 370d | 2018-09-06 A | 2020-02-28 |  | 79% | 77.05d | 2018-09-06 | 2019-02-19 | 118d | 2018-09-06 | 2019-02-19 | 928d |  | 100% | 51 | 100 | 51 | 100 | Socioambiental | 0% | ok | 0% | Boninsegna (distrito Marilândia/ES) |  |  |
| 1949 | 7.7.1.2.3.1 | Aprovação Plano de Trabalho /abertura OSE - Nova ETA - Boninsegna/ES |  | 46d | 2018-09-06 A | 2018-11-08 A | 1925 | 100% |  | 2018-09-06 | 2018-11-08 | 46d | 2018-09-06 | 2018-11-08 |  |  | 100% | 100 | 100 | 100 | 100 | Socioambiental | 0% | Não OK | 0% | Boninsegna (distrito Marilândia/ES) | Não OK |  |
| 1950 | 7.7.1.2.3.2 | Dados de Entrada (levantamento de campo, topografia e sondagem) - Nova ETA - Boninsegna/ES |  | 25d | 2018-11-09 A | 2018-12-13 A | 1949 | 100% |  | 2018-11-09 | 2018-12-13 | 25d | 2018-11-09 | 2018-12-13 |  |  | 100% | 100 | 100 | 100 | 100 | Socioambiental | 0% | Não OK | 0% | Boninsegna (distrito Marilândia/ES) |  |  |
| 1951 | 7.7.1.2.3.3 | Elaborar arranjo para obtenção de Dados de Entrada Licenciamento e Fundiário - Nova ETA - Boninsegna/ES |  | 22d | 2019-06-13 A | 2019-07-15 A | 1950FS+122d | 100% |  | 2018-11-26 | 2018-12-25 | 22d | 2018-11-26 | 2018-12-25 |  |  | 100% | 80 | 100 | 80 | 100 | Socioambiental | 0% | Não OK | 0% | Boninsegna (distrito Marilândia/ES) |  |  |
| 1952 | 7.7.1.2.3.4 | Emitir RT/PQ para Suprimentos - Nova ETA - Boninsegna/ES |  | 20d | 2019-12-02 A | 2020-01-02 A | 1944FS+97d | 100% |  | 2019-02-06 | 2019-02-19 | 10d | 2019-02-06 | 2019-02-19 |  |  | 100% |  | 100 |  | 100 | Socioambiental | 0% | Não OK | 0% | Boninsegna (distrito Marilândia/ES) |  | 8888888 |
| 1953 | 7.7.1.2.3.5 | Elaborar Projeto Executivo - Nova ETA - Boninsegna/ES |  | 166d | 2019-07-01 A | 2020-02-28 | 1951FS-11d | 65% | 58.1d | 2018-12-25 | 2019-02-19 | 40d | 2018-12-25 | 2019-02-19 | 928d | 0d | 100% |  | 100 |  | 100 | Socioambiental | 0% | Não OK | 0% | Boninsegna (distrito Marilândia/ES) |  |  |
| 1954 | 7.7.1.2.3.6 | Elaboração do Projeto Executivo - Nova ETA - Boninsegna/ES | milestone | 0d | 2020-02-28 | 2020-02-28 | 1953 |  |  | 2019-02-19 | 2019-02-19 | 0d | 2019-02-19 | 2019-02-19 | 928d | 252d | 100% |  | 100 |  | 100 |  |  |  |  |  |  |  |

Notes:
- 1927: 12/Dez / - E-mail enviado à Engenharia pelo Mateus em 16/10/18, autorizando a elaboração dos projetos em função da aprovação da nova definição.
- 1940: 25/Jan19: / - Levantamento de campo previsto para iniciar em 25/02 e finalizar em 01/03/19; Topografia iniciada em 19/10 e concluída em 26/12/18; Sondagem prevista para iniciar em 25/02 e finalizar em 29/03/19.
- 1946: 25/Jan19: / - Não estão sendo considerados pela Engenharia para desenvolvimento do Projeto Executivo o Relatório Técnico e o Laudo dos Serviços de Coleta e Análise de Água.
- 1953: 25/Jan19: / - Não está sendo considerado pela Engenharia para desenvolvimento do Projeto Executivo o Laudo dos Serviços de Coleta e Análise de Água.

| ID | WBS | Task | Type | Duration | Start | Finish | Predecessors | Complete | Remaining | Baseline start | Baseline finish | Baseline duration | Baseline 1 start | Baseline 1 finish | Total slack | Free slack | Text3 | Text4 | Text5 | Text7 | Text15 | Text23 | Text25 | Text26 | Text27 | Text29 | Text9 | Text13 |
| --- | --- | --- | --- | --- | --- | --- | --- | --- | --- | --- | --- | --- | --- | --- | --- | --- | --- | --- | --- | --- | --- | --- | --- | --- | --- | --- | --- | --- |
| 1955 | 7.7.1.2.4 | **Engenharia UTR - SE 32103** |  | 370d | 2018-09-06 A | 2020-02-28 |  | 80% | 72.73d | 2018-09-06 | 2019-02-19 | 118d | 2018-09-06 | 2019-02-19 | 533d |  | 100% | 52 | 100 | 52 | 100 | Socioambiental | 0% | ok | 0% | Boninsegna (distrito Marilândia/ES) |  |  |
| 1956 | 7.7.1.2.4.1 | Aprovação Plano de Trabalho /abertura OSE - UTR - Boninsegna/ES |  | 46d | 2018-09-06 A | 2018-11-08 A | 1925 | 100% |  | 2018-09-06 | 2018-11-08 | 46d | 2018-09-06 | 2018-11-08 |  |  | 100% | 100 | 100 | 100 | 100 | Socioambiental | 0% | Não OK | 0% | Boninsegna (distrito Marilândia/ES) | Não OK |  |
| 1957 | 7.7.1.2.4.2 | Dados de Entrada (levantamento de campo, topografia e sondagem) - UTR - Boninsegna/ES |  | 25d | 2018-11-09 A | 2018-12-13 A | 1956 | 100% |  | 2018-11-09 | 2018-12-13 | 25d | 2018-11-09 | 2018-12-13 |  |  | 100% | 100 | 100 | 100 | 100 | Socioambiental | 0% | Não OK | 0% | Boninsegna (distrito Marilândia/ES) |  |  |
| 1958 | 7.7.1.2.4.3 | Elaborar arranjo para obtenção de Dados de Entrada Licenciamento e Fundiário - UTR - Boninsegna/ES |  | 30d | 2019-06-03 A | 2019-07-15 A | 1957FS+114d | 100% |  | 2018-11-26 | 2018-12-25 | 22d | 2018-11-26 | 2018-12-25 |  |  | 100% | 80 | 100 | 80 | 100 | Socioambiental | 0% | Não OK | 0% | Boninsegna (distrito Marilândia/ES) |  |  |
| 1959 | 7.7.1.2.4.4 | Emitir RT/PQ para Suprimentos - UTR - Boninsegna/ES |  | 20d | 2019-12-02 A | 2020-01-02 A | 1944FS+97d | 100% |  | 2019-02-06 | 2019-02-19 | 10d | 2019-02-06 | 2019-02-19 |  |  | 100% |  | 100 |  | 100 | Socioambiental | 0% | Não OK | 0% | Boninsegna (distrito Marilândia/ES) |  | 8888888 |
| 1960 | 7.7.1.2.4.5 | Elaborar Projeto Executivo - UTR - Boninsegna/ES |  | 155d | 2019-07-16 A | 2020-02-28 | 1958 | 65% | 54.25d | 2018-12-25 | 2019-02-19 | 40d | 2018-12-25 | 2019-02-19 | 533d | 0d | 100% |  | 100 |  | 100 | Socioambiental | 0% | Não OK | 0% | Boninsegna (distrito Marilândia/ES) |  |  |
| 1961 | 7.7.1.2.4.6 | Elaboração do Projeto Executivo - UTR - Boninsegna/ES | milestone | 0d | 2020-02-28 | 2020-02-28 | 1960 |  |  | 2019-02-19 | 2019-02-19 | 0d | 2019-02-19 | 2019-02-19 | 533d | 91d | 100% |  | 100 |  | 100 |  |  |  |  |  |  |  |
| 1962 | 7.7.1.3 | **Fundiária** |  | 277d | 2019-05-17 A | 2020-06-26 |  | 16% | 233.65d | 2019-02-20 | 2019-07-01 | 87d | 2019-02-20 | 2019-07-01 | 847d |  | 98% |  | 98 |  | 99 | Socioambiental | 0% | ok | 0% | Boninsegna (distrito Marilândia/ES) |  |  |
| 1963 | 7.7.1.3.1 | Obter Termo de Autorização de Superficiário - Captação Principal - Boninsegna/ES |  | 108d | 2019-09-17 A | 2020-02-20 | 1925FS+259d | 23% | 83.25d | 2019-02-20 | 2019-04-29 | 44d | 2019-02-20 | 2019-04-29 | 452d | 0d | 100% |  | 100 |  | 100 | Socioambiental | 0% | Não OK | 0% | Boninsegna (distrito Marilândia/ES) |  |  |
| 1964 | 7.7.1.3.2 | Captação Principal - Desimpedimento da Área e Negociação de Servidão - Boninsegna/ES |  | 84d | 2020-02-21 | 2020-06-26 | 1934, 1963 |  |  | 2019-04-29 | 2019-07-01 | 44d | 2019-04-29 | 2019-07-01 | 452d | 0d | 97% |  | 97 |  | 97 | Socioambiental | 0% | Não OK | 0% | Boninsegna (distrito Marilândia/ES) |  |  |
| 1965 | 7.7.1.3.3 | Obter Termo de Autorização de Superficiário - Captação Alternativa - Boninsegna/ES |  | 193d | 2019-05-17 A | 2020-02-20 | 1925FS+174d | 24% | 147d | 2019-02-20 | 2019-04-29 | 44d | 2019-02-20 | 2019-04-29 | 452d | 0d | 100% |  | 100 |  | 100 | Socioambiental | 0% | Não OK | 0% | Boninsegna (distrito Marilândia/ES) |  |  |
| 1966 | 7.7.1.3.4 | Captação Alternativa - Desimpedimento da Área e Negociação de Servidão - Boninsegna/ES |  | 84d | 2020-02-21 | 2020-06-26 | 1944, 1965 |  |  | 2019-04-29 | 2019-07-01 | 44d | 2019-04-29 | 2019-07-01 | 452d | 0d | 97% |  | 97 |  | 97 |  | 0% | ok | 0% | Boninsegna (distrito Marilândia/ES) |  |  |
| 1967 | 7.7.1.3.5 | Obter Termo de Autorização de Superficiário - Nova ETA / UTR - Boninsegna/ES |  | 193d | 2019-05-17 A | 2020-02-20 | 1925FS+174d | 24% | 147d | 2019-02-20 | 2019-04-29 | 44d | 2019-02-20 | 2019-04-29 | 847d | 0d | 100% |  | 100 |  | 100 | Socioambiental | 0% | Não OK | 0% | Boninsegna (distrito Marilândia/ES) |  |  |
| 1968 | 7.7.1.3.6 | Nova ETA / UTR - Desimpedimento da Área e Negociação de Servidão - Boninsegna/ES |  | 84d | 2020-02-21 | 2020-06-26 | 1951, 1958, 1967 |  |  | 2019-04-29 | 2019-07-01 | 44d | 2019-04-29 | 2019-07-01 | 847d | 0d | 97% |  | 97 |  | 97 | Socioambiental | 0% | Não OK | 0% | Boninsegna (distrito Marilândia/ES) |  |  |
| 1969 | 7.7.1.3.7 | Conclusão da Regularização Fundiária para as obras de Melhoria do Sistema de Abastecimento da Localidade - Boninsegna/ES | milestone | 0d | 2020-06-26 | 2020-06-26 | 1963, 1964, 1965, 1966, 1967, 1968 |  |  | 2019-07-01 | 2019-07-01 | 0d | 2019-07-01 | 2019-07-01 | 847d | 171d | 0% |  |  |  |  |  |  |  |  |  |  |  |
| 1970 | 7.7.1.4 | **Licenciamento** |  | 234d | 2019-08-01 A | 2020-07-10 |  | 25% | 175.5d | 2018-10-17 | 2019-07-01 | 176d | 2018-10-17 | 2019-07-01 | 837d |  | 99% |  | 99 |  | 99 | Socioambiental | 0% | ok | 0% | Boninsegna (distrito Marilândia/ES) |  |  |
| 1971 | 7.7.1.4.1 | Obter Outorga e autorizações (captação principal, construção ETA e UTR) - Boninsegna/ES |  | 234d | 2019-08-01 A | 2020-07-10 | 1934FS+3d, 1951, 1958 | 25% | 175.5d | 2018-10-17 | 2019-07-01 | 176d | 2018-10-17 | 2019-07-01 | 442d | 0d | 99% |  | 99 |  | 99 | Socioambiental | 0% | Não OK | 0% | Boninsegna (distrito Marilândia/ES) |  |  |
| 1972 | 7.7.1.4.2 | Captação Alternativa - Dispensa de Licença (Poço raso existente) - Boninsegna/ES |  | 149d | 2019-09-05 A | 2020-04-13 | 1944FS+36d | 25% | 111.75d | 2019-03-26 | 2019-07-01 | 66d | 2019-03-26 | 2019-07-01 | 503d | 61d | 98% |  | 98 |  | 98 |  | 0% | ok | 0% | Boninsegna (distrito Marilândia/ES) |  |  |
| 1973 | 7.7.1.4.3 | Conclusão do Licenciamento Ambiental da Localidade - Boninsegna/ES | milestone | 0d | 2020-07-10 | 2020-07-10 | 1971, 1972 |  |  | 2019-07-01 | 2019-07-01 | 0d | 2019-07-01 | 2019-07-01 | 837d | 161d | 0% |  |  |  |  |  |  |  |  |  |  |  |
| 1974 | 7.7.1.5 | **Suprimentos** |  | 111d | 2020-01-02 | 2020-06-16 |  |  |  | 2019-02-19 | 2019-07-01 | 88d | 2019-02-19 | 2019-07-01 | 428d |  | 98% |  | 98 |  | 32 |  | 0% | ok | 0% | Boninsegna (distrito Marilândia/ES) |  |  |
| 1975 | 7.7.1.5.1 | **Processo contratação - Captação Principal, nova ETA e UTR - Boninsegna/ES** |  | 88d | 2020-01-02 | 2020-05-13 |  |  |  | 2019-02-19 | 2019-07-01 | 88d | 2019-02-19 | 2019-07-01 | 451d |  | 98% |  | 98 |  |  |  | 0% | ok | 0% | Boninsegna (distrito Marilândia/ES) |  |  |
| 1976 | 7.7.1.5.1.1 | Recebimento da RT/PQ pelo Suprimentos - Boninsegna/ES | milestone | 0d | 2020-01-02 | 2020-01-02 | 1935, 1952, 1959 |  |  | 2019-12-11 | 2019-12-11 | 0d |  |  | 451d | 0d | 0% |  |  |  |  |  |  |  |  |  |  |  |
| 1977 | 7.7.1.5.1.2 | Realizar Entendimento da Demanda - Boninsegna/ES |  | 10d | 2020-01-03 | 2020-01-16 | 1976 |  |  | 2019-12-11 | 2019-12-27 | 10d |  |  | 451d | 0d | 0% |  |  |  |  |  |  |  |  |  |  |  |
| 1978 | 7.7.1.5.1.3 | Abrir a RC - Boninsegna/ES |  | 8d | 2020-01-17 | 2020-01-28 | 1977 |  |  | 2019-12-30 | 2020-01-09 | 8d |  |  | 451d | 0d | 0% |  |  |  |  |  |  |  |  |  |  |  |
| 1979 | 7.7.1.5.1.4 | Aprovar a RC (liberação) - Boninsegna/ES |  | 8d | 2020-01-29 | 2020-02-07 | 1978 |  |  | 2020-01-10 | 2020-01-21 | 8d |  |  | 451d | 0d | 0% |  |  |  |  |  |  |  |  |  |  |  |
| 1980 | 7.7.1.5.1.5 | Prospectar fornecedores e receber proposta técnicas - Boninsegna/ES |  | 30d | 2020-02-10 | 2020-03-25 | 1979 |  |  | 2020-01-22 | 2020-03-06 | 30d |  |  | 451d | 0d | 0% |  |  |  |  |  |  |  |  |  |  |  |
| 1981 | 7.7.1.5.1.6 | Aprovar proposta técnica - Boninsegna/ES |  | 12d | 2020-03-26 | 2020-04-13 | 1980 |  |  | 2020-03-09 | 2020-03-24 | 12d |  |  | 451d | 0d | 0% |  |  |  |  |  |  |  |  |  |  |  |
| 1982 | 7.7.1.5.1.7 | Realizar negociação e aprovar o pedido - Boninsegna/ES |  | 20d | 2020-04-14 | 2020-05-13 | 1981 |  |  | 2020-03-25 | 2020-04-23 | 20d |  |  | 451d | 0d | 0% |  |  |  |  |  |  |  |  |  |  |  |
| 1983 | 7.7.1.5.1.8 | Conclusão da Contratação de Suprimentos - Boninsegna/ES | milestone | 0d | 2020-05-13 | 2020-05-13 | 1982 |  |  | 2020-04-23 | 2020-04-23 | 0d |  |  | 451d | 23d | 0% |  |  |  |  |  |  |  |  |  |  |  |
| 1984 | 7.7.1.5.2 | Processo contratação Serviço Limpeza em Poços Rasos (Tintori) - Boninsegna/ES |  | 111d | 2020-01-03 | 2020-06-16 | 1945 |  |  | 2019-04-29 | 2019-07-01 | 44d | 2019-04-29 | 2019-07-01 | 428d | 0d | 97% |  | 97 |  | 97 |  | 0% | ok | 0% | Boninsegna (distrito Marilândia/ES) |  |  |
| 1985 | 7.7.1.5.3 | Conclusão da Contratação de Suprimentos das obras de Melhoria do Sistema de Abastecimento de Água - Boninsegna/ES | milestone | 0d | 2020-06-16 | 2020-06-16 | 1984 |  |  | 2019-07-01 | 2019-07-01 | 0d | 2019-07-01 | 2019-07-01 | 855d | 179d | 0% |  |  |  |  |  |  |  |  |  |  |  |

Notes:
- 1963: 19/Fev19: / - Solicitação de envio feita ao PG e à Engenharia nesta data. / 01/Fev19: / - Aguardando definição do ponto de captação pela PG/ENG.
- 1965: 19/Fev19: / - Informado ao Fundiário nesta data que a localização do poço se encontra no DEPP. / 01/Fev19: / - Não foi informado ao Fundiário localização do poço.
- 1967: 18/Fev19: / - Segundo Mateus, ainda não definido. Acompanhar a cada atualização. / 01/Fev19: / - Não foi informado ao Fundiário localização da nova ETA/UTR.
- 1984: 20/Dez: / - Processo de contratação para limpeza em poço raso em Boninsegna e Ipabinha. / - Contratação por PU.

| ID | WBS | Task | Type | Duration | Start | Finish | Predecessors | Complete | Remaining | Baseline start | Baseline finish | Baseline duration | Baseline 1 start | Baseline 1 finish | Total slack | Free slack | Baseline cost | Text3 | Text25 | Text26 | Text27 | Text29 | Text5 | Text15 | Text23 | Text28 | Indicadores MIR | Text4 | Text7 | Text9 |
| --- | --- | --- | --- | --- | --- | --- | --- | --- | --- | --- | --- | --- | --- | --- | --- | --- | --- | --- | --- | --- | --- | --- | --- | --- | --- | --- | --- | --- | --- | --- |
| 1986 | 7.7.1.6 | **Infraestrutura** |  | 428d | 2020-06-17 | 2022-03-05 |  |  |  | 2019-07-01 | 2020-12-31 | 376d | 2019-07-01 | 2020-12-31 | 427d |  |  | 0% | 0% | ok | 0% | Boninsegna (distrito Marilândia/ES) |  |  |  |  |  |  |  |  |
| 1987 | 7.7.1.6.1 | **Obras** |  | 179d | 2020-06-17 | 2021-03-05 |  |  |  | 2019-07-01 | 2019-12-12 | 116d | 2019-07-01 | 2019-12-12 | 428d |  |  | 0% |  |  |  |  |  |  |  |  |  |  |  |  |
| 1988 | 7.7.1.6.1.1 | **Captação Alternativa - Poço raso (Cacimba)** |  | 179d | 2020-06-17 | 2021-03-05 |  |  |  | 2018-10-12 | 2018-11-22 | 30d | 2018-10-12 | 2018-11-22 | 428d |  |  | 100% | 0% | ok | 0% | Boninsegna (distrito Marilândia/ES) | 100 | 100 | Socioambiental |  |  |  |  |  |
| 1989 | 7.7.1.6.1.1.1 | Realizar Recuperação - Captação Alternativa - Cacimba - Boninsegna/ES |  | 5d | 2020-06-17 | 2020-06-23 | 1925, 1965, 1984, 1983 |  |  | 2018-10-12 | 2018-10-18 | 5d | 2018-10-12 | 2018-10-18 | 428d | 0d |  | 100% | 0% | Não OK | 0% | Boninsegna (distrito Marilândia/ES) | 100 | 100 | Socioambiental |  |  |  |  |  |
| 1990 | 7.7.1.6.1.1.2 | Elaborar Relatório Técnico - Captação Alternativa - Cacimba - Boninsegna/ES |  | 24d | 2020-06-24 | 2020-07-27 | 1989 |  |  | 2018-10-18 | 2018-11-20 | 24d | 2018-10-18 | 2018-11-20 | 428d | 0d |  | 100% | 0% | Não OK | 0% | Boninsegna (distrito Marilândia/ES) | 100 | 100 | Socioambiental |  |  |  |  |  |
| 1991 | 7.7.1.6.1.1.3 | Realizar Instrumentação - Captação Alternativa - Cacimba - Boninsegna/ES |  | 3d | 2020-07-28 | 2020-07-30 | 1990 |  |  | 2018-11-20 | 2018-11-22 | 3d | 2018-11-20 | 2018-11-22 | 428d | 0d |  | 100% | 0% | Não OK | 0% | Boninsegna (distrito Marilândia/ES) | 100 | 100 | Socioambiental |  |  |  |  |  |
| 1992 | 7.7.1.6.1.1.4 | Realizar Laudo dos Serviços de Coleta e Análise de Água - Captação Alternativa - Cacimba - Boninsegna/ES |  | 24d | 2020-06-24 | 2020-07-27 | 1989 |  |  | 2018-10-19 | 2018-11-21 | 24d | 2018-10-19 | 2018-11-21 | 431d | 0d |  | 100% | 0% | Não OK | 0% | Boninsegna (distrito Marilândia/ES) | 100 | 100 | Socioambiental | Não ok |  |  |  |  |
| 1993 | 7.7.1.6.1.1.5 | Executar Captação Alternativa (Urbanização Poço Raso existente) - Boninsegna/ES |  | 147d | 2020-07-31 | 2021-03-05 | 1991, 1946, 1966, 1972, 1983, 1994 |  |  | 2019-07-01 | 2019-12-12 | 116d | 2019-07-01 | 2019-12-12 | 428d | 0d |  | 0% | 0% | ok | 0% | Boninsegna (distrito Marilândia/ES) |  |  |  |  | CA |  |  |  |
| 1994 | 7.7.1.6.1.1.6 | Conclusão das obras de Captação Alternativa - Poço Raso (Cacimba) - Boninsegna/ES | milestone | 0d | 2020-07-27 | 2020-07-27 | 1992 |  |  | 2018-11-21 | 2018-11-21 | 0d | 2018-11-21 | 2018-11-21 | 431d | 3d |  | 100% |  |  |  |  | 100 | 100 |  |  |  |  |  |  |
| 1995 | 7.7.1.6.1.2 | Executar Captação, ETA e UTR - Boninsegna/ES |  | 147d | 2020-07-13 | 2021-02-10 | 1936, 1964, 1971, 1983, 1961 |  |  | 2019-07-01 | 2019-12-12 | 116d | 2019-07-01 | 2019-12-12 | 442d | 14d |  | 0% | 0% | ok | 0% | Boninsegna (distrito Marilândia/ES) |  |  |  |  | ETA |  |  |  |
| 1996 | 7.7.1.6.1.3 | Assinatura de Termo de Entrega das Obras de Melhoria do Sistema de Abastecimento de Água - Boninsegna/ES | milestone | 0d | 2021-03-05 | 2021-03-05 | 1995, 1993, 1937, 1947, 1954, 1969, 1973, 1985 |  |  | 2019-12-12 | 2019-12-12 | 0d | 2019-12-12 | 2019-12-12 | 676d | 428d |  | 0% | 0% | ok | 0% | Boninsegna (distrito Marilândia/ES) |  |  |  |  |  |  |  |  |
| 1997 | 7.7.1.6.2 | **Operação** |  | 249d | 2021-03-05 | 2022-03-05 |  |  |  | 2019-12-13 | 2020-12-31 | 260d | 2019-12-13 | 2020-12-31 | 427d |  |  | 0% | 0% | ok | 0% | Boninsegna (distrito Marilândia/ES) |  |  |  |  |  |  |  |  |
| 1998 | 7.7.1.6.2.1 | Realizar Treinamento Operacional do Sistema - Boninsegna/ES |  | 5d | 2021-03-08 | 2021-03-12 | 1995, 1993 |  |  | 2019-12-13 | 2019-12-19 | 5d | 2019-12-13 | 2019-12-19 | 657d | 0d |  | 0% | 0% | ok | 0% | Boninsegna (distrito Marilândia/ES) |  |  |  |  |  |  |  |  |
| 1999 | 7.7.1.6.2.2 | Realizar Testes e Pré-operação - Boninsegna/ES |  | 14d | 2021-03-15 | 2021-04-01 | 1998 |  |  | 2019-12-20 | 2020-01-13 | 14d | 2019-12-20 | 2020-01-13 | 657d |  |  | 0% | 0% | ok | 0% | Boninsegna (distrito Marilândia/ES) |  |  |  |  |  |  |  |  |
| 2000 | 7.7.1.6.2.3 | Realizar Acompanhamento da Funcionalidade do Sistema - Captação Principal, Alternativa, Nova ETA e UTR - Boninsegna (distrito Marilândia/ES) |  | 365ed | 2021-03-05 | 2022-03-05 | 2002SS |  |  | 2019-12-13 | 2020-12-31 | 260d |  |  | 1881d |  |  |  |  |  |  |  |  |  |  |  |  |  |  |  |
| 2001 | 7.7.1.6.2.4 | **Operação Assistida** |  | 61d | 2021-03-05 | 2021-06-03 |  |  |  | 2019-12-13 | 2020-03-19 | 64d | 2019-12-13 | 2020-03-19 | 428d |  |  | 0% | 0% | ok | 0% | Boninsegna (distrito Marilândia/ES) |  |  |  |  |  |  |  |  |
| 2002 | 7.7.1.6.2.4.1 | Realizar Operação Assistida - Boninsegna/ES |  | 90ed | 2021-03-05 | 2021-06-03 | 1995, 1993 |  |  | 2019-12-13 | 2020-03-19 | 3.2mo | 2019-12-13 | 2020-03-19 | 1881d | 0d |  | 0% | 0% | ok | 0% | Boninsegna (distrito Marilândia/ES) |  |  |  |  |  |  |  |  |
| 2003 | 8 | **Território Foz do Rio Doce Litoral** |  | 1199d | 2017-12-22 A | 2022-09-29 |  | 11% | 1062.11d | 2016-07-01 | 2021-08-30 | 1314d | 2016-07-01 | 2021-08-30 | 283d |  | -0 | 58% | 0% | ok | 0% | Boninsegna (distrito Marilândia/ES) | 58 | 34 | Socioambiental |  |  | 23 | 68 |  |
| 2004 | 8.1 | **Linhares/ES (sede)** |  | 1199d | 2017-12-22 A | 2022-09-29 |  | 16% | 1011.59d | 2016-07-01 | 2021-04-16 | 1220d | 2016-07-01 | 2021-04-16 | 283d |  | -0 | 63% | 0% | ok | 0% | Linhares/ES (sede) | 63 | 38 | Socioambiental |  |  | 22 | 58 |  |
| 2005 | 8.1.1 | **Captação Alternativa - Adequação da captação na Lagoa Nova** |  | 847d | 2017-12-22 A | 2021-05-05 |  | 21% | 671.34d | 2016-12-02 | 2021-04-16 | 1110d |  |  | 635d |  |  |  |  |  |  |  |  |  |  |  |  |  |  |  |
| 2006 | 8.1.1.1 | **Estudos de Concepção do Sistema** |  | 65d | 2017-12-22 A | 2018-03-23 A |  | 100% |  | 2016-12-02 | 2019-04-26 | 620d | 2016-12-02 | 2019-04-26 |  |  |  | 100% | 0% | ok | 0% | Linhares/ES (sede) | 100 | 100 |  |  |  | 99 | 99 |  |
| 2007 | 8.1.1.1.1 | Declaração de Escopo e Premissas de Projeto (DEPP) concluída - Linhares/ES | milestone | 0d | 2018-03-23 A | 2018-03-23 A | 25, 26 | 100% |  | 2018-03-23 | 2018-03-23 | 0d | 2018-03-23 | 2018-03-23 |  |  |  | 100% | 0% | ok | 0% | Linhares/ES (sede) | 100 | 100 |  |  |  | 100 | 100 |  |
| 2008 | 8.1.1.1.2 | Aprovação das DEPPs pela Operadora e Prefeitura - Linhares/ES | milestone | 0d | 2017-12-22 A | 2017-12-22 A | 25, 26 | 100% |  | 2017-12-22 | 2017-12-22 | 0d | 2017-12-22 | 2017-12-22 |  |  |  | 100% | 0% | ok | 0% | Linhares/ES (sede) | 100 | 100 |  |  |  | 100 | 100 |  |
| 2009 | 8.1.1.2 | **Engenharia Básica e Detalhada** |  | 304d | 2018-09-18 A | 2019-11-29 A |  | 100% |  | 2018-06-07 | 2020-01-02 | 397d | 2018-06-07 | 2020-01-02 |  |  |  | 67% | 0% | ok | 0% | Linhares/ES (sede) | 67 | 87 | Socioambiental |  |  | 39 | 45 |  |
| 2010 | 8.1.1.2.1 | **Engenharia Captação Alternativa - Lagoa Nova (Recuperação de Erosões) - SE32128** |  | 304d | 2018-09-18 A | 2019-11-29 A |  | 100% |  | 2019-01-22 | 2019-07-24 | 125d | 2019-01-22 | 2019-07-24 |  |  |  | 85% | 0% | Não OK | 0% | Linhares/ES (sede) | 85 | 85 | Socioambiental |  |  | 51 | 60 | Não OK |
| 2011 | 8.1.1.2.1.1 | Aprovar Plano de Trabalho e abrir OSE - Recuperação Erosões - Captação Alternativa - Lagoa Nova - Linhares/ES |  | 11d | 2018-09-25 A | 2018-10-09 A | 2007FS+132d | 100% |  | 2019-01-22 | 2019-02-05 | 11d | 2019-01-22 | 2019-02-05 |  |  |  | 100% |  |  |  |  | 100 | 100 |  |  |  | 100 | 100 |  |
| 2012 | 8.1.1.2.1.2 | Realizar Levantamento de Campo - Recuperação Erosões - Captação Alternativa - Lagoa Nova - Linhares/ES |  | 6d | 2018-10-10 A | 2018-10-17 A | 2011 | 100% |  | 2019-02-06 | 2019-02-13 | 6d | 2019-02-06 | 2019-02-13 |  |  |  | 100% |  |  |  |  | 100 | 100 |  |  |  | 100 | 100 |  |
| 2013 | 8.1.1.2.1.3 | Realizar Sondagem - Recuperação Erosões - Captação Alternativa - Lagoa Nova - Linhares/ES |  | 22d | 2018-09-18 A | 2018-10-17 A | 2011FS-16d | 100% |  | 2019-02-05 | 2019-03-11 | 22d | 2019-02-05 | 2019-03-11 |  |  |  | 100% |  |  |  |  | 100 | 100 |  |  |  | 100 | 100 |  |
| 2014 | 8.1.1.2.1.4 | Executar Topografia - Recuperação Erosões - Captação Alternativa - Lagoa Nova - Linhares/ES |  | 15d | 2018-09-27 A | 2018-10-17 A | 2011FS-9d | 100% |  | 2019-02-06 | 2019-02-26 | 15d | 2019-02-06 | 2019-02-26 |  |  |  | 100% |  |  |  |  | 100 | 100 |  |  |  | 100 | 100 |  |
| 2015 | 8.1.1.2.1.5 | Elaborar arranjo para obtenção de Dados de Entrada Licenciamento e Fundiário - Recuperação Erosões - Captação Alternativa - Lagoa Nova - Linhares/ES |  | 179d | 2018-10-18 A | 2019-07-05 A | 2012, 2013, 2014 | 100% |  | 2019-03-11 | 2019-04-23 | 30d | 2019-03-11 | 2019-04-23 |  |  |  | 100% |  |  |  |  | 100 | 100 |  |  |  | 63 | 63 |  |
| 2016 | 8.1.1.2.1.6 | Emitir RT/PQ para Infra (Guarda-chuva) - Recuperação Erosões - Captação Alternativa - Lagoa Nova - Linhares/ES |  | 10d | 2019-11-18 A | 2019-11-29 A | 2017FF | 100% |  | 2019-07-11 | 2019-07-24 | 10d | 2019-07-11 | 2019-07-24 |  |  |  | 0% |  |  |  |  |  |  |  |  |  |  |  |  |
| 2017 | 8.1.1.2.1.7 | Elaborar Projeto Executivo - Recuperação Erosões - Captação Alternativa - Lagoa Nova - Linhares/ES |  | 61d | 2019-09-05 A | 2019-11-29 A | 2015FS+42d | 100% |  | 2019-04-23 | 2019-07-24 | 65d | 2019-04-23 | 2019-07-24 |  |  |  | 72% |  |  |  |  | 72 | 72 |  |  |  |  |  |  |
| 2018 | 8.1.1.2.1.8 | Elaboração do Projeto Executivo - Recuperação Erosões - Captação Alternativa - Lagoa Nova - Linhares/ES | milestone | 0d | 2019-11-29 A | 2019-11-29 A | 2017 | 100% |  | 2019-07-24 | 2019-07-24 | 0d | 2019-07-24 | 2019-07-24 |  |  |  | 0% |  |  |  |  |  |  |  |  |  |  |  |  |

Notes:
- 1988: 19/Dez / - Empresa a ser contratada pelo PG. Previsão de ser em modalidade "PU".
- 1992: 15/Fev19: / - Essa atividade está sem Sucessora (deveria ser o Projeto Executivo da nova ETA), em função da Engenharia não ter respeitado o sequenciamento de atividades definido. (Ver e-mail enviado em 03/02/19 "Considerações Relevantes: Cronograma Engenharia X Cronograma Master PG 32" e Relato Gerências").
- 2004: 11/Fev19: / - Fundiário irá verificar se houve regularização fundiária. / 14/Dez / - Não há pendências de Fundiário e Licenciamento para Linhares. O que tinha que ser feito, já foi!
- 2008: 26/Nov: / - Anuência dada por meio de e-mail de validação da Ata de Reunião datada de 14/12/17.
- 2010: 20/Dez / - Refere-se aos projetos de "Melhoria do Acesso" (iniciado em 07/06/18 e previsto para finalizar em 15/04/19), "Estudo de Alimentação Elétrica das Bombas" (iniciado em 30/07 e concluído em 06/12/18) e "Adequação do Sistema de Captação" (iniciado em 26/11/18 e previsto para finalizar em 03/06/19). / 20/Dez / - Projeto/obra já entregues.

| ID | WBS | Task | Type | Duration | Start | Finish | Predecessors | Complete | Remaining | Baseline start | Baseline finish | Baseline duration | Baseline 1 start | Baseline 1 finish | Total slack | Free slack | Calendar | Baseline cost | Text3 | Text4 | Text5 | Text15 | Text25 | Text26 | Text27 | Text29 | Text7 | Indicadores MIR |
| --- | --- | --- | --- | --- | --- | --- | --- | --- | --- | --- | --- | --- | --- | --- | --- | --- | --- | --- | --- | --- | --- | --- | --- | --- | --- | --- | --- | --- |
| 2019 | 8.1.1.2.2 | **Engenharia Captação Alternativa - Lagoa Nova (Adequação do Sistema Captação) e Captação Principal (Barrilete)** |  | 55d | 2019-07-01 A | 2019-09-16 A |  | 100% |  | 2019-07-01 | 2019-09-27 | 64d |  |  |  |  |  |  | 0% |  |  |  |  |  |  |  |  |  |
| 2020 | 8.1.1.2.2.1 | Aprovar Plano de Trabalho e abrir OSE - Adequação do Sist. Captação - Captação Alternativa - Lagoa Nova - Linhares/ES |  | 4d | 2019-07-01 A | 2019-07-04 A | 2007FS+323d | 100% |  | 2019-07-01 | 2019-07-05 | 5d |  |  |  |  |  |  | 0% | 100 |  |  |  |  |  |  |  |  |
| 2021 | 8.1.1.2.2.2 | Elaborar arranjo para obtenção de Dados de Entrada Licenciamento e Fundiário - Adequação do Sist. Captação - Captação Alternativa - Lagoa Nova - Linhares/ES |  | 22d | 2019-07-05 A | 2019-08-05 A | 2020 | 100% |  | 2019-07-08 | 2019-08-06 | 22d |  |  |  |  |  |  | 0% |  |  |  |  |  |  |  |  |  |
| 2022 | 8.1.1.2.2.3 | Emitir RT/PQ para Suprimentos - Adequação do Sist. Captação - Captação Alternativa - Lagoa Nova - Linhares/ES |  | 10d | 2019-08-13 A | 2019-08-27 A | 2023FF-20d | 100% |  | 2019-09-16 | 2019-09-27 | 10d |  |  |  |  |  |  | 0% |  |  |  |  |  |  |  |  |  |
| 2023 | 8.1.1.2.2.4 | Elaborar Projeto Executivo - Adequação do Sist. Captação - Captação Alternativa - Lagoa Nova - Linhares/ES |  | 29d | 2019-08-06 A | 2019-09-16 A | 2021 | 100% |  | 2019-07-08 | 2019-09-27 | 59d |  |  |  |  |  |  | 0% |  |  |  |  |  |  |  |  |  |
| 2024 | 8.1.1.2.2.5 | Elaboração do Projeto Executivo - Adequação do Sist. Captação - Captação Alternativa - Lagoa Nova - Linhares/ES | milestone | 0d | 2019-09-16 A | 2019-09-16 A | 2021, 2023 | 100% |  | 2019-09-27 | 2019-09-27 | 0d |  |  |  |  |  |  | 0% |  |  |  |  |  |  |  |  |  |
| 2025 | 8.1.1.3 | **Suprimentos** |  | 110d | 2019-09-17 A | 2020-02-27 |  | 33% | 73.33d | 2019-06-04 | 2019-11-26 | 123d | 2019-06-04 | 2019-11-26 | 929d |  |  |  | 14% |  | 14 | 10 | 0% | ok | 0% | Linhares/ES (sede) |  |  |
| 2026 | 8.1.1.3.1 | **Captação Alternativa e Captação Principal** |  | 88d | 2019-09-18 A | 2020-01-24 |  | 46% | 47.14d | 2019-07-24 | 2019-11-26 | 88d |  |  | 950d |  |  |  |  |  |  |  |  |  |  |  |  |  |
| 2027 | 8.1.1.3.1.1 | Aprovar APRO 130/2019 - Contratação Barrilete e Sist. de Automação - Linhares/ES |  | 1d | 2019-09-18 A | 2019-09-18 A | 2023 | 100% |  | 2019-09-18 | 2019-09-18 | 1d |  |  |  |  | Calendário APRO |  |  |  |  |  |  |  |  |  |  |  |
| 2028 | 8.1.1.3.1.2 | Realizar contratação - Captação Alternativa - Sistema de Automação - e Captação Principal - Barrilete - Linhares/ES |  | 12d | 2019-09-19 A | 2019-10-04 A | 2022, 2027 | 100% |  | 2019-07-24 | 2019-11-26 | 88d | 2019-07-24 | 2019-11-26 |  |  |  |  | 0% |  |  |  | 0% | ok | 0% | Linhares/ES (sede) |  |  |
| 2029 | 8.1.1.3.1.3 | Realizar contratação ou definir execução com contratos existentes - Captação Alternativa - Melhoria de acessos na lagoa nova (correção de focos erosivos) - Linhares/ES |  | 15d | 2020-01-06 | 2020-01-24 | 2017FS+21d |  |  | 2019-07-24 | 2019-11-26 | 88d | 2019-07-24 | 2019-11-26 | 636d | 0d |  |  | 0% |  |  |  | 0% | ok | 0% | Linhares/ES (sede) |  |  |
| 2030 | 8.1.1.3.1.4 | Conclusão da Contratação de Suprimentos - Lagoa Nova - Captação Alternativa - Linhares/ES | milestone | 0d | 2020-01-24 | 2020-01-24 | 2028, 2029 |  |  | 2019-11-26 | 2019-11-26 | 0d |  |  | 950d |  |  |  |  |  |  |  |  |  |  |  |  |  |
| 2031 | 8.1.1.3.2 | Processo de Compras - Barco para Manutenção das Bombas - Lagoa Nova - Captação Alternativa - Linhares/ES |  | 110d | 2019-09-17 A | 2020-02-27 | 2023 | 30% | 77d | 2019-09-17 | 2020-02-27 | 110d |  |  | 637d | 0d |  |  |  |  |  |  |  |  |  |  |  |  |
| 2032 | 8.1.1.3.3 | Conclusão da Contratação de Suprimentos das obras de Melhoria do Sistema de Abastecimento de Água - Linhares/ES | milestone | 0d | 2020-02-27 | 2020-02-27 | 2028, 2031 |  |  | 2019-11-26 | 2019-11-26 | 0d | 2019-11-26 | 2019-11-26 | 929d | 45d |  |  | 0% |  |  |  |  |  |  |  |  |  |
| 2033 | 8.1.1.4 | **Infraestrutura** |  | 315d | 2020-01-27 | 2021-05-05 |  |  |  | 2016-07-01 | 2021-04-16 | 1220d | 2016-07-01 | 2021-04-16 | 635d |  |  | -0 | 63% | 15 | 63 | 15 | 0% | ok | 0% | Linhares/ES (sede) | 100 |  |
| 2034 | 8.1.1.4.1 | **Obras** |  | 66d | 2020-01-27 | 2020-05-05 |  |  |  | 2016-07-01 | 2020-03-30 | 960d | 2016-07-01 | 2020-03-30 | 636d |  |  | -0 | 80% | 44 | 80 | 44 |  |  |  |  | 100 |  |
| 2035 | 8.1.1.4.1.1 | **Captação Alternativa** |  | 66d | 2020-01-27 | 2020-05-05 |  |  |  | 2016-07-01 | 2020-03-30 | 960d |  |  | 636d |  |  | -0 |  |  |  |  |  |  |  |  |  |  |
| 2036 | 8.1.1.4.1.1.1 | Executar adequação na Captação Alternativa - Recuperação de Erosões - Linhares/ES |  | 66d | 2020-01-27 | 2020-05-05 | 2016, 2017, 2029 |  |  | 2019-11-26 | 2020-03-30 | 83d | 2019-11-26 | 2020-03-30 | 636d | 0d |  |  | 0% |  |  |  | 0% | ok | 0% | Linhares/ES (sede) |  | CA |
| 2037 | 8.1.1.4.1.1.2 | Realizar entrega do barco para manutenção das bombas ao SAAE - Lagoa Nova - Captação Alternativa - Linhares/ES |  | 44d | 2020-02-28 | 2020-05-04 | 2031 |  |  | 2020-02-28 | 2020-05-04 | 44d |  |  | 637d | 1d |  |  |  |  |  |  |  |  |  |  |  |  |
| 2038 | 8.1.1.4.1.1.3 | Conclusão das obras de adequação na Captação Alternativa - Linhares/ES | milestone | 0d | 2020-05-05 | 2020-05-05 | 2036, 2037 |  |  | 2020-05-04 | 2020-05-04 | 0d |  |  | 636d | 0d |  |  |  |  |  |  |  |  |  |  |  |  |
| 2039 | 8.1.1.4.1.2 | Assinatura de Termo de Entrega das Obras de Melhoria do Sistema de Abastecimento de Água - Linhares/ES | milestone | 0d | 2020-05-05 | 2020-05-05 | 2038, 2018, 2032 |  |  | 2020-03-30 | 2020-03-30 | 0d | 2020-03-30 | 2020-03-30 | 884d | 636d |  |  | 0% |  |  |  | 0% | ok | 0% | Linhares/ES (sede) |  |  |
| 2040 | 8.1.1.4.2 | **Operação** |  | 249d | 2020-05-05 | 2021-05-05 |  |  |  | 2020-03-31 | 2021-04-16 | 260d | 2020-03-31 | 2021-04-16 | 635d |  |  |  | 0% |  |  |  | 0% | ok | 0% | Linhares/ES (sede) |  |  |
| 2041 | 8.1.1.4.2.1 | Realizar Treinamento Operacional do Sistema - Linhares/ES |  | 5d | 2020-05-06 | 2020-05-12 | 2038 |  |  | 2020-03-31 | 2020-04-06 | 5d | 2020-03-31 | 2020-04-06 | 865d | 0d |  |  | 0% |  |  |  | 0% | ok | 0% | Linhares/ES (sede) |  |  |
| 2042 | 8.1.1.4.2.2 | Realizar Testes e Pré-operação (Para as adequações da ETA) - Linhares/ES |  | 14d | 2020-05-13 | 2020-06-01 | 2041 |  |  | 2020-04-07 | 2020-04-28 | 14d | 2020-04-07 | 2020-04-28 | 865d |  |  |  | 0% |  |  |  | 0% | ok | 0% | Linhares/ES (sede) |  |  |
| 2043 | 8.1.1.4.2.3 | Realizar Acompanhamento da Funcionalidade do Sistema - Captação Alternativa - Adequação da captação na Lagoa Nova - Linhares/ES (sede) |  | 365ed | 2020-05-05 | 2021-05-05 | 2045SS |  |  | 2020-03-31 | 2021-04-16 | 260d |  |  | 2793d |  |  |  |  |  |  |  |  |  |  |  |  |  |

| ID | WBS | Task | Type | Duration | Start | Finish | Predecessors | Complete | Remaining | Baseline start | Baseline finish | Baseline duration | Baseline 1 start | Baseline 1 finish | Total slack | Free slack | Baseline cost | Text3 | Text25 | Text26 | Text27 | Text29 | Text4 | Text5 | Text7 | Text15 | Text23 | Text9 |
| --- | --- | --- | --- | --- | --- | --- | --- | --- | --- | --- | --- | --- | --- | --- | --- | --- | --- | --- | --- | --- | --- | --- | --- | --- | --- | --- | --- | --- |
| 2044 | 8.1.1.4.2.4 | **Operação Assistida** |  | 63d | 2020-05-05 | 2020-08-03 |  |  |  | 2020-03-31 | 2020-07-02 | 64d | 2020-03-31 | 2020-07-02 | 635d |  |  | 0% | 0% | ok | 0% | Linhares/ES (sede) |  |  |  |  |  |  |
| 2045 | 8.1.1.4.2.4.1 | Realizar Operação Assistida - Linhares/ES |  | 90ed | 2020-05-05 | 2020-08-03 | 2038 |  |  | 2020-03-31 | 2020-07-02 | 3.2mo | 2020-03-31 | 2020-07-02 | 2793d | 0d |  | 0% | 0% | ok | 0% | Linhares/ES (sede) |  |  |  |  |  |  |
| 2046 | 8.1.2 | **Melhorias em ETA e Captação Principal** |  | 1016d | 2017-12-22 A | 2022-01-05 |  | 19% | 820.06d | 2016-07-01 | 2021-04-16 | 1220d |  |  | 466d |  | -0 |  |  |  |  |  |  |  |  |  |  |  |
| 2047 | 8.1.2.1 | **Estudos de Concepção do Sistema** |  | 65d | 2017-12-22 A | 2018-03-23 A |  | 100% |  | 2016-12-02 | 2019-04-26 | 620d | 2016-12-02 | 2019-04-26 |  |  |  | 100% | 0% | ok | 0% | Linhares/ES (sede) | 99 | 100 | 99 | 100 |  |  |
| 2048 | 8.1.2.1.1 | Declaração de Escopo e Premissas de Projeto (DEPP) concluída - Linhares/ES | milestone | 0d | 2018-03-23 A | 2018-03-23 A | 25, 26 | 100% |  | 2018-03-23 | 2018-03-23 | 0d | 2018-03-23 | 2018-03-23 |  |  |  | 100% | 0% | ok | 0% | Linhares/ES (sede) | 100 | 100 | 100 | 100 |  |  |
| 2049 | 8.1.2.1.2 | Aprovação das DEPPs pela Operadora e Prefeitura - Linhares/ES | milestone | 0d | 2017-12-22 A | 2017-12-22 A | 25, 26 | 100% |  | 2017-12-22 | 2017-12-22 | 0d | 2017-12-22 | 2017-12-22 |  |  |  | 100% | 0% | ok | 0% | Linhares/ES (sede) | 100 | 100 | 100 | 100 |  |  |
| 2050 | 8.1.2.2 | **Engenharia Básica e Detalhada** |  | 258d | 2019-01-07 A | 2020-01-20 |  | 80% | 52.75d | 2018-06-07 | 2020-01-02 | 397d | 2018-06-07 | 2020-01-02 | 954d |  |  | 67% | 0% | ok | 0% | Linhares/ES (sede) | 39 | 67 | 45 | 87 | Socioambiental |  |
| 2051 | 8.1.2.2.1 | **Engenharia Captação Principal (Pequenas Melhorias) - Rio Pequeno - SE32283** |  | 258d | 2019-01-07 A | 2020-01-20 |  | 78% | 58.01d | 2019-03-26 | 2019-07-24 | 83d | 2019-03-26 | 2019-07-24 | 954d |  |  | 78% | 0% | ok | 0% | Linhares/ES (sede) | 33 | 78 | 40 | 82 | Socioambiental |  |
| 2052 | 8.1.2.2.1.1 | Aprovar Plano de Trabalho e abrir OSE - Captação Principal - Rio Pequeno - Linhares/ES |  | 27d | 2019-01-07 A | 2019-02-12 A | 2048FS+205d | 100% |  | 2019-03-26 | 2019-04-23 | 19d | 2019-03-26 | 2019-04-23 |  |  |  | 100% | 0% | Não OK | 0% | Linhares/ES (sede) | 100 | 100 | 100 | 100 | Socioambiental | Não OK |
| 2053 | 8.1.2.2.1.2 | Realizar Levantamento de Campo - Captação Principal - Rio Pequeno - Linhares/ES |  | 3d | 2019-03-19 A | 2019-03-21 A | 2052FS+21d | 100% |  | 2019-04-16 | 2019-04-23 | 4d | 2019-04-16 | 2019-04-23 |  |  |  | 100% | 0% | Não OK | 0% | Linhares/ES (sede) | 100 | 100 | 100 | 100 | Socioambiental |  |
| 2054 | 8.1.2.2.1.3 | Emitir RT/PQ para Infra - CGC - Captação Principal - Rio Pequeno - Linhares/ES |  | 10d | 2020-01-07 | 2020-01-20 | 2055FF |  |  | 2019-07-11 | 2019-07-24 | 10d | 2019-07-11 | 2019-07-24 | 468d | 0d |  | 0% |  |  |  |  |  |  |  |  |  |  |
| 2055 | 8.1.2.2.1.4 | Elaborar Projeto Executivo - Captação Principal - Rio Pequeno - Linhares/ES |  | 207d | 2019-03-22 A | 2020-01-20 | 2053 | 78% | 45.54d | 2019-04-23 | 2019-07-24 | 65d | 2019-04-23 | 2019-07-24 | 468d | 0d |  | 72% | 0% | Não OK | 0% | Linhares/ES (sede) | 30 | 72 | 42 | 72 | Socioambiental |  |
| 2056 | 8.1.2.2.1.5 | Elaboração do Projeto Executivo - Captação Principal - Rio Pequeno - Linhares/ES | milestone | 0d | 2020-01-20 | 2020-01-20 | 2055 |  |  | 2019-07-24 | 2019-07-24 | 0d | 2019-07-24 | 2019-07-24 | 954d | 238d |  | 0% |  |  |  |  |  |  |  |  |  |  |
| 2057 | 8.1.2.2.2 | **Engenharia Melhorias ETA** |  | 257d | 2019-01-08 A | 2020-01-20 |  | 81% | 47.86d | 2019-01-08 | 2019-07-24 | 135d | 2019-01-08 | 2019-07-24 | 954d |  |  | 86% | 0% | ok | 0% | Linhares/ES (sede) | 30 | 86 | 36 | 84 | Socioambiental |  |
| 2058 | 8.1.2.2.2.1 | Aprovar Plano de Trabalho e abrir OSE - Melhorias na ETA - Linhares/ES |  | 26d | 2019-01-08 A | 2019-02-12 A | 2048 | 100% |  | 2019-01-08 | 2019-02-12 | 26d | 2019-01-08 | 2019-02-12 |  |  |  | 100% | 0% | Não OK | 0% | Linhares/ES (sede) | 100 | 100 | 100 | 100 | Socioambiental | Não OK |
| 2059 | 8.1.2.2.2.2 | Realizar Levantamento de Campo - Melhorias na ETA - Linhares/ES |  | 3d | 2019-03-19 A | 2019-03-21 A | 2058 | 100% |  | 2019-03-19 | 2019-03-21 | 3d | 2019-03-19 | 2019-03-21 |  |  |  | 100% | 0% | Não OK | 0% | Linhares/ES (sede) | 100 | 100 | 100 | 100 | Socioambiental |  |
| 2060 | 8.1.2.2.2.3 | Elaborar arranjo para obtenção de Dados de Entrada Licenciamento e Fundiário - Melhorias na ETA - Linhares/ES |  | 30d | 2019-08-01 A | 2019-09-12 A | 2059FS+90d | 100% |  | 2019-04-30 | 2019-06-11 | 30d | 2019-04-30 | 2019-06-11 |  |  |  | 100% |  |  |  |  |  | 100 |  | 100 |  |  |
| 2061 | 8.1.2.2.2.4 | Emitir RT/PQ para Infra - CGC - Melhorias na ETA - Linhares/ES |  | 10d | 2020-01-07 | 2020-01-20 | 2062FF |  |  | 2019-07-11 | 2019-07-24 | 10d | 2019-07-11 | 2019-07-24 | 468d | 0d |  | 0% |  |  |  |  |  |  |  |  |  |  |
| 2062 | 8.1.2.2.2.5 | Elaborar Projeto Executivo - Melhorias na ETA - Linhares/ES |  | 207d | 2019-03-22 A | 2020-01-20 | 2059, 2060 | 80% | 41.4d | 2019-03-22 | 2019-07-24 | 88d | 2019-03-22 | 2019-07-24 | 468d | 0d |  | 78% | 0% | Não OK | 0% | Linhares/ES (sede) | 30 | 78 | 38 | 78 | Socioambiental |  |
| 2063 | 8.1.2.2.2.6 | Elaboração do Projeto Executivo - Melhorias na ETA - Linhares/ES | milestone | 0d | 2020-01-20 | 2020-01-20 | 2062 |  |  | 2019-07-24 | 2019-07-24 | 0d | 2019-07-24 | 2019-07-24 | 954d | 238d |  | 0% |  |  |  |  |  |  |  |  |  |  |
| 2064 | 8.1.2.3 | **Suprimentos** |  | 163d | 2019-10-01 A | 2020-05-29 |  | 10% | 147.46d | 2019-10-01 | 2020-03-23 | 117d | 2016-07-01 | 2021-04-16 | 866d |  | -0 | 63% | 0% | ok | 0% | Linhares/ES (sede) | 15 | 63 | 100 | 15 |  |  |
| 2065 | 8.1.2.3.1 | **Fornecimento de colmeias e leito filtrante para o SAAE - Linhares/ES** |  | 142d | 2019-10-01 A | 2020-04-29 |  | 16% | 119.08d | 2019-10-01 | 2020-03-23 | 117d | 2019-07-24 | 2019-11-26 | 887d |  | -0 | 0% | 0% | ok | 0% | Linhares/ES (sede) |  |  |  |  |  |  |
| 2066 | 8.1.2.3.1.1 | Aprovação da APRO para fornecimento de colmeia e leito filtrante para o SAAE - Linhares/ES |  | 82d | 2019-10-01 A | 2020-01-29 | 2027FS+8d | 25% | 61.5d | 2019-10-01 | 2020-01-29 | 82d | 2019-07-24 | 2019-11-26 | 887d | 0d |  | 0% | 0% | ok | 0% | Linhares/ES (sede) |  |  |  |  |  |  |
| 2067 | 8.1.2.3.1.2 | Emissão do pedido para compra de colmeias e leito filtrante para fornecimento ao SAAE - Linhares/ES |  | 15d | 2020-01-30 | 2020-02-19 | 2066 |  |  | 2020-01-30 | 2020-02-19 | 15d | 2019-07-24 | 2019-11-26 | 887d | 0d |  | 0% | 0% | ok | 0% | Linhares/ES (sede) |  |  |  |  |  |  |
| 2068 | 8.1.2.3.1.3 | Entrega de colmeias e leito filtrante para o SAAE - Linhares/ES |  | 30d | 2020-03-17 | 2020-04-29 | 2067FS+15d |  |  | 2020-02-20 | 2020-03-23 | 20d | 2019-07-24 | 2019-11-26 | 887d | 171d |  | 0% | 0% | ok | 0% | Linhares/ES (sede) |  |  |  |  |  |  |
| 2069 | 8.1.2.3.2 | Realizar processo de contratação das Melhorias na ETA e Adequação da Captação Principal - Linhares/ES |  | 88d | 2020-01-21 | 2020-05-29 | 2054, 2061 |  |  | 2020-02-20 | 2020-03-23 | 20d | 2019-07-24 | 2019-11-26 | 468d | 0d |  | 0% | 0% | ok | 0% | Linhares/ES (sede) |  |  |  |  |  |  |

Notes:
- 2049: 26/Nov: / - Anuência dada por meio de e-mail de validação da Ata de Reunião datada de 14/12/17.
- 2051: 25/Jan19: / - CR ENG considerando apenas o projeto no rio Pequeno. / 18/01/19 / - Serão desenvolvidos 2 projetos em paralelo, um considerando a captação principal no rio Pequeno e outro no Doce, em função da necessidade de descomissionamento do Barramento no rio Pequeno. Será considerada no cronograma a data mais conservadora. / 13/Dez / - Projeto não previsto no CR ENG (14/12/18). Verificar com a ENG.
- 2057: 25/Jan19: / - CR ENG considerando projeto de "Pequenas Melhorias na ETA".

| ID | WBS | Task | Type | Duration | Start | Finish | Predecessors | Complete | Remaining | Baseline start | Baseline finish | Baseline duration | Baseline 1 start | Baseline 1 finish | Total slack | Free slack | Baseline cost | Text3 | Text4 | Text5 | Text7 | Text15 | Text25 | Text26 | Text27 | Text29 | Indicadores MIR | Text23 | Text1 |
| --- | --- | --- | --- | --- | --- | --- | --- | --- | --- | --- | --- | --- | --- | --- | --- | --- | --- | --- | --- | --- | --- | --- | --- | --- | --- | --- | --- | --- | --- |
| 2070 | 8.1.2.4 | **Infraestrutura** |  | 542d | 2019-10-30 A | 2022-01-05 |  | 3% | 528.13d | 2016-07-01 | 2021-04-16 | 1220d | 2016-07-01 | 2021-04-16 | 466d |  | -0 | 63% | 15 | 63 | 100 | 15 | 0% | ok | 0% | Linhares/ES (sede) |  |  |  |
| 2071 | 8.1.2.4.1 | **Obras** |  | 292d | 2019-10-30 A | 2021-01-05 |  | 12% | 256.96d | 2016-07-01 | 2020-03-30 | 960d | 2016-07-01 | 2020-03-30 | 716d |  | -0 | 80% | 44 | 80 | 100 | 44 |  |  |  |  |  |  |  |
| 2072 | 8.1.2.4.1.1 | Executar adequação na Captação Principal - Manutenção nas 2 bombas de 50 cv do SAAE - Linhares/ES |  | 18d | 2019-11-20 A | 2019-12-16 A | 2027FS+43d | 100% |  | 2019-11-01 | 2019-12-10 | 27d |  |  |  |  |  |  |  |  |  |  |  |  |  |  |  |  |  |
| 2073 | 8.1.2.4.1.2 | Executar adequação na Captação Principal - Manutenção nas 6 bombas de 2 cv do SAAE - Linhares/ES |  | 17d | 2019-10-30 A | 2019-11-22 A | 2027FS+29d | 100% |  | 2019-11-01 | 2019-12-03 | 22d |  |  |  |  |  |  |  |  |  |  |  |  |  |  |  |  |  |
| 2074 | 8.1.2.4.1.3 | Executar adequação na Captação Principal - Barrilete e Sistema de Automação - Linhares/ES |  | 40d | 2019-11-19 A | 2020-01-17 | 2023, 2028FS+30d | 25% | 30d | 2019-11-26 | 2020-03-30 | 83d | 2019-11-26 | 2020-03-30 | 955d | 239d |  | 0% |  |  |  |  | 0% | ok | 0% | Linhares/ES (sede) | CA |  |  |
| 2075 | 8.1.2.4.1.4 | Executar Obras de melhoria na Captação Principal - Captação rio Pequeno - Linhares/ES |  | 150d | 2020-06-01 | 2021-01-05 | 2069 |  |  | 2019-11-26 | 2020-03-30 | 83d | 2019-11-26 | 2020-03-30 | 468d | 0d |  | 0% |  |  |  |  | 0% | ok | 0% | Linhares/ES (sede) |  |  |  |
| 2076 | 8.1.2.4.1.5 | Executar Melhorias na ETA - Linhares/ES |  | 150d | 2020-06-01 | 2021-01-05 | 2069 |  |  | 2019-10-07 | 2020-03-30 | 118d | 2019-10-07 | 2020-03-30 | 468d | 0d |  | 0% |  |  |  |  | 0% | ok | 0% | Linhares/ES (sede) | ETA |  |  |
| 2077 | 8.1.2.4.1.6 | Conclusão das obras de adequação na Captação Principal e Melhoria de ETA - Linhares/ES | milestone | 0d | 2021-01-05 | 2021-01-05 | 2074, 2036, 2073, 2072, 2037, 2076, 2075 |  |  | 2020-05-04 | 2020-05-04 | 0d |  |  | 716d | 0d |  |  |  |  |  |  |  |  |  |  |  |  |  |
| 2078 | 8.1.2.4.1.7 | Assinatura de Termo de Entrega das Obras de Melhoria do Sistema de Abastecimento de Água - Linhares/ES | milestone | 0d | 2021-01-05 | 2021-01-05 | 2056, 2063, 2069, 2077, 2068 |  |  | 2020-03-30 | 2020-03-30 | 0d | 2020-03-30 | 2020-03-30 | 716d | 468d |  | 0% |  |  |  |  | 0% | ok | 0% | Linhares/ES (sede) |  |  |  |
| 2079 | 8.1.2.4.2 | **Operação** |  | 250d | 2021-01-05 | 2022-01-05 |  |  |  | 2020-03-31 | 2021-04-16 | 260d | 2020-03-31 | 2021-04-16 | 466d |  |  | 0% |  |  |  |  | 0% | ok | 0% | Linhares/ES (sede) |  |  |  |
| 2080 | 8.1.2.4.2.1 | Realizar Treinamento Operacional do Sistema - Linhares/ES |  | 5d | 2021-01-06 | 2021-01-12 | 2075, 2076 |  |  | 2020-03-31 | 2020-04-06 | 5d | 2020-03-31 | 2020-04-06 | 697d | 0d |  | 0% |  |  |  |  | 0% | ok | 0% | Linhares/ES (sede) |  |  |  |
| 2081 | 8.1.2.4.2.2 | Realizar Testes e Pré-operação (Para as adequações da ETA) - Linhares/ES |  | 14d | 2021-01-13 | 2021-02-01 | 2080 |  |  | 2020-04-07 | 2020-04-28 | 14d | 2020-04-07 | 2020-04-28 | 697d |  |  | 0% |  |  |  |  | 0% | ok | 0% | Linhares/ES (sede) |  |  |  |
| 2082 | 8.1.2.4.2.3 | Realizar Acompanhamento da Funcionalidade do Sistema - Melhorias em ETA e Captação Principal - Linhares/ES (sede) |  | 365ed | 2021-01-05 | 2022-01-05 | 2084SS |  |  | 2020-03-31 | 2021-04-16 | 260d |  |  | 2058d |  |  |  |  |  |  |  |  |  |  |  |  |  |  |
| 2083 | 8.1.2.4.2.4 | **Operação Assistida** |  | 60d | 2021-01-05 | 2021-04-05 |  |  |  | 2020-03-31 | 2020-07-02 | 64d | 2020-03-31 | 2020-07-02 | 468d |  |  | 0% |  |  |  |  | 0% | ok | 0% | Linhares/ES (sede) |  |  |  |
| 2084 | 8.1.2.4.2.4.1 | Realizar Operação Assistida - Linhares/ES |  | 90ed | 2021-01-05 | 2021-04-05 | 2075, 2076 |  |  | 2020-03-31 | 2020-07-02 | 3.2mo | 2020-03-31 | 2020-07-02 | 2058d | 0d |  | 0% |  |  |  |  | 0% | ok | 0% | Linhares/ES (sede) |  |  |  |
| 2085 | 8.1.3 | **UTR** |  | 1199d | 2017-12-22 A | 2022-09-29 |  | 8% | 1107.15d | 2016-12-02 | 2021-04-16 | 1110d |  |  | 283d |  |  |  |  |  |  |  |  |  |  |  |  |  |  |
| 2086 | 8.1.3.1 | **Estudos de Concepção do Sistema** |  | 65d | 2017-12-22 A | 2018-03-23 A |  | 100% |  | 2016-12-02 | 2019-04-26 | 620d | 2016-12-02 | 2019-04-26 |  |  |  | 100% | 99 | 100 | 99 | 100 | 0% | ok | 0% | Linhares/ES (sede) |  |  |  |
| 2087 | 8.1.3.1.1 | Declaração de Escopo e Premissas de Projeto (DEPP) concluída - Linhares/ES | milestone | 0d | 2018-03-23 A | 2018-03-23 A | 25, 26 | 100% |  | 2018-03-23 | 2018-03-23 | 0d | 2018-03-23 | 2018-03-23 |  |  |  | 100% | 100 | 100 | 100 | 100 | 0% | ok | 0% | Linhares/ES (sede) |  |  |  |
| 2088 | 8.1.3.1.2 | Aprovação das DEPPs pela Operadora e Prefeitura - Linhares/ES | milestone | 0d | 2017-12-22 A | 2017-12-22 A | 25, 26 | 100% |  | 2017-12-22 | 2017-12-22 | 0d | 2017-12-22 | 2017-12-22 |  |  |  | 100% | 100 | 100 | 100 | 100 | 0% | ok | 0% | Linhares/ES (sede) |  |  |  |
| 2089 | 8.1.3.2 | **Engenharia Básica e Detalhada** |  | 530d | 2018-06-07 A | 2020-07-16 |  | 50% | 264.29d | 2018-06-07 | 2020-01-02 | 397d | 2018-06-07 | 2020-01-02 | 833d |  |  | 67% | 39 | 67 | 45 | 87 | 0% | ok | 0% | Linhares/ES (sede) |  | Socioambiental |  |
| 2090 | 8.1.3.2.1 | **Engenharia UTR** |  | 530d | 2018-06-07 A | 2020-07-16 |  | 50% | 264.29d | 2018-06-07 | 2019-06-04 | 252d | 2018-06-07 | 2019-06-04 | 833d |  |  | 100% | 51 | 100 | 51 | 100 | 0% | ok | 0% | Linhares/ES (sede) |  |  |  |
| 2091 | 8.1.3.2.1.1 | Aprovação Plano de Trabalho /abertura OSE - UTR - Linhares/ES |  | 42d | 2018-11-05 A | 2019-01-02 A | 2087 | 100% |  | 2018-11-05 | 2019-01-02 | 42d | 2018-11-05 | 2019-01-02 |  |  |  | 100% | 100 | 100 | 100 | 100 | 0% | ok | 0% | Linhares/ES (sede) |  |  |  |
| 2092 | 8.1.3.2.1.2 | Realizar Levantamento de Campo - UTR - Linhares/ES |  | 3d | 2019-03-19 A | 2019-03-21 A | 2091 | 100% |  | 2019-03-19 | 2019-03-21 | 3d | 2019-03-19 | 2019-03-21 |  |  |  | 100% | 100 | 100 | 100 | 100 | 0% | ok | 0% | Linhares/ES (sede) |  |  |  |
| 2093 | 8.1.3.2.1.3 | Realizar Sondagem - UTR - Linhares/ES |  | 4d | 2020-01-07 | 2020-01-10 | 2091FS+250d |  |  | 2019-02-15 | 2019-03-21 | 22d | 2019-02-15 | 2019-03-21 | 347d | 63d |  | 100% |  | 100 |  | 100 |  |  |  |  |  |  |  |
| 2094 | 8.1.3.2.1.4 | Executar Topografia - UTR - Linhares/ES |  | 97d | 2018-06-07 A | 2018-10-19 A | 2088 | 100% |  | 2018-06-07 | 2018-10-19 | 97d | 2018-06-07 | 2018-10-19 |  |  |  | 100% | 100 | 100 | 100 | 100 |  |  |  |  |  |  |  |
| 2095 | 8.1.3.2.1.5 | Elaborar Projeto Conceitual (Prof. Marcos Vianna) - UTR - Linhares/ES |  | 22d | 2019-09-13 A | 2019-10-14 A | 2092FS+120d, 2094 | 100% |  | 2019-09-13 | 2019-10-14 | 22d |  |  |  |  |  |  |  |  |  |  |  |  |  |  |  |  | 8888 |
| 2096 | 8.1.3.2.1.6 | Elaborar arranjo para obtenção de Dados de Entrada Licenciamento e Fundiário - UTR - Linhares/ES |  | 88d | 2019-09-27 A | 2020-02-04 | 2092, 2094, 2095SS+10d | 25% | 66d | 2019-02-12 | 2019-03-21 | 25d | 2019-02-12 | 2019-03-21 | 284d | 0d |  | 100% |  | 100 |  | 100 | 0% | ok | 0% | Linhares/ES (sede) |  |  |  |
| 2097 | 8.1.3.2.1.7 | Elaborar Projeto Básico - UTR - Linhares/ES |  | 46d | 2020-02-05 | 2020-04-14 | 2096, 2093FF |  |  | 2018-02-08 | 2018-03-21 | 30d | 2018-02-08 | 2018-03-21 | 284d | 0d |  | 100% |  | 100 |  | 100 |  |  |  |  |  |  |  |
| 2098 | 8.1.3.2.1.8 | Emitir RT/PQ para Suprimentos - UTR - Linhares/ES |  | 5d | 2020-04-15 | 2020-04-22 | 2097 |  |  | 2019-03-15 | 2019-03-28 | 10d | 2019-03-15 | 2019-03-28 | 284d | 0d |  | 100% |  | 100 |  | 100 | 0% | ok | 0% | Linhares/ES (sede) |  |  |  |
| 2099 | 8.1.3.2.1.9 | Elaborar Projeto Executivo - UTR - Linhares/ES |  | 64d | 2020-04-15 | 2020-07-16 | 2097 |  |  | 2019-03-21 | 2019-06-04 | 51d | 2019-03-21 | 2019-06-04 | 335d | 0d |  | 100% |  | 100 |  | 100 | 0% | ok | 0% | Linhares/ES (sede) |  |  |  |
| 2100 | 8.1.3.2.1.10 | Elaboração do Projeto Executivo - UTR - Linhares/ES | milestone | 0d | 2020-07-16 | 2020-07-16 | 2099 |  |  | 2019-06-04 | 2019-06-04 | 0d | 2019-06-04 | 2019-06-04 | 833d | 301d |  | 100% |  | 100 |  | 100 |  |  |  |  |  |  |  |

Notes:
- 2076: 07/11/19: AUmento da duração para considerar a drenagem da UTR
- 2088: 26/Nov: / - Anuência dada por meio de e-mail de validação da Ata de Reunião datada de 14/12/17.
- 2092: 25/Jan19: / - Levantamento de campo previsto para iniciar em 01/02 e finalizar em 07/02/19; Sondagem prevista para iniciar em 08/02 e finalizar em 14/03/19.

| ID | WBS | Task | Type | Duration | Start | Finish | Predecessors | Complete | Remaining | Baseline start | Baseline finish | Baseline duration | Baseline 1 start | Baseline 1 finish | Total slack | Free slack | Baseline cost | Text1 | Text3 | Text5 | Text15 | Text25 | Text26 | Text27 | Text29 | Text4 | Text7 | Text23 |
| --- | --- | --- | --- | --- | --- | --- | --- | --- | --- | --- | --- | --- | --- | --- | --- | --- | --- | --- | --- | --- | --- | --- | --- | --- | --- | --- | --- | --- |
| 2101 | 8.1.3.3 | **Fundiária** |  | 160d | 2020-02-05 | 2020-09-25 |  |  |  | 2019-11-20 | 2020-08-17 | 183d |  |  | 285d |  |  | 8888 |  |  |  |  |  |  |  |  |  |  |
| 2102 | 8.1.3.3.1 | Realizar regularização fundiária - UTR - Linhares/ES |  | 160d | 2020-02-05 | 2020-09-25 | 2096 |  |  | 2019-11-20 | 2020-08-17 | 183d |  |  | 285d | 0d |  | 8888 |  |  |  |  |  |  |  |  |  |  |
| 2103 | 8.1.3.3.2 | Conclusão da Regularização Fundiária - UTR - Linhares/ES | milestone | 0d | 2020-09-25 | 2020-09-25 | 2102 |  |  | 2020-08-17 | 2020-08-17 | 0d |  |  | 285d | 1d |  | 8888 |  |  |  |  |  |  |  |  |  |  |
| 2104 | 8.1.3.4 | **Licenciamento** |  | 153d | 2020-02-05 | 2020-09-16 |  |  |  | 2019-11-20 | 2020-08-06 | 176d |  |  | 292d |  |  | 8888 |  |  |  |  |  |  |  |  |  |  |
| 2105 | 8.1.3.4.1 | Obter DAIA para construção de UTR - Linhares/ES |  | 153d | 2020-02-05 | 2020-09-16 | 2096 |  |  | 2019-11-20 | 2020-08-06 | 176d |  |  | 292d | 0d |  | 8888 |  |  |  |  |  |  |  |  |  |  |
| 2106 | 8.1.3.4.2 | Conclusão do Licenciamento Ambiental - UTR - Linhares/ES | milestone | 0d | 2020-09-16 | 2020-09-16 | 2105 |  |  | 2020-08-06 | 2020-08-06 | 0d |  |  | 292d | 8d |  | 8888 |  |  |  |  |  |  |  |  |  |  |
| 2107 | 8.1.3.5 | **Suprimentos** |  | 110d | 2020-04-23 | 2020-09-28 |  |  |  | 2019-06-04 | 2019-11-26 | 123d | 2019-06-04 | 2019-11-26 | 284d |  |  |  | 14% | 14 | 10 | 0% | ok | 0% | Linhares/ES (sede) |  |  |  |
| 2108 | 8.1.3.5.1 | Processo contratação UTR - Linhares/ES |  | 110d | 2020-04-23 | 2020-09-28 | 2098 |  |  | 2019-06-04 | 2019-10-07 | 88d | 2019-06-04 | 2019-10-07 | 284d | 0d |  |  | 20% | 20 | 20 | 0% | ok | 0% | Linhares/ES (sede) |  |  |  |
| 2109 | 8.1.3.5.2 | Conclusão da Contratação de Suprimentos das obras de Melhoria do Sistema de Abastecimento de Água - Linhares/ES | milestone | 0d | 2020-09-28 | 2020-09-28 | 2108 |  |  | 2019-11-26 | 2019-11-26 | 0d | 2019-11-26 | 2019-11-26 | 782d | 250d |  |  | 0% |  |  |  |  |  |  |  |  |  |
| 2110 | 8.1.3.6 | **Infraestrutura** |  | 499d | 2020-09-29 | 2022-09-29 |  |  |  | 2016-07-01 | 2021-04-16 | 1220d | 2016-07-01 | 2021-04-16 | 283d |  | -0 |  | 63% | 63 | 15 | 0% | ok | 0% | Linhares/ES (sede) | 15 | 100 |  |
| 2111 | 8.1.3.6.1 | **Obras** |  | 250d | 2020-09-29 | 2021-09-29 |  |  |  | 2016-07-01 | 2020-03-30 | 960d | 2016-07-01 | 2020-03-30 | 284d |  | -0 |  | 80% | 80 | 44 |  |  |  |  | 44 | 100 |  |
| 2112 | 8.1.3.6.1.1 | Executar UTR - Linhares/ES |  | 250d | 2020-09-29 | 2021-09-29 | 2099, 2108, 2103, 2106 |  |  | 2019-10-07 | 2020-03-30 | 118d | 2019-10-07 | 2020-03-30 | 284d | 0d |  |  | 0% |  |  | 0% | ok | 0% | Linhares/ES (sede) |  |  |  |
| 2113 | 8.1.3.6.1.2 | Assinatura de Termo de Entrega das Obras de Melhoria do Sistema de Abastecimento de Água - Linhares/ES | milestone | 0d | 2021-09-29 | 2021-09-29 | 2112, 2100, 2109 |  |  | 2020-03-30 | 2020-03-30 | 0d | 2020-03-30 | 2020-03-30 | 532d | 284d |  |  | 0% |  |  | 0% | ok | 0% | Linhares/ES (sede) |  |  |  |
| 2114 | 8.1.3.6.2 | **Operação** |  | 249d | 2021-09-29 | 2022-09-29 |  |  |  | 2020-03-31 | 2021-04-16 | 260d | 2020-03-31 | 2021-04-16 | 283d |  |  |  | 0% |  |  | 0% | ok | 0% | Linhares/ES (sede) |  |  |  |
| 2115 | 8.1.3.6.2.1 | Realizar Treinamento Operacional do Sistema - Linhares/ES |  | 5d | 2021-09-30 | 2021-10-06 | 2112 |  |  | 2020-03-31 | 2020-04-06 | 5d | 2020-03-31 | 2020-04-06 | 513d | 0d |  |  | 0% |  |  | 0% | ok | 0% | Linhares/ES (sede) |  |  |  |
| 2116 | 8.1.3.6.2.2 | Realizar Testes e Pré-operação (Para as adequações da ETA) - Linhares/ES |  | 14d | 2021-10-07 | 2021-10-27 | 2115 |  |  | 2020-04-07 | 2020-04-28 | 14d | 2020-04-07 | 2020-04-28 | 513d |  |  |  | 0% |  |  | 0% | ok | 0% | Linhares/ES (sede) |  |  |  |
| 2117 | 8.1.3.6.2.3 | Realizar Acompanhamento da Funcionalidade do Sistema - UTR - Linhares/ES (sede) |  | 365ed | 2021-09-29 | 2022-09-29 | 2119SS |  |  | 2020-03-31 | 2021-04-16 | 260d |  |  | 1257d |  |  |  |  |  |  |  |  |  |  |  |  |  |
| 2118 | 8.1.3.6.2.4 | **Operação Assistida** |  | 60d | 2021-09-29 | 2021-12-28 |  |  |  | 2020-03-31 | 2020-07-02 | 64d | 2020-03-31 | 2020-07-02 | 284d |  |  |  | 0% |  |  | 0% | ok | 0% | Linhares/ES (sede) |  |  |  |
| 2119 | 8.1.3.6.2.4.1 | Realizar Operação Assistida - Linhares/ES |  | 90ed | 2021-09-29 | 2021-12-28 | 2112 |  |  | 2020-03-31 | 2020-07-02 | 3.2mo | 2020-03-31 | 2020-07-02 | 1257d | 0d |  |  | 0% |  |  | 0% | ok | 0% | Linhares/ES (sede) |  |  |  |
| 2120 | 8.2 | **Regência (distrito Linhares/ES)** |  | 1103d | 2018-03-23 A | 2022-08-16 |  | 5% | 1042.61d | 2017-06-30 | 2021-08-30 | 1054d | 2017-06-30 | 2021-08-30 | 314d |  | -0 |  | 48% | 48 | 30 | 0% | ok | 0% | Regência (distrito Linhares/ES) | 25 | 83 | Socioambiental |
| 2121 | 8.2.1 | **Captação Alternativa** |  | 707d | 2018-03-23 A | 2021-01-13 |  | 45% | 387.87d | 2018-03-23 | 2021-01-13 | 707d |  |  | 710d |  |  |  |  |  |  |  |  |  |  |  |  |  |
| 2122 | 8.2.1.1 | **Estudos de Concepção do Sistema** |  | 222d | 2018-03-23 A | 2019-01-29 A |  | 100% |  | 2018-03-23 | 2019-07-05 | 328d | 2018-03-23 | 2019-07-05 |  |  |  |  | 98% | 98 | 97 | 0% | ok | 0% | Regência (distrito Linhares/ES) | 100 | 103 | Socioambiental |
| 2123 | 8.2.1.1.1 | Declaração de Escopo e Premissas de Projeto (DEPP) concluída - Regência/ES | milestone | 0d | 2018-03-23 A | 2018-03-23 A | 25, 26 | 100% |  | 2018-03-23 | 2018-03-23 | 0d | 2018-03-23 | 2018-03-23 |  |  |  |  | 100% | 100 | 100 | 0% | ok | 0% | Regência (distrito Linhares/ES) | 100 | 100 |  |
| 2124 | 8.2.1.1.2 | **Estudos de Geofísica para Poço Tubular** |  | 16d | 2018-10-01 A | 2018-10-22 A |  | 100% |  | 2018-10-01 | 2018-10-22 | 16d | 2018-10-01 | 2018-10-22 |  |  |  |  | 100% | 100 | 100 | 0% | ok | 0% | Regência (distrito Linhares/ES) | 100 | 100 |  |
| 2125 | 8.2.1.1.2.1 | Executar Levantamento de Campo - Regência/ES |  | 2d | 2018-10-01 A | 2018-10-02 A | 2123 | 100% |  | 2018-10-01 | 2018-10-02 | 2d | 2018-10-01 | 2018-10-02 |  |  |  |  | 100% | 100 | 100 | 0% | ok | 0% | Regência (distrito Linhares/ES) | 100 | 100 |  |
| 2126 | 8.2.1.1.2.2 | Emitir Relatório - Regência/ES |  | 14d | 2018-10-03 A | 2018-10-22 A | 2125 | 100% |  | 2018-10-03 | 2018-10-22 | 14d | 2018-10-03 | 2018-10-22 |  |  |  |  | 100% | 100 | 100 | 0% | ok | 0% | Regência (distrito Linhares/ES) | 100 | 100 |  |
| 2127 | 8.2.1.1.2.3 | Conclusão dos Estudos de Geofísica para Poço Tubular - Regência/ES | milestone | 0d | 2018-10-22 A | 2018-10-22 A | 2126 | 100% |  | 2018-10-22 | 2018-10-22 | 0d | 2018-10-22 | 2018-10-22 |  |  |  |  | 100% | 100 | 100 |  |  |  |  | 100 | 100 |  |

| ID | WBS | Task | Type | Duration | Start | Finish | Predecessors | Complete | Remaining | Baseline start | Baseline finish | Baseline duration | Baseline 1 start | Baseline 1 finish | Total slack | Free slack | Text3 | Text4 | Text5 | Text7 | Text15 | Text23 | Text25 | Text26 | Text27 | Text29 | Text28 | Indicadores MIR | Text9 |
| --- | --- | --- | --- | --- | --- | --- | --- | --- | --- | --- | --- | --- | --- | --- | --- | --- | --- | --- | --- | --- | --- | --- | --- | --- | --- | --- | --- | --- | --- |
| 2128 | 8.2.1.1.3 | **Serviços em Poços Tubulares - Poço Existente Interligado** |  | 27d | 2018-05-10 A | 2018-06-15 A |  | 100% |  | 2018-05-10 | 2019-07-05 | 294d | 2018-05-10 | 2019-07-05 |  |  | 98% | 100 | 98 | 123 | 81 | Socioambiental | 0% | ok | 0% | Regência (distrito Linhares/ES) |  |  |  |
| 2129 | 8.2.1.1.3.1 | Realizar Perfilagem (Poço existente interligado) - Regência/ES |  | 2d | 2018-05-10 A | 2018-05-11 A | 2123 | 100% |  | 2018-05-10 | 2018-05-11 | 2d | 2018-05-10 | 2018-05-11 |  |  | 100% | 100 | 100 | 100 | 100 |  | 0% | ok | 0% | Regência (distrito Linhares/ES) |  |  |  |
| 2130 | 8.2.1.1.3.2 | Realizar Recuperação (Poço existente interligado) - Regência/ES |  | 5d | 2018-05-14 A | 2018-05-18 A | 2129 | 100% |  | 2019-05-31 | 2019-06-06 | 5d | 2019-05-31 | 2019-06-06 |  |  | 100% | 100 | 100 | 100 | 100 | Socioambiental | 0% | Não OK | 0% | Regência (distrito Linhares/ES) |  |  |  |
| 2131 | 8.2.1.1.3.3 | Elaborar Relatório Técnico (poço existente interligado) - Regência/ES |  | 20d | 2018-05-21 A | 2018-06-15 A | 2130 | 100% |  | 2019-06-07 | 2019-07-05 | 20d | 2019-06-07 | 2019-07-05 |  |  | 75% | 100 | 75 | 133 | 75 | Socioambiental | 0% | Não OK | 0% | Regência (distrito Linhares/ES) | Não OK |  |  |
| 2132 | 8.2.1.1.3.4 | Conclusão dos Serviços em poço tubular - Regência/ES | milestone | 0d | 2018-06-15 A | 2018-06-15 A | 2131 | 100% |  | 2019-07-05 | 2019-07-05 | 0d | 2019-07-05 | 2019-07-05 |  |  | 0% | 100 |  |  |  |  |  |  |  |  |  |  |  |
| 2133 | 8.2.1.1.4 | Conclusão dos Estudos de Concepção das Melhorias do Sistema de Abastecimento de Água - Regência/ES | milestone | 0d | 2019-01-29 A | 2019-01-29 A | 2127, 2132 | 100% |  | 2019-07-01 | 2019-07-01 | 0d | 2019-07-01 | 2019-07-01 |  |  | 0% | 100 |  |  |  |  |  |  |  |  |  |  |  |
| 2134 | 8.2.1.2 | **Engenharia Básica e Detalhada** |  | 20d | 2018-12-17 A | 2019-01-14 A |  | 100% |  | 2017-11-20 | 2019-10-23 | 494d | 2017-11-20 | 2019-10-23 |  |  | 83% | 46 | 83 | 60 | 77 | Socioambiental | 0% | ok | 0% | Regência (distrito Linhares/ES) |  |  |  |
| 2135 | 8.2.1.2.1 | **Engenharia Captação Alternativa (Poço interligado a ETA)** |  | 20d | 2018-12-17 A | 2019-01-14 A |  | 100% |  | 2018-12-17 | 2019-01-14 | 20d | 2018-12-17 | 2019-01-14 |  |  | 100% | 100 | 100 | 100 | 100 |  | 0% | ok | 0% | Regência (distrito Linhares/ES) |  |  |  |
| 2136 | 8.2.1.2.1.1 | Aprovação Plano de Trabalho /abertura OSE - Captação Alternativa - Poço Existente - Regência/ES |  | 16d | 2018-12-17 A | 2019-01-08 A | 2123 | 100% |  | 2018-12-17 | 2019-01-08 | 16d | 2018-12-17 | 2019-01-08 |  |  | 100% | 100 | 100 | 100 | 100 |  | 0% | ok | 0% | Regência (distrito Linhares/ES) |  |  |  |
| 2137 | 8.2.1.2.1.2 | Dados de Entrada (levantamento de campo, topografia e recebimento das informações do poço: perfil, vazão, análise água) - Captação Alternativa - Poço Existente - Regência/ES |  | 5d | 2019-01-08 A | 2019-01-14 A | 2136 | 100% |  | 2019-01-08 | 2019-01-14 | 5d | 2019-01-08 | 2019-01-14 |  |  | 100% | 100 | 100 | 100 | 100 |  | 0% | ok | 0% | Regência (distrito Linhares/ES) |  |  |  |
| 2138 | 8.2.1.2.1.3 | Elaborar Projeto Executivo - Captação Alternativa - Poço Existente - Regência/ES |  | 1d | 2019-01-14 A | 2019-01-14 A | 2131, 2132, 2137FF | 100% |  | 2019-01-14 | 2019-01-14 | 1d | 2019-01-14 | 2019-01-14 |  |  | 100% | 100 | 100 | 100 | 100 |  | 0% | ok | 0% | Regência (distrito Linhares/ES) |  |  |  |
| 2139 | 8.2.1.2.1.4 | Elaboração do Projeto Executivo - Captação Alternativa - Poço Existente - Regência/ES | milestone | 0d | 2019-01-14 A | 2019-01-14 A | 2138 | 100% |  | 2019-01-14 | 2019-01-14 | 0d | 2019-01-14 | 2019-01-14 |  |  | 100% | 100 | 100 | 100 | 100 |  |  |  |  |  |  |  |  |
| 2140 | 8.2.1.3 | **Infraestrutura** |  | 79d | 2020-09-18 | 2021-01-13 |  |  |  | 2017-08-01 | 2021-08-30 | 1032d | 2017-08-01 | 2021-08-30 | 710d |  | 47% |  | 47 | 24 | 25 |  | 0% | ok | 0% | Regência (distrito Linhares/ES) |  |  |  |
| 2141 | 8.2.1.3.1 | **Obras** |  | 79d | 2020-09-18 | 2021-01-13 |  |  |  | 2017-08-01 | 2020-08-13 | 772d | 2017-08-01 | 2020-08-13 | 710d |  | 63% | 31 | 63 | 124 | 25 |  |  |  |  |  |  |  |  |
| 2142 | 8.2.1.3.1.1 | Executar Captação Alternativa - Urbanização Poço existente - Regência/ES |  | 79d | 2020-09-18 | 2021-01-13 | 2138, 2139FS+417d |  |  | 2020-02-04 | 2020-06-01 | 79d | 2020-02-04 | 2020-06-01 | 710d | 0d | 0% |  |  |  |  |  | 0% | ok | 0% | Regência (distrito Linhares/ES) |  | CA |  |
| 2143 | 8.2.1.3.1.2 | Assinatura de Termo de Entrega das Obras de Melhoria do Sistema de Abastecimento de Água - Regência/ES | milestone | 0d | 2021-01-13 | 2021-01-13 | 2142 |  |  | 2020-08-13 | 2020-08-13 | 0d | 2020-08-13 | 2020-08-13 | 710d | 462d | 0% |  |  |  |  |  | 0% | ok | 0% | Regência (distrito Linhares/ES) |  |  |  |
| 2144 | 8.2.2 | **Captação Principal (rio Doce) e adequações na ETA/UTR** |  | 789d | 2019-06-14 A | 2022-08-16 |  | 3% | 766.16d | 2017-11-20 | 2021-08-30 | 953d |  |  | 314d |  |  |  |  |  |  |  |  |  |  |  |  |  |  |
| 2145 | 8.2.2.1 | **Engenharia** |  | 216d | 2019-06-14 A | 2020-04-29 |  | 18% | 176.55d | 2017-11-20 | 2019-10-23 | 494d | 2017-11-20 | 2019-10-23 | 887d |  | 83% | 64 | 83 | 76 | 84 | Socioambiental |  | ok |  |  |  |  |  |
| 2146 | 8.2.2.1.1 | **Estudos de Concepção do Sistema** |  | 0d | 2019-06-14 A | 2019-06-14 A |  | 100% |  | 2018-03-23 | 2019-07-05 | 328d | 2018-03-23 | 2019-07-05 |  |  | 98% | 100 | 98 | 103 | 97 | Socioambiental | 0% | ok | 0% | Regência (distrito Linhares/ES) |  |  |  |
| 2147 | 8.2.2.1.1.1 | Aprovação da Revisão de Definição pela Operadora e Prefeitura - Regência/ES | milestone | 0d | 2019-06-14 A | 2019-06-14 A |  | 100% |  | 2019-05-30 | 2019-05-30 | 0d | 2019-05-30 | 2019-05-30 |  |  | 100% | 100 | 100 | 100 | 100 |  | 0% | ok | 0% | Regência (distrito Linhares/ES) |  |  |  |
| 2148 | 8.2.2.1.2 | **Engenharia Básica e Detalhada** |  | 141d | 2019-10-02 A | 2020-04-29 |  | 18% | 115.25d | 2017-11-20 | 2019-10-23 | 494d | 2017-11-20 | 2019-10-23 | 887d |  | 83% | 46 | 83 | 60 | 77 | Socioambiental | 0% | ok | 0% | Regência (distrito Linhares/ES) |  |  |  |
| 2149 | 8.2.2.1.2.1 | **Engenharia Captação Principal (rio Doce) e adequação da ETA - SE 32029** |  | 141d | 2019-10-02 A | 2020-04-29 |  | 18% | 115.25d | 2017-11-20 | 2019-08-05 | 438d | 2017-11-20 | 2019-08-05 | 887d |  | 94% | 66 | 94 | 72 | 92 | Socioambiental | 0% | ok | 0% | Regência (distrito Linhares/ES) |  |  |  |
| 2150 | 8.2.2.1.2.1.1 | Aprovação Plano de Trabalho /abertura OSE + Levantamento de Campo - Captação Principal - Rio Doce - Regência/ES |  | 70d | 2019-10-02 A | 2020-01-14 | 26FS+478d | 25% | 52.5d | 2017-11-20 | 2018-10-02 | 227d | 2017-11-20 | 2018-10-02 | 958d | 0d | 100% | 100 | 100 | 100 | 100 | Socioambiental | 0% | Não OK | 0% | Regência (distrito Linhares/ES) |  |  | Não OK |
| 2151 | 8.2.2.1.2.1.2 | Executar Topografia - Captação Principal - Rio Doce - Regência/ES |  | 69d | 2019-10-02 A | 2020-01-13 | 2150SS | 35% | 44.85d | 2018-07-27 | 2018-11-06 | 73d | 2018-07-27 | 2018-11-06 | 358d | 0d | 100% | 100 | 100 | 100 | 100 | Socioambiental | 0% | Não OK | 0% | Regência (distrito Linhares/ES) |  |  | Não OK |
| 2152 | 8.2.2.1.2.1.3 | Realizar Sondagem - Captação Principal - Rio Doce - Regência/ES |  | 69d | 2019-10-02 A | 2020-01-13 | 2151SS | 25% | 51.75d | 2018-11-06 | 2018-12-06 | 23d |  |  | 959d | 0d | 100% |  | 100 |  |  |  |  |  |  |  |  |  |  |
| 2153 | 8.2.2.1.2.1.4 | Elaborar arranjo para obtenção de Dados de Entrada Licenciamento e Fundiário - Captação Principal - Rio Doce - Regência/ES |  | 61d | 2019-10-14 A | 2020-01-13 | 2152SS+8d | 25% | 45.75d | 2019-05-03 | 2019-06-13 | 30d | 2019-05-03 | 2019-06-13 | 315d | 0d | 100% |  | 100 |  | 100 |  |  |  |  |  |  |  |  |
| 2154 | 8.2.2.1.2.1.5 | Elaborar Projeto Básico - Captação Principal - Rio Doce - Regência/ES |  | 50d | 2020-01-14 | 2020-03-26 | 2147, 2151, 2153 |  |  | 2018-02-08 | 2018-03-21 | 30d | 2018-02-08 | 2018-03-21 | 358d | 0d | 100% |  | 100 |  | 100 |  |  |  |  |  |  |  |  |
| 2155 | 8.2.2.1.2.1.6 | Obter aprovação do Projeto Básico Regência/ES |  | 22d | 2020-03-27 | 2020-04-29 | 2154 |  |  | 2020-04-09 | 2020-05-13 | 22d |  |  | 868d | 0d |  |  |  |  |  |  |  |  |  |  |  |  |  |
| 2156 | 8.2.2.1.2.1.7 | Emitir RT/PQ para Suprimentos - Captação Principal - Rio Doce - Regência/ES |  | 15d | 2020-02-28 | 2020-03-19 | 2157FF-25d |  |  | 2019-07-23 | 2019-08-05 | 10d | 2019-07-23 | 2019-08-05 | 358d | 0d | 0% |  |  |  |  | Socioambiental | 0% | Não OK | 0% | Regência (distrito Linhares/ES) |  |  |  |
| 2157 | 8.2.2.1.2.1.8 | Elaborar Projeto Executivo - Captação Principal - Rio Doce - Regência/ES |  | 50d | 2020-02-11 | 2020-04-27 | 2154FS-30d |  |  | 2019-05-03 | 2019-08-05 | 66d | 2019-05-03 | 2019-08-05 | 358d | 0d | 60% |  | 60 |  | 60 | Socioambiental | 0% | Não OK | 0% | Regência (distrito Linhares/ES) |  |  | Não OK |
| 2158 | 8.2.2.1.2.1.9 | Elaboração do Projeto Executivo - Captação Principal - Rio Doce - Regência/ES | milestone | 0d | 2020-04-29 | 2020-04-29 | 2157, 2155 |  |  | 2019-08-05 | 2019-08-05 | 0d | 2019-08-05 | 2019-08-05 | 868d | 324d | 0% |  |  |  |  |  |  |  |  |  |  |  |  |

Notes:
- 2130: 20/Dez / - Incluir no cronograma da HIDROPOÇOS.
- 2131: 15/Fev19: / - Essa atividade está sem Sucessora - deveria ser o Projeto Executivo da Captação Alternativa do Poço existente interligado - porém não consta no Crongorama da Engenharia a previsão para elaboração desse projeto. (Ver e-mail enviado em 03/02/19 "Considerações Relevantes: Cronograma Engenharia X Cronograma Master PG 32").
- 2134: 20/Dez / - Nova ETA construída e formalmente entregue ao SAAE Linhares em Mar/18. / - Não há definição da captação alternativa pois a mesma depende da retomada do rio Doce nesta localidade.
- 2137: 25/Jan19: / - Levantamento de campo iniciado em 08/01 e concluído em 09/01/19; Topografia iniciada e concluída em 14/01/19; Informações do poço recebidas em 14/01/19.
- 2147: 24/04/19: / - Será realizada reunião para aprovação do SAA (Captação Principal no Rio Doce; Alternativa em poço) / 20/Dez/18 / - Nova ETA construída e formalmente entregue ao SAAE Linhares em Mar/18. / - Não há definição da captação alternativa pois a mesma depende da retomada do rio Doce nesta localidade.
- 2148: 20/Dez / - Nova ETA construída e formalmente entregue ao SAAE Linhares em Mar/18. / - Não há definição da captação alternativa pois a mesma depende da retomada do rio Doce nesta localidade.
- 2149: 25/Jan19: / - Engenharia considerando projeto de CAPTAÇÃO PRINCIPAL E ADUÇÃO - RIO DOCE e de EXTENSÃO REDE ELÉTRICA para esta captação. / 29/Nov: / - Segundo a Iude, NÃO houve aprovação do SAAE para voltar a captar no Doce. Projeto para construção da adutora no rio Doce (captação principal) e utilização do poço existente como captação alternativa em "hold". / 05/Dez: / - Engenharia considerando projetos de "Captação e Adução" e de "Extensão de Rede Elétrica". Verificar com o PG se está correto. / 14/Dez / - Considerando as datas dos projetos supracitados como referentes a Captação Principal, segundo informação do José Alaércio (ENG) nesta data.
- 2150: 25/Jan19: / - Considerando que os dados de entrada do projeto de CAPTAÇÃO PRINCIPAL E ADUÇÃO - RIO DOCE iniciou em 22/03 e foi concluído em 12/11/18 e o da "Extensão da Rede Elétrica" iniciou em 14/01 com previsão de término para 01/02/19.
- 2151: 25/Jan19: / - Topografia e Sondagem previstas apenas para o projeto de CAPTAÇÃO PRINCIPAL E ADUÇÃO - RIO DOCE, para o de EXTENSÃO REDE ELÉTRICA não há previsão. / - Topografia iniciada em 28/11/18 e finalizada em 17/01/19; Sondagem prevista para iniciar em 04/02 e finalizar em 08/03/19. / 14/Dez / - Considerando que os dados de entrada do projeto de Captação e Adução iniciou em 22/03 com término previsto para 18/12/18 e da "Extensão da Rede Elétrica" tem previsão para iniciar em 20/02 com previsão de término para 15/03/19.
- 2156: 14/Dez / - Atividade prevista apenas para o projeto de Captação e Adução; o de "Extensão Rede Elétrica" não prevê emissão preliminar desses documentos, apenas a emissão final.
- 2157: 14/Dez / - Considerando que o projeto executivo da "Captação e Adução" iniciou em 18/01 com previsão de término para 03/05/19 e da "Extensão da Rede Elétrica" tem previsão para iniciar em 04/02 com previsão de término para 20/05/19.

| ID | WBS | Task | Type | Duration | Start | Finish | Predecessors | Complete | Remaining | Baseline start | Baseline finish | Baseline duration | Baseline 1 start | Baseline 1 finish | Total slack | Free slack | Baseline cost | Text3 | Text25 | Text26 | Text27 | Text29 | Text5 | Text23 | Text7 | Text15 | Text4 | Text1 | Indicadores MIR | Text9 |
| --- | --- | --- | --- | --- | --- | --- | --- | --- | --- | --- | --- | --- | --- | --- | --- | --- | --- | --- | --- | --- | --- | --- | --- | --- | --- | --- | --- | --- | --- | --- |
| 2159 | 8.2.2.2 | **Fundiária** |  | 168d | 2020-01-14 | 2020-09-15 |  |  |  | 2019-07-03 | 2019-09-10 | 49d | 2019-07-03 | 2019-09-10 | 323d |  |  | 0% | 0% | ok | 0% | Regência (distrito Linhares/ES) |  |  |  |  |  |  |  |  |
| 2160 | 8.2.2.2.1 | Captação Principal (rio Doce) - Desimpedimento de área - Regência/ES |  | 168d | 2020-01-14 | 2020-09-15 | 2153 |  |  | 2019-07-10 | 2019-09-10 | 44d | 2019-07-10 | 2019-09-10 | 323d | 0d |  | 0% | 0% | ok | 0% | Regência (distrito Linhares/ES) |  |  |  |  |  |  |  |  |
| 2161 | 8.2.2.2.2 | Conclusão da Regularização Fundiária para as obras de Melhoria do Sistema de Abastecimento da Localidade - Regência/ES | milestone | 0d | 2020-09-15 | 2020-09-15 | 2160 |  |  | 2019-09-10 | 2019-09-10 | 0d | 2019-09-10 | 2019-09-10 | 772d | 228d |  | 0% |  |  |  |  |  |  |  |  |  |  |  |  |
| 2162 | 8.2.2.3 | **Licenciamento** |  | 176d | 2020-01-14 | 2020-09-25 |  |  |  | 2017-06-30 | 2020-04-22 | 715d | 2017-06-30 | 2020-04-22 | 315d |  |  | 71% | 0% | ok | 0% | Regência (distrito Linhares/ES) | 71 | Socioambiental |  |  |  |  |  |  |
| 2163 | 8.2.2.3.1 | Captação Principal - Outorga e Autorizações rio Doce - Regência/ES |  | 176d | 2020-01-14 | 2020-09-25 | 2153 |  |  | 2019-08-06 | 2020-04-22 | 176d | 2019-08-06 | 2020-04-22 | 315d | 0d |  | 0% | 0% | Não OK | 0% | Regência (distrito Linhares/ES) |  | Socioambiental |  |  |  |  |  |  |
| 2164 | 8.2.2.3.2 | Conclusão do Licenciamento Ambiental da Localidade - Regência/ES | milestone | 0d | 2020-09-25 | 2020-09-25 | 2163 |  |  | 2020-04-22 | 2020-04-22 | 0d | 2020-04-22 | 2020-04-22 | 764d | 220d |  | 0% |  |  |  |  |  |  |  |  |  |  |  |  |
| 2165 | 8.2.2.4 | **Suprimentos** |  | 88d | 2020-03-20 | 2020-07-27 |  |  |  | 2019-09-26 | 2020-02-03 | 88d | 2019-09-26 | 2020-02-03 | 358d |  |  | 0% | 0% | ok | 0% | Regência (distrito Linhares/ES) |  |  |  |  |  |  |  |  |
| 2166 | 8.2.2.4.1 | Processo contratação - Captação Principal rio Doce - Regência/ES |  | 88d | 2020-03-20 | 2020-07-27 | 2156 |  |  | 2019-09-26 | 2020-02-03 | 88d | 2019-09-26 | 2020-02-03 | 358d | 0d |  | 0% | 0% | ok | 0% | Regência (distrito Linhares/ES) |  |  |  |  |  |  |  |  |
| 2167 | 8.2.2.4.2 | Conclusão da Contratação de Suprimentos das obras de Melhoria do Sistema de Abastecimento de Água - Regência/ES | milestone | 0d | 2020-07-27 | 2020-07-27 | 2166 |  |  | 2020-02-03 | 2020-02-03 | 0d | 2020-02-03 | 2020-02-03 | 807d | 263d |  | 0% |  |  |  |  |  |  |  |  |  |  |  |  |
| 2168 | 8.2.2.5 | **Infraestrutura** |  | 469d | 2020-09-28 | 2022-08-16 |  |  |  | 2017-08-01 | 2021-08-30 | 1032d | 2017-08-01 | 2021-08-30 | 314d |  |  | 47% | 0% | ok | 0% | Regência (distrito Linhares/ES) | 47 |  | 24 | 25 |  |  |  |  |
| 2169 | 8.2.2.5.1 | **Obras** |  | 220d | 2020-09-28 | 2021-08-16 |  |  |  | 2017-08-01 | 2020-08-13 | 772d | 2017-08-01 | 2020-08-13 | 315d |  |  | 63% |  |  |  |  | 63 |  | 124 | 25 | 31 |  |  |  |
| 2170 | 8.2.2.5.1.1 | Executar Captação Principal e adutora de 11km do Rio Doce - Regência/ES |  | 220d | 2020-09-28 | 2021-08-16 | 2157, 2160, 2163, 2166 |  |  | 2020-04-23 | 2020-08-13 | 79d | 2020-04-23 | 2020-08-13 | 315d | 0d |  | 0% | 0% | ok | 0% | Regência (distrito Linhares/ES) |  |  |  |  |  |  |  |  |
| 2171 | 8.2.2.5.1.2 | Executar Adequação ETA/UTR (caso haja nova captação no rio Doce) - Regência/ES |  | 120d | 2020-09-28 | 2021-03-24 | 2170SS |  |  | 2020-06-24 | 2021-03-15 | 180d |  |  | 644d | 100d |  |  |  |  |  |  |  |  |  |  |  | 8888 | ETA |  |
| 2172 | 8.2.2.5.1.3 | Assinatura de Termo de Entrega das Obras de Melhoria do Sistema de Abastecimento de Água - Regência/ES | milestone | 0d | 2021-08-16 | 2021-08-16 | 2170, 2171, 2158, 2161, 2164, 2167 |  |  | 2020-08-13 | 2020-08-13 | 0d | 2020-08-13 | 2020-08-13 | 544d | 0d |  | 0% | 0% | ok | 0% | Regência (distrito Linhares/ES) |  |  |  |  |  |  |  |  |
| 2173 | 8.2.2.5.2 | **Operação** |  | 249d | 2021-08-16 | 2022-08-16 |  |  |  | 2020-08-14 | 2021-08-30 | 260d | 2020-08-14 | 2021-08-30 | 314d |  |  | 0% | 0% | ok | 0% | Regência (distrito Linhares/ES) |  |  |  |  |  |  |  |  |
| 2174 | 8.2.2.5.2.1 | Realizar Treinamento Operacional do Sistema - Regência/ES |  | 5d | 2021-08-17 | 2021-08-23 | 2170, 2172 |  |  | 2020-08-14 | 2020-08-20 | 5d | 2020-08-14 | 2020-08-20 | 544d | 0d |  | 0% | 0% | ok | 0% | Regência (distrito Linhares/ES) |  |  |  |  |  |  |  |  |
| 2175 | 8.2.2.5.2.2 | Realizar Testes e Pré-operação - Regência/ES |  | 14d | 2021-08-24 | 2021-09-13 | 2174 |  |  | 2020-08-21 | 2020-09-10 | 14d | 2020-08-21 | 2020-09-10 | 544d |  |  | 0% | 0% | ok | 0% | Regência (distrito Linhares/ES) |  |  |  |  |  |  |  |  |
| 2176 | 8.2.2.5.2.3 | Realizar Acompanhamento da Funcionalidade do Sistema - Captação Principal (rio Doce) e adequações na ETA/UTR - Regência (distrito Linhares/ES) |  | 365ed | 2021-08-16 | 2022-08-16 | 2178SS |  |  | 2020-08-14 | 2021-08-30 | 260d |  |  | 1389d |  |  |  |  |  |  |  |  |  |  |  |  |  |  |  |
| 2177 | 8.2.2.5.2.4 | **Operação Assistida** |  | 61d | 2021-08-16 | 2021-11-14 |  |  |  | 2020-08-14 | 2020-11-16 | 64d | 2020-08-14 | 2020-11-16 | 315d |  |  | 0% | 0% | ok | 0% | Regência (distrito Linhares/ES) |  |  |  |  |  |  |  |  |
| 2178 | 8.2.2.5.2.4.1 | Realizar Operação Assistida - Regência/ES |  | 90ed | 2021-08-16 | 2021-11-14 | 2170 |  |  | 2020-08-14 | 2020-11-16 | 3.2mo | 2020-08-14 | 2020-11-16 | 1389d | 0d |  | 0% | 0% | ok | 0% | Regência (distrito Linhares/ES) |  |  |  |  |  |  |  |  |
| 2179 | 8.2.3 | **Captação Principal - Novo Poço** |  | 917d | 2018-03-23 A | 2021-11-17 |  | 6% | 863.04d | 2017-06-30 | 2021-08-30 | 1054d |  |  | 500d |  | -0 |  |  |  |  |  |  |  |  |  |  |  |  |  |
| 2180 | 8.2.3.1 | **Estudos de Concepção do Sistema - Etapa 1** |  | 222d | 2018-03-23 A | 2019-01-29 A |  | 100% |  | 2018-03-23 | 2019-07-05 | 328d | 2018-03-23 | 2019-07-05 |  |  |  | 98% | 0% | ok | 0% | Regência (distrito Linhares/ES) | 98 | Socioambiental | 103 | 97 | 100 |  |  |  |
| 2181 | 8.2.3.1.1 | Declaração de Escopo e Premissas de Projeto (DEPP) concluída - Regência/ES | milestone | 0d | 2018-03-23 A | 2018-03-23 A | 25, 26 | 100% |  | 2018-03-23 | 2018-03-23 | 0d | 2018-03-23 | 2018-03-23 |  |  |  | 100% | 0% | ok | 0% | Regência (distrito Linhares/ES) | 100 |  | 100 | 100 | 100 |  |  |  |
| 2182 | 8.2.3.1.2 | **Serviços em Poços Tubulares - Poço (Não será utilizado como fonte de captação)** |  | 47d | 2018-11-23 A | 2019-01-29 A |  | 100% |  | 2018-11-23 | 2019-07-01 | 149d | 2018-11-23 | 2019-07-01 |  |  |  | 99% |  |  |  |  | 99 |  | 108 | 93 | 100 |  |  |  |
| 2183 | 8.2.3.1.2.1 | Realizar Perfuração - Regência/ES |  | 12d | 2018-11-23 A | 2018-12-10 A | 2181 | 100% |  | 2018-11-23 | 2018-12-10 | 12d | 2018-11-23 | 2018-12-10 |  |  |  | 100% | 0% | ok | 0% | Regência (distrito Linhares/ES) | 100 |  | 100 | 100 | 100 |  |  |  |
| 2184 | 8.2.3.1.2.2 | Realizar Teste bombeamento - Regência/ES |  | 3d | 2018-12-08 A | 2018-12-12 A | 2183 | 100% |  | 2018-12-08 | 2018-12-12 | 3d | 2018-12-08 | 2018-12-12 |  |  |  | 100% | 0% | ok | 0% | Regência (distrito Linhares/ES) | 100 |  | 100 | 100 | 100 |  |  |  |
| 2185 | 8.2.3.1.2.3 | Elaborar Relatório Técnico - Regência/ES |  | 24d | 2018-12-11 A | 2019-01-14 A | 2183 | 100% |  | 2019-05-31 | 2019-07-04 | 24d | 2019-05-31 | 2019-07-04 |  |  |  | 83% | 0% | Não OK | 0% | Regência (distrito Linhares/ES) | 83 | Socioambiental | 120 | 83 | 100 |  |  | Não OK |
| 2186 | 8.2.3.1.2.4 | Realizar Laudo dos Serviços de Coleta e Análise de Água - Regência/ES |  | 12d | 2018-12-13 A | 2018-12-28 A | 2184 | 100% |  | 2018-12-13 | 2018-12-28 | 12d | 2018-12-13 | 2018-12-28 |  |  |  | 100% | 0% | ok | 0% | Regência (distrito Linhares/ES) | 100 |  | 100 | 100 | 100 |  |  |  |
| 2187 | 8.2.3.1.2.5 | Realizar Tamponamento - Regência/ES |  | 21d | 2018-12-31 A | 2019-01-29 A | 2186 | 100% |  | 2019-05-31 | 2019-07-01 | 21d | 2019-05-31 | 2019-07-01 |  |  |  | 95% | 0% | Não OK | 0% | Regência (distrito Linhares/ES) | 95 | Socioambiental | 105 | 95 | 100 |  |  | Não OK |
| 2188 | 8.2.3.1.2.6 | Conclusão dos Serviços em poço tubular - Regência/ES | milestone | 0d | 2019-01-29 A | 2019-01-29 A | 2185, 2187 | 100% |  | 2019-07-01 | 2019-07-01 | 0d | 2019-07-01 | 2019-07-01 |  |  |  | 0% |  |  |  |  |  |  |  |  | 100 |  |  |  |

Notes:
- 2159: 29/Nov: / - Segundo a Iude, NÃO houve aprovação do SAAE para voltar a captar no Doce. Projeto para construção da adutora no rio Doce (captação principal) e utilização do poço existente como captação alternativa em "hold".
- 2185: 28/Jan19: / - Salvo Linha de Base para esta tarefa: "Linha de Base 1". Mostrar o atraso.

| ID | WBS | Task | Type | Duration | Start | Finish | Predecessors | Complete | Remaining | Baseline start | Baseline finish | Baseline duration | Baseline 1 start | Baseline 1 finish | Total slack | Free slack | Baseline cost | Text3 | Text4 | Text5 | Text7 | Text15 | Text25 | Text26 | Text27 | Text29 | Text23 | Text1 |
| --- | --- | --- | --- | --- | --- | --- | --- | --- | --- | --- | --- | --- | --- | --- | --- | --- | --- | --- | --- | --- | --- | --- | --- | --- | --- | --- | --- | --- |
| 2189 | 8.2.3.2 | **Estudos de Concepção do Sistema - Etapa 2** |  | 275d | 2019-01-29 A | 2020-03-11 |  |  | 275d | 2019-01-29 | 2020-03-04 | 271d |  |  | 901d |  |  |  |  |  |  |  |  |  |  |  |  |  |
| 2190 | 8.2.3.2.1 | Aprovação da Revisão de Definição pela Operadora e Prefeitura - Regência/ES | milestone | 0d | 2019-06-14 A | 2019-06-14 A | 2181 | 100% |  | 2019-05-30 | 2019-05-30 | 0d | 2019-05-30 | 2019-05-30 |  |  |  | 100% | 100 | 100 | 100 | 100 | 0% | ok | 0% | Regência (distrito Linhares/ES) |  |  |
| 2191 | 8.2.3.2.2 | Definição de perfuração de um novo poço para Captação Principal - Regência/ES | milestone | 0d | 2019-08-14 A | 2019-08-14 A | 2181 | 100% |  | 2019-08-14 | 2019-08-14 | 0d |  |  |  |  |  |  |  |  |  |  |  |  |  |  |  |  |
| 2192 | 8.2.3.2.3 | **Serviços em Poços Tubulares - Novo Poço** |  | 26d | 2020-01-31 | 2020-03-11 |  |  |  | 2019-12-20 | 2020-01-29 | 26d |  |  | 500d |  |  |  |  |  |  |  |  |  |  |  |  |  |
| 2193 | 8.2.3.2.3.1 | Realizar Perfuração - Regência/ES |  | 1d | 2020-01-31 | 2020-01-31 | 2211, 2215 |  |  | 2019-12-20 | 2019-12-20 | 1d |  |  | 500d | 0d |  |  |  |  |  |  |  |  |  |  |  |  |
| 2194 | 8.2.3.2.3.2 | Realizar Teste bombeamento - Regência/ES |  | 3d | 2020-02-03 | 2020-02-05 | 2193 |  |  | 2019-12-23 | 2019-12-27 | 3d |  |  | 500d | 0d |  |  |  |  |  |  |  |  |  |  |  |  |
| 2195 | 8.2.3.2.3.3 | Elaborar Relatório Técnico - Regência/ES |  | 22d | 2020-02-06 | 2020-03-11 | 2194 |  |  | 2019-12-30 | 2020-01-29 | 22d |  |  | 901d | 0d |  |  |  |  |  |  |  |  |  |  |  |  |
| 2196 | 8.2.3.2.3.4 | Realizar Laudo dos Serviços de Coleta e Análise de Água - Regência/ES |  | 22d | 2020-02-06 | 2020-03-11 | 2194 |  |  | 2019-12-30 | 2020-01-29 | 22d |  |  | 500d | 0d |  |  |  |  |  |  |  |  |  |  |  |  |
| 2197 | 8.2.3.2.3.5 | Conclusão dos Serviços em poço tubular - Regência/ES | milestone | 0d | 2020-03-11 | 2020-03-11 | 2195, 2196 |  |  | 2020-01-29 | 2020-01-29 | 0d |  |  | 901d | 172d |  |  |  |  |  |  |  |  |  |  |  |  |
| 2198 | 8.2.3.2.4 | Conclusão dos Estudos de Concepção das Melhorias do Sistema de Abastecimento de Água - Regência/ES | milestone | 0d | 2019-01-29 A | 2019-01-29 A | 2188 | 100% |  | 2019-07-01 | 2019-07-01 | 0d | 2019-07-01 | 2019-07-01 |  |  |  | 0% | 100 |  |  |  |  |  |  |  |  |  |
| 2199 | 8.2.3.3 | **Engenharia Básica e Detalhada** |  | 68d | 2020-03-11 | 2020-06-18 |  |  |  | 2020-01-30 | 2020-08-07 | 130d | 2017-11-20 | 2019-10-23 | 500d |  | -0 | 83% | 46 | 83 | 60 | 77 | 0% | ok | 0% | Regência (distrito Linhares/ES) | Socioambiental |  |
| 2200 | 8.2.3.3.1 | **Engenharia Captação Principal (Novo Poço)** |  | 68d | 2020-03-11 | 2020-06-18 |  |  |  | 2020-01-30 | 2020-08-07 | 130d |  |  | 500d |  | -0 |  |  |  |  |  |  |  |  |  |  | 8888 |
| 2201 | 8.2.3.3.1.1 | Aprovação Plano de Trabalho /abertura OSE - Captação Principal - Novo Poço - Regência/ES |  | 5d | 2020-03-12 | 2020-03-18 | 2196 |  |  | 2020-01-30 | 2020-02-05 | 5d |  |  | 500d | 0d |  |  |  |  |  |  |  |  |  |  |  | 8888 |
| 2202 | 8.2.3.3.1.2 | Dados de Entrada (levantamento de campo, topografia e recebimento das informações do poço: perfil, vazão, análise água) - Captação Principal - Regência/ES |  | 22d | 2020-03-19 | 2020-04-20 | 2201 |  |  | 2020-02-06 | 2020-03-11 | 22d |  |  | 500d | 0d |  |  |  |  |  |  |  |  |  |  |  | 8888 |
| 2203 | 8.2.3.3.1.3 | Emitir RT/PQ para Suprimentos - Captação Principal - Novo Poço - Regência/ES |  | 10d | 2020-03-11 | 2020-03-24 | 2204FF-58d |  |  | 2020-07-27 | 2020-08-07 | 10d |  |  | 500d | 0d |  |  |  |  |  |  |  |  |  |  |  | 8888 |
| 2204 | 8.2.3.3.1.4 | Elaborar Projeto Executivo - Captação Principal - Novo Poço - Regência/ES |  | 40d | 2020-04-22 | 2020-06-18 | 2202 |  |  | 2020-03-12 | 2020-06-16 | 65d |  |  | 500d | 0d |  |  |  |  |  |  |  |  |  |  |  | 8888 |
| 2205 | 8.2.3.3.1.5 | Elaboração do Projeto Executivo - Captação Principal - Novo Poço - Regência/ES | milestone | 0d | 2020-06-18 | 2020-06-18 | 2204 |  |  | 2020-06-16 | 2020-06-16 | 0d |  |  | 530d | 30d |  |  |  |  |  |  |  |  |  |  |  | 8888 |
| 2206 | 8.2.3.4 | **Fundiária** |  | 185d | 2019-08-16 A | 2020-05-15 |  | 18% | 151.47d | 2019-07-03 | 2019-09-10 | 49d | 2019-07-03 | 2019-09-10 | 553d |  |  | 0% |  |  |  |  | 0% | ok | 0% | Regência (distrito Linhares/ES) |  |  |
| 2207 | 8.2.3.4.1 | Obter Termo de Autorização de Superficiário - Captação Principal (Novo Poço) - Regência/ES |  | 116d | 2019-08-16 A | 2020-01-31 | 2191 | 25% | 87d | 2019-08-16 | 2019-09-26 | 30d |  |  | 509d | 0d |  |  |  |  |  |  |  |  |  |  |  |  |
| 2208 | 8.2.3.4.2 | Captação Principal (Novo Poço) - Desimpedimento de área - Regência/ES |  | 44d | 2020-03-12 | 2020-05-15 | 2196 |  |  | 2019-09-27 | 2019-11-28 | 44d |  |  | 553d | 0d |  |  |  |  |  |  |  |  |  |  |  |  |
| 2209 | 8.2.3.4.3 | Conclusão da Regularização Fundiária para as obras de Melhoria do Sistema de Abastecimento da Localidade - Regência/ES | milestone | 0d | 2020-05-15 | 2020-05-15 | 2208 |  |  | 2019-09-10 | 2019-09-10 | 0d | 2019-09-10 | 2019-09-10 | 553d | 53d |  | 0% |  |  |  |  |  |  |  |  |  |  |
| 2210 | 8.2.3.5 | **Licenciamento** |  | 221d | 2020-01-06 | 2020-11-23 |  |  |  | 2017-06-30 | 2020-04-22 | 715d | 2017-06-30 | 2020-04-22 | 509d |  |  | 71% |  | 71 |  |  | 0% | ok | 0% | Regência (distrito Linhares/ES) | Socioambiental |  |
| 2211 | 8.2.3.5.1 | Captação Principal - Autorização de Perfuração - Regência/ES |  | 10d | 2020-01-06 | 2020-01-17 | 2207FS-20d |  |  | 2019-08-23 | 2019-10-03 | 30d |  |  | 509d | 9d |  |  |  |  |  |  |  |  |  |  |  |  |
| 2212 | 8.2.3.5.2 | Captação Principal - Outorga novo poço - Regência/ES |  | 176d | 2020-03-12 | 2020-11-23 | 2196 |  |  | 2020-01-30 | 2020-10-14 | 176d |  |  | 744d | 0d |  |  |  |  |  |  |  |  |  |  |  | 8888 |
| 2213 | 8.2.3.5.3 | Conclusão do Licenciamento Ambiental da Localidade - Regência/ES | milestone | 0d | 2020-11-23 | 2020-11-23 | 2211, 2212 |  |  | 2020-04-22 | 2020-04-22 | 0d | 2020-04-22 | 2020-04-22 | 744d |  |  | 0% |  |  |  |  |  |  |  |  |  |  |

Notes:
- 2190: 24/04/19: / - Será realizada reunião para aprovação do SAA (Captação Principal no Rio Doce; Alternativa em poço) / 20/Dez/18 / - Nova ETA construída e formalmente entregue ao SAAE Linhares em Mar/18. / - Não há definição da captação alternativa pois a mesma depende da retomada do rio Doce nesta localidade.
- 2199: 20/Dez / - Nova ETA construída e formalmente entregue ao SAAE Linhares em Mar/18. / - Não há definição da captação alternativa pois a mesma depende da retomada do rio Doce nesta localidade.
- 2206: 29/Nov: / - Segundo a Iude, NÃO houve aprovação do SAAE para voltar a captar no Doce. Projeto para construção da adutora no rio Doce (captação principal) e utilização do poço existente como captação alternativa em "hold".

| ID | WBS | Task | Type | Duration | Start | Finish | Predecessors | Complete | Remaining | Baseline start | Baseline finish | Baseline duration | Baseline 1 start | Baseline 1 finish | Total slack | Free slack | Text3 | Text25 | Text26 | Text27 | Text29 | Text5 | Text7 | Text15 | Text4 | Text1 | Indicadores MIR | Text28 |
| --- | --- | --- | --- | --- | --- | --- | --- | --- | --- | --- | --- | --- | --- | --- | --- | --- | --- | --- | --- | --- | --- | --- | --- | --- | --- | --- | --- | --- |
| 2214 | 8.2.3.6 | **Suprimentos** |  | 238d | 2019-08-16 A | 2020-07-30 |  | 14% | 204.29d | 2019-09-26 | 2020-02-03 | 88d | 2019-09-26 | 2020-02-03 | 500d |  | 0% | 0% | ok | 0% | Regência (distrito Linhares/ES) |  |  |  |  |  |  |  |
| 2215 | 8.2.3.6.1 | Processo de Contratação Tintori - Novo Poço - Captação Principal - Regência/ES |  | 115d | 2019-08-16 A | 2020-01-30 | 2191 | 25% | 86.25d | 2019-08-16 | 2019-12-19 | 88d |  |  | 500d | 0d |  |  |  |  |  |  |  |  |  |  |  |  |
| 2216 | 8.2.3.6.2 | Processo de Contratação da Obra - Novo Poço - Captação Principal - Regência/ES |  | 88d | 2020-03-25 | 2020-07-30 | 2203 |  |  | 2019-08-16 | 2019-12-19 | 88d |  |  | 500d | 0d |  |  |  |  |  |  |  |  |  |  |  |  |
| 2217 | 8.2.3.6.3 | Conclusão da Contratação de Suprimentos das obras de Melhoria do Sistema de Abastecimento de Água - Regência/ES | milestone | 0d | 2020-07-30 | 2020-07-30 | 2215, 2216 |  |  | 2020-02-03 | 2020-02-03 | 0d | 2020-02-03 | 2020-02-03 | 500d | 0d | 0% |  |  |  |  |  |  |  |  |  |  |  |
| 2218 | 8.2.3.7 | **Infraestrutura** |  | 323d | 2020-07-31 | 2021-11-17 |  |  |  | 2017-08-01 | 2021-08-30 | 1032d | 2017-08-01 | 2021-08-30 | 500d |  | 47% | 0% | ok | 0% | Regência (distrito Linhares/ES) | 47 | 24 | 25 |  |  |  |  |
| 2219 | 8.2.3.7.1 | **Obras** |  | 75d | 2020-07-31 | 2020-11-17 |  |  |  | 2017-08-01 | 2020-08-13 | 772d | 2017-08-01 | 2020-08-13 | 500d |  | 63% |  |  |  |  | 63 | 124 | 25 | 31 |  |  |  |
| 2220 | 8.2.3.7.1.1 | Executar Obras de Captação Principal - Novo Poço - Regência/ES |  | 75d | 2020-07-31 | 2020-11-17 | 2217, 2209, 2205 |  |  | 2020-06-24 | 2020-10-14 | 79d |  |  | 500d | 0d |  |  |  |  |  |  |  |  |  | 8888 |  |  |
| 2221 | 8.2.3.7.1.2 | Assinatura de Termo de Entrega das Obras de Melhoria do Sistema de Abastecimento de Água - Regência/ES | milestone | 0d | 2020-11-17 | 2020-11-17 | 2220, 2197 |  |  | 2020-08-13 | 2020-08-13 | 0d | 2020-08-13 | 2020-08-13 | 729d | 0d | 0% | 0% | ok | 0% | Regência (distrito Linhares/ES) |  |  |  |  |  |  |  |
| 2222 | 8.2.3.7.2 | **Operação** |  | 248d | 2020-11-17 | 2021-11-17 |  |  |  | 2020-08-14 | 2021-08-30 | 260d | 2020-08-14 | 2021-08-30 | 500d |  | 0% | 0% | ok | 0% | Regência (distrito Linhares/ES) |  |  |  |  |  |  |  |
| 2223 | 8.2.3.7.2.1 | Realizar Treinamento Operacional do Sistema - Regência/ES |  | 5d | 2020-11-18 | 2020-11-24 | 2221 |  |  | 2020-08-14 | 2020-08-20 | 5d | 2020-08-14 | 2020-08-20 | 729d | 0d | 0% | 0% | ok | 0% | Regência (distrito Linhares/ES) |  |  |  |  |  |  |  |
| 2224 | 8.2.3.7.2.2 | Realizar Testes e Pré-operação - Regência/ES |  | 14d | 2020-11-25 | 2020-12-14 | 2223 |  |  | 2020-08-21 | 2020-09-10 | 14d | 2020-08-21 | 2020-09-10 | 729d |  | 0% | 0% | ok | 0% | Regência (distrito Linhares/ES) |  |  |  |  |  |  |  |
| 2225 | 8.2.3.7.2.3 | Realizar Acompanhamento da Funcionalidade do Sistema - Captação Principal - Novo Poço - Regência (distrito Linhares/ES) |  | 365ed | 2020-11-17 | 2021-11-17 | 2227SS |  |  | 2020-08-14 | 2021-08-30 | 260d |  |  | 2205d |  |  |  |  |  |  |  |  |  |  |  |  |  |
| 2226 | 8.2.3.7.2.4 | **Operação Assistida** |  | 60d | 2020-11-17 | 2021-02-15 |  |  |  | 2020-08-14 | 2020-11-16 | 64d | 2020-08-14 | 2020-11-16 | 500d |  | 0% | 0% | ok | 0% | Regência (distrito Linhares/ES) |  |  |  |  |  |  |  |
| 2227 | 8.2.3.7.2.4.1 | Realizar Operação Assistida - Regência/ES |  | 90ed | 2020-11-17 | 2021-02-15 | 2220 |  |  | 2020-08-14 | 2020-11-16 | 3.2mo | 2020-08-14 | 2020-11-16 | 2205d | 0d | 0% | 0% | ok | 0% | Regência (distrito Linhares/ES) |  |  |  |  |  |  |  |
| 2228 | 9 | **Obras Emergenciais** |  | 484d | 2015-11-09 A | 2017-09-14 A |  | 100% |  | 2015-11-09 | 2017-09-14 | 484d |  |  |  |  |  |  |  |  |  |  |  |  |  |  |  |  |
| 2229 | 9.1 | Pedra Corrida (distrito de Periquito) |  | 64d | 2016-10-03 A | 2016-12-29 A | 24 | 100% |  | 2016-10-03 | 2016-12-29 | 3.2mo | 2016-10-03 | 2016-12-29 |  |  | 100% | 0% | ok | 0% |  | 100 | 100 | 100 | 100 |  |  |  |
| 2230 | 9.2 | Governador Valadares/MG (sede) |  | 16d | 2015-11-09 A | 2015-11-30 A | 24 | 100% |  | 2016-03-23 | 2016-04-13 | 16d | 2016-03-23 | 2016-04-13 |  |  | 100% | 0% | ok | 0% |  | 100 | 100 | 100 | 100 |  |  |  |
| 2231 | 9.3 | São Vítor (distrito de Governador Valadares) |  | 64d | 2016-10-03 A | 2016-12-29 A | 24 | 100% |  | 2016-10-03 | 2016-12-29 | 3.2mo | 2016-10-03 | 2016-12-29 |  |  | 100% | 0% | ok | 0% |  | 100 | 100 | 100 | 100 |  |  |  |
| 2232 | 9.4 | São Tomé do Rio Doce (distrito de Tumiritinga) |  | 64d | 2016-10-03 A | 2016-12-29 A | 24 | 100% |  | 2016-10-03 | 2016-12-29 | 3.2mo | 2016-10-03 | 2016-12-29 |  |  | 100% |  | ok |  |  | 100 | 100 | 100 | 100 |  |  |  |
| 2233 | 9.5 | Galiléia/MG |  | 64d | 2016-10-03 A | 2016-12-29 A | 24 | 100% |  | 2016-10-03 | 2016-12-29 | 3.2mo | 2016-10-03 | 2016-12-29 |  |  | 100% | 0% | ok | 0% |  | 100 | 100 | 100 | 100 |  |  |  |
| 2234 | 9.6 | Captação Alternativa - Lagoa Nova - Linhares/ES |  | 315d | 2016-07-01 A | 2017-09-14 A | 24 | 100% |  | 2016-07-01 | 2017-09-14 | 315d | 2016-07-01 | 2017-09-14 |  |  | 100% | 0% | ok | 0% |  | 100 | 100 | 100 | 100 |  |  |  |
| 2235 | 9.7 | Colatina (Sede) - Colatina/ES |  | 180d | 2016-03-23 A | 2016-11-29 A | 24 | 100% |  | 2016-03-23 | 2016-11-29 | 9mo | 2016-03-23 | 2016-11-29 |  |  | 100% | 0% | ok | 0% |  | 100 | 100 | 100 | 100 |  | CA/ETA |  |
| 2236 | 10 | Fim da Execução | milestone | 0d | 2023-11-22 | 2023-11-22 | 265, 266, 267, 273, 312, 313, 314, 320, 327, 338, 407, 408, 409, 416, 423, 432, 459, 461, 464, 593, 594, 597, 600, 674, 676, 702, 703, 706, 709, 795, 796, 799, 802, 806, 834, 835, 836, 843, 846, 1209, 1210, 1213, 1216, 1275, 1278, 1274, 1281, 1284, 1287, 1379, 1380, 1383, 1386, 1427, 1442, 1446, 1460, 1539, 1563, 1564, 1567, 1570, 1575, 1616, 1617, 1618, 1619, 1620, 1624, 1626, 1632, 1670, 1671, 1672, 1676, 1678, 1776, 1777, 1780, 1783, 1788, 1825, 1826, 1829, 1832, 1911, 1912, 1915, 1918, 1923, 1925, 1995, 1993, 1996, 1999, 2002, 2088, 2112, 2113, 2116, 2119, 2190, 2185, 2187, 2221, 2224, 2227, 460, 837, 838, 839, 146, 155, 156, 202, 203, 209, 284, 306, 307, 467, 474, 477, 510, 511, 512, 515, 518, 522, 523, 529, 570, 573, 576, 605, 607, 663, 664, 667, 670, 714, 733, 755, 756, 760, 764, 767, 770, 851, 870, 874, 876, 881, 921, 922, 923, 928, 931, 936, 969, 970, 976, 979, 984, 1026, 1027, 1033, 1036, 1041, 1063, 1076, 1081, 1087, 1090, 1095, 1133, 1136, 1141, 1144, 1175, 1176, 1179, 1182, 1292, 1311, 1312, 1313, 1316, 1319, 1323, 1357, 1358, 1361, 1364, 1391, 1417, 1420, 1423, 1466, 1491, 1496, 1498, 1501, 1504, 1509, 1526, 1529, 1532, 1535, 1683, 1717, 1718, 1721, 1724, 1728, 1743, 1744, 1747, 1750, 1854, 1855, 1858, 1861, 1883, 1884, 1887, 1890, 2008, 2017, 2038, 2039, 2042, 2045, 2049, 2078, 2081, 2084, 2142, 2143, 2147, 2170, 2172, 2175, 2178, 210, 468, 516, 574, 598, 668, 707, 768, 800, 844, 875, 929, 977, 1034, 1088, 1142, 1180, 1214, 1285, 1317, 1362, 1384, 1421, 1502, 1533, 1568, 1621, 1673, 1722, 1748, 1781, 1830, 1859, 1888, 1916, 2000, 2043, 2082, 2117, 2176, 2225, 1134, 2077 |  |  | 2022-03-21 | 2022-03-21 | 0d | 2022-03-21 | 2022-03-21 | 0d |  | 0% |  | ok |  |  |  |  |  |  |  |  |  |
| 2237 | 11 | **Encerramento** |  | 21d | 2023-10-23 | 2023-11-22 |  |  |  | 2021-09-24 | 2022-03-21 | 120d | 2021-09-24 | 2022-03-21 | 0d |  | 0% | 0% | ok | 0% |  |  |  |  |  |  |  |  |
| 2238 | 11.1 | Apresentar Resultados à Diretoria |  | 21d | 2023-10-23 | 2023-11-22 | 2236FF |  |  | 2021-09-24 | 2022-03-21 | 6mo | 2021-09-24 | 2022-03-21 | 0d |  | 0% | 0% | ok | 0% |  |  |  |  |  |  |  | Não Ok |
| 2239 | 11.2 | Protocolar o encerramento do programa ao Sistema CIF |  | 21d | 2023-10-23 | 2023-11-22 | 2236FF |  |  | 2021-09-24 | 2022-03-21 | 6mo | 2021-09-24 | 2022-03-21 | 0d |  | 0% | 0% | ok | 0% |  |  |  |  |  |  |  |  |
| 2240 | 11.3 | Assinatura do Termo de Aceite | milestone | 0d | 2023-11-22 | 2023-11-22 | 27, 29, 30, 32, 2236, 2238, 2239, 31, 3, 4 |  |  | 2022-03-21 | 2022-03-21 | 0d | 2022-03-21 | 2022-03-21 | 0d |  | 0% |  |  |  |  |  |  |  |  |  |  |  |
| 2241 | 11.4 | Encerramento do Programa | milestone | 0d | 2023-11-22 | 2023-11-22 | 2240, 6, 7, 8, 9, 10, 11, 14, 12, 13, 15, 16, 17, 18, 19, 20, 21, 22, 125, 140, 235, 251, 260, 274, 349, 363, 504, 301, 1158, 1169, 1256, 1270, 1300, 1307, 1331, 1434, 1543, 1581, 1633, 1686, 1729, 1735, 1737, 1756, 1793, 1926, 2024, 2133, 2198, 103, 321, 417 |  |  | 2022-03-21 | 2022-03-21 | 0d | 2022-03-21 | 2022-03-21 | 0d |  | 0% | 0% | ok | 0% |  |  |  |  |  |  |  |  |
